# PG031 Coleta e Tratamento de Esgoto e Destinação de Resíduos Sólidos_190705

Schedule from MS Project, 2016-12-28 to 2023-12-04, status date 2019-06-30, A marks actual dates.

## Calendars

- Padrão_FR: Mon-Fri 09:00-12:00, 13:00-18:00; Sat-Sun off. Exceptions (off unless hours are given): 2019-01-01 (Ano-novo), 2019-03-04 to 2019-03-06 (Carnaval), 2019-04-18 (Quinta-feira santa (recesso)), 2019-04-19 (Sexta-feira Santa), 2019-04-21 (Tiradentes), 2019-05-01 (Trabalho), 2019-06-20 (Corpus Christi), 2019-08-15 (Assunção de Nossa Senhora), 2019-09-07 (Independência), 2019-10-12 (Nossa Senhora Aparecida), 2019-11-02 (Finados), 2019-11-15 (Proclamação da República), 2019-12-12 (Aniversário BH), 2019-12-24 (Véspera de Natal), 2019-12-25 (Natal), 2020-01-01 (Ano-novo), 2020-02-24 to 2020-02-26 (Carnaval), 2020-04-10 (Sexta-feira Santa), 2020-04-21 (Tiradentes), 2020-05-01 (Trabalho), 2020-06-11 (Corpus Christi), 2020-08-15 (Assunção de Nossa Senhora), 2020-09-07 (Independência), 2020-10-12 (Nossa Senhora Aparecida), 2020-11-02 (Finados), 2020-11-15 (Proclamação da República), 2020-12-12 (Aniversário BH), 2020-12-24 (Véspera de Natal), 2020-12-25 (Natal), 2021-01-01 (Ano-novo), 2021-02-15 to 2021-02-17 (Carnaval), 2021-04-02 (Sexta-feira Santa), 2021-04-21 (Tiradentes), 2021-05-01 (Trabalho), 2021-06-03 (Corpus Christi), 2021-08-15 (Assunção de Nossa Senhora), 2021-09-07 (Independência), 2021-10-12 (Nossa Senhora Aparecida), 2021-11-02 (Finados), 2021-11-15 (Programação da República), 2021-12-12 (Aniversário BH), 2021-12-24 (Véspera de Natal), 2021-12-25 (Natal), 2022-01-01 (Ano-novo), 2022-02-28 to 2022-03-02 (Carnaval), 2022-04-15 (Sexta-feira Santa), 2022-04-21 (Tiradentes), 2022-05-01 (Trabalho), 2022-06-16 (Corpus Christi), 2022-08-15 (Assunção de Nossa Senhora), 2022-09-07 (Independência), 2022-10-12 (Nossa Senhora Aparecida), 2022-11-02 (Finados), 2022-11-15 (Proclamação da República), 2022-12-12 (Aniversário BH), 2022-12-24 (Véspera de Natal), 2022-12-25 (Natal), 2023-01-01 (Ano-novo), 2023-02-20 to 2023-02-22 (Carnaval), 2023-04-07 (Sexta-feira Santa), 2023-04-21 (Tiradentes), 2023-05-01 (Trabalho), 2023-06-08 (Corpus Christ), 2023-08-15 (Assunção de Nossa Senhora), 2023-09-07 (Independência), 2023-10-12 (Nossa Senhora Aparecida), 2023-11-02 (Finados), 2023-11-15 (Proclamação da República).

## Resources

| Resource |
| --- |
| 03 - Rio Doce2 |
| 41 - Linhares2 |
| 32 - Galiléia2 |
| 26 - Periquito2 |

## Schedule

| ID | WBS | Task | Type | Duration | Start | Finish | Predecessors | Complete | Remaining | Baseline start | Baseline finish | Baseline duration | Baseline 1 start | Baseline 1 finish | Total slack | Free slack | Constraint | Text1 | Text2 | Text3 | Text6 | Text12 | Text14 | Text16 | Text4 | Text5 | Text7 | Text8 | Text15 | Text17 |
| --- | --- | --- | --- | --- | --- | --- | --- | --- | --- | --- | --- | --- | --- | --- | --- | --- | --- | --- | --- | --- | --- | --- | --- | --- | --- | --- | --- | --- | --- | --- |
| 1 | 1 | **Atividade Interna Renova** |  | 1724d | 2016-12-28 A | 2023-10-30 |  |  | 1724d | 2016-12-28 | 2023-10-30 | 1724d |  |  | 23d |  |  | Verde | Verde | 0% | 0% | Verde | 0% | 0% |  |  |  |  |  |  |
| 2 | 1.1 | Atividade Interna Renova | milestone | 0d | 2016-12-28 A | 2016-12-28 A |  | 100% |  | 2016-12-28 | 2016-12-28 | 0d |  |  |  |  |  | Verde | Verde | 100% | 100% | Verde | 100% | 100% | 100 | 100 | 100 | Compensatória | 100 | 100 |
| 3 | 1.2 | **Atividade Interna Renova** |  | 1724d | 2016-12-28 A | 2023-10-30 |  |  | 1724d | 2016-12-28 | 2023-10-30 | 1724d | 2016-12-28 | 2025-02-25 | 0d |  |  | Verde | Verde | 36% | 0% | Vermelho | 0% | 0% |  | 36 |  | Compensatória |  |  |
| 4 | 1.2.1 | Atividade Interna Renova | milestone | 0d | 2023-10-30 | 2023-10-30 | 3115 |  |  | 2023-10-30 | 2023-10-30 | 0d | 2025-02-25 | 2025-02-25 | 0d |  |  | Verde | Verde | 0% | 0% | Verde | 0% | 0% |  |  |  | Compensatória |  |  |
| 5 | 1.2.2 | **Atividade Interna Renova** |  | 771d | 2016-12-28 A | 2019-12-30 |  |  | 771d | 2016-12-28 | 2019-12-30 | 771d | 2016-12-28 | 2019-12-30 | 953d |  |  | Verde | Verde | 81% | 0% | Vermelho | 0% | 0% |  | 81 |  | Compensatória |  |  |
| 6 | 1.2.2.1 | Atividade Interna Renova | milestone | 0d | 2016-12-28 A | 2016-12-28 A |  | 100% |  | 2016-12-28 | 2016-12-28 | 0d | 2016-12-28 | 2016-12-28 |  |  | start no earlier than 2016-12-28 | Verde | Verde | 100% | 100% | Verde | 100% | 100% | 100 | 100 | 100 | Compensatória | 100 | 100 |
| 7 | 1.2.2.2 | Atividade Interna Renova | milestone | 0d | 2017-06-12 A | 2017-06-12 A | 6FS+85d | 100% |  | 2017-06-12 | 2017-06-12 | 0d | 2017-06-12 | 2017-06-12 |  |  | start no earlier than 2017-06-12 | Verde | Verde | 100% | 100% | Verde | 100% | 100% | 100 | 100 | 100 | Compensatória | 100 | 100 |
| 8 | 1.2.2.3 | Atividade Interna Renova | milestone | 0d | 2017-12-18 A | 2017-12-18 A | 7FS+136ed | 100% |  | 2017-12-18 | 2017-12-18 | 0d | 2017-12-18 | 2017-12-18 |  |  | start no earlier than 2017-12-18 | Verde | Verde | 100% | 100% | Verde | 100% | 100% | 100 | 100 | 100 | Compensatória | 100 | 100 |
| 9 | 1.2.2.4 | Atividade Interna Renova | milestone | 0d | 2019-06-28 A | 2019-06-28 A | 8FS+392d | 100% |  | 2019-06-28 | 2019-06-28 | 0d | 2019-06-28 | 2019-06-28 |  |  |  | Verde | Verde | 0% | 0% | Verde | 0% | 0% |  |  |  | Compensatória |  |  |
| 10 | 1.2.2.5 | Atividade Interna Renova | milestone | 0d | 2019-12-30 | 2019-12-30 | 9FS+126d |  |  | 2019-12-30 | 2019-12-30 | 0d | 2019-12-30 | 2019-12-30 | 953d | 0d |  | Verde | Verde | 0% | 0% | Verde | 0% | 0% |  |  |  | Compensatória |  |  |
| 11 | 1.2.2.6 | Atividade Interna Renova | milestone | 0d | 2019-12-30 | 2019-12-30 | 10 |  |  | 2019-12-30 | 2019-12-30 | 0d | 2019-12-30 | 2019-12-30 | 953d |  |  | Verde | Verde | 0% | 0% | Verde | 0% | 0% |  |  |  | Compensatória |  |  |
| 12 | 1.2.3 | Atividade Interna Renova | milestone | 0d | 2023-10-30 | 2023-10-30 | 3115 |  |  | 2023-10-30 | 2023-10-30 | 0d | 2025-02-25 | 2025-02-25 | 0d |  |  | Verde | Verde | 0% | 0% | Verde | 0% | 0% |  |  |  | Compensatória |  |  |
| 13 | 1.3 | **Atividade Interna Renova** |  | 1574d | 2017-07-26 A | 2023-10-30 |  |  | 1574d | 2023-02-14 | 2023-10-30 | 174d | 2020-03-25 | 2025-02-25 | 23d |  |  | Verde | Verde | 0% | 0% | Verde | 0% | 0% |  |  |  | Compensatória |  |  |
| 14 | 1.3.1 | Atividade Interna Renova | milestone | 0d | 2017-07-26 A | 2017-07-26 A | 38 | 100% |  | 2017-07-26 | 2017-07-26 | 0d | 2025-02-25 | 2025-02-25 |  |  |  | Verde | Verde | 0% | 0% | Verde | 0% | 0% |  |  |  | Compensatória |  |  |
| 15 | 1.3.2 | Atividade Interna Renova | milestone | 0d | 2023-10-30 | 2023-10-30 | 2929 |  |  | 2023-10-30 | 2023-10-30 | 0d |  |  | 23d |  |  |  |  |  |  |  |  |  |  |  |  |  |  |  |
| 16 | 1.3.3 | Atividade Interna Renova | milestone | 0d | 2019-07-31 | 2019-07-31 | 3058, 3055 |  |  | 2019-07-31 | 2019-07-31 | 0d |  |  | 1079d |  |  |  |  |  |  |  |  |  |  |  |  |  |  |  |
| 17 | 2 | **Atividade Interna Renova** |  | 647d | 2017-03-20 A | 2019-09-23 |  | 99% | 0d | 2017-03-20 | 2019-09-23 | 647d | 2016-12-28 | 2025-02-25 | 1019d |  |  | Verde | Verde | 87% | 100% | Verde | 100% | 100% | 99 | 87 | 100 | Compensatória | 100 | 100 |
| 18 | 2.1 | **Atividade Interna Renova** |  | 65d | 2017-03-20 A | 2017-06-16 A |  | 100% |  | 2017-03-20 | 2017-06-16 | 65d | 2017-03-20 | 2017-06-16 |  |  |  | Verde | Verde | 100% | 100% | Verde | 100% | 100% | 100 | 100 | 100 | Compensatória | 100 | 100 |
| 19 | 2.1.1 | Atividade Interna Renova |  | 51d | 2017-03-20 A | 2017-05-29 A | 6FS+83ed, 2 | 100% |  | 2017-03-20 | 2017-05-29 | 51d | 2017-03-20 | 2017-05-29 |  |  | start no earlier than 2017-03-20 | Verde | Verde | 100% | 100% | Verde | 100% | 100% | 100 | 100 | 100 | Compensatória | 100 | 100 |
| 20 | 2.1.2 | Atividade Interna Renova |  | 55d | 2017-04-02 A | 2017-06-16 A | 19SS+13ed | 100% |  | 2017-04-02 | 2017-06-16 | 55d | 2017-04-02 | 2017-06-16 |  |  |  | Verde | Verde | 100% | 100% | Verde | 100% | 100% | 100 | 100 | 100 | Compensatória | 100 | 100 |
| 21 | 2.1.3 | Atividade Interna Renova |  | 43d | 2017-04-03 A | 2017-05-31 A | 20SS+1ed | 100% |  | 2017-04-03 | 2017-05-31 | 43d | 2017-04-03 | 2017-05-31 |  |  |  | Verde | Verde | 100% | 100% | Verde | 100% | 100% | 100 | 100 | 100 | Compensatória | 100 | 100 |
| 22 | 2.1.4 | Atividade Interna Renova |  | 39d | 2017-04-03 A | 2017-05-25 A | 20SS+1ed | 100% |  | 2017-04-03 | 2017-05-25 | 39d | 2017-04-03 | 2017-05-25 |  |  |  | Verde | Verde | 100% | 100% | Verde | 100% | 100% | 100 | 100 | 100 | Compensatória | 100 | 100 |
| 23 | 2.1.5 | Atividade Interna Renova |  | 17d | 2017-05-05 A | 2017-05-29 A | 22SS+32ed | 100% |  | 2017-05-05 | 2017-05-29 | 17d | 2017-05-05 | 2017-05-29 |  |  |  | Verde | Verde | 100% | 100% | Verde | 100% | 100% | 100 | 100 | 100 | Compensatória | 100 | 100 |
| 24 | 2.1.6 | Atividade Interna Renova | milestone | 0d | 2017-05-10 A | 2017-05-10 A | 19SS+51ed | 100% |  | 2017-05-10 | 2017-05-10 | 0d | 2017-05-10 | 2017-05-10 |  |  |  | Verde | Verde | 100% | 100% | Verde | 100% | 100% | 100 | 100 | 100 | Compensatória | 100 | 100 |
| 25 | 2.1.7 | Atividade Interna Renova | milestone | 0d | 2017-05-12 A | 2017-05-12 A | 19SS+53ed | 100% |  | 2017-05-12 | 2017-05-12 | 0d | 2017-05-12 | 2017-05-12 |  |  |  | Verde | Verde | 100% | 100% | Verde | 100% | 100% | 100 | 100 | 100 | Compensatória | 100 | 100 |
| 26 | 2.1.8 | Atividade Interna Renova |  | 6d | 2017-05-22 A | 2017-05-29 A | 19SS+63ed | 100% |  | 2017-05-22 | 2017-05-29 | 6d | 2017-05-22 | 2017-05-29 |  |  |  | Verde | Verde | 100% | 100% | Verde | 100% | 100% | 100 | 100 | 100 | Compensatória | 100 | 100 |
| 27 | 2.1.9 | Atividade Interna Renova |  | 3d | 2017-05-25 A | 2017-05-29 A | 26SS+3ed | 100% |  | 2017-05-25 | 2017-05-29 | 3d | 2017-05-25 | 2017-05-29 |  |  |  | Verde | Verde | 100% | 100% | Verde | 100% | 100% | 100 | 100 | 100 | Compensatória | 100 | 100 |
| 28 | 2.1.10 | Atividade Interna Renova |  | 3d | 2017-05-25 A | 2017-05-29 A | 19SS+66ed | 100% |  | 2017-05-25 | 2017-05-29 | 3d | 2017-05-25 | 2017-05-29 |  |  |  | Verde | Verde | 100% | 100% | Verde | 100% | 100% | 100 | 100 | 100 | Compensatória | 100 | 100 |
| 29 | 2.1.11 | Atividade Interna Renova | milestone | 0d | 2017-05-29 A | 2017-05-29 A | 23, 24, 25, 27, 28 | 100% |  | 2017-05-29 | 2017-05-29 | 0d | 2017-05-29 | 2017-05-29 |  |  |  | Verde | Verde | 100% | 100% | Verde | 100% | 100% | 100 | 100 | 100 | Compensatória | 100 | 100 |
| 30 | 2.1.12 | Atividade Interna Renova | milestone | 0d | 2017-05-31 A | 2017-05-31 A | 21SS+58ed, 29 | 100% |  | 2017-05-31 | 2017-05-31 | 0d | 2017-05-31 | 2017-05-31 |  |  |  | Verde | Verde | 100% | 100% | Verde | 100% | 100% | 100 | 100 | 100 | Compensatória | 100 | 100 |

Notes:
- 9: 01/07/2019: no dia 28/06/2019 foi feita a transferência de R$ 141.950.050,00 para a conta da Fundação Renova (fonte e-mail Bruna Buldrini

| ID | WBS | Task | Type | Duration | Start | Finish | Predecessors | Complete | Baseline start | Baseline finish | Baseline duration | Baseline 1 start | Baseline 1 finish | Total slack | Free slack | Text1 | Text2 | Text3 | Text4 | Text5 | Text6 | Text7 | Text8 | Text12 | Text14 | Text15 | Text16 | Text17 |
| --- | --- | --- | --- | --- | --- | --- | --- | --- | --- | --- | --- | --- | --- | --- | --- | --- | --- | --- | --- | --- | --- | --- | --- | --- | --- | --- | --- | --- |
| 31 | 2.2 | **Atividade Interna Renova** |  | 139d | 2017-06-15 A | 2017-12-26 A |  | 100% | 2017-06-15 | 2017-12-26 | 139d | 2017-06-15 | 2017-12-26 |  |  | Verde | Verde | 100% | 100 | 100 | 100% | 100 | Compensatória | Verde | 100% | 100 | 100% | 100 |
| 32 | 2.2.1 | Atividade Interna Renova |  | 8d | 2017-06-15 A | 2017-06-26 A | 20SS+74ed | 100% | 2017-06-15 | 2017-06-26 | 8d | 2017-06-15 | 2017-06-26 |  |  | Verde | Verde | 100% | 100 | 100 | 100% | 100 | Compensatória | Verde | 100% | 100 | 100% | 100 |
| 33 | 2.2.2 | Atividade Interna Renova |  | 7d | 2017-06-19 A | 2017-06-27 A | 26SS+28ed | 100% | 2017-06-19 | 2017-06-27 | 7d | 2017-06-19 | 2017-06-27 |  |  | Verde | Verde | 100% | 100 | 100 | 100% | 100 | Compensatória | Verde | 100% | 100 | 100% | 100 |
| 34 | 2.2.3 | Atividade Interna Renova | milestone | 0d | 2017-06-27 A | 2017-06-27 A | 32 | 100% | 2017-06-27 | 2017-06-27 | 0d | 2017-06-27 | 2017-06-27 |  |  | Verde | Verde | 100% | 100 | 100 | 100% | 100 | Compensatória | Verde | 100% | 100 | 100% | 100 |
| 35 | 2.2.4 | Atividade Interna Renova |  | 20d | 2017-06-27 A | 2017-07-24 A | 34SS | 100% | 2017-06-27 | 2017-07-24 | 20d | 2017-06-27 | 2017-07-24 |  |  | Verde | Verde | 100% | 100 | 100 | 100% | 100 | Compensatória | Verde | 100% | 100 | 100% | 100 |
| 36 | 2.2.5 | Atividade Interna Renova |  | 39d | 2017-06-27 A | 2017-08-18 A | 34SS | 100% | 2017-06-27 | 2017-08-18 | 39d | 2017-06-27 | 2017-08-18 |  |  | Verde | Verde | 100% | 100 | 100 | 100% | 100 | Compensatória | Verde | 100% | 100 | 100% | 100 |
| 37 | 2.2.6 | Atividade Interna Renova | milestone | 0d | 2017-07-24 A | 2017-07-24 A | 33, 35 | 100% | 2017-07-24 | 2017-07-24 | 0d | 2017-07-24 | 2017-07-24 |  |  | Verde | Verde | 100% | 100 | 100 | 100% | 100 | Compensatória | Verde | 100% | 100 | 100% | 100 |
| 38 | 2.2.7 | Atividade Interna Renova | milestone | 0d | 2017-07-26 A | 2017-07-26 A | 37FS+2ed | 100% | 2017-07-26 | 2017-07-26 | 0d | 2017-07-26 | 2017-07-26 |  |  | Verde | Verde | 100% | 100 | 100 | 100% | 100 | Compensatória | Verde | 100% | 100 | 100% | 100 |
| 39 | 2.2.8 | Atividade Interna Renova |  | 3d | 2017-08-17 A | 2017-08-21 A | 38FS+22ed | 100% | 2017-08-17 | 2017-08-21 | 3d | 2017-08-17 | 2017-08-21 |  |  | Verde | Verde | 100% | 100 | 100 | 100% | 100 | Compensatória | Verde | 100% | 100 | 100% | 100 |
| 40 | 2.2.9 | Atividade Interna Renova |  | 5d | 2017-08-18 A | 2017-08-24 A | 36 | 100% | 2017-08-18 | 2017-08-24 | 5d | 2017-08-18 | 2017-08-24 |  |  | Verde | Verde | 100% | 100 | 100 | 100% | 100 | Compensatória | Verde | 100% | 100 | 100% | 100 |
| 41 | 2.2.10 | Atividade Interna Renova |  | 2d | 2017-08-21 A | 2017-08-22 A | 39 | 100% | 2017-08-21 | 2017-08-22 | 2d | 2017-08-21 | 2017-08-22 |  |  | Verde | Verde | 100% | 100 | 100 | 100% | 100 | Compensatória | Verde | 100% | 100 | 100% | 100 |
| 42 | 2.2.11 | Atividade Interna Renova |  | 5d | 2017-08-18 A | 2017-08-24 A | 36 | 100% | 2017-08-18 | 2017-08-24 | 5d | 2017-08-18 | 2017-08-24 |  |  | Verde | Verde | 100% | 100 | 100 | 100% | 100 | Compensatória | Verde | 100% | 100 | 100% | 100 |
| 43 | 2.2.12 | Atividade Interna Renova |  | 45d | 2017-08-22 A | 2017-10-23 A | 41 | 100% | 2017-08-22 | 2017-10-23 | 45d | 2017-08-22 | 2017-10-23 |  |  | Verde | Verde | 100% | 100 | 100 | 100% | 100 | Compensatória | Verde | 100% | 100 | 100% | 100 |
| 44 | 2.2.13 | Atividade Interna Renova | milestone | 0d | 2017-08-25 A | 2017-08-25 A | 40FS+1ed, 42FS+1ed | 100% | 2017-08-25 | 2017-08-25 | 0d | 2017-08-25 | 2017-08-25 |  |  | Verde | Verde | 100% | 100 | 100 | 100% | 100 | Compensatória | Verde | 100% | 100 | 100% | 100 |
| 45 | 2.2.14 | Atividade Interna Renova |  | 83d | 2017-09-01 A | 2017-12-26 A | 44FS+7ed | 100% | 2017-09-01 | 2017-12-26 | 83d | 2017-09-01 | 2017-12-26 |  |  | Verde | Verde | 100% | 100 | 100 | 100% | 100 | Compensatória | Verde | 100% | 100 | 100% | 100 |
| 46 | 2.2.15 | Atividade Interna Renova | milestone | 0d | 2017-09-21 A | 2017-09-21 A | 45SS+20ed | 100% | 2017-09-21 | 2017-09-21 | 0d | 2017-09-21 | 2017-09-21 |  |  | Verde | Verde | 100% | 100 | 100 | 100% | 100 | Compensatória | Verde | 100% | 100 | 100% | 100 |
| 47 | 2.2.16 | Atividade Interna Renova |  | 6d | 2017-09-29 A | 2017-10-06 A | 44FS+35ed | 100% | 2017-09-29 | 2017-10-06 | 6d | 2017-09-29 | 2017-10-06 |  |  | Verde | Verde | 100% | 100 | 100 | 100% | 100 | Compensatória | Verde | 100% | 100 | 100% | 100 |
| 48 | 2.2.17 | Atividade Interna Renova | milestone | 0d | 2017-10-06 A | 2017-10-06 A | 47 | 100% | 2017-10-06 | 2017-10-06 | 0d | 2017-10-06 | 2017-10-06 |  |  | Verde | Verde | 100% | 100 | 100 | 100% | 100 | Compensatória | Verde | 100% | 100 | 100% | 100 |
| 49 | 2.3 | **Atividade Interna Renova** |  | 57d | 2017-10-01 A | 2017-12-19 A |  | 100% | 2017-10-01 | 2017-12-19 | 57d | 2017-10-01 | 2017-12-19 |  |  | Verde | Verde | 100% | 100 | 100 | 100% | 100 | Compensatória | Verde | 100% | 100 | 100% | 100 |
| 50 | 2.3.1 | Atividade Interna Renova |  | 35d | 2017-10-01 A | 2017-11-17 A | 47SS+1ed | 100% | 2017-10-01 | 2017-11-17 | 35d | 2017-10-01 | 2017-11-17 |  |  | Verde | Verde | 100% | 100 | 100 | 100% | 100 | Compensatória | Verde | 100% | 100 | 100% | 100 |
| 51 | 2.3.2 | Atividade Interna Renova |  | 35d | 2017-10-01 A | 2017-11-17 A | 50SS | 100% | 2017-10-01 | 2017-11-17 | 35d | 2017-10-01 | 2017-11-17 |  |  | Verde | Verde | 100% | 100 | 100 | 100% | 100 | Compensatória | Verde | 100% | 100 | 100% | 100 |
| 52 | 2.3.3 | Atividade Interna Renova |  | 35d | 2017-10-01 A | 2017-11-17 A | 30, 50SS, 51SS | 100% | 2017-10-01 | 2017-11-17 | 35d | 2017-10-01 | 2017-11-17 |  |  | Verde | Verde | 100% | 100 | 100 | 100% | 100 | Compensatória | Verde | 100% | 100 | 100% | 100 |
| 53 | 2.3.4 | Atividade Interna Renova |  | 7d | 2017-10-06 A | 2017-10-16 A | 47 | 100% | 2017-10-06 | 2017-10-16 | 7d | 2017-10-06 | 2017-10-16 |  |  | Verde | Verde | 100% | 100 | 100 | 100% | 100 | Compensatória | Verde | 100% | 100 | 100% | 100 |
| 54 | 2.3.5 | Atividade Interna Renova |  | 7d | 2017-10-06 A | 2017-10-16 A | 47, 48 | 100% | 2017-10-06 | 2017-10-16 | 7d | 2017-10-06 | 2017-10-16 |  |  | Verde | Verde | 100% | 100 | 100 | 100% | 100 | Compensatória | Verde | 100% | 100 | 100% | 100 |
| 55 | 2.3.6 | Atividade Interna Renova |  | 6d | 2017-10-16 A | 2017-10-23 A | 54 | 100% | 2017-10-16 | 2017-10-23 | 6d | 2017-10-16 | 2017-10-23 |  |  | Verde | Verde | 100% | 100 | 100 | 100% | 100 | Compensatória | Verde | 100% | 100 | 100% | 100 |
| 56 | 2.3.7 | Atividade Interna Renova |  | 5d | 2017-10-21 A | 2017-10-27 A | 46FS+8d, 53, 55 | 100% | 2017-10-21 | 2017-10-27 | 5d | 2017-10-21 | 2017-10-27 |  |  | Verde | Verde | 100% | 100 | 100 | 100% | 100 | Compensatória | Verde | 100% | 100 | 100% | 100 |
| 57 | 2.3.8 | Atividade Interna Renova | milestone | 0d | 2017-10-27 A | 2017-10-27 A | 43, 56 | 100% | 2017-10-27 | 2017-10-27 | 0d | 2017-10-27 | 2017-10-27 |  |  | Verde | Verde | 100% | 100 | 100 | 100% | 100 | Compensatória | Verde | 100% | 100 | 100% | 100 |
| 58 | 2.3.9 | Atividade Interna Renova | milestone | 0d | 2017-11-20 A | 2017-11-20 A | 57FS+24ed | 100% | 2017-11-20 | 2017-11-20 | 0d | 2017-11-20 | 2017-11-20 |  |  | Verde | Verde | 100% | 100 | 100 | 100% | 100 | Compensatória | Verde | 100% | 100 | 100% | 100 |
| 59 | 2.3.10 | Atividade Interna Renova |  | 6d | 2017-11-17 A | 2017-11-24 A | 52 | 100% | 2017-11-17 | 2017-11-24 | 6d | 2017-11-17 | 2017-11-24 |  |  | Verde | Verde | 100% | 100 | 100 | 100% | 100 | Compensatória | Verde | 100% | 100 | 100% | 100 |
| 60 | 2.3.11 | Atividade Interna Renova |  | 18d | 2017-11-24 A | 2017-12-19 A | 58, 59 | 100% | 2017-11-24 | 2017-12-19 | 18d | 2017-11-24 | 2017-12-19 |  |  | Verde | Verde | 100% | 100 | 100 | 100% | 100 | Compensatória | Verde | 100% | 100 | 100% | 100 |
| 61 | 2.4 | Atividade Interna Renova |  | 1d | 2019-01-02 A | 2019-01-02 A | 60FS+3ed | 100% | 2019-01-02 | 2019-01-02 | 1d | 2019-01-02 | 2019-01-02 |  |  | Verde | Verde | 100% | 100 | 100 | 100% | 100 | Compensatória | Verde | 100% | 100 | 100% | 100 |
| 62 | 2.5 | Atividade Interna Renova | milestone | 0d | 2019-09-23 | 2019-09-23 | 61FS+180d |  | 2019-09-23 | 2019-09-23 | 0d | 2019-09-23 | 2019-09-23 | 1019d | 0d | Verde | Verde | 0% |  |  | 0% |  | Compensatória | Verde | 0% |  | 0% |  |
| 63 | 2.6 | Atividade Interna Renova | milestone | 0d | 2019-09-23 | 2019-09-23 | 62 |  | 2019-09-23 | 2019-09-23 | 0d |  |  | 1019d |  | Verde | Verde | 0% |  |  | 0% |  |  | Verde | 0% |  | 0% |  |

Notes:
- 62: Em 19/03/19: por solicitação da A&M foi modificada a latência da atividade Aprovação da Definição do Programa pelo CIF de 480 dias para 104 dias para atendimento à demanda do MP e igualar as datas de término tendência às da definição do programa.

| ID | WBS | Task | Type | Duration | Start | Finish | Predecessors | Complete | Remaining | Baseline start | Baseline finish | Baseline duration | Baseline 1 start | Baseline 1 finish | Total slack | Free slack | Constraint | Text1 | Text2 | Text3 | Text4 | Text5 | Text6 | Text7 | Text8 | Text12 | Text14 | Text15 | Text16 | Text17 | Text13 | Text9 | Text18 |
| --- | --- | --- | --- | --- | --- | --- | --- | --- | --- | --- | --- | --- | --- | --- | --- | --- | --- | --- | --- | --- | --- | --- | --- | --- | --- | --- | --- | --- | --- | --- | --- | --- | --- |
| 64 | 3 | **Execução** |  | 1557d | 2017-08-18 A | 2023-10-30 |  | 9% | 1421.29d | 2016-12-28 | 2023-10-30 | 1724d | 2017-08-18 | 2025-02-25 | 23d |  |  | Verde | Verde | 36% | 14 | 36 | 100% | 100 | Compensatória | Verde | 30% | 30 | 30% | 30 |  |  |  |
| 65 | 3.1 | **Processo de Repasse de Recurso** |  | 1557d | 2017-08-18 A | 2023-10-30 |  | 7% | 1449.1d | 2017-08-18 | 2023-10-30 | 1557d |  |  | 23d |  |  | Verde | Verde | 29% |  | 29 | 100% | 100 | Compensatória | Verde | 15% | 15 | 15% | 15 |  |  |  |
| 66 | 3.1.1 | **Atividade Interna Renova** |  | 104d | 2017-08-18 A | 2018-01-10 A |  | 100% |  | 2017-08-18 | 2018-01-10 | 104d | 2017-08-18 | 2018-01-10 |  |  |  | Verde | Verde | 100% | 100 | 100 | 100% | 100 | Compensatória | Verde | 100% | 100 | 100% | 100 |  |  |  |
| 67 | 3.1.1.1 | Atividade Interna Renova |  | 2d | 2017-08-18 A | 2017-08-21 A | 36 | 100% |  | 2017-08-18 | 2017-08-21 | 2d | 2017-08-18 | 2017-08-21 |  |  |  | Verde | Verde | 100% | 100 | 100 | 100% | 100 | Compensatória | Verde | 100% | 100 | 100% | 100 | Suprimentos |  |  |
| 68 | 3.1.1.2 | Atividade Interna Renova |  | 1d | 2017-09-11 A | 2017-09-11 A | 44FS+17ed, 67FS+21ed | 100% |  | 2017-09-11 | 2017-09-11 | 1d | 2017-09-11 | 2017-09-11 |  |  |  | Verde | Verde | 100% | 100 | 100 | 100% | 100 | Compensatória | Verde | 100% | 100 | 100% | 100 | Suprimentos |  |  |
| 69 | 3.1.1.3 | Atividade Interna Renova |  | 35d | 2017-09-11 A | 2017-10-30 A | 68 | 100% |  | 2017-09-11 | 2017-10-30 | 35d | 2017-09-11 | 2017-10-30 |  |  |  | Verde | Verde | 100% | 100 | 100 | 100% | 100 | Compensatória | Verde | 100% | 100 | 100% | 100 | Suprimentos |  |  |
| 70 | 3.1.1.4 | Atividade Interna Renova |  | 52d | 2017-10-30 A | 2018-01-10 A | 69 | 100% |  | 2017-10-30 | 2018-01-10 | 52d | 2017-10-30 | 2018-01-10 |  |  |  | Verde | Verde | 100% | 100 | 100 | 100% | 100 | Compensatória | Verde | 100% | 100 | 100% | 100 | Suprimentos |  |  |
| 71 | 3.1.1.5 | Atividade Interna Renova | milestone | 0d | 2018-01-10 A | 2018-01-10 A | 70 | 100% |  | 2018-01-10 | 2018-01-10 | 0d | 2018-01-10 | 2018-01-10 |  |  |  | Verde | Verde | 100% | 100 | 100 | 100% | 100 | Compensatória | Verde | 100% | 100 | 100% | 100 | Suprimentos |  |  |
| 72 | 3.1.2 | **Atividade Interna Renova** |  | 251d | 2018-02-20 A | 2019-02-06 A |  | 100% |  | 2018-02-20 | 2019-02-06 | 251d | 2018-02-20 | 2019-02-06 |  |  |  | Verde | Verde | 100% | 100 | 100 | 100% | 100 | Compensatória | Verde | 100% | 100 | 100% | 100 |  |  |  |
| 73 | 3.1.2.1 | Atividade Interna Renova | milestone | 0d | 2018-02-20 A | 2018-02-20 A | 71FS+40ed | 100% |  | 2018-02-20 | 2018-02-20 | 0d | 2018-02-20 | 2018-02-20 |  |  |  | Verde | Verde | 100% | 100 | 100 | 100% | 100 | Compensatória | Verde | 100% | 100 | 100% | 100 |  |  |  |
| 74 | 3.1.2.2 | Atividade Interna Renova |  | 14d | 2018-02-20 A | 2018-03-09 A | 73 | 100% |  | 2018-02-20 | 2018-03-09 | 14d | 2018-02-20 | 2018-03-09 |  |  |  | Verde | Verde | 100% | 100 | 100 | 100% | 100 | Compensatória | Verde | 100% | 100 | 100% | 100 |  |  |  |
| 75 | 3.1.2.3 | Atividade Interna Renova |  | 204d | 2018-04-05 A | 2019-02-06 A | 74FS+27ed | 100% |  | 2018-04-05 | 2019-02-06 | 204d | 2018-04-05 | 2019-02-06 |  |  |  | Verde | Verde | 100% | 100 | 100 | 100% | 100 | Compensatória | Verde | 100% | 100 | 100% | 100 |  |  |  |
| 76 | 3.1.2.4 | Atividade Interna Renova | milestone | 0d | 2019-02-06 A | 2019-02-06 A | 75 | 100% |  | 2019-02-06 | 2019-02-06 | 0d | 2019-02-06 | 2019-02-06 |  |  |  | Verde | Verde | 100% | 100 | 100 | 100% | 100 | Compensatória | Verde | 100% | 100 | 100% | 100 |  |  |  |
| 77 | 3.1.3 | **Processo de Repasse de Recursos aos Municípios** |  | 1342d | 2018-06-15 A | 2023-10-30 |  | 7% | 1253.91d | 2018-06-15 | 2023-10-30 | 1342d | 2018-06-15 | 2025-02-25 | 23d |  |  | Verde | Verde | 18% |  | 18 | 50% | 50 | Compensatória | Vermelho | 2% |  | 1% |  |  |  |  |
| 78 | 3.1.3.1 | Repasse de recursos aos municípios iniciado | milestone | 0d | 2018-12-21 A | 2018-12-21 A | 2583 | 100% |  | 2018-12-21 | 2018-12-21 | 0d |  |  |  |  |  | Verde | Verde | 100% | 100 | 100 | 100% | 100 | Compensatória | Verde | 100% | 100 | 100% | 100 |  |  |  |
| 79 | 3.1.3.2 | **Aimorés** |  | 913d | 2019-04-23 A | 2022-12-22 |  | 1% | 908.41d | 2019-04-23 | 2022-12-22 | 913d | 2019-04-23 | 2023-03-21 | 212d |  |  | Verde | Verde | 2% |  |  | 0% |  | Compensatória | Vermelho | 0% |  | 0% |  |  |  |  |
| 80 | 3.1.3.2.1 | **Pleito AIMESPJ03 - Elaboração de projeto, incluindo levantamento topográfico e licenciamento para tratamento dos esgotos sanitários gerados somente na sede** |  | 302d | 2019-04-23 A | 2020-07-09 |  | 3% | 292.95d | 2019-04-23 | 2020-07-09 | 302d | 2019-04-23 | 2020-07-24 | 823d |  |  | Verde | Verde | 8% |  |  | 0% |  | Compensatória | Vermelho | 2% |  | 0% |  |  |  |  |
| 81 | 3.1.3.2.1.1 | Pleito AIMESPJ03 - Elaboração de projeto, incluindo levantamento topográfico e licenciamento para tratamento dos esgotos sanitários gerados somente na sede aprovado | milestone | 0d | 2019-04-23 A | 2019-04-23 A |  | 100% |  | 2019-04-23 | 2019-04-23 | 0d | 2019-04-23 | 2019-04-23 |  |  | must start on 2019-04-23 | Verde | Verde | 100% | 100 | 100 | 100% | 100 | Compensatória | Verde | 100% | 100 | 100% | 100 |  | CT/CIF |  |
| 82 | 3.1.3.2.1.2 | **Licitação do projeto** |  | 76d | 2019-05-13 A | 2019-08-29 |  | 20% | 61.01d | 2019-05-13 | 2019-08-29 | 76d | 2019-05-08 | 2019-08-02 | 823d |  |  | Verde | Verde | 18% | 20 | 18 | 0% |  | Compensatória | Vermelho | 19% | 19 | 0% |  |  |  |  |
| 83 | 3.1.3.2.1.2.1 | Licitação do projeto do Pleito AIMESPJ03 - Elaboração de projeto, incluindo levantamento topográfico e licenciamento para tratamento dos esgotos sanitários gerados somente na sede autorizada pelo banco | milestone | 0d | 2019-05-13 A | 2019-05-13 A | 81FS+13d | 100% |  | 2019-05-13 | 2019-05-13 | 0d | 2019-05-08 | 2019-05-08 |  |  |  | Verde | Verde | 100% | 100 | 100 | 100% | 100 | Compensatória | Verde | 100% | 100 | 100% | 100 |  | Banco |  |
| 84 | 3.1.3.2.1.2.2 | Licitar projeto |  | 56d | 2019-05-14 A | 2019-07-31 | 83 | 25% | 42d | 2019-05-14 | 2019-07-31 | 56d | 2019-05-09 | 2019-07-05 | 823d | 0d |  | Verde | Verde | 25% | 25 | 25 | 0% |  | Compensatória | Vermelho | 25% | 25 | 0% |  |  | Município | Conforme agendado |
| 85 | 3.1.3.2.1.2.3 | Documentação de licitação do projeto do Pleito AIMESPJ03 - Elaboração de projeto, incluindo levantamento topográfico e licenciamento para tratamento dos esgotos sanitários gerados somente na sede apresentada ao banco | milestone | 0d | 2019-08-07 | 2019-08-07 | 84FS+5d |  |  | 2019-08-07 | 2019-08-07 | 0d | 2019-07-12 | 2019-07-12 | 823d | 0d |  | Verde | Verde | 0% |  |  | 0% |  | Compensatória | Verde | 0% |  | 0% |  |  | Município |  |
| 86 | 3.1.3.2.1.2.4 | Analisar e emitir resultado da licitação do projeto |  | 15d | 2019-08-08 | 2019-08-29 | 85 |  |  | 2019-08-08 | 2019-08-29 | 15d | 2019-07-15 | 2019-08-02 | 823d | 0d |  | Verde | Verde | 0% |  |  | 0% |  | Compensatória | Verde | 0% |  | 0% |  |  | Banco | Critério FR |
| 87 | 3.1.3.2.1.2.5 | Licitação do projeto do Pleito AIMESPJ03 - Elaboração de projeto, incluindo levantamento topográfico e licenciamento para tratamento dos esgotos sanitários gerados somente na sede concluída | milestone | 0d | 2019-08-29 | 2019-08-29 | 86 |  |  | 2019-08-29 | 2019-08-29 | 0d | 2019-08-02 | 2019-08-02 | 823d | 0d |  | Verde | Verde | 0% |  |  | 0% |  | Compensatória | Verde | 0% |  | 0% |  |  | Município |  |

Notes:
- 75: - Falta apenas o munícipio de Rio Doce para assinatura de contrato de repasse com o BDMG, porque o mesmo está com pendência no CND. / - O múnicípio de Rio Doce não está mais com pendência
- 77: Premissas: / Como não temos dados suficientes das ações a serem implantadas pelos municípios, devido aos pleitos incompletos e mesmo pelo tempo de execução destas ações que não cabem à Renova, é importante considerar: / ·Os municípios ainda não definiram todas as ações a serem executadas / ·Os municípios irão contratar diretamente os projetos e obras a serem executados e não temos ainda o cronograma destas atividades / ·Não sabemos ainda o impacto do prazo para o licenciamento das áreas necessárias para a implantação do programa nos municípios / ·Diante destes fatos, adotamos como premissa para o cronograma de obra, o valor financeiro destinado às mesmas de acordo com o pleito dos munícipios: / Até 1.000.000 - 6 meses / De 1.000.001 a 3.000.000 - 8 meses / De 3.000.001 a 5.000.000 - 12 meses / De 5.000.001 a 7.000.000 - 15 meses / De 7.000.001 a 9.000.000 - 18 meses / De 9.000.001 a 11.000.000 - 20 meses / De 11.000.001 a 14.000.000 - 24 meses / Acima de 14.000.000 - 30 meses / ·Na parte de licenciamento usamos como premissa dois prazos / 6 meses - Até 30.000 hab./ Até 50l/s / 9 meses - Maior que 30.000hab./ maior que 50l/s / ·Licitação de Projetos/Obras / 2/3/4 meses / ·Elaboração de projetos - Prazo depende do porte da obra e do prazo de licenciamento / Projeto Básico - 2 meses/3 meses / Projeto Executivo - 2meses/4 meses/ 6 meses/ 9 meses / ·Gestão das ações implementadas / 6 meses / Ainda deverá ser detalhado por munícipio as ações de Resíduos Sólidos. Como a maioria dos munícipios ainda não têm os pleitos aprovados e os consórcios ainda estão em fase de planejamento, deve-se esperar uma maturidade maior para fazer eata programação.
- 79: Aimorés teve 33,2% dos pleitos de Esgotamento Sanitário aprovado (R$3.664.703,00), conforme Deliberação 75. / O município teve o pleito de resíduos sólidos negado (R$1.102.965,05), equivalente a 10% do total do recurso,). / Aimorés solicitou mudança de pleito, conforme abaixo, mas ainda não foi autorizado pelo CIF. / Solicitação: Substituição dos distritos de São Sebastião da Vala e Mundo Novo pela sede para implantação de SES (R$ 9.326.685,45) e Aquisição de terreno (R$ 200.000,00).
- 81: Em 12/04/19: o pleito foi aprovado na CT (NT36) e pode ser aprovado no próximo CIF (26/04) / Em 26/04/19: pleito aprovado no CIF dia 23/04/2019 na deliberação 276.
- 83: 05/05/2019: não autorizado até o momento conforme planilha Controle Gerencial Renova / 21/05/2019: autorizado pelo banco conforme planilha Controle Gerencial Renova
- 84: 31/05/2019: TR está pronto.

| ID | WBS | Task | Type | Duration | Start | Finish | Predecessors | Complete | Remaining | Baseline start | Baseline finish | Baseline duration | Baseline 1 start | Baseline 1 finish | Total slack | Free slack | Text1 | Text2 | Text3 | Text6 | Text8 | Text12 | Text14 | Text16 | Text18 | Text9 | Text4 | Text5 | Text7 | Text15 | Text17 |
| --- | --- | --- | --- | --- | --- | --- | --- | --- | --- | --- | --- | --- | --- | --- | --- | --- | --- | --- | --- | --- | --- | --- | --- | --- | --- | --- | --- | --- | --- | --- | --- |
| 88 | 3.1.3.2.1.3 | **Elaboração do Estudo de Concepção** |  | 105d | 2019-08-30 | 2020-01-30 |  |  |  | 2019-08-30 | 2020-01-30 | 105d |  |  | 823d |  | Verde | Verde | 0% | 0% | Compensatória | Verde | 0% | 0% |  |  |  |  |  |  |  |
| 89 | 3.1.3.2.1.3.1 | Elaborar estudo |  | 40d | 2019-08-30 | 2019-10-24 | 87 |  |  | 2019-08-30 | 2019-10-24 | 40d |  |  | 823d | 0d | Verde | Verde | 0% | 0% | Compensatória | Verde | 0% | 0% | Critério FR |  |  |  |  |  |  |
| 90 | 3.1.3.2.1.3.2 | Estudo do Pleito AIMESPJ03 - Elaboração de projeto, incluindo levantamento topográfico e licenciamento para tratamento dos esgotos sanitários gerados somente na sede apresentado ao banco | milestone | 0d | 2019-10-24 | 2019-10-24 | 89 |  |  | 2019-10-24 | 2019-10-24 | 0d |  |  | 823d | 0d | Verde | Verde | 0% | 0% | Compensatória | Verde | 0% | 0% |  |  |  |  |  |  |  |
| 91 | 3.1.3.2.1.3.3 | Analisar estudo |  | 60d | 2019-10-25 | 2020-01-23 | 90 |  |  | 2019-10-25 | 2020-01-23 | 60d |  |  | 823d | 0d | Verde | Verde | 0% | 0% | Compensatória | Verde | 0% | 0% | Critério FR |  |  |  |  |  |  |
| 92 | 3.1.3.2.1.3.4 | Estudo do Pleito AIMESPJ03 - Elaboração de projeto, incluindo levantamento topográfico e licenciamento para tratamento dos esgotos sanitários gerados somente na sede aprovado | milestone | 0d | 2020-01-23 | 2020-01-23 | 91 |  |  | 2020-01-23 | 2020-01-23 | 0d |  |  | 921d | 0d | Verde | Verde | 0% | 0% | Compensatória | Verde | 0% | 0% |  |  |  |  |  |  |  |
| 93 | 3.1.3.2.1.3.5 | Recurso do estudo do Pleito AIMESPJ03 - Elaboração de projeto, incluindo levantamento topográfico e licenciamento para tratamento dos esgotos sanitários gerados somente na sede repassado | milestone | 0d | 2020-01-30 | 2020-01-30 | 92FS+5d |  |  | 2020-01-30 | 2020-01-30 | 0d |  |  | 921d | 44d | Verde | Verde | 0% | 0% | Compensatória | Verde | 0% | 0% |  |  |  |  |  |  |  |
| 94 | 3.1.3.2.1.4 | **Elaboração do Projeto Básico** |  | 114d | 2019-10-25 | 2020-04-14 |  |  |  | 2019-08-30 | 2020-02-12 | 114d | 2019-08-05 | 2020-02-28 | 844d |  | Verde | Verde | 0% | 0% | Compensatória | Verde | 0% | 0% |  |  |  |  |  |  |  |
| 95 | 3.1.3.2.1.4.1 | Elaborar Projeto Básico |  | 40d | 2019-10-25 | 2019-12-23 | 89 |  |  | 2019-08-30 | 2019-10-24 | 40d | 2019-08-05 | 2019-11-06 | 844d | 0d | Verde | Verde | 0% | 0% | Compensatória | Verde | 0% | 0% | Critério FR | Município |  |  |  |  |  |
| 96 | 3.1.3.2.1.4.2 | Projeto Básico do Pleito AIMESPJ03 - Elaboração de projeto, incluindo levantamento topográfico e licenciamento para tratamento dos esgotos sanitários gerados somente na sede apresentado ao banco | milestone | 0d | 2019-12-23 | 2019-12-23 | 95 |  |  | 2019-10-24 | 2019-10-24 | 0d | 2019-11-06 | 2019-11-06 | 844d | 0d | Verde | Verde | 0% | 0% | Compensatória | Verde | 0% | 0% |  | Município |  |  |  |  |  |
| 97 | 3.1.3.2.1.4.3 | Analisar Projeto Básico |  | 69d | 2019-12-26 | 2020-04-06 | 96 |  |  | 2019-12-26 | 2020-04-06 | 69d | 2019-11-07 | 2019-12-09 | 877d | 0d | Verde | Verde | 0% | 0% | Compensatória | Verde | 0% | 0% | Critério FR | Banco |  |  |  |  |  |
| 98 | 3.1.3.2.1.4.4 | Projeto Básico do Pleito AIMESPJ03 - Elaboração de projeto, incluindo levantamento topográfico e licenciamento para tratamento dos esgotos sanitários gerados somente na sede aprovado | milestone | 0d | 2020-04-06 | 2020-04-06 | 93, 97 |  |  | 2020-02-05 | 2020-02-05 | 0d | 2020-02-18 | 2020-02-18 | 877d | 0d | Verde | Verde | 0% | 0% | Compensatória | Verde | 0% | 0% |  | Município |  |  |  |  |  |
| 99 | 3.1.3.2.1.4.5 | Recurso do projeto básico do Pleito AIMESPJ03 - Elaboração de projeto, incluindo levantamento topográfico e licenciamento para tratamento dos esgotos sanitários gerados somente na sede repassado | milestone | 0d | 2020-04-14 | 2020-04-14 | 98FS+5d |  |  | 2020-02-12 | 2020-02-12 | 0d | 2020-02-28 | 2020-02-28 | 877d | 54d | Verde | Verde | 0% | 0% | Compensatória | Verde | 0% | 0% |  | Banco |  |  |  |  |  |
| 100 | 3.1.3.2.1.5 | Realizar Licenciamento Ambiental |  | 80d | 2019-11-25 | 2020-03-24 | 91FS-40d |  |  | 2019-11-25 | 2020-03-24 | 80d | 2019-11-07 | 2020-05-26 | 891d | 68d | Verde | Verde | 0% | 0% | Compensatória | Verde | 0% | 0% |  | Município |  |  |  |  |  |
| 101 | 3.1.3.2.1.6 | **Elaboração do Projeto Executivo** |  | 133d | 2019-12-26 | 2020-07-09 |  |  |  | 2019-10-25 | 2020-07-09 | 173d | 2019-11-07 | 2020-07-24 | 823d |  | Verde | Verde | 0% | 0% | Compensatória | Verde | 0% | 0% |  |  |  |  |  |  |  |
| 102 | 3.1.3.2.1.6.1 | Elaborar Projeto Executivo |  | 40d | 2019-12-26 | 2020-02-20 | 96 |  |  | 2019-10-25 | 2019-12-23 | 40d | 2019-11-07 | 2020-02-13 | 844d | 0d | Verde | Verde | 0% | 0% | Compensatória | Verde | 0% | 0% | Critério FR | Município |  |  |  |  |  |
| 103 | 3.1.3.2.1.6.2 | Projeto Executivo do Pleito AIMESPJ03 - Elaboração de projeto, incluindo levantamento topográfico e licenciamento para tratamento dos esgotos sanitários gerados somente na sede apresentado ao banco | milestone | 0d | 2020-02-20 | 2020-02-20 | 102 |  |  | 2019-12-23 | 2019-12-23 | 0d | 2020-02-13 | 2020-02-13 | 844d | 0d | Verde | Verde | 0% | 0% | Compensatória | Verde | 0% | 0% |  | Município |  |  |  |  |  |
| 104 | 3.1.3.2.1.6.3 | Analisar Projeto Executivo |  | 67d | 2020-02-21 | 2020-06-02 | 103 |  |  | 2020-02-21 | 2020-06-02 | 67d | 2020-02-14 | 2020-03-19 | 844d | 21d | Verde | Verde | 0% | 0% | Compensatória | Verde | 0% | 0% |  | Banco |  |  |  |  |  |
| 105 | 3.1.3.2.1.6.4 | Projeto Executivo Pleito AIMESPJ03 - Elaboração de projeto, incluindo levantamento topográfico e licenciamento para tratamento dos esgotos sanitários gerados somente na sede aprovado | milestone | 0d | 2020-07-02 | 2020-07-02 | 117, 100, 99, 104 |  |  | 2020-07-02 | 2020-07-02 | 0d | 2020-07-17 | 2020-07-17 | 823d | 0d | Verde | Verde | 0% | 0% | Compensatória | Verde | 0% | 0% |  | Município |  |  |  |  |  |
| 106 | 3.1.3.2.1.6.5 | Recurso do projeto executivo do Pleito AIMESPJ03 - Elaboração de projeto, incluindo levantamento topográfico e licenciamento para tratamento dos esgotos sanitários gerados somente na sede repassado | milestone | 0d | 2020-07-09 | 2020-07-09 | 105FS+5d |  |  | 2020-07-09 | 2020-07-09 | 0d | 2020-07-24 | 2020-07-24 | 823d | 0d | Verde | Verde | 0% | 0% | Compensatória | Verde | 0% | 0% |  | Banco |  |  |  |  |  |
| 107 | 3.1.3.2.1.7 | Pleito AIMESPJ03 - Elaboração de projeto, incluindo levantamento topográfico e licenciamento para tratamento dos esgotos sanitários gerados somente na sede de Aimorés concluído | milestone | 0d | 2020-07-09 | 2020-07-09 | 106 |  |  | 2020-07-09 | 2020-07-09 | 0d | 2020-07-24 | 2020-07-24 | 823d | 611d | Verde | Verde | 0% | 0% | Compensatória | Verde | 0% | 0% |  | Município |  |  |  |  |  |
| 108 | 3.1.3.2.2 | **Pleito AIMESCT02 - Aquisição de terreno** |  | 297d | 2019-04-23 A | 2020-07-02 |  |  | 297d | 2019-04-23 | 2020-07-02 | 297d | 2019-04-23 | 2020-07-17 | 828d |  | Verde | Verde | 9% | 0% | Compensatória | Vermelho | 0% | 0% |  |  |  |  |  |  |  |
| 109 | 3.1.3.2.2.1 | Pleito AIMESCT02 - Aquisição de terreno aprovado | milestone | 0d | 2019-04-23 A | 2019-04-23 A | 81 | 100% |  | 2019-04-23 | 2019-04-23 | 0d | 2019-04-23 | 2019-04-23 |  |  | Verde | Verde | 100% | 100% | Compensatória | Verde | 100% | 100% |  | CT/CIF | 100 | 100 | 100 | 100 | 100 |
| 110 | 3.1.3.2.2.2 | **Aquisição de terreno** |  | 148d | 2019-11-25 | 2020-07-02 |  |  |  | 2019-11-25 | 2020-07-02 | 148d | 2019-12-10 | 2020-07-17 | 823d |  | Verde | Verde | 0% | 0% | Compensatória | Verde | 0% | 0% |  |  |  |  |  |  |  |
| 111 | 3.1.3.2.2.2.1 | Regularizar terreno e apresentar escritura ao banco |  | 88d | 2019-11-25 | 2020-04-03 | 109, 91FS-40d |  |  | 2019-11-25 | 2020-04-03 | 88d | 2019-12-10 | 2020-04-22 | 823d | 0d | Verde | Verde | 0% | 0% | Compensatória | Verde | 0% | 0% |  | Município |  |  |  |  |  |
| 112 | 3.1.3.2.2.2.2 | Analisar documentação do terreno |  | 10d | 2020-04-06 | 2020-04-20 | 111 |  |  | 2020-04-06 | 2020-04-20 | 10d | 2020-04-23 | 2020-05-07 | 868d | 0d | Verde | Verde | 0% | 0% | Compensatória | Verde | 0% | 0% |  | Banco |  |  |  |  |  |
| 113 | 3.1.3.2.2.2.3 | 50% do valor do imóvel do Pleito AIMESCT02 - Aquisição de terreno repassado | milestone | 0d | 2020-04-28 | 2020-04-28 | 112FS+5d |  |  | 2020-04-28 | 2020-04-28 | 0d | 2020-05-14 | 2020-05-14 | 868d | 45d | Verde | Verde | 0% | 0% | Compensatória | Verde | 0% | 0% |  | Banco |  |  |  |  |  |
| 114 | 3.1.3.2.2.2.4 | Registrar imóvel e apresentar documentação ao banco |  | 45d | 2020-04-06 | 2020-06-10 | 111 |  |  | 2020-04-06 | 2020-06-10 | 45d | 2020-04-23 | 2020-06-26 | 823d | 0d | Verde | Verde | 0% | 0% | Compensatória | Verde | 0% | 0% |  | Município |  |  |  |  |  |
| 115 | 3.1.3.2.2.2.5 | Analisar documentação do terreno |  | 10d | 2020-06-12 | 2020-06-25 | 114 |  |  | 2020-06-12 | 2020-06-25 | 10d | 2020-06-29 | 2020-07-10 | 823d | 0d | Verde | Verde | 0% | 0% | Compensatória | Verde | 0% | 0% |  | Banco |  |  |  |  |  |
| 116 | 3.1.3.2.2.2.6 | 50% do valor do imóvel do Pleito AIMESCT02 - Aquisição de terreno repassado | milestone | 0d | 2020-07-02 | 2020-07-02 | 115FS+5d |  |  | 2020-07-02 | 2020-07-02 | 0d | 2020-07-17 | 2020-07-17 | 823d | 0d | Verde | Verde | 0% | 0% | Compensatória | Verde | 0% | 0% |  | Banco |  |  |  |  |  |
| 117 | 3.1.3.2.2.2.7 | Aquisição de terreno do Pleito AIMESCT02 - Aquisição de terreno concluída | milestone | 0d | 2020-07-02 | 2020-07-02 | 113, 116 |  |  | 2020-07-02 | 2020-07-02 | 0d | 2020-07-17 | 2020-07-17 | 823d | 0d | Verde | Verde | 0% | 0% | Compensatória | Verde | 0% | 0% |  | Município |  |  |  |  |  |
| 118 | 3.1.3.2.2.3 | Pleito AIMESCT02 - Aquisição de terreno de Aimorés concluído | milestone | 0d | 2020-07-02 | 2020-07-02 | 117 |  |  | 2020-07-02 | 2020-07-02 | 0d | 2020-07-17 | 2020-07-17 | 828d | 616d | Verde | Verde | 0% | 0% | Compensatória | Verde | 0% | 0% |  | Município |  |  |  |  |  |

Notes:
- 102: 24/05/2019: município pactuou com a Renova 3 meses para elaborar projeto executivo
- 109: Em 12/04/19: o pleito foi aprovado na CT (NT36) e pode ser aprovado no próximo CIF (26/04) / Em 26/04/19: pleito aprovado no CIF dia 23/04/2019 na deliberação 276.

| ID | WBS | Task | Type | Duration | Start | Finish | Predecessors | Complete | Remaining | Baseline start | Baseline finish | Baseline duration | Baseline 1 start | Baseline 1 finish | Total slack | Free slack | Text1 | Text2 | Text3 | Text6 | Text8 | Text12 | Text14 | Text16 | Text9 | Text18 |
| --- | --- | --- | --- | --- | --- | --- | --- | --- | --- | --- | --- | --- | --- | --- | --- | --- | --- | --- | --- | --- | --- | --- | --- | --- | --- | --- |
| 119 | 3.1.3.2.3 | **Pleito de Aimorés a definir - Implantação de SES na sede do município (R$ 9.326.685,45)** |  | 639d | 2020-05-29 | 2022-12-22 |  |  |  | 2020-05-29 | 2022-12-22 | 639d | 2020-05-29 | 2023-01-09 | 212d |  | Verde | Verde | 0% | 0% | Compensatória | Verde | 0% | 0% |  |  |
| 120 | 3.1.3.2.3.1 | Pleito de Aimorés a definir - Implantação de SES na sede do município (R$ 9.326.685,45) a definir aprovado | milestone | 0d | 2020-05-29 | 2020-05-29 | 3052FS+362d |  |  | 2020-05-29 | 2020-05-29 | 0d | 2020-05-29 | 2020-05-29 | 212d | 0d | Verde | Verde | 0% | 0% | Compensatória | Verde | 0% | 0% | CT/CIF |  |
| 121 | 3.1.3.2.3.2 | **Licitação da obra** |  | 82d | 2020-06-15 | 2020-10-08 |  |  |  | 2020-06-15 | 2020-10-08 | 82d | 2020-06-15 | 2020-10-08 | 212d |  | Verde | Verde | 0% | 0% | Compensatória | Verde | 0% | 0% |  |  |
| 122 | 3.1.3.2.3.2.1 | Licitação da obra do Pleito de Aimorés a definir - Implantação de SES na sede do município (R$ 9.326.685,45) autorizada pelo banco | milestone | 0d | 2020-06-15 | 2020-06-15 | 120FS+10d |  |  | 2020-06-15 | 2020-06-15 | 0d | 2020-06-15 | 2020-06-15 | 212d | 0d | Verde | Verde | 0% | 0% | Compensatória | Verde | 0% | 0% | Banco |  |
| 123 | 3.1.3.2.3.2.2 | Licitar obra |  | 67d | 2020-06-16 | 2020-09-17 | 122 |  |  | 2020-06-16 | 2020-09-17 | 67d | 2020-06-16 | 2020-09-17 | 212d | 0d | Verde | Verde | 0% | 0% | Compensatória | Verde | 0% | 0% | Município |  |
| 124 | 3.1.3.2.3.2.3 | Analisar e emitir resultado da licitação da obra |  | 15d | 2020-09-18 | 2020-10-08 | 123 |  |  | 2020-09-18 | 2020-10-08 | 15d | 2020-09-18 | 2020-10-08 | 212d | 0d | Verde | Verde | 0% | 0% | Compensatória | Verde | 0% | 0% | Banco |  |
| 125 | 3.1.3.2.3.2.4 | Licitação da obra do Pleito de Aimorés a definir - Implantação de SES na sede do município (R$ 9.326.685,45) concluída | milestone | 0d | 2020-10-08 | 2020-10-08 | 124 |  |  | 2020-10-08 | 2020-10-08 | 0d | 2020-10-08 | 2020-10-08 | 212d | 0d | Verde | Verde | 0% | 0% | Compensatória | Verde | 0% | 0% | Município |  |
| 126 | 3.1.3.2.3.3 | Executar obra |  | 400d | 2020-11-12 | 2022-06-22 | 125FS+22d |  |  | 2020-11-12 | 2022-06-22 | 400d | 2020-11-12 | 2022-06-22 | 212d | 0d | Verde | Verde | 0% | 0% | Compensatória | Verde | 0% | 0% | Município |  |
| 127 | 3.1.3.2.3.4 | Realizar processo de pré-operação |  | 120d | 2022-06-23 | 2022-12-15 | 126 |  |  | 2022-06-23 | 2022-12-15 | 120d | 2022-06-23 | 2023-01-02 | 212d | 0d | Verde | Verde | 0% | 0% | Compensatória | Verde | 0% | 0% | Município |  |
| 128 | 3.1.3.2.3.5 | Recurso da obra do Pleito de Aimorés a definir - Implantação de SES na sede do município (R$ 9.326.685,45) a definir repassado | milestone | 0d | 2022-12-22 | 2022-12-22 | 127FS+5d |  |  | 2022-12-22 | 2022-12-22 | 0d | 2023-01-09 | 2023-01-09 | 212d | 0d | Verde | Verde | 0% | 0% | Compensatória | Verde | 0% | 0% | Banco |  |
| 129 | 3.1.3.2.3.6 | Pleito de Aimorés a definir - Implantação de SES na sede do município (R$ 9.326.685,45) a definir concluído | milestone | 0d | 2022-12-22 | 2022-12-22 | 128 |  |  | 2022-12-22 | 2022-12-22 | 0d | 2023-01-09 | 2023-01-09 | 212d | 0d | Verde | Verde | 0% | 0% | Compensatória | Verde | 0% | 0% | Município |  |
| 130 | 3.1.3.2.4 | **Pleito AIMRSOB03 - Adequação do atual Aterro Sanitário, conforme projeto existente** |  | 383d | 2019-06-25 A | 2021-01-07 |  |  | 383d | 2019-06-25 | 2021-01-06 | 382d | 2019-08-30 | 2023-03-21 | 699d |  | Verde | Verde | 0% | 0% | Compensatória | Verde | 0% | 0% |  |  |
| 131 | 3.1.3.2.4.1 | Pleito AIMRSOB03 - Adequação do atual Aterro Sanitário, conforme projeto existente aprovado | milestone | 0d | 2019-06-25 A | 2019-06-25 A | 3052FS+131d | 100% |  | 2019-06-25 | 2019-06-25 | 0d | 2019-08-30 | 2019-08-30 |  |  | Verde | Verde | 0% | 0% | Compensatória | Verde | 0% | 0% | CT/CIF |  |
| 132 | 3.1.3.2.4.2 | Iniciar tarefas do Pleito AIMRSOB03 - Adequação do atual Aterro Sanitário, conforme projeto existente |  | 1d | 2019-07-10 | 2019-07-10 | 131FS+10d |  |  | 2019-06-26 | 2019-06-26 | 1d | 2019-09-02 | 2019-09-02 | 699d | 0d | Verde | Verde | 0% | 0% | Compensatória | Verde | 0% | 0% | Município | Critério FR |
| 133 | 3.1.3.2.4.3 | **Aprovação do Projeto** |  | 72d | 2019-07-10 | 2019-10-21 |  |  |  | 2019-07-09 | 2019-10-18 | 72d |  |  | 699d |  | Verde | Verde | 0% | 0% | Compensatória | Verde | 0% | 0% |  |  |
| 134 | 3.1.3.2.4.3.1 | Apresentação do projeto do Pleito AIMRSOB03 - Adequação do atual Aterro Sanitário, conforme projeto existente solicitada pelo banco | milestone | 0d | 2019-07-10 | 2019-07-10 | 131FS+10d, 132 |  |  | 2019-07-09 | 2019-07-09 | 0d |  |  | 699d | 0d | Verde | Verde | 0% | 0% | Compensatória | Verde | 0% | 0% |  |  |
| 135 | 3.1.3.2.4.3.2 | Projeto do Pleito AIMRSOB03 - Adequação do atual Aterro Sanitário, conforme projeto existente apresentado ao banco | milestone | 0d | 2019-07-15 | 2019-07-15 | 134FS+3d |  |  | 2019-07-12 | 2019-07-12 | 0d |  |  | 699d | 0d | Verde | Verde | 0% | 0% | Compensatória | Verde | 0% | 0% |  |  |
| 136 | 3.1.3.2.4.3.3 | Analisar projeto |  | 69d | 2019-07-16 | 2019-10-21 | 135 |  |  | 2019-07-16 | 2019-10-21 | 69d |  |  | 699d | 0d | Verde | Verde | 0% | 0% | Compensatória | Verde | 0% | 0% |  | Critério FR |
| 137 | 3.1.3.2.4.3.4 | Projeto do Pleito AIMRSOB03 - Adequação do atual Aterro Sanitário, conforme projeto existente aprovado | milestone | 0d | 2019-10-21 | 2019-10-21 | 136 |  |  | 2019-10-18 | 2019-10-18 | 0d |  |  | 699d | 0d | Verde | Verde | 0% | 0% | Compensatória | Verde | 0% | 0% |  |  |
| 138 | 3.1.3.2.4.4 | **Licitar Obra** |  | 75d | 2019-10-21 | 2020-02-10 |  |  |  | 2019-10-18 | 2020-02-07 | 75d |  |  | 699d |  | Verde | Verde | 0% | 0% | Compensatória | Verde | 0% | 0% |  |  |
| 139 | 3.1.3.2.4.4.1 | Licitação da obra do Pleito AIMRSOB03 - Adequação do atual Aterro Sanitário, conforme projeto existente autorizada pelo banco | milestone | 0d | 2019-10-21 | 2019-10-21 | 137 |  |  | 2019-10-18 | 2019-10-18 | 0d |  |  | 699d | 0d | Verde | Verde | 0% | 0% | Compensatória | Verde | 0% | 0% |  |  |
| 140 | 3.1.3.2.4.4.2 | Licitar Obra |  | 60d | 2019-10-22 | 2020-01-20 | 139 |  |  | 2019-10-21 | 2020-01-17 | 60d |  |  | 699d | 0d | Verde | Verde | 0% | 0% | Compensatória | Verde | 0% | 0% |  |  |
| 141 | 3.1.3.2.4.4.3 | Analisar licitação da obra |  | 15d | 2020-01-21 | 2020-02-10 | 140 |  |  | 2020-01-20 | 2020-02-07 | 15d |  |  | 699d | 0d | Verde | Verde | 0% | 0% | Compensatória | Verde | 0% | 0% |  |  |
| 142 | 3.1.3.2.4.4.4 | Licitação da obra do Pleito AIMRSOB03 - Adequação do atual Aterro Sanitário, conforme projeto existente concluída | milestone | 0d | 2020-02-10 | 2020-02-10 | 141 |  |  | 2020-02-07 | 2020-02-07 | 0d |  |  | 699d | 0d | Verde | Verde | 0% | 0% | Compensatória | Verde | 0% | 0% |  |  |
| 143 | 3.1.3.2.4.5 | Executar obra |  | 80d | 2020-03-13 | 2020-07-08 | 142FS+20d |  |  | 2020-03-12 | 2020-07-07 | 80d |  |  | 699d | 0d | Verde | Verde | 0% | 0% | Compensatória | Verde | 0% | 0% |  |  |
| 144 | 3.1.3.2.4.6 | Realizar processo de pré-operação |  | 120d | 2020-07-09 | 2020-12-30 | 143 |  |  | 2020-07-08 | 2020-12-29 | 120d |  |  | 699d | 0d | Verde | Verde | 0% | 0% | Compensatória | Verde | 0% | 0% |  |  |
| 145 | 3.1.3.2.4.7 | Recurso da obra do Pleito AIMRSOB03 - Adequação do atual Aterro Sanitário, conforme projeto existente repassado | milestone | 0d | 2021-01-07 | 2021-01-07 | 144FS+5d |  |  | 2021-01-06 | 2021-01-06 | 0d |  |  | 699d | 0d | Verde | Verde | 0% | 0% | Compensatória | Verde | 0% | 0% |  |  |
| 146 | 3.1.3.2.4.8 | Pleito AIMRSOB03 - Adequação do atual Aterro Sanitário, conforme projeto existente concluído | milestone | 0d | 2021-01-07 | 2021-01-07 | 145 |  |  | 2021-01-06 | 2021-01-06 | 0d | 2023-03-21 | 2023-03-21 | 699d | 487d | Verde | Verde | 0% | 0% | Compensatória | Verde | 0% | 0% | Município |  |

Notes:
- 120: Em 12/04/19: Usando o cronograma da NT 33 o pleito será analisado e aprovado pelo CT/CIF até o dia 31/05/2020
- 131: 24/04/2019: considerado que pleito será elaborado até julho e aprovado no CT/CIF de agosto 2019 / 01/07/2019: pleito foi aprovado pelo CIF no dia 25/06/2019 conforme Deliberação 297
- 132: 02/07/2019: alterado o início da tarefa conforme primeira tarefa do pleito que é a solicitação do projeto pelo banco.

| ID | WBS | Task | Type | Duration | Start | Finish | Predecessors | Complete | Remaining | Baseline start | Baseline finish | Baseline duration | Total slack | Free slack | Text1 | Text2 | Text3 | Text6 | Text8 | Text12 | Text14 | Text16 | Text18 |
| --- | --- | --- | --- | --- | --- | --- | --- | --- | --- | --- | --- | --- | --- | --- | --- | --- | --- | --- | --- | --- | --- | --- | --- |
| 147 | 3.1.3.2.5 | **Pleito AIMRSPM01 - Elaboração de estudo ambiental para licenciamento do atual Aterro Sanitário** |  | 179d | 2019-06-25 A | 2020-03-13 |  |  | 179d | 2019-06-25 | 2020-03-13 | 179d | 903d |  |  |  |  |  |  |  |  |  |  |
| 148 | 3.1.3.2.5.1 | Pleito AIMRSPM01 - Elaboração de estudo ambiental para licenciamento do atual Aterro Sanitário de Aimorés aprovado | milestone | 0d | 2019-06-25 A | 2019-06-25 A | 3052FS+131d | 100% |  | 2019-06-25 | 2019-06-25 | 0d |  |  |  |  |  |  |  |  |  |  |  |
| 149 | 3.1.3.2.5.2 | Analisar a necessidade do Pleito AIMRSPM01 - Elaboração de estudo ambiental para licenciamento do atual Aterro Sanitário |  | 1d | 2020-03-13 | 2020-03-13 | 143SS, 148 |  |  | 2020-03-13 | 2020-03-13 | 1d | 903d | 0d |  |  |  |  |  |  |  |  |  |
| 150 | 3.1.3.2.5.3 | Pleito AIMRSPM01 - Elaboração de estudo ambiental para licenciamento do atual Aterro Sanitário concluído | milestone | 0d | 2020-03-13 | 2020-03-13 | 149 |  |  | 2020-03-13 | 2020-03-13 | 0d | 903d | 691d |  |  |  |  |  |  |  |  |  |
| 151 | 3.1.3.2.6 | **Pleito AIMRSOB04 - Melhorias e reformas na Usina de Triagem e Compostagem (UTC)** |  | 382d | 2019-06-25 A | 2021-01-06 |  |  | 382d | 2019-06-25 | 2021-01-06 | 382d | 700d |  |  |  |  |  |  |  |  |  |  |
| 152 | 3.1.3.2.6.1 | Pleito AIMRSOB04 - Melhorias e reformas na Usina de Triagem e Compostagem (UTC) aprovado | milestone | 0d | 2019-06-25 A | 2019-06-25 A | 3052FS+131d | 100% |  | 2019-06-25 | 2019-06-25 | 0d |  |  |  |  |  |  |  |  |  |  |  |
| 153 | 3.1.3.2.6.2 | **Aprovação do Projeto** |  | 72d | 2019-07-09 | 2019-10-18 |  |  |  | 2019-07-09 | 2019-10-18 | 72d | 613d |  |  |  |  |  |  |  |  |  |  |
| 154 | 3.1.3.2.6.2.1 | Apresentação do projeto do Pleito AIMRSOB04 - Melhorias e reformas na Usina de Triagem e Compostagem (UTC) solicitada pelo banco | milestone | 0d | 2019-07-09 | 2019-07-09 | 152FS+10d |  |  | 2019-07-09 | 2019-07-09 | 0d | 613d | 0d |  |  |  |  |  |  |  |  |  |
| 155 | 3.1.3.2.6.2.2 | Projeto do Pleito AIMRSOB04 - Melhorias e reformas na Usina de Triagem e Compostagem (UTC) apresentado ao banco | milestone | 0d | 2019-07-12 | 2019-07-12 | 154FS+3d |  |  | 2019-07-12 | 2019-07-12 | 0d | 613d | 0d |  |  |  |  |  |  |  |  |  |
| 156 | 3.1.3.2.6.2.3 | Analisar projeto de melhorias e reformas na Usina de Triagem e Compostagem (UTC) |  | 69d | 2019-07-15 | 2019-10-18 | 155 |  |  | 2019-07-15 | 2019-10-18 | 69d | 613d | 0d |  |  |  |  |  |  |  |  |  |
| 157 | 3.1.3.2.6.2.4 | Projeto do Pleito AIMRSOB04 - Melhorias e reformas na Usina de Triagem e Compostagem (UTC) aprovado | milestone | 0d | 2019-10-18 | 2019-10-18 | 156 |  |  | 2019-10-18 | 2019-10-18 | 0d | 613d | 0d |  |  |  |  |  |  |  |  |  |
| 158 | 3.1.3.2.6.3 | **Licitar Obra** |  | 75d | 2019-10-18 | 2020-02-07 |  |  |  | 2019-10-18 | 2020-02-07 | 75d | 613d |  |  |  |  |  |  |  |  |  |  |
| 159 | 3.1.3.2.6.3.1 | Licitação da obra do Pleito AIMRSOB04 - Melhorias e reformas na Usina de Triagem e Compostagem (UTC) autorizada pelo banco | milestone | 0d | 2019-10-18 | 2019-10-18 | 157 |  |  | 2019-10-18 | 2019-10-18 | 0d | 613d | 0d |  |  |  |  |  |  |  |  |  |
| 160 | 3.1.3.2.6.3.2 | Licitar Obra |  | 60d | 2019-10-21 | 2020-01-17 | 159 |  |  | 2019-10-21 | 2020-01-17 | 60d | 613d | 0d |  |  |  |  |  |  |  |  |  |
| 161 | 3.1.3.2.6.3.3 | Analisar licitação da obra |  | 15d | 2020-01-20 | 2020-02-07 | 160 |  |  | 2020-01-20 | 2020-02-07 | 15d | 613d | 0d |  |  |  |  |  |  |  |  |  |
| 162 | 3.1.3.2.6.3.4 | Licitação da obra do Pleito AIMRSOB04 - Melhorias e reformas na Usina de Triagem e Compostagem (UTC) concluída | milestone | 0d | 2020-02-07 | 2020-02-07 | 161 |  |  | 2020-02-07 | 2020-02-07 | 0d | 613d | 0d |  |  |  |  |  |  |  |  |  |
| 163 | 3.1.3.2.6.4 | Executar obra |  | 80d | 2020-03-12 | 2020-07-07 | 162FS+20d |  |  | 2020-03-12 | 2020-07-07 | 80d | 613d | 0d |  |  |  |  |  |  |  |  |  |
| 164 | 3.1.3.2.6.5 | Realizar processo de pré-operação |  | 120d | 2020-07-08 | 2020-12-29 | 163 |  |  | 2020-07-08 | 2020-12-29 | 120d | 700d | 0d |  |  |  |  |  |  |  |  |  |
| 165 | 3.1.3.2.6.6 | Recurso da obra do Pleito AIMRSOB04 - Melhorias e reformas na Usina de Triagem e Compostagem (UTC) repassado | milestone | 0d | 2021-01-06 | 2021-01-06 | 164FS+5d |  |  | 2021-01-06 | 2021-01-06 | 0d | 700d | 0d |  |  |  |  |  |  |  |  |  |
| 166 | 3.1.3.2.6.7 | Pleito AIMRSOB04 - Melhorias e reformas na Usina de Triagem e Compostagem (UTC) concluído | milestone | 0d | 2021-01-06 | 2021-01-06 | 165 |  |  | 2021-01-06 | 2021-01-06 | 0d | 700d | 488d |  |  |  |  |  |  |  |  |  |
| 167 | 3.1.3.2.7 | **Pleito AIMRSPJ01 - Elaboração de projeto de ampliação do aterro sanitário** |  | 332d | 2019-06-25 A | 2020-10-22 |  |  | 332d | 2019-06-25 | 2020-10-22 | 332d | 750d |  | Verde | Verde | 0% | 0% | Compensatória | Verde | 0% | 0% |  |
| 168 | 3.1.3.2.7.1 | Pleito AIMRSPJ01 - Elaboração de projeto de ampliação do aterro sanitário aprovado | milestone | 0d | 2019-06-25 A | 2019-06-25 A | 3052FS+131d | 100% |  | 2019-06-25 | 2019-06-25 | 0d |  |  | Verde | Verde | 0% | 0% | Compensatória | Verde | 0% | 0% |  |
| 169 | 3.1.3.2.7.2 | **Licitação do projeto** |  | 137d | 2019-07-09 | 2020-01-24 |  |  |  | 2019-07-09 | 2020-01-24 | 137d | 576d |  | Verde | Verde | 0% | 0% | Compensatória | Verde | 0% | 0% |  |
| 170 | 3.1.3.2.7.2.1 | Licitação do projeto do Pleito AIMRSPJ01 - Elaboração de projeto de ampliação do aterro sanitário autorizada pelo banco | milestone | 0d | 2019-07-09 | 2019-07-09 | 168FS+10d |  |  | 2019-07-09 | 2019-07-09 | 0d | 576d | 0d | Verde | Verde | 0% | 0% | Compensatória | Verde | 0% | 0% |  |
| 171 | 3.1.3.2.7.2.2 | Licitar projeto |  | 60d | 2019-10-01 | 2019-12-27 | 170FS+58d |  |  | 2019-10-01 | 2019-12-27 | 60d | 576d | 0d | Verde | Verde | 0% | 0% | Compensatória | Verde | 0% | 0% | Critério FR |
| 172 | 3.1.3.2.7.2.3 | Documentação de licitação do Pleito AIMRSPJ01 - Elaboração de projeto de ampliação do aterro sanitário apresentada ao banco | milestone | 0d | 2020-01-06 | 2020-01-06 | 171FS+5d |  |  | 2020-01-06 | 2020-01-06 | 0d | 576d | 0d | Verde | Verde | 0% | 0% | Compensatória | Verde | 0% | 0% |  |
| 173 | 3.1.3.2.7.2.4 | Analisar e emitir resultado da licitação do projeto |  | 14d | 2020-01-07 | 2020-01-24 | 172 |  |  | 2020-01-07 | 2020-01-24 | 14d | 576d | 0d | Verde | Verde | 0% | 0% | Compensatória | Verde | 0% | 0% |  |
| 174 | 3.1.3.2.7.2.5 | Licitação do projeto do Pleito AIMRSPJ01 - Elaboração de projeto de ampliação do aterro sanitário concluída | milestone | 0d | 2020-01-24 | 2020-01-24 | 173 |  |  | 2020-01-24 | 2020-01-24 | 0d | 576d | 0d | Verde | Verde | 0% | 0% | Compensatória | Verde | 0% | 0% |  |

Notes:
- 149: 03/07/2019: na reunião da 2a rodada dos municípios o ponto focal informou que o licenciamento venceu em fevereiro. / Fernando vai verificar com a consultora se será necessário esse pleito mesmo e Fernanda do Apoio Técnico entendeu que será cancelado depois.
- 168: 01/07/2019: pleito foi aprovado pelo CIF no dia 25/06/2019 conforme Deliberação 297

| ID | WBS | Task | Type | Duration | Start | Finish | Predecessors | Complete | Remaining | Baseline start | Baseline finish | Baseline duration | Total slack | Free slack | Text1 | Text2 | Text3 | Text6 | Text8 | Text12 | Text14 | Text16 |
| --- | --- | --- | --- | --- | --- | --- | --- | --- | --- | --- | --- | --- | --- | --- | --- | --- | --- | --- | --- | --- | --- | --- |
| 175 | 3.1.3.2.7.3 | **Elaboração do Estudo de Concepção** |  | 105d | 2020-01-27 | 2020-06-30 |  |  |  | 2020-01-27 | 2020-06-30 | 105d | 576d |  | Verde | Verde | 0% | 0% | Compensatória | Verde | 0% | 0% |
| 176 | 3.1.3.2.7.3.1 | Elaborar estudo |  | 40d | 2020-01-27 | 2020-03-25 | 174 |  |  | 2020-01-27 | 2020-03-25 | 40d | 576d | 0d | Verde | Verde | 0% | 0% | Compensatória | Verde | 0% | 0% |
| 177 | 3.1.3.2.7.3.2 | Estudo de concepção do Pleito AIMRSPJ01 - Elaboração de projeto de ampliação do aterro sanitário apresentado ao banco | milestone | 0d | 2020-03-25 | 2020-03-25 | 176 |  |  | 2020-03-25 | 2020-03-25 | 0d | 576d | 0d | Verde | Verde | 0% | 0% | Compensatória | Verde | 0% | 0% |
| 178 | 3.1.3.2.7.3.3 | Analisar estudo |  | 60d | 2020-03-26 | 2020-06-23 | 177 |  |  | 2020-03-26 | 2020-06-23 | 60d | 576d | 0d | Verde | Verde | 0% | 0% | Compensatória | Verde | 0% | 0% |
| 179 | 3.1.3.2.7.3.4 | Estudo de concepção do Pleito AIMRSPJ01 - Elaboração de projeto de ampliação do aterro sanitário aprovado | milestone | 0d | 2020-06-23 | 2020-06-23 | 178 |  |  | 2020-06-23 | 2020-06-23 | 0d | 820d | 0d | Verde | Verde | 0% | 0% | Compensatória | Verde | 0% | 0% |
| 180 | 3.1.3.2.7.3.5 | Recurso do estudo de concepção do Pleito AIMRSPJ01 - Elaboração de projeto de ampliação do aterro sanitário repassado | milestone | 0d | 2020-06-30 | 2020-06-30 | 179FS+5d |  |  | 2020-06-30 | 2020-06-30 | 0d | 820d | 35d | Verde | Verde | 0% | 0% | Compensatória | Verde | 0% | 0% |
| 181 | 3.1.3.2.7.4 | **Elaboração do Projeto Básico** |  | 105d | 2020-03-26 | 2020-08-25 |  |  |  | 2020-03-26 | 2020-08-25 | 105d | 750d |  | Verde | Verde | 0% | 0% | Compensatória | Verde | 0% | 0% |
| 182 | 3.1.3.2.7.4.1 | Elaborar Projeto Básico |  | 40d | 2020-03-26 | 2020-05-25 | 176 |  |  | 2020-03-26 | 2020-05-25 | 40d | 750d | 0d | Verde | Verde | 0% | 0% | Compensatória | Verde | 0% | 0% |
| 183 | 3.1.3.2.7.4.2 | Projeto básico do Pleito AIMRSPJ01 - Elaboração de projeto de ampliação do aterro sanitário apresentado ao banco | milestone | 0d | 2020-05-25 | 2020-05-25 | 182 |  |  | 2020-05-25 | 2020-05-25 | 0d | 785d | 0d | Verde | Verde | 0% | 0% | Compensatória | Verde | 0% | 0% |
| 184 | 3.1.3.2.7.4.3 | Analisar Projeto Básico |  | 60d | 2020-05-26 | 2020-08-18 | 183 |  |  | 2020-05-26 | 2020-08-18 | 60d | 785d | 0d | Verde | Verde | 0% | 0% | Compensatória | Verde | 0% | 0% |
| 185 | 3.1.3.2.7.4.4 | Projeto básico do Pleito AIMRSPJ01 - Elaboração de projeto de ampliação do aterro sanitário aprovado | milestone | 0d | 2020-08-18 | 2020-08-18 | 180, 184 |  |  | 2020-08-18 | 2020-08-18 | 0d | 785d | 0d | Verde | Verde | 0% | 0% | Compensatória | Verde | 0% | 0% |
| 186 | 3.1.3.2.7.4.5 | Recurso do projeto básico do Pleito AIMRSPJ01 - Elaboração de projeto de ampliação do aterro sanitário repassado | milestone | 0d | 2020-08-25 | 2020-08-25 | 185FS+5d |  |  | 2020-08-25 | 2020-08-25 | 0d | 785d | 35d | Verde | Verde | 0% | 0% | Compensatória | Verde | 0% | 0% |
| 187 | 3.1.3.2.7.5 | Realizar Licenciamento Ambiental |  | 120d | 2020-04-27 | 2020-10-15 | 178FS-40d |  |  | 2020-04-27 | 2020-10-15 | 120d | 576d | 0d | Verde | Verde | 0% | 0% | Compensatória | Verde | 0% | 0% |
| 188 | 3.1.3.2.7.6 | **Elaboração do Projeto Executivo** |  | 105d | 2020-05-26 | 2020-10-22 |  |  |  | 2020-05-26 | 2020-10-22 | 105d | 750d |  | Verde | Verde | 0% | 0% | Compensatória | Verde | 0% | 0% |
| 189 | 3.1.3.2.7.6.1 | Elaborar Projeto Executivo |  | 40d | 2020-05-26 | 2020-07-21 | 182 |  |  | 2020-05-26 | 2020-07-21 | 40d | 750d | 0d | Verde | Verde | 0% | 0% | Compensatória | Verde | 0% | 0% |
| 190 | 3.1.3.2.7.6.2 | Projeto Executivo do Pleito AIMRSPJ01 - Elaboração de projeto de ampliação do aterro sanitário apresentado ao banco | milestone | 0d | 2020-07-21 | 2020-07-21 | 189 |  |  | 2020-07-21 | 2020-07-21 | 0d | 750d | 0d | Verde | Verde | 0% | 0% | Compensatória | Verde | 0% | 0% |
| 191 | 3.1.3.2.7.6.3 | Analisar Projeto Executivo |  | 60d | 2020-07-22 | 2020-10-15 | 190 |  |  | 2020-07-22 | 2020-10-15 | 60d | 750d | 0d | Verde | Verde | 0% | 0% | Compensatória | Verde | 0% | 0% |
| 192 | 3.1.3.2.7.6.4 | Projeto Executivo do Pleito AIMRSPJ01 - Elaboração de projeto de ampliação do aterro sanitário aprovado | milestone | 0d | 2020-10-15 | 2020-10-15 | 186, 187, 191 |  |  | 2020-10-15 | 2020-10-15 | 0d | 750d | 0d | Verde | Verde | 0% | 0% | Compensatória | Verde | 0% | 0% |
| 193 | 3.1.3.2.7.6.5 | Recurso do projeto executivo do Pleito AIMRSPJ01 - Elaboração de projeto de ampliação do aterro sanitário repassado | milestone | 0d | 2020-10-22 | 2020-10-22 | 192FS+5d |  |  | 2020-10-22 | 2020-10-22 | 0d | 750d | 0d | Verde | Verde | 0% | 0% | Compensatória | Verde | 0% | 0% |
| 194 | 3.1.3.2.7.7 | Pleito AIMRSPJ01 - Elaboração de projeto de ampliação do aterro sanitário de Aimorés concluído | milestone | 0d | 2020-10-22 | 2020-10-22 | 193 |  |  | 2020-10-22 | 2020-10-22 | 0d | 750d | 538d | Verde | Verde | 0% | 0% | Compensatória | Verde | 0% | 0% |
| 195 | 3.1.3.2.8 | **Pleito AIMRSPM02 - Elaboração de estudo ambiental para licenciamento da ampliação do aterro sanitário** |  | 332d | 2019-06-25 A | 2020-10-22 |  |  | 332d | 2019-06-25 | 2020-10-22 | 332d | 750d |  |  |  |  |  |  |  |  |  |
| 196 | 3.1.3.2.8.1 | Pleito AIMRSPM02 - Elaboração de estudo ambiental para licenciamento da ampliação do aterro sanitário aprovado | milestone | 0d | 2019-06-25 A | 2019-06-25 A | 3052FS+131d | 100% |  | 2019-06-25 | 2019-06-25 | 0d |  |  |  |  |  |  |  |  |  |  |
| 197 | 3.1.3.2.8.2 | **Licitação de Empresa para Licenciamento Ambiental** |  | 54d | 2020-02-04 | 2020-04-24 |  |  |  | 2020-02-04 | 2020-04-24 | 54d | 750d |  |  |  |  |  |  |  |  |  |
| 198 | 3.1.3.2.8.2.1 | Licitação da empresa para Licenciamento Ambiental do Pleito AIMRSPM02 - Elaboração de estudo ambiental para licenciamento da ampliação do aterro sanitário autorizada pelo banco | milestone | 0d | 2020-02-04 | 2020-02-04 | 196, 187SS-54d |  |  | 2020-02-04 | 2020-02-04 | 0d | 750d | 0d |  |  |  |  |  |  |  |  |
| 199 | 3.1.3.2.8.2.2 | Licitar empresa para Licenciamento Ambiental |  | 40d | 2020-02-04 | 2020-04-02 | 198 |  |  | 2020-02-04 | 2020-04-02 | 40d | 750d | 0d |  |  |  |  |  |  |  |  |
| 200 | 3.1.3.2.8.2.3 | Documentação de licitação da empresa para Licenciamento Ambiental do Pleito AIMRSPM02 - Elaboração de estudo ambiental para licenciamento da ampliação do aterro sanitário apresentada ao banco | milestone | 0d | 2020-04-02 | 2020-04-02 | 199 |  |  | 2020-04-02 | 2020-04-02 | 0d | 750d | 0d |  |  |  |  |  |  |  |  |
| 201 | 3.1.3.2.8.2.4 | Analisar e emitir resultado da licitação do empresa para Licenciamento Ambiental |  | 14d | 2020-04-03 | 2020-04-24 | 200 |  |  | 2020-04-03 | 2020-04-24 | 14d | 750d | 0d |  |  |  |  |  |  |  |  |
| 202 | 3.1.3.2.8.2.5 | Licitação da empresa para Licenciamento Ambiental do Pleito AIMRSPM02 - Elaboração de estudo ambiental para licenciamento da ampliação do aterro sanitário concluída | milestone | 0d | 2020-04-24 | 2020-04-24 | 201 |  |  | 2020-04-24 | 2020-04-24 | 0d | 750d | 0d |  |  |  |  |  |  |  |  |
| 203 | 3.1.3.2.8.3 | Executar o Licenciamento Ambiental |  | 120d | 2020-04-27 | 2020-10-15 | 202 |  |  | 2020-04-27 | 2020-10-15 | 120d | 750d | 0d |  |  |  |  |  |  |  |  |
| 204 | 3.1.3.2.8.4 | Recurso do serviço de Aimorés do Pleito AIMRSPM02 - Elaboração de estudo ambiental para licenciamento da ampliação do aterro sanitário repassado | milestone | 0d | 2020-10-22 | 2020-10-22 | 203FS+5d |  |  | 2020-10-22 | 2020-10-22 | 0d | 750d | 0d |  |  |  |  |  |  |  |  |
| 205 | 3.1.3.2.8.5 | Pleito AIMRSPM02 - Elaboração de estudo ambiental para licenciamento da ampliação do aterro sanitário de Aimorés concluído | milestone | 0d | 2020-10-22 | 2020-10-22 | 204 |  |  | 2020-10-22 | 2020-10-22 | 0d | 750d | 538d |  |  |  |  |  |  |  |  |

| ID | WBS | Task | Type | Duration | Start | Finish | Predecessors | Complete | Remaining | Baseline start | Baseline finish | Baseline duration | Baseline 1 start | Baseline 1 finish | Total slack | Free slack | Text1 | Text2 | Text3 | Text6 | Text8 | Text9 | Text12 | Text14 | Text16 | Text4 | Text5 | Text7 | Text15 | Text17 | Text18 |
| --- | --- | --- | --- | --- | --- | --- | --- | --- | --- | --- | --- | --- | --- | --- | --- | --- | --- | --- | --- | --- | --- | --- | --- | --- | --- | --- | --- | --- | --- | --- | --- |
| 206 | 3.1.3.2.9 | **Pleito AIMRSPM03 - Elaboração de estudo de viabilidade de gestão regional dos resíduos sólidos urbanos** |  | 469d | 2019-06-25 A | 2021-05-14 |  |  | 469d | 2019-06-25 | 2021-05-14 | 469d |  |  | 613d |  |  |  |  |  |  |  |  |  |  |  |  |  |  |  |  |
| 207 | 3.1.3.2.9.1 | Pleito AIMRSPM03 - Elaboração de estudo de viabilidade de gestão regional dos resíduos sólidos urbanos de Aimorés aprovado | milestone | 0d | 2019-06-25 A | 2019-06-25 A | 3052FS+131d | 100% |  | 2019-06-25 | 2019-06-25 | 0d |  |  |  |  |  |  |  |  |  |  |  |  |  |  |  |  |  |  |  |
| 208 | 3.1.3.2.9.2 | **Licitação de Empresa para Estudo de Viabilidade** |  | 59d | 2020-07-07 | 2020-09-29 |  |  |  | 2020-07-07 | 2020-09-29 | 59d |  |  | 613d |  |  |  |  |  |  |  |  |  |  |  |  |  |  |  |  |
| 209 | 3.1.3.2.9.2.1 | Licitação da empresa para Estudo de Viabilidade do Pleito AIMRSPM03 - Elaboração de estudo de viabilidade de gestão regional dos resíduos sólidos urbanos autorizada pelo banco | milestone | 0d | 2020-07-07 | 2020-07-07 | 163, 207 |  |  | 2020-07-07 | 2020-07-07 | 0d |  |  | 613d | 0d |  |  |  |  |  |  |  |  |  |  |  |  |  |  |  |
| 210 | 3.1.3.2.9.2.2 | Licitar empresa para Estudo de Viabilidade |  | 40d | 2020-07-08 | 2020-09-01 | 209 |  |  | 2020-07-08 | 2020-09-01 | 40d |  |  | 613d | 0d |  |  |  |  |  |  |  |  |  |  |  |  |  |  |  |
| 211 | 3.1.3.2.9.2.3 | Documentação de licitação do Pleito AIMRSPM03 - Elaboração de estudo de viabilidade de gestão regional dos resíduos sólidos urbanos apresentada ao banco | milestone | 0d | 2020-09-09 | 2020-09-09 | 210FS+5d |  |  | 2020-09-09 | 2020-09-09 | 0d |  |  | 613d | 0d |  |  |  |  |  |  |  |  |  |  |  |  |  |  |  |
| 212 | 3.1.3.2.9.2.4 | Analisar e emitir resultado da licitação da empresa para Estudo de Viabilidade |  | 14d | 2020-09-10 | 2020-09-29 | 211 |  |  | 2020-09-10 | 2020-09-29 | 14d |  |  | 613d | 0d |  |  |  |  |  |  |  |  |  |  |  |  |  |  |  |
| 213 | 3.1.3.2.9.2.5 | Licitação da empresa para Estudo de Viabilidade do Pleito AIMRSPM03 - Elaboração de estudo de viabilidade de gestão regional dos resíduos sólidos urbanos concluída | milestone | 0d | 2020-09-29 | 2020-09-29 | 212 |  |  | 2020-09-29 | 2020-09-29 | 0d |  |  | 613d | 0d |  |  |  |  |  |  |  |  |  |  |  |  |  |  |  |
| 214 | 3.1.3.2.9.3 | **Elaboração do estudo de viabilidade** |  | 148d | 2020-09-30 | 2021-05-07 |  |  |  | 2020-09-30 | 2021-05-07 | 148d |  |  | 613d |  |  |  |  |  |  |  |  |  |  |  |  |  |  |  |  |
| 215 | 3.1.3.2.9.3.1 | Elaborar estudo de viabilidade |  | 88d | 2020-09-30 | 2021-02-05 | 213 |  |  | 2020-09-30 | 2021-02-05 | 88d |  |  | 613d | 0d |  |  |  |  |  |  |  |  |  |  |  |  |  |  |  |
| 216 | 3.1.3.2.9.3.2 | Analisar estudo |  | 60d | 2021-02-08 | 2021-05-07 | 215 |  |  | 2021-02-08 | 2021-05-07 | 60d |  |  | 613d | 0d |  |  |  |  |  |  |  |  |  |  |  |  |  |  |  |
| 217 | 3.1.3.2.9.3.3 | Estudo de Aimorés do Pleito AIMRSPM03 - Elaboração de estudo de viabilidade de gestão regional dos resíduos sólidos urbanos concluído | milestone | 0d | 2021-05-07 | 2021-05-07 | 216 |  |  | 2021-05-07 | 2021-05-07 | 0d |  |  | 613d | 0d |  |  |  |  |  |  |  |  |  |  |  |  |  |  |  |
| 218 | 3.1.3.2.9.4 | Recurso do serviço do Pleito AIMRSPM03 - Elaboração de estudo de viabilidade de gestão regional dos resíduos sólidos urbanos repassado | milestone | 0d | 2021-05-14 | 2021-05-14 | 217FS+5d |  |  | 2021-05-14 | 2021-05-14 | 0d |  |  | 613d | 0d |  |  |  |  |  |  |  |  |  |  |  |  |  |  |  |
| 219 | 3.1.3.2.9.5 | Pleito AIMRSPM03 - Elaboração de estudo de viabilidade de gestão regional dos resíduos sólidos urbanos de Aimorés concluído | milestone | 0d | 2021-05-14 | 2021-05-14 | 218 |  |  | 2021-05-14 | 2021-05-14 | 0d |  |  | 613d | 401d |  |  |  |  |  |  |  |  |  |  |  |  |  |  |  |
| 220 | 3.1.3.2.10 | Recursos de Aimorés repassados | milestone | 0d | 2022-12-22 | 2022-12-22 | 107, 129, 146, 118, 194, 150, 166, 205, 219 |  |  | 2022-12-22 | 2022-12-22 | 0d | 2023-03-21 | 2023-03-21 | 212d |  | Verde | Verde | 0% | 0% | Compensatória | Banco | Verde | 0% | 0% |  |  |  |  |  |  |
| 221 | 3.1.3.3 | **Alpercata** |  | 912d | 2018-06-15 A | 2022-02-03 |  | 19% | 740.08d | 2018-06-15 | 2022-02-03 | 912d | 2018-06-15 | 2022-03-25 | 430d |  | Verde | Verde | 26% | 50% | Compensatória |  | Vermelho | 2% | 1% | 18 | 26 | 50 |  |  |  |
| 222 | 3.1.3.3.1 | **Pleito ALPESPJ01 - Elaboração de projeto de sistema de esgotamento sanitário da sede do município e distrito de Era Nova** |  | 369d | 2018-10-09 A | 2020-04-01 |  | 21% | 291.66d | 2018-10-09 | 2020-04-01 | 369d | 2018-10-09 | 2020-05-04 | 890d |  | Verde | Verde | 43% | 58% | Compensatória |  | Vermelho | 19% | 11% | 20 | 43 | 58 | 19 | 11 |  |
| 223 | 3.1.3.3.1.1 | **Licitação do projeto** |  | 129d | 2018-10-09 A | 2019-04-12 A |  | 100% |  | 2018-10-09 | 2019-04-12 | 129d | 2018-10-09 | 2019-04-12 |  |  | Verde | Verde | 100% | 100% | Compensatória |  | Verde | 100% | 100% | 100 | 100 | 100 | 100 | 100 |  |
| 224 | 3.1.3.3.1.1.1 | Licitar projeto |  | 85d | 2018-10-09 A | 2019-02-12 A | 3014FS+92ed | 100% |  | 2018-10-09 | 2019-02-12 | 85d | 2018-10-09 | 2019-02-12 |  |  | Verde | Verde | 100% | 100% | Compensatória | Município | Verde | 100% | 100% | 100 | 100 | 100 | 100 | 100 |  |
| 225 | 3.1.3.3.1.1.2 | Documentação de licitação do Pleito ALPESPJ01 - Elaboração de projeto de sistema de esgotamento sanitário da sede do município e distrito de Era Nova apresentada ao banco | milestone | 0d | 2019-03-28 A | 2019-03-28 A | 224FS+29d | 100% |  | 2019-03-28 | 2019-03-28 | 0d | 2019-03-28 | 2019-03-28 |  |  | Verde | Verde | 100% | 100% | Compensatória | Município | Verde | 100% | 100% | 100 | 100 | 100 | 100 | 100 |  |
| 226 | 3.1.3.3.1.1.3 | Analisar e emitir resultado da análise de licitação do projeto |  | 11d | 2019-03-29 A | 2019-04-12 A | 225 | 100% |  | 2019-03-29 | 2019-04-12 | 11d | 2019-03-29 | 2019-04-12 |  |  | Verde | Verde | 100% | 100% | Compensatória | Banco | Verde | 100% | 100% | 100 | 100 | 100 | 100 | 100 |  |
| 227 | 3.1.3.3.1.1.4 | Licitação do projeto do Pleito ALPESPJ01 - Elaboração de projeto de sistema de esgotamento sanitário da sede do município e distrito de Era Nova concluída | milestone | 0d | 2019-04-12 A | 2019-04-12 A | 226 | 100% |  | 2019-04-12 | 2019-04-12 | 0d | 2019-04-12 | 2019-04-12 |  |  | Verde | Verde | 100% | 100% | Compensatória | Município | Verde | 100% | 100% | 100 | 100 | 100 | 100 | 100 |  |
| 228 | 3.1.3.3.1.2 | **Elaboração do Estudo de Concepção** |  | 135d | 2019-04-15 A | 2019-10-25 |  | 12% | 118.9d | 2019-04-15 | 2019-10-25 | 135d | 2019-04-15 | 2019-10-18 | 525d |  | Verde | Verde | 23% | 0% | Compensatória |  | Vermelho | 29% | 0% |  | 23 |  | 29 |  |  |
| 229 | 3.1.3.3.1.2.1 | Elaborar estudo |  | 62d | 2019-04-15 A | 2019-07-15 | 227 | 25% | 46.5d | 2019-04-15 | 2019-07-15 | 62d | 2019-04-15 | 2019-07-10 | 481d | 0d | Verde | Verde | 51% | 0% | Compensatória | Município | Vermelho | 51% | 0% | 16 | 51 |  | 51 |  | Conforme agendado |
| 230 | 3.1.3.3.1.2.2 | Estudo de concepção do Pleito ALPESPJ01 - Elaboração de projeto de sistema de esgotamento sanitário da sede do município e distrito de Era Nova apresentado ao banco | milestone | 0d | 2019-07-15 | 2019-07-15 | 229 |  |  | 2019-07-15 | 2019-07-15 | 0d | 2019-07-10 | 2019-07-10 | 525d | 0d | Verde | Verde | 0% | 0% | Compensatória | Município | Verde | 0% | 0% |  |  |  |  |  |  |
| 231 | 3.1.3.3.1.2.3 | Analisar estudo |  | 68d | 2019-07-16 | 2019-10-18 | 230 |  |  | 2019-07-16 | 2019-10-18 | 68d | 2019-07-11 | 2019-08-12 | 525d | 0d | Verde | Verde | 0% | 0% | Compensatória | Banco | Verde | 0% | 0% |  |  |  |  |  | Critério FR |
| 232 | 3.1.3.3.1.2.4 | Estudo de concepção do Pleito ALPESPJ01 - Elaboração de projeto de sistema de esgotamento sanitário da sede do município e distrito de Era Nova aprovado | milestone | 0d | 2019-10-18 | 2019-10-18 | 231 |  |  | 2019-10-18 | 2019-10-18 | 0d | 2019-10-11 | 2019-10-11 | 525d | 0d | Verde | Verde | 0% | 0% | Compensatória | Município | Verde | 0% | 0% |  |  |  |  |  |  |
| 233 | 3.1.3.3.1.2.5 | Recurso do estudo de concepção do Pleito ALPESPJ01 - Elaboração de projeto de sistema de esgotamento sanitário da sede do município e distrito de Era Nova repassado | milestone | 0d | 2019-10-25 | 2019-10-25 | 232FS+5d |  |  | 2019-10-25 | 2019-10-25 | 0d | 2019-10-18 | 2019-10-18 | 525d | 20d | Verde | Verde | 0% | 0% | Compensatória | Banco | Verde | 0% | 0% |  |  |  |  |  |  |

Notes:
- 209: 03/07/2019: na reunião da 2a rodada o município informou que ainda não definiu quando será iniciado esse pleito. Foi premissado que o pleito iniciará após a conclusão das melhorias da UTC.
- 221: O pleito de Esgotamento Sanitário de Alpercata, contempla apenas a elaboração do projeto da sede do município e do distrito de Nova Era (5,3% do valor de SES- R$250.000,00), conforme Deliberação 75. Somente após o projeto vai ser feito o pleito para as obras. Este pleito foi aprovado. / O município teve 0,8%, dos 10% do valor teto destinado a Resíduos Sólidos aprovado (R$37.131,34).
- 224: 11/04/2019: premissa de início de licitação baseado no início da elaboração do TR. / 30/05/2019: A licitação de projeto da sede e distrito de Era Nova foi concluída, sendo a empresa ganhadora Equilíbrio Engenharia LTDA.
- 225: 30/05/2019: A documentação de licitação do projeto da sede foi protocolada no BDMG dia 28/03, pois houve interposição de vários recursos durante o processo licitatório, atrasando assim o cronograma pactuado em reunião junto à CT;
- 226: 30/04/2019: banco aprovou a licitação no dia 12/04/2019 conforme planilha Controle Gerencial Renova.
- 227: 30/04/2019: banco aprovou a licitação no dia 12/04/2019 conforme planilha Controle Gerencial Renova.
- 229: 30/05/2019: empresa está elaborando o estudo de acordo com o município. A previsão de término será mantida. / 01/07/2019: e-mail da Claudia - Realizada reunião no dia 18/06/2019 no BDMG com a participação do representante do Município, Sra. Sonia Heringer, para verificação das etapas de pagamentos do estudo de concepção, Projeto Básico e Projeto executivo. Foi agendada uma reunião no dia 04/07/2019 com o representante da prefeitura e da empresa Equilíbrio Engenharia, ganhadora da licitação para elaboração dos projetos descritos acima, para repasse das informações discutidas no BDMG e recebimento dos produtos concluídos. Na oportunidade atualizarei a data de entrega prevista.
- 233: Em 11/04/19: 5 dias após a aprovação do projeto básico o município receberá o recurso do projeto básico (40% do valor do projeto total)

| ID | WBS | Task | Type | Duration | Start | Finish | Predecessors | Baseline start | Baseline finish | Baseline duration | Baseline 1 start | Baseline 1 finish | Total slack | Free slack | Text1 | Text2 | Text3 | Text6 | Text8 | Text12 | Text14 | Text16 | Text18 | Text9 |
| --- | --- | --- | --- | --- | --- | --- | --- | --- | --- | --- | --- | --- | --- | --- | --- | --- | --- | --- | --- | --- | --- | --- | --- | --- |
| 234 | 3.1.3.3.1.3 | **Elaboração do Projeto Básico** |  | 109d | 2019-07-01 | 2019-12-02 |  | 2019-06-17 | 2019-11-19 | 109d |  |  | 481d |  | Verde | Verde | 0% | 0% | Compensatória | Verde | 0% | 0% |  |  |
| 235 | 3.1.3.3.1.3.1 | Elaborar projeto básico |  | 44d | 2019-07-01 | 2019-08-30 | 229FS-11d | 2019-06-17 | 2019-08-19 | 44d |  |  | 481d | 0d | Verde | Verde | 0% | 0% | Compensatória | Verde | 0% | 0% | Critério FR |  |
| 236 | 3.1.3.3.1.3.2 | Projeto básico do Pleito ALPESPJ01 - Elaboração de projeto de sistema de esgotamento sanitário da sede do município e distrito de Era Nova apresentado ao banco | milestone | 0d | 2019-08-30 | 2019-08-30 | 235 | 2019-08-19 | 2019-08-19 | 0d |  |  | 505d | 0d | Verde | Verde | 0% | 0% | Compensatória | Verde | 0% | 0% |  |  |
| 237 | 3.1.3.3.1.3.3 | Analisar projeto básico |  | 60d | 2019-09-02 | 2019-11-25 | 236 | 2019-08-20 | 2019-11-11 | 60d |  |  | 505d | 0d | Verde | Verde | 0% | 0% | Compensatória | Verde | 0% | 0% | Critério FR |  |
| 238 | 3.1.3.3.1.3.4 | Projeto básico do Pleito ALPESPJ01 - Elaboração de projeto de sistema de esgotamento sanitário da sede do município e distrito de Era Nova aprovado | milestone | 0d | 2019-11-25 | 2019-11-25 | 233, 237 | 2019-11-11 | 2019-11-11 | 0d |  |  | 505d | 0d | Verde | Verde | 0% | 0% | Compensatória | Verde | 0% | 0% |  |  |
| 239 | 3.1.3.3.1.3.5 | Recurso do projeto básico do Pleito ALPESPJ01 - Elaboração de projeto de sistema de esgotamento sanitário da sede do município e distrito de Era Nova repassado | milestone | 0d | 2019-12-02 | 2019-12-02 | 238FS+5d | 2019-11-19 | 2019-11-19 | 0d |  |  | 505d | 75d | Verde | Verde | 0% | 0% | Compensatória | Verde | 0% | 0% |  |  |
| 240 | 3.1.3.3.1.4 | Realizar Licenciamento Ambiental |  | 113d | 2019-07-16 | 2019-12-26 | 229 | 2019-07-16 | 2019-12-26 | 113d | 2019-07-11 | 2020-01-20 | 490d | 60d | Verde | Verde | 0% | 0% | Compensatória | Verde | 0% | 0% | Critério FR | Município |
| 241 | 3.1.3.3.1.5 | **Elaboração do Projeto Executivo** |  | 145d | 2019-09-02 | 2020-04-01 |  | 2019-08-20 | 2020-04-01 | 154d | 2019-07-15 | 2020-05-04 | 481d |  | Verde | Verde | 0% | 0% | Compensatória | Verde | 0% | 0% |  |  |
| 242 | 3.1.3.3.1.5.1 | Elaborar Projeto Executivo |  | 24d | 2019-09-02 | 2019-10-03 | 235 | 2019-08-20 | 2019-09-20 | 24d | 2019-07-15 | 2019-10-11 | 481d | 0d | Verde | Verde | 0% | 0% | Compensatória | Verde | 0% | 0% | Critério FR | Município |
| 243 | 3.1.3.3.1.5.2 | Projeto executivo do Pleito ALPESPJ01 - Elaboração de projeto de sistema de esgotamento sanitário da sede do município e distrito de Era Nova apresentado ao banco | milestone | 0d | 2019-10-03 | 2019-10-03 | 242 | 2019-09-20 | 2019-09-20 | 0d | 2019-10-11 | 2019-10-11 | 481d | 0d | Verde | Verde | 0% | 0% | Compensatória | Verde | 0% | 0% |  | Município |
| 244 | 3.1.3.3.1.5.3 | Analisar projeto executivo |  | 65d | 2019-10-04 | 2020-01-09 | 243 | 2019-09-23 | 2019-12-26 | 65d | 2019-10-14 | 2019-11-12 | 481d | 51d | Verde | Verde | 0% | 0% | Compensatória | Verde | 0% | 0% | Critério FR | Banco |
| 245 | 3.1.3.3.1.5.4 | Projeto executivo do Pleito ALPESPJ01 - Elaboração de projeto de sistema de esgotamento sanitário da sede do município e distrito de Era Nova aprovado | milestone | 0d | 2020-03-25 | 2020-03-25 | 240, 258, 239, 244 | 2020-03-25 | 2020-03-25 | 0d | 2020-04-24 | 2020-04-24 | 430d | 0d | Verde | Verde | 0% | 0% | Compensatória | Verde | 0% | 0% |  | Município |
| 246 | 3.1.3.3.1.5.5 | Recurso do projeto executivo do Pleito ALPESPJ01 - Elaboração de projeto de sistema de esgotamento sanitário da sede do município e distrito de Era Nova repassado | milestone | 0d | 2020-04-01 | 2020-04-01 | 245FS+5d | 2020-04-01 | 2020-04-01 | 0d | 2020-05-04 | 2020-05-04 | 890d | 0d | Verde | Verde | 0% | 0% | Compensatória | Verde | 0% | 0% |  | Banco |
| 247 | 3.1.3.3.1.6 | Pleito ALPESPJ01 - Elaboração de projeto de sistema de esgotamento sanitário da sede do município e distrito de Era Nova de Alpercata concluído | milestone | 0d | 2020-04-01 | 2020-04-01 | 246 | 2020-04-01 | 2020-04-01 | 0d | 2020-05-04 | 2020-05-04 | 890d | 460d | Verde | Verde | 0% | 0% | Compensatória | Verde | 0% | 0% |  | Município |
| 248 | 3.1.3.3.2 | **Pleito de Alpercata a definir - Aquisição de terreno** |  | 160d | 2019-08-01 | 2020-03-25 |  | 2019-08-01 | 2020-03-25 | 160d | 2019-08-30 | 2020-04-24 | 430d |  | Verde | Verde | 0% | 0% | Compensatória | Verde | 0% | 0% |  |  |
| 249 | 3.1.3.3.2.1 | Pleito de Alpercata a definir - Aquisição de terreno aprovado | milestone | 0d | 2019-08-01 | 2019-08-01 | 3052FS+158d | 2019-08-01 | 2019-08-01 | 0d | 2019-08-30 | 2019-08-30 | 430d | 0d | Verde | Verde | 0% | 0% | Compensatória | Verde | 0% | 0% |  | CT/CIF |
| 250 | 3.1.3.3.2.2 | Autorização de compra do terreno do Pleito de Alpercata a definir - Aquisição de terreno emitida pelo banco | milestone | 0d | 2019-08-16 | 2019-08-16 | 249FS+10d | 2019-08-16 | 2019-08-16 | 0d | 2019-09-13 | 2019-09-13 | 430d | 0d | Verde | Verde | 0% | 0% | Compensatória | Verde | 0% | 0% |  | Banco |
| 251 | 3.1.3.3.2.3 | **Aquisição do Terreno** |  | 150d | 2019-08-19 | 2020-03-25 |  | 2019-08-19 | 2020-03-25 | 150d | 2019-09-16 | 2020-04-24 | 430d |  | Verde | Verde | 0% | 0% | Compensatória | Verde | 0% | 0% |  |  |
| 252 | 3.1.3.3.2.3.1 | Regularizar terreno e apresentar escritura ao banco |  | 87d | 2019-08-19 | 2019-12-19 | 250 | 2019-08-19 | 2019-12-19 | 87d | 2019-09-16 | 2020-01-21 | 430d | 0d | Verde | Verde | 0% | 0% | Compensatória | Verde | 0% | 0% | Critério FR | Município |
| 253 | 3.1.3.3.2.3.2 | Analisar documentação do terreno |  | 10d | 2019-12-20 | 2020-01-07 | 252 | 2019-12-20 | 2020-01-07 | 10d | 2020-01-22 | 2020-02-04 | 473d | 0d | Verde | Verde | 0% | 0% | Compensatória | Verde | 0% | 0% |  | Banco |
| 254 | 3.1.3.3.2.3.3 | 50% do valor do imóvel do Pleito de Alpercata a definir - Aquisição de terreno repassado | milestone | 0d | 2020-01-21 | 2020-01-21 | 253FS+10d | 2020-01-21 | 2020-01-21 | 0d | 2020-02-18 | 2020-02-18 | 473d | 43d | Verde | Verde | 0% | 0% | Compensatória | Verde | 0% | 0% |  | Banco |
| 255 | 3.1.3.3.2.3.4 | Registrar imóvel e apresentar documentação ao banco |  | 43d | 2019-12-20 | 2020-02-21 | 252 | 2019-12-20 | 2020-02-21 | 43d | 2020-01-22 | 2020-03-25 | 430d | 0d | Verde | Verde | 0% | 0% | Compensatória | Verde | 0% | 0% |  | Município |
| 256 | 3.1.3.3.2.3.5 | Analisar documentação do terreno |  | 10d | 2020-02-27 | 2020-03-11 | 255 | 2020-02-27 | 2020-03-11 | 10d | 2020-03-26 | 2020-04-08 | 430d | 0d | Verde | Verde | 0% | 0% | Compensatória | Verde | 0% | 0% |  | Banco |
| 257 | 3.1.3.3.2.3.6 | 50% do valor do imóvel do Pleito de Alpercata a definir - Aquisição de terreno repassado | milestone | 0d | 2020-03-25 | 2020-03-25 | 256FS+10d | 2020-03-25 | 2020-03-25 | 0d | 2020-04-24 | 2020-04-24 | 430d | 0d | Verde | Verde | 0% | 0% | Compensatória | Verde | 0% | 0% |  | Banco |
| 258 | 3.1.3.3.2.4 | Pleito de Alpercata a definir - Aquisição de terreno concluído | milestone | 0d | 2020-03-25 | 2020-03-25 | 254, 257 | 2020-03-25 | 2020-03-25 | 0d | 2020-04-24 | 2020-04-24 | 430d | 0d | Verde | Verde | 0% | 0% | Compensatória | Verde | 0% | 0% |  | Município |

Notes:
- 235: 30/05/2019: o início do projeto básico será 1 mês antes da entrega do estudo / 03/07/2019: Fernanda informou que o município não começou a elaborar o projeto básico. Ela vai conseguir uma previsão na próxima reunião, por isso atividade foi reprogramada para o próximo ciclo.
- 240: Em 11/04/19: Início do licenciamento igual o fim da elaboração do projeto básico e término igual a aprovação do projeto executivo pelo banco
- 242: 24/05/2019: município pactuou com a Renova 3 meses para elaborar projeto executivo
- 246: Em 11/04/19: o pagamento do recurso do projeto executivo (60% do valor do projeto total) será realizado 5 dias após a aprovação do mesmo
- 249: Em 12/04/2019: o pleito será enviado 10/07/2019 e será aprovado pela CT/CIF até 30/08/19 (NT 33) / 30/05/2019: município vai enviar o pleito antes e está prevista a aprovação pela CT/CIF em julho
- 254: Em 11/04/2019: Repasse de 50% do valor do imóvel após 10 dias úteis (premissa adotada) a apresentação da escritura pública de compra e venda ao BDMG.
- 257: Em 11/04/19: repasse de 50% do valor do imóvel após 10 dias úteis (premissa adotada) a apresentação do registro da escritura pública na matrícula do imóvel ao BDMG.

| ID | WBS | Task | Type | Duration | Start | Finish | Predecessors | Complete | Remaining | Baseline start | Baseline finish | Baseline duration | Baseline 1 start | Baseline 1 finish | Total slack | Free slack | Constraint | Text1 | Text2 | Text3 | Text6 | Text8 | Text12 | Text14 | Text16 | Text9 | Text4 | Text5 | Text7 | Text15 | Text17 | Text18 |
| --- | --- | --- | --- | --- | --- | --- | --- | --- | --- | --- | --- | --- | --- | --- | --- | --- | --- | --- | --- | --- | --- | --- | --- | --- | --- | --- | --- | --- | --- | --- | --- | --- |
| 259 | 3.1.3.3.3 | **Pleito de Alpercata a definir - Obra de sistema de esgotamento sanitário da sede do município e distrito de Era Nova** |  | 541d | 2019-11-29 | 2022-02-03 |  |  |  | 2019-11-29 | 2022-02-03 | 541d | 2019-11-29 | 2022-03-25 | 430d |  |  | Verde | Verde | 0% | 0% | Compensatória | Verde | 0% | 0% |  |  |  |  |  |  |  |
| 260 | 3.1.3.3.3.1 | Pleito de Alpercata a definir - Obra de sistema de esgotamento sanitário da sede do município e distrito de Era Nova aprovado | milestone | 0d | 2019-11-29 | 2019-11-29 | 3052FS+242d |  |  | 2019-11-29 | 2019-11-29 | 0d | 2019-11-29 | 2019-11-29 | 496d | 66d |  | Verde | Verde | 0% | 0% | Compensatória | Verde | 0% | 0% | CT/CIF |  |  |  |  |  |  |
| 261 | 3.1.3.3.3.2 | **Licitação da obra** |  | 79d | 2020-03-25 | 2020-07-20 |  |  |  | 2020-03-25 | 2020-07-20 | 79d | 2020-04-24 | 2020-08-17 | 430d |  |  | Verde | Verde | 0% | 0% | Compensatória | Verde | 0% | 0% |  |  |  |  |  |  |  |
| 262 | 3.1.3.3.3.2.1 | Licitação da obra do Pleito de Alpercata a definir - Obra de sistema de esgotamento sanitário da sede do município e distrito de Era Nova autorizada pelo banco | milestone | 0d | 2020-03-25 | 2020-03-25 | 260FS+10d, 245 |  |  | 2020-03-25 | 2020-03-25 | 0d | 2020-04-24 | 2020-04-24 | 430d | 0d |  | Verde | Verde | 0% | 0% | Compensatória | Verde | 0% | 0% | Banco |  |  |  |  |  |  |
| 263 | 3.1.3.3.3.2.2 | Licitar obra |  | 65d | 2020-03-26 | 2020-06-30 | 262 |  |  | 2020-03-26 | 2020-06-30 | 65d | 2020-04-27 | 2020-07-28 | 430d | 0d |  | Verde | Verde | 0% | 0% | Compensatória | Verde | 0% | 0% | Município |  |  |  |  |  |  |
| 264 | 3.1.3.3.3.2.3 | Analisar e emitir resultado da licitação da obra |  | 14d | 2020-07-01 | 2020-07-20 | 263 |  |  | 2020-07-01 | 2020-07-20 | 14d | 2020-07-29 | 2020-08-17 | 430d | 0d |  | Verde | Verde | 0% | 0% | Compensatória | Verde | 0% | 0% | Banco |  |  |  |  |  |  |
| 265 | 3.1.3.3.3.2.4 | Licitação da obra do Pleito de Alpercata a definir - Obra de sistema de esgotamento sanitário da sede do município e distrito de Era Novaconcluída | milestone | 0d | 2020-07-20 | 2020-07-20 | 264 |  |  | 2020-07-20 | 2020-07-20 | 0d | 2020-08-17 | 2020-08-17 | 430d | 0d |  | Verde | Verde | 0% | 0% | Compensatória | Verde | 0% | 0% | Município |  |  |  |  |  |  |
| 266 | 3.1.3.3.3.3 | Executar obra |  | 240d | 2020-08-19 | 2021-08-05 | 265FS+21d |  |  | 2020-08-19 | 2021-08-05 | 240d | 2020-09-17 | 2021-09-02 | 430d | 0d |  | Verde | Verde | 0% | 0% | Compensatória | Verde | 0% | 0% | Município |  |  |  |  |  |  |
| 267 | 3.1.3.3.3.4 | Realizar processo de pré-operação da sede |  | 120d | 2021-08-06 | 2022-01-27 | 266 |  |  | 2021-08-06 | 2022-01-27 | 120d | 2021-09-03 | 2022-03-18 | 430d | 0d |  | Verde | Verde | 0% | 0% | Compensatória | Verde | 0% | 0% | Município |  |  |  |  |  |  |
| 268 | 3.1.3.3.3.5 | Recurso da obra do Pleito de Alpercata a definir - Obra de sistema de esgotamento sanitário da sede do município e distrito de Era Nova repassado | milestone | 0d | 2022-02-03 | 2022-02-03 | 267FS+5d |  |  | 2022-02-03 | 2022-02-03 | 0d | 2022-03-25 | 2022-03-25 | 430d | 0d |  | Verde | Verde | 0% | 0% | Compensatória | Verde | 0% | 0% | Banco |  |  |  |  |  |  |
| 269 | 3.1.3.3.3.6 | Pleito de Alpercata a definir - Obra de sistema de esgotamento sanitário da sede do município e distrito de Era Nova concluído | milestone | 0d | 2022-02-03 | 2022-02-03 | 268 |  |  | 2022-02-03 | 2022-02-03 | 0d | 2022-03-25 | 2022-03-25 | 430d | 0d |  | Verde | Verde | 0% | 0% | Compensatória | Verde | 0% | 0% | Município |  |  |  |  |  |  |
| 270 | 3.1.3.3.4 | **Pleito ALPRSPM01 - Elaboração de estudos de viabilidade para a concepção dos serviços de infraestrutura de sistemas integrados de destinação final de resíduos sólidos urbanos, bem como educação ambiental e programas de coleta seletiva** |  | 486d | 2018-06-15 A | 2020-05-22 |  | 43% | 278.87d | 2018-06-15 | 2020-05-22 | 486d | 2018-06-15 | 2020-03-11 | 856d |  |  | Verde | Verde | 50% | 80% | Compensatória | Vermelho | 10% | 8% |  | 43 | 50 | 80 | 10 |  |  |
| 271 | 3.1.3.3.4.1 | **Licitação de Empresa para Estudo de Viabilidade** |  | 332d | 2018-06-15 A | 2019-10-04 |  | 66% | 112.71d | 2018-06-15 | 2019-10-04 | 332d | 2018-06-15 | 2019-07-26 | 856d |  |  | Verde | Verde | 73% | 77% | Compensatória | Vermelho | 57% | 44% |  | 66 | 73 | 77 | 57 | 44 |  |
| 272 | 3.1.3.3.4.1.1 | Licitação da empresa para Estudo de Viabilidade do Pleito ALPRSPM01 - Elaboração de estudos de viabilidade para a concepção dos serviços de infraestrutura de sistemas integrados de destinação final de resíduos sólidos urbanos autorizada pelo banco | milestone | 0d | 2018-06-15 A | 2018-06-15 A |  | 100% |  | 2018-06-15 | 2018-06-15 | 0d | 2018-06-15 | 2018-06-15 |  |  | must start on 2018-06-15 | Verde | Verde | 100% | 100% | Compensatória | Verde | 100% | 100% | Banco | 100 | 100 | 100 | 100 | 100 |  |
| 273 | 3.1.3.3.4.1.2 | Licitar empresa para Estudo de Viabilidade |  | 257d | 2018-09-03 A | 2019-09-09 | 272FS+56d | 70% | 78d | 2018-09-03 | 2019-09-09 | 257d | 2018-09-03 | 2019-07-01 | 856d | 0d |  | Verde | Verde | 73% | 78% | Compensatória | Vermelho | 73% | 57% | Município | 70 | 73 | 78 | 73 | 57 | Conforme agendado |
| 274 | 3.1.3.3.4.1.3 | Documentação de licitação do Pleito ALPRSPM01 - Elaboração de estudos de viabilidade para a concepção dos serviços de infraestrutura de sistemas integrados de destinação final de resíduos sólidos urbanos apresentada ao banco | milestone | 0d | 2019-09-16 | 2019-09-16 | 273FS+5d |  |  | 2019-09-16 | 2019-09-16 | 0d | 2019-07-08 | 2019-07-08 | 856d | 0d |  | Verde | Verde | 0% | 0% | Compensatória | Verde | 0% | 0% | Município |  |  |  |  |  |  |
| 275 | 3.1.3.3.4.1.4 | Analisar e emitir resultado da licitação da empresa para Estudo de Viabilidade |  | 14d | 2019-09-17 | 2019-10-04 | 274 |  |  | 2019-09-17 | 2019-10-04 | 14d | 2019-07-09 | 2019-07-26 | 856d | 0d |  | Verde | Verde | 0% | 0% | Compensatória | Verde | 0% | 0% | Banco |  |  |  |  |  | Critério FR |
| 276 | 3.1.3.3.4.1.5 | Licitação da empresa para Estudo de Viabilidade do Pleito ALPRSPM01 - Elaboração de estudos de viabilidade para a concepção dos serviços de infraestrutura de sistemas integrados de destinação final de resíduos sólidos urbanos concluída | milestone | 0d | 2019-10-04 | 2019-10-04 | 275 |  |  | 2019-10-04 | 2019-10-04 | 0d | 2019-07-26 | 2019-07-26 | 856d | 0d |  | Verde | Verde | 0% | 0% | Compensatória | Verde | 0% | 0% | Município |  |  |  |  |  |  |
| 277 | 3.1.3.3.4.2 | **Elaboração do estudo de viabilidade** |  | 149d | 2019-10-07 | 2020-05-15 |  |  |  | 2019-10-07 | 2020-05-15 | 149d | 2019-07-29 | 2020-03-04 | 856d |  |  | Verde | Verde | 0% | 0% | Compensatória | Verde | 0% | 0% |  |  |  |  |  |  |  |
| 278 | 3.1.3.3.4.2.1 | Elaborar estudo de viabilidade |  | 88d | 2019-10-07 | 2020-02-12 | 276 |  |  | 2019-10-07 | 2020-02-12 | 88d | 2019-07-29 | 2019-11-29 | 856d | 0d |  | Verde | Verde | 0% | 0% | Compensatória | Verde | 0% | 0% | Município |  |  |  |  |  |  |
| 279 | 3.1.3.3.4.2.2 | Analisar estudo |  | 61d | 2020-02-13 | 2020-05-15 | 278 |  |  | 2020-02-13 | 2020-05-15 | 61d | 2019-12-02 | 2020-01-02 | 856d | 0d |  | Verde | Verde | 0% | 0% | Compensatória | Verde | 0% | 0% | Banco |  |  |  |  |  |  |
| 280 | 3.1.3.3.4.2.3 | Estudo Pleito ALPRSPM01 - Elaboração de estudos de viabilidade para a concepção dos serviços de infraestrutura de sistemas integrados de destinação final de resíduos sólidos urbanos, bem como educação ambiental e programas de coleta seletiva concluído | milestone | 0d | 2020-05-15 | 2020-05-15 | 279 |  |  | 2020-05-15 | 2020-05-15 | 0d | 2020-03-04 | 2020-03-04 | 856d | 0d |  | Verde | Verde | 0% | 0% | Compensatória | Verde | 0% | 0% | Município |  |  |  |  |  |  |
| 281 | 3.1.3.3.4.3 | Recurso do serviço do Pleito ALPRSPM01 - Elaboração de estudos de viabilidade para a concepção dos serviços de infraestrutura de sistemas integrados de destinação final de resíduos sólidos urbanos repassado | milestone | 0d | 2020-05-22 | 2020-05-22 | 280FS+5d |  |  | 2020-05-22 | 2020-05-22 | 0d | 2020-03-11 | 2020-03-11 | 856d | 0d |  | Verde | Verde | 0% | 0% | Compensatória | Verde | 0% | 0% | Banco |  |  |  |  |  |  |
| 282 | 3.1.3.3.4.4 | Pleito ALPRSPM01 - Elaboração de estudos de viabilidade para a concepção dos serviços de infraestrutura de sistemas integrados de destinação final de resíduos sólidos urbanos de Alpercata concluído | milestone | 0d | 2020-05-22 | 2020-05-22 | 281 |  |  | 2020-05-22 | 2020-05-22 | 0d | 2020-03-11 | 2020-03-11 | 856d | 426d |  | Verde | Verde | 0% | 0% | Compensatória | Verde | 0% | 0% | Município |  |  |  |  |  |  |
| 283 | 3.1.3.3.5 | Recursos de Alpercata repassados | milestone | 0d | 2022-02-03 | 2022-02-03 | 247, 258, 269, 282 |  |  | 2022-02-03 | 2022-02-03 | 0d | 2022-03-25 | 2022-03-25 | 430d |  |  | Verde | Verde | 0% | 0% | Compensatória | Verde | 0% | 0% | Banco |  |  |  |  |  |  |

Notes:
- 260: Em 11/04/2019: o pleito será enviado até o dia 10/10/19, portanto o pleito será analisado pela CT/CIF até o dia 29/11/2019
- 266: 22/05/2019: valor da obra igual a 90% do teto menos outros pleitos de ES - teto ( R$ 4.726.993,07 ) menos projeto (250 mil) = R$ 4.004.293,76 - 1 ano
- 272: Em 24/04/2019: a autorização foi enviada ao município no dia 15/06/2018
- 273: 24/09/2019: conforme relatórios do apoio técnico o município iniciou o processo licitatório em setembro 2018 / 21/05/2019: atualizada a data de término conforme cronograma do consórcio

| ID | WBS | Task | Type | Duration | Start | Finish | Predecessors | Complete | Remaining | Baseline start | Baseline finish | Baseline duration | Baseline 1 start | Baseline 1 finish | Total slack | Free slack | Text1 | Text2 | Text3 | Text6 | Text8 | Text12 | Text14 | Text16 | Text4 | Text5 | Text7 | Text15 | Text17 | Text9 | Text18 |
| --- | --- | --- | --- | --- | --- | --- | --- | --- | --- | --- | --- | --- | --- | --- | --- | --- | --- | --- | --- | --- | --- | --- | --- | --- | --- | --- | --- | --- | --- | --- | --- |
| 284 | 3.1.3.4 | **Baixo Guandu** |  | 814d | 2019-02-08 A | 2022-05-23 |  | 7% | 754.6d | 2019-02-08 | 2022-05-23 | 814d | 2019-02-08 | 2022-06-07 | 358d |  | Verde | Verde | 9% | 0% | Compensatória | Vermelho | 1% | 0% |  |  |  |  |  |  |  |
| 285 | 3.1.3.4.1 | **Pleito BAGESPJ01 - Elaboração de projeto de sistema de esgotamento sanitário da sede municipal** |  | 319d | 2019-02-08 A | 2020-05-27 |  | 18% | 260.25d | 2019-02-08 | 2020-05-21 | 315d | 2019-02-08 | 2020-04-07 | 853d |  | Verde | Verde | 23% | 25% | Compensatória | Vermelho | 4% | 1% | 10 | 23 | 25 |  |  |  |  |
| 286 | 3.1.3.4.1.1 | **Licitação de Projetos** |  | 107d | 2019-02-08 A | 2019-07-18 |  | 87% | 14d | 2019-02-08 | 2019-07-12 | 103d | 2019-02-08 | 2019-05-31 | 853d |  | Verde | Verde | 71% | 38% | Compensatória | Vermelho | 66% | 25% | 53 | 71 | 38 | 66 | 25 |  |  |
| 287 | 3.1.3.4.1.1.1 | Licitar projetos |  | 93d | 2019-02-08 A | 2019-06-28 A | 3015FS+182ed | 100% |  | 2019-02-08 | 2019-06-14 | 84d | 2019-02-08 | 2019-05-10 |  |  | Verde | Verde | 88% | 38% | Compensatória | Vermelho | 88% | 33% | 62 | 88 | 38 | 88 | 33 | Município | Conforme agendado |
| 288 | 3.1.3.4.1.1.2 | Documentação de licitação do Pleito BAGESPJ01 - Elaboração de projeto de sistema de esgotamento sanitário da sede municipal apresentada ao banco | milestone | 0d | 2019-06-28 A | 2019-06-28 A | 287 | 100% |  | 2019-06-24 | 2019-06-24 | 0d | 2019-05-13 | 2019-05-13 |  |  | Verde | Verde | 0% | 0% | Compensatória | Verde | 0% | 0% |  |  |  |  |  | Município |  |
| 289 | 3.1.3.4.1.1.3 | Analisar e emitir resultado da licitação do projeto |  | 14d | 2019-07-01 | 2019-07-18 | 288 |  |  | 2019-06-25 | 2019-07-12 | 14d | 2019-05-14 | 2019-05-31 | 853d | 0d | Verde | Verde | 0% | 0% | Compensatória | Verde | 0% | 0% |  |  |  |  |  | Banco | Critério FR |
| 290 | 3.1.3.4.1.1.4 | Licitação do projeto do Pleito BAGESPJ01 - Elaboração de projeto de sistema de esgotamento sanitário da sede municipal concluída | milestone | 0d | 2019-07-18 | 2019-07-18 | 289 |  |  | 2019-07-12 | 2019-07-12 | 0d | 2019-05-31 | 2019-05-31 | 853d | 0d | Verde | Verde | 0% | 0% | Compensatória | Verde | 0% | 0% |  |  |  |  |  | Município |  |
| 291 | 3.1.3.4.1.2 | **Elaboração do Projeto** |  | 212d | 2019-07-19 | 2020-05-27 |  |  |  | 2019-07-15 | 2020-05-21 | 212d | 2019-06-03 | 2020-04-07 | 853d |  | Verde | Verde | 0% | 0% | Compensatória | Verde | 0% | 0% |  |  |  |  |  |  |  |
| 292 | 3.1.3.4.1.2.1 | Elaborar Projeto |  | 124d | 2019-07-19 | 2020-01-16 | 290 |  |  | 2019-07-15 | 2020-01-10 | 124d | 2019-06-03 | 2019-11-26 | 853d | 0d | Verde | Verde | 0% | 0% | Compensatória | Verde | 0% | 0% |  |  |  |  |  | Município |  |
| 293 | 3.1.3.4.1.2.2 | Projeto do Pleito BAGESPJ01 - Elaboração de projeto de sistema de esgotamento sanitário da sede municipal apresentado ao banco | milestone | 0d | 2020-01-16 | 2020-01-16 | 292 |  |  | 2020-01-10 | 2020-01-10 | 0d | 2019-11-26 | 2019-11-26 | 936d | 83d | Verde | Verde | 0% | 0% | Compensatória | Verde | 0% | 0% |  |  |  |  |  | Município |  |
| 294 | 3.1.3.4.1.2.3 | Analisar projeto |  | 124d | 2019-08-19 | 2020-02-13 | 292SS+20d |  |  | 2019-08-19 | 2020-02-13 | 124d | 2019-07-02 | 2019-12-27 | 916d | 63d | Verde | Verde | 0% | 0% | Compensatória | Verde | 0% | 0% |  |  |  |  |  | Banco |  |
| 295 | 3.1.3.4.1.2.4 | Projeto do Pleito BAGESPJ01 - Elaboração de projeto de sistema de esgotamento sanitário da sede municipal aprovado | milestone | 0d | 2020-05-20 | 2020-05-20 | 294, 300, 293, 297 |  |  | 2020-05-14 | 2020-05-14 | 0d | 2020-03-31 | 2020-03-31 | 853d | 0d | Verde | Verde | 0% | 0% | Compensatória | Verde | 0% | 0% |  |  |  |  |  | Município |  |
| 296 | 3.1.3.4.1.2.5 | Recurso do projeto do Pleito BAGESPJ01 - Elaboração de projeto de sistema de esgotamento sanitário da sede municipal repassado | milestone | 0d | 2020-05-27 | 2020-05-27 | 295FS+5d |  |  | 2020-05-21 | 2020-05-21 | 0d | 2020-04-07 | 2020-04-07 | 853d | 0d | Verde | Verde | 0% | 0% | Compensatória | Verde | 0% | 0% |  |  |  |  |  | Banco |  |
| 297 | 3.1.3.4.1.3 | Realizar Licenciamento Ambiental |  | 23d | 2019-11-11 | 2019-12-13 | 292SS+80d |  |  | 2019-11-05 | 2019-12-06 | 23d | 2019-09-25 | 2019-10-25 | 957d | 104d | Verde | Verde | 0% | 0% | Compensatória | Verde | 0% | 0% |  |  |  |  |  | Município | Critério FR |
| 298 | 3.1.3.4.1.4 | **Regularização de terreno** |  | 127d | 2019-11-11 | 2020-05-20 |  |  |  | 2019-11-05 | 2020-05-14 | 127d | 2019-09-25 | 2020-03-31 | 853d |  | Verde | Verde | 0% | 0% | Compensatória | Verde | 0% | 0% |  |  |  |  |  |  |  |
| 299 | 3.1.3.4.1.4.1 | Regularizar terreno |  | 127d | 2019-11-11 | 2020-05-20 | 292SS+80d |  |  | 2019-11-05 | 2020-05-14 | 127d | 2019-09-25 | 2020-03-31 | 853d | 0d | Verde | Verde | 0% | 0% | Compensatória | Verde | 0% | 0% |  |  |  |  |  | Município |  |
| 300 | 3.1.3.4.1.4.2 | Regularização de terreno do Pleito BAGESPJ01 - Elaboração de projeto de sistema de esgotamento sanitário da sede municipal concluída | milestone | 0d | 2020-05-20 | 2020-05-20 | 299 |  |  | 2020-05-14 | 2020-05-14 | 0d | 2020-03-31 | 2020-03-31 | 853d | 0d | Verde | Verde | 0% | 0% | Compensatória | Verde | 0% | 0% |  |  |  |  |  | Município |  |
| 301 | 3.1.3.4.1.5 | Pleito BAGESPJ01 - Elaboração de projeto de sistema de esgotamento sanitário da sede municipal de Baixo Guandu concluído | milestone | 0d | 2020-05-27 | 2020-05-27 | 296 |  |  | 2020-05-21 | 2020-05-21 | 0d | 2020-04-07 | 2020-04-07 | 853d | 495d | Verde | Verde | 0% | 0% | Compensatória | Verde | 0% | 0% |  |  |  |  |  | Município |  |
| 302 | 3.1.3.4.2 | **Pleito de Baixo Guandu a definir - Obra de sistema de esgotamento sanitário da sede municipal e dos distritos** |  | 613d | 2019-11-29 | 2022-05-23 |  |  |  | 2019-11-29 | 2022-05-23 | 613d | 2019-11-29 | 2022-06-07 | 358d |  | Verde | Verde | 0% | 0% | Compensatória | Verde | 0% | 0% |  |  |  |  |  |  |  |
| 303 | 3.1.3.4.2.1 | Pleito de Baixo Guandu a definir - Obra de sistema de esgotamento sanitário da sede municipal e dos distritos aprovado | milestone | 0d | 2019-11-29 | 2019-11-29 | 3052FS+242d |  |  | 2019-11-29 | 2019-11-29 | 0d | 2019-11-29 | 2019-11-29 | 358d | 0d | Verde | Verde | 0% | 0% | Compensatória | Verde | 0% | 0% |  |  |  |  |  | CT/CIF |  |
| 304 | 3.1.3.4.2.2 | **Licitação da obra** |  | 58d | 2019-12-16 | 2020-03-13 |  |  |  | 2019-12-16 | 2020-03-13 | 58d | 2019-12-16 | 2020-03-13 | 358d |  | Verde | Verde | 0% | 0% | Compensatória | Verde | 0% | 0% |  |  |  |  |  |  |  |
| 305 | 3.1.3.4.2.2.1 | Licitação da obra do Pleito de Baixo Guandu a definir - Obra de sistema de esgotamento sanitário da sede municipal e dos distritos autorizada pelo banco | milestone | 0d | 2019-12-16 | 2019-12-16 | 303FS+10d |  |  | 2019-12-16 | 2019-12-16 | 0d | 2019-12-16 | 2019-12-16 | 358d | 0d | Verde | Verde | 0% | 0% | Compensatória | Verde | 0% | 0% |  |  |  |  |  | Banco |  |
| 306 | 3.1.3.4.2.2.2 | Licitar Obra |  | 44d | 2019-12-17 | 2020-02-19 | 305 |  |  | 2019-12-17 | 2020-02-19 | 44d | 2019-12-17 | 2020-02-19 | 358d | 0d | Verde | Verde | 0% | 0% | Compensatória | Verde | 0% | 0% |  |  |  |  |  | Município |  |
| 307 | 3.1.3.4.2.2.3 | Analisar e emitir resultado da licitação da obra |  | 14d | 2020-02-20 | 2020-03-13 | 306 |  |  | 2020-02-20 | 2020-03-13 | 14d | 2020-02-20 | 2020-03-13 | 358d | 0d | Verde | Verde | 0% | 0% | Compensatória | Verde | 0% | 0% |  |  |  |  |  | Banco |  |
| 308 | 3.1.3.4.2.2.4 | Licitação da obra do Pleito de Baixo Guandu a definir - Obra de sistema de esgotamento sanitário da sede municipal e dos distritos concluída | milestone | 0d | 2020-03-13 | 2020-03-13 | 307 |  |  | 2020-03-13 | 2020-03-13 | 0d | 2020-03-13 | 2020-03-13 | 358d | 0d | Verde | Verde | 0% | 0% | Compensatória | Verde | 0% | 0% |  |  |  |  |  | Município |  |
| 309 | 3.1.3.4.2.3 | Executar obra |  | 400d | 2020-04-14 | 2021-11-19 | 308FS+20d |  |  | 2020-04-14 | 2021-11-19 | 400d | 2020-04-14 | 2021-11-19 | 358d | 0d | Verde | Verde | 0% | 0% | Compensatória | Verde | 0% | 0% |  |  |  |  |  | Município |  |
| 310 | 3.1.3.4.2.4 | Realizar processo de pré-operação |  | 120d | 2021-11-22 | 2022-05-16 | 309 |  |  | 2021-11-22 | 2022-05-16 | 120d | 2021-11-22 | 2022-05-31 | 358d | 0d | Verde | Verde | 0% | 0% | Compensatória | Verde | 0% | 0% |  |  |  |  |  | Município |  |
| 311 | 3.1.3.4.2.5 | Recurso da obra do Pleito de Baixo Guandu a definir - Obra de sistema de esgotamento sanitário da sede municipal e dos distritos repassado | milestone | 0d | 2022-05-23 | 2022-05-23 | 310FS+5d |  |  | 2022-05-23 | 2022-05-23 | 0d | 2022-06-07 | 2022-06-07 | 358d | 0d | Verde | Verde | 0% | 0% | Compensatória | Verde | 0% | 0% |  |  |  |  |  | Banco |  |
| 312 | 3.1.3.4.2.6 | Pleito de Baixo Guandu a definir - Obra de sistema de esgotamento sanitário da sede municipal e dos distritos de Baixo Guandu concluído | milestone | 0d | 2022-05-23 | 2022-05-23 | 311 |  |  | 2022-05-23 | 2022-05-23 | 0d | 2022-06-07 | 2022-06-07 | 358d | 0d | Verde | Verde | 0% | 0% | Compensatória | Verde | 0% | 0% |  |  |  |  |  | Município |  |

Notes:
- 284: O pleito de Esgotamento Sanitário de Baixo Guandu, contempla apenas a elaboração do projeto da sede do município e de distritos (5,2% do valor de SES - R$650.000,00), e foi aprovado conforme Deliberação 75. Somente após o projeto, vai ser feito o pleito para as obras. / O pleito de resíduos sólido (10% do total do recurso destinado ao munícipio) foi aprovado. / Para este cronograma, foi consideradouma obra de maior porte que contempla os 14 bairros.
- 287: 31/05/2019: Mônica informou que o processo licitatório será concluído dia 14/06/2019. / 01/07/2019: e-mail Luiz - No dia 28/06 eles protocolaram todos os documentos no Banco. Como o Luiz não conseguiu informar a data de conclusão do processo licitatório, foi considerada a mesma data da entrega dos documentos ao banco.
- 288: 12/04/2019: considerado 1 dia para apresentação dos documentos, pois foi acordado com o município. Não foi utilizada a premissa de 5 dias. / 31/05/2019: Mônica informou que o processo licitatório será apresentado ao banco no dia 24/06/2019. / 01/07/2019: e-mail Luiz - No dia 28/06 eles protocolaram todos os documentos no Banco.
- 303: Em 15/04: O pleito será enviado até o final de out/2019 o município enviará e será aprovado até o dia 30/11/2019
- 309: Em 15/04/2019: valor da obra igual 90% do teto menos valor do projeto (650 mil) - R$ 10.694.783,37 - 20 meses

| ID | WBS | Task | Type | Duration | Start | Finish | Predecessors | Complete | Remaining | Baseline start | Baseline finish | Baseline duration | Baseline 1 start | Baseline 1 finish | Total slack | Free slack | Constraint | Text1 | Text2 | Text3 | Text6 | Text7 | Text8 | Text12 | Text14 | Text16 | Text4 | Text5 | Text15 | Text17 | Text9 | Text18 |
| --- | --- | --- | --- | --- | --- | --- | --- | --- | --- | --- | --- | --- | --- | --- | --- | --- | --- | --- | --- | --- | --- | --- | --- | --- | --- | --- | --- | --- | --- | --- | --- | --- |
| 313 | 3.1.3.4.3 | **Pleito BAGRSOB01 - Viabilizar a solução consorciada, com objetivo de executar as obras para a implantação da Central de Tratamento de Resíduos – CTR Colatina** |  | 638d | 2019-03-14 A | 2021-10-05 |  | 5% | 606.1d | 2019-03-14 | 2021-10-05 | 638d | 2019-03-14 | 2021-09-16 | 513d |  |  | Verde | Verde | 8% | 60% | 60 | Compensatória | Vermelho | 5% | 3% |  |  |  |  |  |  |
| 314 | 3.1.3.4.3.1 | **Licitação da obra** |  | 114d | 2019-03-14 A | 2019-08-28 |  | 28% | 82.21d | 2019-03-14 | 2019-08-28 | 114d | 2019-03-14 | 2019-05-30 | 513d |  |  | Verde | Verde | 46% | 54% | 54 | Compensatória | Vermelho | 28% | 15% | 28 | 46 | 28 | 15 |  |  |
| 315 | 3.1.3.4.3.1.1 | Licitação da obra do Pleito BAGRSOB01 - Viabilizar a solução consorciada, com objetivo de executar as obras para a implantação da Central de Tratamento de Resíduos – CTR Colatina autorizada pelo banco | milestone | 0d | 2019-03-14 A | 2019-03-14 A |  | 100% |  | 2019-03-14 | 2019-03-14 | 0d | 2019-03-14 | 2019-03-14 |  |  | must start on 2019-03-14 | Verde | Verde | 100% | 100% | 100 | Compensatória | Verde | 100% | 100% | 100 | 100 | 100 | 100 | Banco |  |
| 316 | 3.1.3.4.3.1.2 | Licitar obra |  | 94d | 2019-03-15 A | 2019-07-30 | 315 | 32% | 63.6d | 2019-03-15 | 2019-07-30 | 94d | 2019-03-15 | 2019-05-10 | 513d | 0d |  | Verde | Verde | 56% | 55% | 55 | Compensatória | Vermelho | 56% | 31% | 32 | 56 | 56 | 31 | Município | Conforme agendado |
| 317 | 3.1.3.4.3.1.3 | Analisar e emitir resultado da licitação da obra |  | 15d | 2019-08-07 | 2019-08-28 | 316FS+5d |  |  | 2019-08-07 | 2019-08-28 | 15d | 2019-05-21 | 2019-05-30 | 513d | 0d |  | Verde | Verde | 0% | 0% |  | Compensatória | Verde | 0% | 0% |  |  |  |  | Banco | Critério FR |
| 318 | 3.1.3.4.3.1.4 | Licitação da obra do Pleito BAGRSOB01 - Viabilizar a solução consorciada, com objetivo de executar as obras para a implantação da Central de Tratamento de Resíduos – CTR Colatina concluída | milestone | 0d | 2019-08-28 | 2019-08-28 | 317 |  |  | 2019-08-28 | 2019-08-28 | 0d | 2019-05-30 | 2019-05-30 | 513d | 0d |  | Verde | Verde | 0% | 0% |  | Compensatória | Verde | 0% | 0% |  |  |  |  | Município |  |
| 319 | 3.1.3.4.3.2 | Executar obra |  | 249d | 2019-09-26 | 2020-09-25 | 318FS+20d |  |  | 2019-09-26 | 2020-09-25 | 249d | 2019-07-09 | 2021-03-09 | 513d | 0d |  | Verde | Verde | 0% | 0% |  | Compensatória | Verde | 0% | 0% |  |  |  |  | Município |  |
| 320 | 3.1.3.4.3.3 | Realizar processo de pré-operação |  | 250d | 2020-09-28 | 2021-09-28 | 319 |  |  | 2020-09-28 | 2021-09-28 | 250d | 2021-03-10 | 2021-09-09 | 513d | 0d |  | Verde | Verde | 0% | 0% |  | Compensatória | Verde | 0% | 0% |  |  |  |  | Município |  |
| 321 | 3.1.3.4.3.4 | Recurso da obra do Pleito BAGRSOB01 - Viabilizar a solução consorciada, com objetivo de executar as obras para a implantação da Central de Tratamento de Resíduos – CTR Colatina repassado | milestone | 0d | 2021-10-05 | 2021-10-05 | 320FS+5d |  |  | 2021-10-05 | 2021-10-05 | 0d | 2021-09-16 | 2021-09-16 | 513d | 0d |  | Verde | Verde | 0% | 0% |  | Compensatória | Verde | 0% | 0% |  |  |  |  | Banco |  |
| 322 | 3.1.3.4.3.5 | Pleito BAGRSOB01 - Viabilizar a solução consorciada, com objetivo de executar as obras para a implantação da Central de Tratamento de Resíduos – CTR Colatina de Baixo Guandu concluído | milestone | 0d | 2021-10-05 | 2021-10-05 | 321 |  |  | 2021-10-05 | 2021-10-05 | 0d | 2021-09-16 | 2021-09-16 | 513d | 155d |  | Verde | Verde | 0% | 0% |  | Compensatória | Verde | 0% | 0% |  |  |  |  | Município |  |
| 323 | 3.1.3.4.4 | Recursos de Baixo Guandu repassados | milestone | 0d | 2022-05-23 | 2022-05-23 | 301, 312, 322 |  |  | 2022-05-23 | 2022-05-23 | 0d | 2022-06-07 | 2022-06-07 | 358d |  |  | Verde | Verde | 0% | 0% |  | Compensatória | Verde | 0% | 0% |  |  |  |  | Banco |  |
| 324 | 3.1.3.5 | **Barra Longa** |  | 1181d | 2019-01-29 A | 2023-10-30 |  | 9% | 1075.71d | 2019-01-29 | 2023-10-30 | 1181d | 2019-01-29 | 2024-01-30 | 0d |  |  | Verde | Verde | 7% | 0% |  | Compensatória | Vermelho | 0% | 0% |  |  |  |  |  |  |
| 325 | 3.1.3.5.1 | **Pleito BALESPJ01 - Adequação de projeto de engenharia da ETE de Barra Longa** |  | 312d | 2019-01-29 A | 2020-05-05 |  | 19% | 253.85d | 2019-01-29 | 2020-05-05 | 312d | 2019-01-29 | 2019-11-26 | 295d |  |  | Verde | Verde | 26% | 56% | 56 | Compensatória | Vermelho | 9% | 5% | 12 | 26 |  |  |  |  |
| 326 | 3.1.3.5.1.1 | **Licitação do Projeto** |  | 105d | 2019-01-29 A | 2019-07-03 |  | 90% | 10.5d | 2019-01-29 | 2019-07-03 | 105d | 2019-01-29 | 2019-06-18 | 295d |  |  | Verde | Verde | 79% | 54% | 54 | Compensatória | Vermelho | 61% | 33% | 58 | 79 | 61 | 33 |  |  |
| 327 | 3.1.3.5.1.1.1 | Licitar Projeto |  | 91d | 2019-01-29 A | 2019-06-12 A | 3016FS+121d | 100% |  | 2019-01-29 | 2019-06-12 | 91d | 2019-01-29 | 2019-05-29 |  |  |  | Verde | Verde | 91% | 55% | 55 | Compensatória | Vermelho | 91% | 50% | 67 | 91 | 91 | 50 | Município | Conforme agendado |
| 328 | 3.1.3.5.1.1.2 | Analisar e emitir resultado da licitação do projeto |  | 14d | 2019-06-13 A | 2019-07-03 | 327 | 25% | 10.5d | 2019-06-13 | 2019-07-03 | 14d | 2019-05-30 | 2019-06-18 | 295d | 0d |  | Verde | Verde | 0% | 0% |  | Compensatória | Verde | 0% | 0% |  |  |  |  | Banco | Critério FR |
| 329 | 3.1.3.5.1.1.3 | Licitação do projeto do Pleito BALESPJ01 - Adequação de projeto de engenharia da ETE de Barra Longa concluída | milestone | 0d | 2019-07-03 | 2019-07-03 | 328 |  |  | 2019-07-03 | 2019-07-03 | 0d | 2019-06-18 | 2019-06-18 | 295d | 0d |  | Verde | Verde | 0% | 0% |  | Compensatória | Verde | 0% | 0% |  |  |  |  | Município |  |
| 330 | 3.1.3.5.1.2 | **Elaboração do Estudo de Concepção** |  | 85d | 2019-07-04 | 2019-10-31 |  |  |  | 2019-07-04 | 2019-10-31 | 85d |  |  | 295d |  |  | Verde | Verde | 0% | 0% |  | Compensatória | Verde | 0% | 0% |  |  |  |  |  |  |
| 331 | 3.1.3.5.1.2.1 | Elaborar estudo |  | 20d | 2019-07-04 | 2019-07-31 | 329 |  |  | 2019-07-04 | 2019-07-31 | 20d |  |  | 295d | 0d |  | Verde | Verde | 0% | 0% |  | Compensatória | Verde | 0% | 0% |  |  |  |  |  | Critério FR |
| 332 | 3.1.3.5.1.2.2 | Estudo de concepção do Pleito BALESPJ01 - Adequação de projeto de engenharia da ETE de Barra Longa apresentado ao banco | milestone | 0d | 2019-07-31 | 2019-07-31 | 331 |  |  | 2019-07-31 | 2019-07-31 | 0d |  |  | 295d | 0d |  | Verde | Verde | 0% | 0% |  | Compensatória | Verde | 0% | 0% |  |  |  |  |  |  |
| 333 | 3.1.3.5.1.2.3 | Analisar estudo |  | 60d | 2019-08-01 | 2019-10-24 | 332 |  |  | 2019-08-01 | 2019-10-24 | 60d |  |  | 295d | 0d |  | Verde | Verde | 0% | 0% |  | Compensatória | Verde | 0% | 0% |  |  |  |  |  | Critério FR |
| 334 | 3.1.3.5.1.2.4 | Estudo de concepção do Pleito BALESPJ01 - Adequação de projeto de engenharia da ETE de Barra Longa aprovado | milestone | 0d | 2019-10-24 | 2019-10-24 | 333 |  |  | 2019-10-24 | 2019-10-24 | 0d |  |  | 407d | 0d |  | Verde | Verde | 0% | 0% |  | Compensatória | Verde | 0% | 0% |  |  |  |  |  |  |
| 335 | 3.1.3.5.1.2.5 | Recurso do estudo de concepção do Pleito BALESPJ01 - Adequação de projeto de engenharia da ETE de Barra Longa repassado | milestone | 0d | 2019-10-31 | 2019-10-31 | 334FS+5d |  |  | 2019-10-31 | 2019-10-31 | 0d |  |  | 407d | 15d |  | Verde | Verde | 0% | 0% |  | Compensatória | Verde | 0% | 0% |  |  |  |  |  |  |
| 336 | 3.1.3.5.1.3 | **Elaboração do Projeto Básico** |  | 85d | 2019-08-01 | 2019-11-29 |  |  |  | 2019-08-01 | 2019-11-29 | 85d |  |  | 377d |  |  | Verde | Verde | 0% | 0% |  | Compensatória | Verde | 0% | 0% |  |  |  |  |  |  |
| 337 | 3.1.3.5.1.3.1 | Elaborar projeto básico |  | 20d | 2019-08-01 | 2019-08-29 | 331 |  |  | 2019-08-01 | 2019-08-29 | 20d |  |  | 377d | 0d |  | Verde | Verde | 0% | 0% |  | Compensatória | Verde | 0% | 0% |  |  |  |  |  | Critério FR |
| 338 | 3.1.3.5.1.3.2 | Projeto básico do Pleito BALESPJ01 - Adequação de projeto de engenharia da ETE de Barra Longa apresentado ao banco | milestone | 0d | 2019-08-29 | 2019-08-29 | 337 |  |  | 2019-08-29 | 2019-08-29 | 0d |  |  | 392d | 0d |  | Verde | Verde | 0% | 0% |  | Compensatória | Verde | 0% | 0% |  |  |  |  |  |  |
| 339 | 3.1.3.5.1.3.3 | Analisar projeto básico |  | 60d | 2019-08-30 | 2019-11-22 | 338 |  |  | 2019-08-30 | 2019-11-22 | 60d |  |  | 392d | 0d |  | Verde | Verde | 0% | 0% |  | Compensatória | Verde | 0% | 0% |  |  |  |  |  | Critério FR |
| 340 | 3.1.3.5.1.3.4 | Projeto básico do Pleito BALESPJ01 - Adequação de projeto de engenharia da ETE de Barra Longa aprovado | milestone | 0d | 2019-11-22 | 2019-11-22 | 335, 339 |  |  | 2019-11-22 | 2019-11-22 | 0d |  |  | 392d | 0d |  | Verde | Verde | 0% | 0% |  | Compensatória | Verde | 0% | 0% |  |  |  |  |  |  |
| 341 | 3.1.3.5.1.3.5 | Recurso do projeto básico do Pleito BALESPJ01 - Adequação de projeto de engenharia da ETE de Barra Longa repassado | milestone | 0d | 2019-11-29 | 2019-11-29 | 340FS+5d |  |  | 2019-11-29 | 2019-11-29 | 0d |  |  | 392d | 97d |  | Verde | Verde | 0% | 0% |  | Compensatória | Verde | 0% | 0% |  |  |  |  |  |  |

Notes:
- 315: 24/04/2019: considerado a data de início do processo licitatório do cronograma pactuado junto ao CONDOESTE como data de autorização da licitação pelo banco
- 316: 31/05/2019: conforme e-mail da Mônica, algumas empresas entraram com recurso e por isso os envelopes de preço ainda não foram abertos. Considerado mais um mês de prazo. / 03/06/2019: consórcio falou que termina a licitação dia 30/07/2019 / 01/07/2019: e-mail Luiz - Os envelopes serão abertos no dia 03/07. Caso não haja imprevisto e nenhuma empresa entre com recurso, o prazo de término continuará dia 30/07.
- 319: 24/09/2019: o valor da obra do CONDOESTE é de R$ 10,9 milhões - 20 meses / 06/06/2019: o CONDOESTE prevê 1 ano para a execução da obra
- 320: 06/06/2019: o CONDOESTE informou que está prevendo 1 ano de operação assistida.
- 323: Valor de recurso destinado ao munícipio: R$12.605.314,86
- 324: Barra Longa teve 100% dos pleitos de Esgotamento Sanitário aprovado (R$7.825.714,29), conforme Deliberação 75. / O município teve o pleito de resíduos sólidos negado (R$869.523,81, equivalente a 10% do total do recurso). / Munícipio vai solicitar mudança de pleito, vai arcar com recurso próprio o projeto e vão solicitar o valor para obra.
- 327: 25/04/2019: município não entregou processo licitatório ao banco conforme planilha controle gerencial Renova / 28/05/2019: município enviará processo licitatório ao banco no dia 12/06/2019. / 13/06/2019: município protocolou processo licitatório no banco dia 12/06/2019. Porém faltou a a declaração de atendimento a lei 8.666/93.
- 328: 13/06/2019: Processo encaminhado para análise do Jurídico, aguardando a declaração de atendimento a lei 8.666/93 no dia 13/06/2019 conforme planilha Controle Gerencial Renova. / 01/07/2019: e-mail Lauro - O município informou que não encaminhou a declaração de atendimento a lei 8666/93 devido a licença médica do procurador municipal. Em contato por e-mail foi informado que o documento será enviado até 05/07/2019.

| ID | WBS | Task | Type | Duration | Start | Finish | Predecessors | Complete | Remaining | Baseline start | Baseline finish | Baseline duration | Baseline 1 start | Baseline 1 finish | Total slack | Free slack | Constraint | Text1 | Text2 | Text3 | Text6 | Text8 | Text12 | Text14 | Text16 | Text9 | Text18 | Text5 | Text4 | Text15 | Text7 | Text17 |
| --- | --- | --- | --- | --- | --- | --- | --- | --- | --- | --- | --- | --- | --- | --- | --- | --- | --- | --- | --- | --- | --- | --- | --- | --- | --- | --- | --- | --- | --- | --- | --- | --- |
| 342 | 3.1.3.5.1.4 | **Elaboração do Projeto Executivo** |  | 167d | 2019-08-30 | 2020-05-05 |  |  |  | 2019-08-30 | 2020-05-05 | 167d | 2019-06-19 | 2019-11-26 | 295d |  |  | Verde | Verde | 0% | 0% | Compensatória | Verde | 0% | 0% |  |  |  |  |  |  |  |
| 343 | 3.1.3.5.1.4.1 | Elaborar projeto executivo |  | 20d | 2019-08-30 | 2019-09-26 | 337 |  |  | 2019-08-30 | 2019-09-26 | 20d | 2019-06-19 | 2019-08-16 | 377d | 0d |  | Verde | Verde | 0% | 0% | Compensatória | Verde | 0% | 0% | Município | Critério FR |  |  |  |  |  |
| 344 | 3.1.3.5.1.4.2 | Projeto executivo do Pleito BALESPJ01 - Adequação de projeto de engenharia da ETE de Barra Longa apresentado ao banco | milestone | 0d | 2019-09-26 | 2019-09-26 | 343 |  |  | 2019-09-26 | 2019-09-26 | 0d |  |  | 377d | 0d |  | Verde | Verde | 0% | 0% | Compensatória | Verde | 0% | 0% |  |  |  |  |  |  |  |
| 345 | 3.1.3.5.1.4.3 | Analisar projeto executivo |  | 60d | 2019-09-27 | 2019-12-23 | 344 |  |  | 2019-09-27 | 2019-12-23 | 60d | 2019-08-19 | 2019-09-17 | 377d | 82d |  | Verde | Verde | 0% | 0% | Compensatória | Verde | 0% | 0% | Banco | Critério FR |  |  |  |  |  |
| 346 | 3.1.3.5.1.4.4 | Projeto executivo do Pleito BALESPJ01 - Adequação de projeto de engenharia da ETE de Barra Longa aprovado | milestone | 0d | 2020-04-27 | 2020-04-27 | 348, 341, 345 |  |  | 2020-04-27 | 2020-04-27 | 0d | 2019-11-19 | 2019-11-19 | 295d | 0d |  | Verde | Verde | 0% | 0% | Compensatória | Verde | 0% | 0% | Município |  |  |  |  |  |  |
| 347 | 3.1.3.5.1.4.5 | Recurso do projeto executivo do Pleito BALESPJ01 - Adequação de projeto de engenharia da ETE de Barra Longa repassado | milestone | 0d | 2020-05-05 | 2020-05-05 | 346FS+5d |  |  | 2020-05-05 | 2020-05-05 | 0d | 2019-11-26 | 2019-11-26 | 295d | 0d |  | Verde | Verde | 0% | 0% | Compensatória | Verde | 0% | 0% | Banco |  |  |  |  |  |  |
| 348 | 3.1.3.5.1.5 | Realizar Licenciamento Ambiental |  | 162d | 2019-08-30 | 2020-04-27 | 333FS-40d |  |  | 2019-08-30 | 2020-04-27 | 162d | 2019-01-29 | 2019-09-23 | 295d | 0d |  | Verde | Verde | 0% | 0% | Compensatória | Verde | 0% | 0% | Município |  |  |  |  |  |  |
| 349 | 3.1.3.5.1.6 | Pleito BALESPJ01 - Adequação de projeto de engenharia da ETE de Barra Longa concluído | milestone | 0d | 2020-05-05 | 2020-05-05 | 347 |  |  | 2020-05-05 | 2020-05-05 | 0d | 2019-11-26 | 2019-11-26 | 295d | 0d |  | Verde | Verde | 0% | 0% | Compensatória | Verde | 0% | 0% | Município |  |  |  |  |  |  |
| 350 | 3.1.3.5.2 | **Pleito BALESOB01 - Substituição de rede de esgoto incluindo execução de rede inteceptora e contrução da ETE** |  | 574d | 2020-05-05 | 2022-08-22 |  |  |  | 2020-05-05 | 2022-08-22 | 574d | 2019-11-26 | 2022-03-30 | 295d |  |  | Verde | Verde | 0% | 0% | Compensatória | Verde | 0% | 0% |  |  |  |  |  |  |  |
| 351 | 3.1.3.5.2.1 | **Licitação da obra** |  | 55d | 2020-05-05 | 2020-07-22 |  |  |  | 2020-05-05 | 2020-07-22 | 55d | 2019-11-26 | 2020-02-17 | 295d |  |  | Verde | Verde | 0% | 0% | Compensatória | Verde | 0% | 0% |  |  |  |  |  |  |  |
| 352 | 3.1.3.5.2.1.1 | Licitação da obra do Pleito BALESOB01 - Substituição de rede de esgoto incluindo execução de rede inteceptora e contrução da ETE autorizada pelo banco | milestone | 0d | 2020-05-05 | 2020-05-05 | 349 |  |  | 2020-05-05 | 2020-05-05 | 0d | 2019-11-26 | 2019-11-26 | 295d | 0d |  | Verde | Verde | 0% | 0% | Compensatória | Verde | 0% | 0% | Banco |  |  |  |  |  |  |
| 353 | 3.1.3.5.2.1.2 | Licitar obra |  | 41d | 2020-05-06 | 2020-07-02 | 352 |  |  | 2020-05-06 | 2020-07-02 | 41d | 2019-11-27 | 2020-01-28 | 295d | 0d |  | Verde | Verde | 0% | 0% | Compensatória | Verde | 0% | 0% | Município |  |  |  |  |  |  |
| 354 | 3.1.3.5.2.1.3 | Analisar e emitir resultado da licitação da obra |  | 14d | 2020-07-03 | 2020-07-22 | 353 |  |  | 2020-07-03 | 2020-07-22 | 14d | 2020-01-29 | 2020-02-17 | 295d | 0d |  | Verde | Verde | 0% | 0% | Compensatória | Verde | 0% | 0% | Banco |  |  |  |  |  |  |
| 355 | 3.1.3.5.2.1.4 | Licitação da obra do Pleito BALESOB01 - Substituição de rede de esgoto incluindo execução de rede inteceptora e contrução da ETE concluída | milestone | 0d | 2020-07-22 | 2020-07-22 | 354 |  |  | 2020-07-22 | 2020-07-22 | 0d | 2020-02-17 | 2020-02-17 | 295d | 0d |  | Verde | Verde | 0% | 0% | Compensatória | Verde | 0% | 0% | Município |  |  |  |  |  |  |
| 356 | 3.1.3.5.2.2 | Executar obra |  | 377d | 2020-08-17 | 2022-02-17 | 355FS+17d |  |  | 2020-08-17 | 2022-02-17 | 377d | 2020-02-20 | 2021-09-15 | 295d | 0d |  | Verde | Verde | 0% | 0% | Compensatória | Verde | 0% | 0% | Município |  |  |  |  |  |  |
| 357 | 3.1.3.5.2.3 | Realizar processo de pré-operação |  | 120d | 2022-02-18 | 2022-08-12 | 356 |  |  | 2022-02-18 | 2022-08-12 | 120d | 2021-09-16 | 2022-03-23 | 295d | 0d |  | Verde | Verde | 0% | 0% | Compensatória | Verde | 0% | 0% | Município |  |  |  |  |  |  |
| 358 | 3.1.3.5.2.4 | Recurso da obra do Pleito BALESOB01 - Substituição de rede de esgoto incluindo execução de rede inteceptora e contrução da ETE repassado | milestone | 0d | 2022-08-22 | 2022-08-22 | 357FS+5d |  |  | 2022-08-22 | 2022-08-22 | 0d | 2022-03-30 | 2022-03-30 | 295d | 0d |  | Verde | Verde | 0% | 0% | Compensatória | Verde | 0% | 0% | Banco |  |  |  |  |  |  |
| 359 | 3.1.3.5.2.5 | Pleito BALESOB01 - Substituição de rede de esgoto incluindo execução de rede inteceptora e contrução da ETE de Barra Longa concluído | milestone | 0d | 2022-08-22 | 2022-08-22 | 358 |  |  | 2022-08-22 | 2022-08-22 | 0d | 2022-03-30 | 2022-03-30 | 295d |  |  | Verde | Verde | 0% | 0% | Compensatória | Verde | 0% | 0% | Município |  |  |  |  |  |  |
| 360 | 3.1.3.5.3 | **Pleito BALRSPM01 - Elaboração do Plano Intermunicipal de Gestão Integrada de Resíduos Sólidos para os Municípios associados ao Consórcio Intermunicipal Multissetorial do Vale do Piranga (PIGIRS/CIMVALPI),** |  | 1082d | 2019-06-25 A | 2023-10-30 |  |  | 1082d | 2019-08-30 | 2023-10-30 | 1035d | 2019-08-30 | 2024-01-30 | 0d |  |  | Verde | Verde | 0% | 0% | Compensatória | Verde | 0% | 0% |  |  |  |  |  |  |  |
| 361 | 3.1.3.5.3.1 | Pleito BALRSPM01 - Elaboração do Plano Intermunicipal de Gestão Integrada de Resíduos Sólidos para os Municípios associados ao Consórcio Intermunicipal Multissetorial do Vale do Piranga (PIGIRS/CIMVALPI), aprovado pelo CIF | milestone | 0d | 2019-06-25 A | 2019-06-25 A | 3052FS+131d | 100% |  | 2019-08-30 | 2019-08-30 | 0d | 2019-08-30 | 2019-08-30 |  |  |  | Verde | Verde | 0% | 0% | Compensatória | Verde | 0% | 0% | CT/CIF |  |  |  |  |  |  |
| 362 | 3.1.3.5.3.2 | Iniciar serviço/projeto/obra do pleito de Barra Longa de Resíduos Sólidos a definir |  | 1d | 2019-09-02 | 2019-09-02 | 361FS+47d |  |  | 2019-09-02 | 2019-09-02 | 1d | 2019-09-02 | 2019-09-02 | 0d |  |  | Verde | Verde | 0% | 0% | Compensatória | Verde | 0% | 0% | Município | Critério FR |  |  |  |  |  |
| 363 | 3.1.3.5.3.3 | Pleito BALRSPM01 - Elaboração do Plano Intermunicipal de Gestão Integrada de Resíduos Sólidos para os Municípios associados ao Consórcio Intermunicipal Multissetorial do Vale do Piranga (PIGIRS/CIMVALPI) concluído | milestone | 0d | 2023-10-30 | 2023-10-30 | 362FS+1034d |  |  | 2023-10-30 | 2023-10-30 | 0d | 2024-01-30 | 2024-01-30 | 0d |  |  | Verde | Verde | 0% | 0% | Compensatória | Verde | 0% | 0% | Município |  |  |  |  |  |  |
| 364 | 3.1.3.5.4 | Recursos de Barra Longa repassados | milestone | 0d | 2023-10-30 | 2023-10-30 | 349, 359, 363 |  |  | 2023-10-30 | 2023-10-30 | 0d | 2024-01-30 | 2024-01-30 | 0d |  |  | Verde | Verde | 0% | 0% | Compensatória | Verde | 0% | 0% | Banco |  |  |  |  |  |  |
| 365 | 3.1.3.6 | **Belo Oriente** |  | 899d | 2019-03-21 A | 2022-10-28 |  | 3% | 871.68d | 2019-03-21 | 2022-10-28 | 899d | 2019-03-21 | 2025-02-25 | 248d |  |  | Verde | Verde | 5% | 0% | Compensatória | Vermelho | 0% | 0% |  |  |  |  |  |  |  |
| 366 | 3.1.3.6.1 | **Pleito BEOESPJ01 - Elaboração de projetos de sistema de esgotamento sanitário da sede do município e distritos de Bom Jesus do Bagre e São Sebastião de Braúnas** |  | 343d | 2019-03-21 A | 2020-08-05 |  | 7% | 318.31d | 2019-03-21 | 2020-08-05 | 343d | 2019-03-21 | 2020-07-09 | 804d |  |  | Verde | Verde | 14% | 0% | Compensatória | Vermelho | 2% | 0% |  |  | 14 |  |  |  |  |
| 367 | 3.1.3.6.1.1 | **Licitação do Projeto** |  | 152d | 2019-03-21 A | 2019-10-25 |  | 23% | 117.62d | 2019-03-21 | 2019-10-25 | 152d | 2019-03-21 | 2019-06-17 | 804d |  |  | Verde | Verde | 32% | 0% | Compensatória | Vermelho | 24% | 0% |  |  | 32 | 18 | 24 |  |  |
| 368 | 3.1.3.6.1.1.1 | Licitação do projeto do Pleito BEOESPJ01 - Elaboração de projetos de sistema de esgotamento sanitário da sede do município e distritos de Bom Jesus do Bagre e São Sebastião de Braúnas autorizada pelo banco | milestone | 0d | 2019-03-21 A | 2019-03-21 A |  | 100% |  | 2019-03-21 | 2019-03-21 | 0d | 2019-03-21 | 2019-03-21 |  |  | start no earlier than 2019-03-21 | Verde | Verde | 100% | 100% | Compensatória | Verde | 100% | 100% | Banco |  | 100 | 100 | 100 | 100 | 100 |
| 369 | 3.1.3.6.1.1.2 | Licitar projeto |  | 133d | 2019-03-21 A | 2019-09-30 | 368 | 25% | 99.75d | 2019-03-21 | 2019-09-30 | 133d | 2019-03-21 | 2019-05-21 | 804d | 0d |  | Verde | Verde | 36% | 0% | Compensatória | Vermelho | 36% | 0% | Município | Conforme agendado | 36 | 20 | 36 |  |  |
| 370 | 3.1.3.6.1.1.3 | Documentação de licitação do projeto do Pleito BEOESPJ01 - Elaboração de projetos de sistema de esgotamento sanitário da sede do município e distritos de Bom Jesus do Bagre e São Sebastião de Braúnas apresentada ao banco | milestone | 0d | 2019-10-07 | 2019-10-07 | 369FS+5d |  |  | 2019-10-07 | 2019-10-07 | 0d | 2019-05-28 | 2019-05-28 | 804d | 0d |  | Verde | Verde | 0% | 0% | Compensatória | Verde | 0% | 0% | Município |  |  |  |  |  |  |
| 371 | 3.1.3.6.1.1.4 | Analisar e emitir resultado da análise de licitação do projeto |  | 14d | 2019-10-08 | 2019-10-25 | 370 |  |  | 2019-10-08 | 2019-10-25 | 14d | 2019-05-29 | 2019-06-17 | 804d | 0d |  | Verde | Verde | 0% | 0% | Compensatória | Verde | 0% | 0% | Banco | Critério FR |  |  |  |  |  |
| 372 | 3.1.3.6.1.1.5 | Licitação do projeto do Pleito BEOESPJ01 - Elaboração de projetos de sistema de esgotamento sanitário da sede do município e distritos de Bom Jesus do Bagre e São Sebastião de Braúnas concluída | milestone | 0d | 2019-10-25 | 2019-10-25 | 371 |  |  | 2019-10-25 | 2019-10-25 | 0d | 2019-06-17 | 2019-06-17 | 804d | 0d |  | Verde | Verde | 0% | 0% | Compensatória | Verde | 0% | 0% | Município |  |  |  |  |  |  |

Notes:
- 343: 24/05/2019: município pactuou com a Renova 2 meses para adequar projeto executivo
- 348: 28/05/2019: Licenciamento será realizado pela empresa que realizará o projeto
- 353: 24/05/2019: município pactuou com a Renova 2 meses para licitação da obra
- 356: Em 15/04/2019: valor da obra 7 milhões, considerada a premissa da Helena de 18 meses
- 361: Em 24/09/2018: premissa conforme NT 33 que pleito será aprovado em agosto de 2019. Município precisa elaborar e protocolar pleito em junho ou julho.
- 364: Valor de recurso destinado ao munícipio: R$8.695.238,10
- 365: Belo Oriente teve 100% dos pleitos de Esgotamento Sanitário Aprovado (R$9.926.685,00), conforme Deliberação 75. / O município teve o pleito de resíduos sólidos negado (R$1.102.965,05, equivalente a 10% do total do recurso,). / Belo Oriente solicitou mudança de pleito e foi autorizado pelo CIF na NT21. / ·Equívoco na exclusão do distrito de Cachoeira Escura do pleito de obras, solicita-se voltar com o distrito. / Aderiu à ata de registro de preço.
- 368: 25/04/2019: em 21/03/2019 o banco informou que o processo licitatório está desconforme e o município irá reiniciar o processo.
- 369: 30/05/2019: município solicitou mais 4 meses para conclusão do processo licitatório / 01/07/2019: e-mail Claudia - Agendada uma reunião no dia 02/07/2019 para apoio na elaboração no termo de referência.

| ID | WBS | Task | Type | Duration | Start | Finish | Predecessors | Baseline start | Baseline finish | Baseline duration | Baseline 1 start | Baseline 1 finish | Total slack | Free slack | Text1 | Text2 | Text3 | Text6 | Text8 | Text12 | Text14 | Text16 | Text18 | Text9 |
| --- | --- | --- | --- | --- | --- | --- | --- | --- | --- | --- | --- | --- | --- | --- | --- | --- | --- | --- | --- | --- | --- | --- | --- | --- |
| 373 | 3.1.3.6.1.2 | **Elaboração do Estudo de Concepção** |  | 105d | 2019-10-28 | 2020-04-01 |  | 2019-10-28 | 2020-04-01 | 105d |  |  | 804d |  | Verde | Verde | 0% | 0% | Compensatória | Verde | 0% | 0% |  |  |
| 374 | 3.1.3.6.1.2.1 | Elaborar estudo |  | 40d | 2019-10-28 | 2019-12-26 | 372 | 2019-10-28 | 2019-12-26 | 40d |  |  | 804d | 0d | Verde | Verde | 0% | 0% | Compensatória | Verde | 0% | 0% | Critério FR |  |
| 375 | 3.1.3.6.1.2.2 | Estudo de concepção do Pleito BEOESPJ01 - Elaboração de projetos de sistema de esgotamento sanitário da sede do município e distritos de Bom Jesus do Bagre e São Sebastião de Braúnas apresentado ao banco | milestone | 0d | 2019-12-26 | 2019-12-26 | 374 | 2019-12-26 | 2019-12-26 | 0d |  |  | 804d | 0d | Verde | Verde | 0% | 0% | Compensatória | Verde | 0% | 0% |  |  |
| 376 | 3.1.3.6.1.2.3 | Analisar estudo |  | 60d | 2019-12-27 | 2020-03-25 | 375 | 2019-12-27 | 2020-03-25 | 60d |  |  | 880d | 0d | Verde | Verde | 0% | 0% | Compensatória | Verde | 0% | 0% |  |  |
| 377 | 3.1.3.6.1.2.4 | Estudo de concepção do Pleito BEOESPJ01 - Elaboração de projetos de sistema de esgotamento sanitário da sede do município e distritos de Bom Jesus do Bagre e São Sebastião de Braúnas concluído | milestone | 0d | 2020-03-25 | 2020-03-25 | 376 | 2020-03-25 | 2020-03-25 | 0d |  |  | 880d | 0d | Verde | Verde | 0% | 0% | Compensatória | Verde | 0% | 0% |  |  |
| 378 | 3.1.3.6.1.2.5 | Recurso do estudo de concepção do Pleito BEOESPJ01 - Elaboração de projetos de sistema de esgotamento sanitário da sede do município e distritos de Bom Jesus do Bagre e São Sebastião de Braúnas repassado | milestone | 0d | 2020-04-01 | 2020-04-01 | 377FS+5d | 2020-04-01 | 2020-04-01 | 0d |  |  | 880d | 44d | Verde | Verde | 0% | 0% | Compensatória | Verde | 0% | 0% |  |  |
| 379 | 3.1.3.6.1.3 | **Elaboração do Projeto Básico** |  | 114d | 2019-12-27 | 2020-06-15 |  | 2019-12-27 | 2020-06-15 | 114d | 2019-06-18 | 2019-11-25 | 804d |  | Verde | Verde | 0% | 0% | Compensatória | Verde | 0% | 0% |  |  |
| 380 | 3.1.3.6.1.3.1 | Elaborar Projeto Básico |  | 40d | 2019-12-27 | 2020-02-21 | 375 | 2019-12-27 | 2020-02-21 | 40d | 2019-06-18 | 2019-08-19 | 804d | 0d | Verde | Verde | 0% | 0% | Compensatória | Verde | 0% | 0% |  | Município |
| 381 | 3.1.3.6.1.3.2 | Projeto básico do Pleito BEOESPJ01 - Elaboração de projetos de sistema de esgotamento sanitário da sede do município e distritos de Bom Jesus do Bagre e São Sebastião de Braúnas apresentado ao banco | milestone | 0d | 2020-02-21 | 2020-02-21 | 380 | 2020-02-21 | 2020-02-21 | 0d | 2019-08-19 | 2019-08-19 | 836d | 0d | Verde | Verde | 0% | 0% | Compensatória | Verde | 0% | 0% |  | Município |
| 382 | 3.1.3.6.1.3.3 | Analisar Projeto Básico |  | 69d | 2020-02-27 | 2020-06-05 | 381 | 2020-02-27 | 2020-06-05 | 69d | 2019-08-20 | 2019-09-20 | 836d | 0d | Verde | Verde | 0% | 0% | Compensatória | Verde | 0% | 0% |  | Banco |
| 383 | 3.1.3.6.1.3.4 | Projeto básico do Pleito BEOESPJ01 - Elaboração de projetos de sistema de esgotamento sanitário da sede do município e distritos de Bom Jesus do Bagre e São Sebastião de Braúnas concluído | milestone | 0d | 2020-06-05 | 2020-06-05 | 378, 382 | 2020-06-05 | 2020-06-05 | 0d | 2019-11-25 | 2019-11-25 | 836d | 0d | Verde | Verde | 0% | 0% | Compensatória | Verde | 0% | 0% |  | Município |
| 384 | 3.1.3.6.1.3.5 | Recurso do projeto básico do Pleito BEOESPJ01 - Elaboração de projetos de sistema de esgotamento sanitário da sede do município e distritos de Bom Jesus do Bagre e São Sebastião de Braúnas repassado | milestone | 0d | 2020-06-15 | 2020-06-15 | 383FS+5d | 2020-06-15 | 2020-06-15 | 0d | 2019-11-25 | 2019-11-25 | 836d | 32d | Verde | Verde | 0% | 0% | Compensatória | Verde | 0% | 0% |  | Banco |
| 385 | 3.1.3.6.1.4 | **Elaboração do Projeto Executivo** |  | 111d | 2020-02-27 | 2020-08-05 |  | 2020-02-27 | 2020-08-05 | 111d | 2019-11-26 | 2020-07-09 | 804d |  | Verde | Verde | 0% | 0% | Compensatória | Verde | 0% | 0% |  |  |
| 386 | 3.1.3.6.1.4.1 | Elaborar Projeto Executivo |  | 40d | 2020-02-27 | 2020-04-24 | 380 | 2020-02-27 | 2020-04-24 | 40d | 2019-11-26 | 2020-04-02 | 804d | 0d | Verde | Verde | 0% | 0% | Compensatória | Verde | 0% | 0% |  | Município |
| 387 | 3.1.3.6.1.4.2 | Projeto executivo do Pleito BEOESPJ01 - Elaboração de projetos de sistema de esgotamento sanitário da sede do município e distritos de Bom Jesus do Bagre e São Sebastião de Braúnas apresentado ao banco | milestone | 0d | 2020-04-24 | 2020-04-24 | 386 | 2020-04-24 | 2020-04-24 | 0d | 2020-04-02 | 2020-04-02 | 804d | 0d | Verde | Verde | 0% | 0% | Compensatória | Verde | 0% | 0% |  | Município |
| 388 | 3.1.3.6.1.4.3 | Analisar projeto executivo |  | 66d | 2020-04-27 | 2020-07-29 | 387 | 2020-04-27 | 2020-07-29 | 66d | 2020-04-03 | 2020-05-07 | 804d | 0d | Verde | Verde | 0% | 0% | Compensatória | Verde | 0% | 0% |  | Banco |
| 389 | 3.1.3.6.1.4.4 | Projeto executivo do Pleito BEOESPJ01 - Elaboração de projetos de sistema de esgotamento sanitário da sede do município e distritos de Bom Jesus do Bagre e São Sebastião de Braúnas concluído | milestone | 0d | 2020-07-29 | 2020-07-29 | 384, 388 | 2020-07-29 | 2020-07-29 | 0d | 2020-07-09 | 2020-07-09 | 804d | 0d | Verde | Verde | 0% | 0% | Compensatória | Verde | 0% | 0% |  | Município |
| 390 | 3.1.3.6.1.4.5 | Recurso do projeto executivo do Pleito BEOESPJ01 - Elaboração de projetos de sistema de esgotamento sanitário da sede do município e distritos de Bom Jesus do Bagre e São Sebastião de Braúnas repassado | milestone | 0d | 2020-08-05 | 2020-08-05 | 389FS+5d | 2020-08-05 | 2020-08-05 | 0d | 2020-07-09 | 2020-07-09 | 804d | 0d | Verde | Verde | 0% | 0% | Compensatória | Verde | 0% | 0% |  | Banco |
| 391 | 3.1.3.6.1.5 | Pleito BEOESPJ01 - Elaboração de projetos de sistema de esgotamento sanitário da sede do município e distritos de Bom Jesus do Bagre e São Sebastião de Braúnas de Belo Oriente concluído | milestone | 0d | 2020-08-05 | 2020-08-05 | 390 | 2020-08-05 | 2020-08-05 | 0d | 2020-07-09 | 2020-07-09 | 804d | 556d | Verde | Verde | 0% | 0% | Compensatória | Verde | 0% | 0% |  | Município |
| 392 | 3.1.3.6.2 | **Pleito BEOESOB01 - Implantação de rede e interceptor de esgotamento sanitário da sede** |  | 1d | 2019-07-31 | 2019-07-31 |  | 2019-07-31 | 2019-07-31 | 1d | 2019-05-31 | 2019-05-31 | 1056d |  | Verde | Verde | 0% | 0% | Compensatória | Verde | 0% | 0% |  |  |
| 393 | 3.1.3.6.2.1 | Avaliar cancelamento do pleito BEOESOB01 |  | 1d | 2019-07-31 | 2019-07-31 | 3052FS+156d | 2019-07-31 | 2019-07-31 | 1d | 2019-05-31 | 2019-05-31 | 1056d | 0d | Verde | Verde | 0% | 0% | Compensatória | Verde | 0% | 0% | Critério FR | Município |
| 394 | 3.1.3.6.2.2 | Pleito BEOESOB01 - Implantação de rede e interceptor de esgotamento sanitário da sede concluído | milestone | 0d | 2019-07-31 | 2019-07-31 | 393 | 2019-07-31 | 2019-07-31 | 0d | 2019-05-31 | 2019-05-31 | 1056d | 808d | Verde | Verde | 0% | 0% | Compensatória | Verde | 0% | 0% |  | Município |
| 395 | 3.1.3.6.3 | **Pleito BEOESOB02 - Ampliação e reestruturação de redes coletoras no município e implantação do programa caça esgoto** |  | 1d | 2019-07-31 | 2019-07-31 |  | 2019-07-31 | 2019-07-31 | 1d | 2019-06-03 | 2019-06-03 | 1056d |  | Verde | Verde | 0% | 0% | Compensatória | Verde | 0% | 0% |  |  |
| 396 | 3.1.3.6.3.1 | Avaliar cancelamento do pleito BEOESOB02 |  | 1d | 2019-07-31 | 2019-07-31 | 3052FS+156d | 2019-07-31 | 2019-07-31 | 1d | 2019-06-03 | 2019-06-03 | 1056d | 0d | Verde | Verde | 0% | 0% | Compensatória | Verde | 0% | 0% | Critério FR | Município |
| 397 | 3.1.3.6.3.2 | Pleito BEOESOB02 - Ampliação e reestruturação de redes coletoras no município e implantação do programa caça esgoto concluído | milestone | 0d | 2019-07-31 | 2019-07-31 | 396 | 2019-07-31 | 2019-07-31 | 0d | 2019-06-03 | 2019-06-03 | 1056d | 808d | Verde | Verde | 0% | 0% | Compensatória | Verde | 0% | 0% |  | Município |

Notes:
- 374: 30/05/2019: município vai pedir no TR 2 meses para cada etapa do projeto
- 380: 30/05/2019: município vai pedir no TR 2 meses para cada etapa do projeto
- 386: 30/05/2019: município vai pedir no TR 2 meses para cada etapa do projeto
- 393: Em 25/04/2019: município informou que vai pedir o cancelamento do pleito da sede e manter apenas Cachoeira Escura. Foi considerado que o pleito será aprovado em 31/05/2019 no próximo CIF. / 30/05/2019: pleito não foi analisado no CIF de maio.
- 396: Em 25/04/2019: município informou que vai pedir o cancelamento do pleito da sede e manter apenas Cachoeira Escura. Foi considerado que o pleito será aprovado em 31/05/2019 no próximo CIF. / 30/05/2019: pleito não foi analisado no CIF de maio.

| ID | WBS | Task | Type | Duration | Start | Finish | Predecessors | Complete | Remaining | Baseline start | Baseline finish | Baseline duration | Baseline 1 start | Baseline 1 finish | Total slack | Free slack | Text1 | Text2 | Text3 | Text6 | Text8 | Text12 | Text14 | Text16 | Text9 | Text18 |
| --- | --- | --- | --- | --- | --- | --- | --- | --- | --- | --- | --- | --- | --- | --- | --- | --- | --- | --- | --- | --- | --- | --- | --- | --- | --- | --- |
| 398 | 3.1.3.6.4 | **Pleito BEOESOB04 - Implantação do SES na sede e distritos de São Sebatião de Braúnas e de Perpétuo Socorro (Cachoeira Escura)** |  | 637d | 2019-06-13 A | 2022-01-04 |  |  | 637d | 2019-06-13 | 2022-01-04 | 637d | 2019-05-31 | 2022-02-11 | 452d |  | Verde | Verde | 0% | 0% | Compensatória | Verde | 0% | 0% |  |  |
| 399 | 3.1.3.6.4.1 | Alteração do Pleito BEOESOB04 - Implantação do SES na sede e distritos de São Sebatião de Braúnas e de Perpétuo Socorro (Cachoeira Escura) aprovada | milestone | 0d | 2019-07-31 | 2019-07-31 | 3052FS+157d |  |  | 2019-07-31 | 2019-07-31 | 0d | 2019-05-31 | 2019-05-31 | 452d | 0d | Verde | Verde | 0% | 0% | Compensatória | Verde | 0% | 0% | CT/CIF |  |
| 400 | 3.1.3.6.4.2 | **Aprovação do Estudo de Concepção** |  | 93d | 2019-06-13 A | 2019-10-24 |  |  | 93d | 2019-06-13 | 2019-09-09 | 60d |  |  | 462d |  | Verde | Verde | 0% | 0% | Compensatória | Verde | 0% | 0% |  |  |
| 401 | 3.1.3.6.4.2.1 | Estudo de concepção do Pleito BEOESOB04 - Implantação do SES na sede e distritos de São Sebatião de Braúnas e de Perpétuo Socorro (Cachoeira Escura) apresentado ao banco | milestone | 0d | 2019-06-13 A | 2019-06-13 A | 3052FS+124d | 100% |  | 2019-06-13 | 2019-06-13 | 0d |  |  |  |  | Verde | Verde | 0% | 0% | Compensatória | Verde | 0% | 0% |  |  |
| 402 | 3.1.3.6.4.2.2 | Analisar estudo |  | 60d | 2019-08-01 | 2019-10-24 | 401, 399 |  |  | 2019-08-01 | 2019-10-24 | 60d |  |  | 462d | 0d | Verde | Verde | 0% | 0% | Compensatória | Verde | 0% | 0% |  | Critério FR |
| 403 | 3.1.3.6.4.2.3 | Estudo Pleito BEOESOB04 - Implantação do SES na sede e distritos de São Sebatião de Braúnas e de Perpétuo Socorro (Cachoeira Escura) aprovado | milestone | 0d | 2019-10-24 | 2019-10-24 | 402 |  |  | 2019-09-09 | 2019-09-09 | 0d |  |  | 462d | 10d | Verde | Verde | 0% | 0% | Compensatória | Verde | 0% | 0% |  |  |
| 404 | 3.1.3.6.4.3 | **Aprovação do Projeto** |  | 60d | 2019-08-14 | 2019-11-07 |  |  |  | 2019-08-14 | 2019-11-07 | 60d |  |  | 452d |  | Verde | Verde | 0% | 0% | Compensatória | Verde | 0% | 0% |  |  |
| 405 | 3.1.3.6.4.3.1 | Projeto do Pleito BEOESOB04 - Implantação do SES na sede e distritos de São Sebatião de Braúnas e de Perpétuo Socorro (Cachoeira Escura) apresentado ao banco | milestone | 0d | 2019-08-14 | 2019-08-14 | 399FS+10d |  |  | 2019-08-14 | 2019-08-14 | 0d |  |  | 452d | 0d | Verde | Verde | 0% | 0% | Compensatória | Verde | 0% | 0% |  |  |
| 406 | 3.1.3.6.4.3.2 | Analisar projeto |  | 60d | 2019-08-16 | 2019-11-07 | 405 |  |  | 2019-08-16 | 2019-11-07 | 60d |  |  | 452d | 0d | Verde | Verde | 0% | 0% | Compensatória | Verde | 0% | 0% |  | Critério FR |
| 407 | 3.1.3.6.4.3.3 | Projeto do Pleito BEOESOB04 - Implantação do SES na sede e distritos de São Sebatião de Braúnas e de Perpétuo Socorro (Cachoeira Escura) aprovado | milestone | 0d | 2019-11-07 | 2019-11-07 | 403, 406 |  |  | 2019-11-07 | 2019-11-07 | 0d |  |  | 452d | 0d | Verde | Verde | 0% | 0% | Compensatória | Verde | 0% | 0% |  |  |
| 408 | 3.1.3.6.4.4 | **Licitação da obra** |  | 78d | 2019-11-07 | 2020-03-06 |  |  |  | 2019-11-07 | 2020-03-06 | 78d | 2019-06-14 | 2019-10-04 | 452d |  | Verde | Verde | 0% | 0% | Compensatória | Verde | 0% | 0% |  |  |
| 409 | 3.1.3.6.4.4.1 | Licitação da obra do Pleito BEOESOB04 - Implantação do SES na sede e distritos de São Sebatião de Braúnas e de Perpétuo Socorro (Cachoeira Escura) autorizada pelo banco | milestone | 0d | 2019-11-07 | 2019-11-07 | 407 |  |  | 2019-11-07 | 2019-11-07 | 0d | 2019-06-14 | 2019-06-14 | 452d | 0d | Verde | Verde | 0% | 0% | Compensatória | Verde | 0% | 0% | Banco |  |
| 410 | 3.1.3.6.4.4.2 | Licitar obra |  | 64d | 2019-11-08 | 2020-02-12 | 409 |  |  | 2019-11-08 | 2020-02-12 | 64d | 2019-06-17 | 2019-09-16 | 452d | 0d | Verde | Verde | 0% | 0% | Compensatória | Verde | 0% | 0% | Município |  |
| 411 | 3.1.3.6.4.4.3 | Analisar e emitir resultado da análise de licitação da obra |  | 14d | 2020-02-13 | 2020-03-06 | 410 |  |  | 2020-02-13 | 2020-03-06 | 14d | 2019-09-17 | 2019-10-04 | 452d | 0d | Verde | Verde | 0% | 0% | Compensatória | Verde | 0% | 0% | Banco |  |
| 412 | 3.1.3.6.4.4.4 | Licitação da obra do Pleito BEOESOB04 - Implantação do SES na sede e distritos de São Sebatião de Braúnas e de Perpétuo Socorro (Cachoeira Escura) concluída | milestone | 0d | 2020-03-06 | 2020-03-06 | 411 |  |  | 2020-03-06 | 2020-03-06 | 0d | 2019-10-04 | 2019-10-04 | 452d | 0d | Verde | Verde | 0% | 0% | Compensatória | Verde | 0% | 0% | Município |  |
| 413 | 3.1.3.6.4.5 | Executar obra |  | 311d | 2020-04-06 | 2021-07-06 | 412FS+20d |  |  | 2020-04-06 | 2021-07-06 | 311d | 2019-11-04 | 2021-08-03 | 452d | 0d | Verde | Verde | 0% | 0% | Compensatória | Verde | 0% | 0% | Município |  |
| 414 | 3.1.3.6.4.6 | Realizar processo de pré-operação |  | 120d | 2021-07-07 | 2021-12-28 | 413 |  |  | 2021-07-07 | 2021-12-28 | 120d | 2021-08-04 | 2022-02-04 | 452d | 0d | Verde | Verde | 0% | 0% | Compensatória | Verde | 0% | 0% | Município |  |
| 415 | 3.1.3.6.4.7 | Recurso da obra do Pleito BEOESOB04 - Implantação do SES na sede e distritos de São Sebatião de Braúnas e de Perpétuo Socorro (Cachoeira Escura) repassado | milestone | 0d | 2022-01-04 | 2022-01-04 | 414FS+5d |  |  | 2022-01-04 | 2022-01-04 | 0d | 2022-02-11 | 2022-02-11 | 452d | 0d | Verde | Verde | 0% | 0% | Compensatória | Verde | 0% | 0% | Banco |  |
| 416 | 3.1.3.6.4.8 | Pleito BEOESOB04 - Implantação do SES na sede e distritos de São Sebatião de Braúnas e de Perpétuo Socorro (Cachoeira Escura) de Belo Oriente concluído | milestone | 0d | 2022-01-04 | 2022-01-04 | 415 |  |  | 2022-01-04 | 2022-01-04 | 0d | 2022-02-11 | 2022-02-11 | 452d | 204d | Verde | Verde | 0% | 0% | Compensatória | Verde | 0% | 0% | Município |  |
| 417 | 3.1.3.6.5 | **Pleito de Belo Oriente de Resíduos Sólidos a definir** |  | 787d | 2019-08-30 | 2022-10-28 |  |  |  | 2019-08-30 | 2022-10-28 | 787d | 2019-08-30 | 2025-02-25 | 248d |  | Verde | Verde | 0% | 0% | Compensatória | Verde | 0% | 0% |  |  |
| 418 | 3.1.3.6.5.1 | Pleito de Belo Oriente de Resíduos Sólidos a definir aprovado | milestone | 0d | 2019-08-30 | 2019-08-30 | 3052FS+178d |  |  | 2019-08-30 | 2019-08-30 | 0d | 2019-08-30 | 2019-08-30 | 248d | 0d | Verde | Verde | 0% | 0% | Compensatória | Verde | 0% | 0% | CT/CIF |  |
| 419 | 3.1.3.6.5.2 | Iniciar serviço/projeto/obra do pleito de Belo Oriente de Resíduos Sólidos a definir |  | 1d | 2019-09-02 | 2019-09-02 | 418 |  |  | 2019-09-02 | 2019-09-02 | 1d | 2019-09-02 | 2019-09-02 | 248d | 0d | Verde | Verde | 0% | 0% | Compensatória | Verde | 0% | 0% | Município | Critério FR |
| 420 | 3.1.3.6.5.3 | Pleito de Belo Oriente de Resíduos Sólidos a definir concluído | milestone | 0d | 2022-10-28 | 2022-10-28 | 419FS+786d |  |  | 2022-10-28 | 2022-10-28 | 0d | 2025-02-25 | 2025-02-25 | 248d | 0d | Verde | Verde | 0% | 0% | Compensatória | Verde | 0% | 0% | Município |  |
| 421 | 3.1.3.6.6 | Recursos de Belo Oriente repassados | milestone | 0d | 2022-10-28 | 2022-10-28 | 391, 394, 397, 416, 420 |  |  | 2022-10-28 | 2022-10-28 | 0d | 2025-02-25 | 2025-02-25 | 248d |  | Verde | Verde | 0% | 0% | Compensatória | Verde | 0% | 0% | Banco |  |

Notes:
- 399: Em 25/04/2019: município informou que vai pedir o cancelamento do pleito da sede e manter apenas Cachoeira Escura. Foi considerado que o pleito será aprovado em 31/05/2019 no próximo CIF. / 30/05/2019: pleito não foi analisado no CIF de maio.
- 401: 27/06/2019: o município protocolou o projeto na data combinada 13/06/2019 conforme e-mail do Deiwid Estudos Concepções (Análise Documental) - Município de Belo Oriente - BEOESOB04 - Implantação do SES na sede e distritos de São Sebastião de Braúnas e de Perpétuo Socorro (Cachoeira Escura).
- 402: 27/06/2019: Banco só vai iniciar a análise do estudo após a aprovação da alteração do pleito pelo CIF. Na 2a rodada de reuniões o banco tinha combinado de iniciar a análise antes da aprovação. e-mail da Cynthia Estudos Concepções (Análise Documental) - Município de Belo Oriente - BEOESOB04 - Implantação do SES na sede e distritos de São Sebastião de Braúnas e de Perpétuo Socorro (Cachoeira Escura)
- 413: 22/05/2019: valor da obra 5.760.000,00 - 15 meses
- 418: Em 24/04/2019: no prazo foi considerado estudo de viabilidade, projeto e obra (vide Ipatinga)
- 421: Valor de recurso destinado ao munícipio: R$11.029.650,50

| ID | WBS | Task | Type | Duration | Start | Finish | Predecessors | Complete | Remaining | Baseline start | Baseline finish | Baseline duration | Baseline 1 start | Baseline 1 finish | Total slack | Free slack | Constraint | Text1 | Text2 | Text3 | Text6 | Text8 | Text12 | Text14 | Text16 | Text5 | Text4 | Text7 | Text9 | Text15 | Text17 | Text18 |
| --- | --- | --- | --- | --- | --- | --- | --- | --- | --- | --- | --- | --- | --- | --- | --- | --- | --- | --- | --- | --- | --- | --- | --- | --- | --- | --- | --- | --- | --- | --- | --- | --- |
| 422 | 3.1.3.7 | **Bom Jesus do Galho** |  | 840d | 2019-03-29 A | 2022-08-12 |  | 4% | 805.25d | 2019-03-29 | 2022-08-12 | 840d | 2019-03-29 | 2023-01-02 | 300d |  |  | Verde | Verde | 5% | 0% | Compensatória | Vermelho | 0% | 0% |  |  |  |  |  |  |  |
| 423 | 3.1.3.7.1 | **Pleito BJGESPJ02 - Elaboração de projetos de sistemas de esgotamento sanitário para a sede do município e para o distrito de Revés do Belém** |  | 292d | 2019-03-29 A | 2020-06-03 |  | 3% | 282.55d | 2019-03-29 | 2020-06-03 | 292d | 2019-03-29 | 2020-10-07 | 848d |  |  | Verde | Verde | 14% | 0% | Compensatória | Vermelho | 2% | 0% | 14 |  |  |  |  |  |  |
| 424 | 3.1.3.7.1.1 | Pleito BJGESPJ02 - Elaboração de projetos de sistemas de esgotamento sanitário para a sede do município e para o distrito de Revés do Belém aprovado | milestone | 0d | 2019-03-29 A | 2019-03-29 A |  | 100% |  | 2019-03-29 | 2019-03-29 | 0d | 2019-03-29 | 2019-03-29 |  |  | must start on 2019-03-29 | Verde | Verde | 100% | 100% | Compensatória | Verde | 100% | 100% | 100 | 100 | 100 | CT/CIF | 100 | 100 |  |
| 425 | 3.1.3.7.1.2 | **Licitação do projeto** |  | 89d | 2019-04-16 A | 2019-08-26 |  | 21% | 70.46d | 2019-04-16 | 2019-08-26 | 89d | 2019-04-16 | 2019-07-15 | 300d |  |  | Verde | Verde | 33% | 0% | Compensatória | Vermelho | 21% | 0% | 33 | 10 |  |  | 21 |  |  |
| 426 | 3.1.3.7.1.2.1 | Licitação do projeto do Pleito BJGESPJ02 - Elaboração de projetos de sistemas de esgotamento sanitário para a sede do município e para o distrito de Revés do Belém autorizada | milestone | 0d | 2019-04-16 A | 2019-04-16 A | 424FS+12d | 100% |  | 2019-04-16 | 2019-04-16 | 0d | 2019-04-16 | 2019-04-16 |  |  |  | Verde | Verde | 100% | 100% | Compensatória | Verde | 100% | 100% | 100 | 100 | 100 | Banco | 100 | 100 |  |
| 427 | 3.1.3.7.1.2.2 | Licitar projeto |  | 70d | 2019-04-17 A | 2019-07-29 | 426 | 25% | 52.5d | 2019-04-17 | 2019-07-29 | 70d | 2019-04-17 | 2019-06-17 | 300d | 0d |  | Verde | Verde | 42% | 0% | Compensatória | Vermelho | 42% | 0% | 42 | 11 |  | Município | 42 |  | Conforme agendado |
| 428 | 3.1.3.7.1.2.3 | Documentação de licitação do Pleito BJGESPJ02 - Elaboração de projetos de sistemas de esgotamento sanitário para a sede do município e para o distrito de Revés do Belém apresentada ao banco | milestone | 0d | 2019-08-05 | 2019-08-05 | 427FS+5d |  |  | 2019-08-05 | 2019-08-05 | 0d | 2019-06-25 | 2019-06-25 | 300d | 0d |  | Verde | Verde | 0% | 0% | Compensatória | Verde | 0% | 0% |  |  |  | Município |  |  |  |
| 429 | 3.1.3.7.1.2.4 | Analisar e emitir resultado da análise de licitação do projeto |  | 14d | 2019-08-06 | 2019-08-26 | 428 |  |  | 2019-08-06 | 2019-08-26 | 14d | 2019-06-26 | 2019-07-15 | 300d | 0d |  | Verde | Verde | 0% | 0% | Compensatória | Verde | 0% | 0% |  |  |  | Banco |  |  | Critério FR |
| 430 | 3.1.3.7.1.2.5 | Licitação do projeto do Pleito BJGESPJ02 - Elaboração de projetos de sistemas de esgotamento sanitário para a sede do município e para o distrito de Revés do Belém concluída | milestone | 0d | 2019-08-26 | 2019-08-26 | 429 |  |  | 2019-08-26 | 2019-08-26 | 0d | 2019-07-15 | 2019-07-15 | 300d | 0d |  | Verde | Verde | 0% | 0% | Compensatória | Verde | 0% | 0% |  |  |  | Município |  |  |  |
| 431 | 3.1.3.7.1.3 | **Elaboração do Estudo de Concepção** |  | 105d | 2019-08-27 | 2020-01-27 |  |  |  | 2019-08-27 | 2020-01-27 | 105d |  |  | 300d |  |  | Verde | Verde | 0% | 0% | Compensatória | Verde | 0% | 0% |  |  |  |  |  |  |  |
| 432 | 3.1.3.7.1.3.1 | Elaborar estudo |  | 40d | 2019-08-27 | 2019-10-21 | 430 |  |  | 2019-08-27 | 2019-10-21 | 40d |  |  | 300d | 0d |  | Verde | Verde | 0% | 0% | Compensatória | Verde | 0% | 0% |  |  |  |  |  |  | Critério FR |
| 433 | 3.1.3.7.1.3.2 | Estudo de concepção do Pleito BJGESPJ02 - Elaboração de projetos de sistemas de esgotamento sanitário para a sede do município e para o distrito de Revés do Belém apresentado ao banco | milestone | 0d | 2019-10-21 | 2019-10-21 | 432 |  |  | 2019-10-21 | 2019-10-21 | 0d |  |  | 381d | 0d |  | Verde | Verde | 0% | 0% | Compensatória | Verde | 0% | 0% |  |  |  |  |  |  |  |
| 434 | 3.1.3.7.1.3.3 | Analisar estudo |  | 60d | 2019-10-22 | 2020-01-20 | 433 |  |  | 2019-10-22 | 2020-01-20 | 60d |  |  | 381d | 0d |  | Verde | Verde | 0% | 0% | Compensatória | Verde | 0% | 0% |  |  |  |  |  |  | Critério FR |
| 435 | 3.1.3.7.1.3.4 | Estudo de concepção do Pleito BJGESPJ02 - Elaboração de projetos de sistemas de esgotamento sanitário para a sede do município e para o distrito de Revés do Belém concluído | milestone | 0d | 2020-01-20 | 2020-01-20 | 434 |  |  | 2020-01-20 | 2020-01-20 | 0d |  |  | 381d | 0d |  | Verde | Verde | 0% | 0% | Compensatória | Verde | 0% | 0% |  |  |  |  |  |  |  |
| 436 | 3.1.3.7.1.3.5 | Recurso do estudo de concepção do Pleito BJGESPJ02 - Elaboração de projetos de sistemas de esgotamento sanitário para a sede do município e para o distrito de Revés do Belém repassado | milestone | 0d | 2020-01-27 | 2020-01-27 | 435FS+5d |  |  | 2020-01-27 | 2020-01-27 | 0d |  |  | 381d | 45d |  | Verde | Verde | 0% | 0% | Compensatória | Verde | 0% | 0% |  |  |  |  |  |  |  |
| 437 | 3.1.3.7.1.4 | **Elaboração do Projeto Básico** |  | 110d | 2019-10-22 | 2020-04-02 |  |  |  | 2019-10-22 | 2020-04-02 | 110d | 2019-07-16 | 2020-03-31 | 300d |  |  | Verde | Verde | 0% | 0% | Compensatória | Verde | 0% | 0% |  |  |  |  |  |  |  |
| 438 | 3.1.3.7.1.4.1 | Elaborar Projeto Básico |  | 40d | 2019-10-22 | 2019-12-18 | 432 |  |  | 2019-10-22 | 2019-12-18 | 40d | 2019-07-16 | 2019-12-16 | 300d | 0d |  | Verde | Verde | 0% | 0% | Compensatória | Verde | 0% | 0% |  |  |  | Município |  |  | Critério FR |
| 439 | 3.1.3.7.1.4.2 | Projeto básico do Pleito BJGESPJ02 - Elaboração de projetos de sistemas de esgotamento sanitário para a sede do município e para o distrito de Revés do Belém apresentado ao banco | milestone | 0d | 2019-12-18 | 2019-12-18 | 438 |  |  | 2019-12-18 | 2019-12-18 | 0d | 2019-12-16 | 2019-12-16 | 336d | 0d |  | Verde | Verde | 0% | 0% | Compensatória | Verde | 0% | 0% |  |  |  | Município |  |  |  |
| 440 | 3.1.3.7.1.4.3 | Analisar Projeto Básico |  | 65d | 2019-12-19 | 2020-03-26 | 439 |  |  | 2019-12-19 | 2020-03-26 | 65d | 2019-12-17 | 2020-01-21 | 336d | 0d |  | Verde | Verde | 0% | 0% | Compensatória | Verde | 0% | 0% |  |  |  | Banco |  |  |  |
| 441 | 3.1.3.7.1.4.4 | Projeto básico do Pleito BJGESPJ02 - Elaboração de projetos de sistemas de esgotamento sanitário para a sede do município e para o distrito de Revés do Belém concluído | milestone | 0d | 2020-03-26 | 2020-03-26 | 440 |  |  | 2020-03-26 | 2020-03-26 | 0d | 2020-03-24 | 2020-03-24 | 336d | 0d |  | Verde | Verde | 0% | 0% | Compensatória | Verde | 0% | 0% |  |  |  | Município |  |  |  |
| 442 | 3.1.3.7.1.4.5 | Recurso do projeto básico do Pleito BJGESPJ02 - Elaboração de projetos de sistemas de esgotamento sanitário para a sede do município e para o distrito de Revés do Belém repassado | milestone | 0d | 2020-04-02 | 2020-04-02 | 441FS+5d, 436 |  |  | 2020-04-02 | 2020-04-02 | 0d | 2020-03-31 | 2020-03-31 | 336d | 36d |  | Verde | Verde | 0% | 0% | Compensatória | Verde | 0% | 0% |  |  |  | Banco |  |  |  |
| 443 | 3.1.3.7.1.5 | Realizar Licenciamento Ambiental |  | 146d | 2019-10-22 | 2020-05-27 | 432 |  |  | 2019-10-22 | 2020-05-27 | 146d | 2019-12-17 | 2020-09-30 | 300d | 0d |  | Verde | Verde | 0% | 0% | Compensatória | Verde | 0% | 0% |  |  |  | Município |  |  |  |
| 444 | 3.1.3.7.1.6 | **Elaboração do Projeto Executivo** |  | 111d | 2019-12-19 | 2020-06-03 |  |  |  | 2019-12-19 | 2020-06-03 | 111d | 2019-12-17 | 2020-10-07 | 300d |  |  | Verde | Verde | 0% | 0% | Compensatória | Verde | 0% | 0% |  |  |  |  |  |  |  |
| 445 | 3.1.3.7.1.6.1 | Elaborar Projeto Executivo |  | 40d | 2019-12-19 | 2020-02-17 | 438 |  |  | 2019-12-19 | 2020-02-17 | 40d | 2019-12-17 | 2020-06-29 | 300d | 0d |  | Verde | Verde | 0% | 0% | Compensatória | Verde | 0% | 0% |  |  |  | Município |  |  |  |
| 446 | 3.1.3.7.1.6.2 | Projeto executivo do Pleito BJGESPJ02 - Elaboração de projetos de sistemas de esgotamento sanitário para a sede do município e para o distrito de Revés do Belém apresentado ao banco | milestone | 0d | 2020-02-17 | 2020-02-17 | 445 |  |  | 2020-02-17 | 2020-02-17 | 0d | 2020-06-29 | 2020-06-29 | 300d | 0d |  | Verde | Verde | 0% | 0% | Compensatória | Verde | 0% | 0% |  |  |  | Município |  |  |  |
| 447 | 3.1.3.7.1.6.3 | Analisar projeto executivo |  | 66d | 2020-02-18 | 2020-05-27 | 446 |  |  | 2020-02-18 | 2020-05-27 | 66d | 2020-06-30 | 2020-07-29 | 300d | 0d |  | Verde | Verde | 0% | 0% | Compensatória | Verde | 0% | 0% |  |  |  | Banco |  |  |  |
| 448 | 3.1.3.7.1.6.4 | Projeto executivo do Pleito BJGESPJ02 - Elaboração de projetos de sistemas de esgotamento sanitário para a sede do município e para o distrito de Revés do Belém concluído | milestone | 0d | 2020-05-27 | 2020-05-27 | 442, 443, 447 |  |  | 2020-05-27 | 2020-05-27 | 0d | 2020-09-30 | 2020-09-30 | 300d | 0d |  | Verde | Verde | 0% | 0% | Compensatória | Verde | 0% | 0% |  |  |  | Município |  |  |  |
| 449 | 3.1.3.7.1.6.5 | Recurso do projeto executivo do Pleito BJGESPJ02 - Elaboração de projetos de sistemas de esgotamento sanitário para a sede do município e para o distrito de Revés do Belém repassado | milestone | 0d | 2020-06-03 | 2020-06-03 | 448FS+5d |  |  | 2020-06-03 | 2020-06-03 | 0d | 2020-10-07 | 2020-10-07 | 848d | 0d |  | Verde | Verde | 0% | 0% | Compensatória | Verde | 0% | 0% |  |  |  | Banco |  |  |  |
| 450 | 3.1.3.7.1.7 | Pleito BJGESPJ02 - Elaboração de projetos de sistemas de esgotamento sanitário para a sede do município e para o distrito de Revés do Belém de Bom Jesus do Galho concluído | milestone | 0d | 2020-06-03 | 2020-06-03 | 449 |  |  | 2020-06-03 | 2020-06-03 | 0d | 2020-10-07 | 2020-10-07 | 848d | 548d |  | Verde | Verde | 0% | 0% | Compensatória | Verde | 0% | 0% |  |  |  | Município |  |  |  |

Notes:
- 422: Bom Jesus do Galho teve 100% dos pleitos de Esgotamento Sanitário aprovado (R$7.090.489,61), conforme Deliberação 75. / O município teve o pleito de resíduos sólidos negado (R$787.832,18, equivalente a 10% do total do recurso).
- 424: 15/04/2019: a alteração do pleito de projeto foi aprovada pela Renova no dia 29/03/2019
- 426: 28/05/2019: autorização encaminhada pelo banco dia 16/04/2019 conforme planilha Controle Gerencial Renova (aba Pleitos)
- 427: 19/12/18 - Devido aos conflitos políticos entre revés e Belem, o processo havia sido paralizado. Ainda é necessário cria a TR para então iniciar a licitação (Sem previsão). Será considerado o prazo para inicio no final de março de 2019 até obtermos informações precisas / 28/05/2019: cancelaram o TR antigo e fizeram um novo TR que vai entrar para licitação. Previsão de término igual a de Raul Soares - 29/07/2019. / 01/07/2019: o município informou que o processo licitatório está com o setor de licitação para publicação do edital na reunião do dia 04/06/2019 com Carlos e Danielle.
- 432: 28/05/2019: município pactuou com a Renova prazo de 6 meses para elaboração do estudo, projeto básico e projeto executivo
- 438: Em 15/04/19: duração de 5 meses para projeto básico

| ID | WBS | Task | Type | Duration | Start | Finish | Predecessors | Complete | Remaining | Baseline start | Baseline finish | Baseline duration | Baseline 1 start | Baseline 1 finish | Total slack | Free slack | Constraint | Text1 | Text2 | Text3 | Text6 | Text8 | Text12 | Text14 | Text16 | Text9 | Text7 | Text4 | Text5 | Text15 | Text17 | Text18 |
| --- | --- | --- | --- | --- | --- | --- | --- | --- | --- | --- | --- | --- | --- | --- | --- | --- | --- | --- | --- | --- | --- | --- | --- | --- | --- | --- | --- | --- | --- | --- | --- | --- |
| 451 | 3.1.3.7.2 | **Pleito BJGESCT01 - Aquisição de imóvel para implantação da Estação de Tratamento de Esgoto - ETE** |  | 141d | 2019-10-22 | 2020-05-20 |  |  |  | 2019-10-22 | 2020-05-20 | 141d | 2020-01-22 | 2020-08-14 | 858d |  |  | Verde | Verde | 0% | 0% | Compensatória | Verde | 0% | 0% |  |  |  |  |  |  |  |
| 452 | 3.1.3.7.2.1 | **Aquisição de Terreno** |  | 141d | 2019-10-22 | 2020-05-20 |  |  |  | 2019-10-22 | 2020-05-20 | 141d | 2020-01-22 | 2020-08-14 | 858d |  |  | Verde | Verde | 0% | 0% | Compensatória | Verde | 0% | 0% |  |  |  |  |  |  |  |
| 453 | 3.1.3.7.2.1.1 | Regularizar terreno e apresentar escritura ao banco |  | 82d | 2019-10-22 | 2020-02-19 | 432 |  |  | 2019-10-22 | 2020-02-19 | 82d | 2020-01-22 | 2020-05-22 | 858d | 0d |  | Verde | Verde | 0% | 0% | Compensatória | Verde | 0% | 0% | Município |  |  |  |  |  |  |
| 454 | 3.1.3.7.2.1.2 | Analisar documentação do terreno |  | 10d | 2020-02-20 | 2020-03-09 | 453 |  |  | 2020-02-20 | 2020-03-09 | 10d | 2020-05-25 | 2020-06-05 | 902d | 0d |  | Verde | Verde | 0% | 0% | Compensatória | Verde | 0% | 0% | Banco |  |  |  |  |  |  |
| 455 | 3.1.3.7.2.1.3 | 50% do valor do imóvel do Pleito BJGESCT01 - Aquisição de imóvel para implantação da Estação de Tratamento de Esgoto - ETE repassado | milestone | 0d | 2020-03-16 | 2020-03-16 | 454FS+5d |  |  | 2020-03-16 | 2020-03-16 | 0d | 2020-06-15 | 2020-06-15 | 902d | 44d |  | Verde | Verde | 0% | 0% | Compensatória | Verde | 0% | 0% | Banco |  |  |  |  |  |  |
| 456 | 3.1.3.7.2.1.4 | Registrar imóvel e apresentar documentação ao banco |  | 44d | 2020-02-20 | 2020-04-28 | 453 |  |  | 2020-02-20 | 2020-04-28 | 44d | 2020-05-25 | 2020-07-24 | 858d | 0d |  | Verde | Verde | 0% | 0% | Compensatória | Verde | 0% | 0% | Município |  |  |  |  |  |  |
| 457 | 3.1.3.7.2.1.5 | Analisar documentação do terreno |  | 10d | 2020-04-29 | 2020-05-13 | 456 |  |  | 2020-04-29 | 2020-05-13 | 10d | 2020-07-27 | 2020-08-07 | 858d | 0d |  | Verde | Verde | 0% | 0% | Compensatória | Verde | 0% | 0% | Banco |  |  |  |  |  |  |
| 458 | 3.1.3.7.2.1.6 | 50% do valor do imóvel do Pleito BJGESCT01 - Aquisição de imóvel para implantação da Estação de Tratamento de Esgoto - ETE repassado | milestone | 0d | 2020-05-20 | 2020-05-20 | 457FS+5d |  |  | 2020-05-20 | 2020-05-20 | 0d | 2020-08-14 | 2020-08-14 | 858d | 0d |  | Verde | Verde | 0% | 0% | Compensatória | Verde | 0% | 0% | Banco |  |  |  |  |  |  |
| 459 | 3.1.3.7.2.1.7 | Aquisição de Terreno do Pleito BJGESCT01 - Aquisição de imóvel para implantação da Estação de Tratamento de Esgoto - ETE concluída | milestone | 0d | 2020-05-20 | 2020-05-20 | 455, 458 |  |  | 2020-05-20 | 2020-05-20 | 0d | 2020-08-14 | 2020-08-14 | 858d | 0d |  | Verde | Verde | 0% | 0% | Compensatória | Verde | 0% | 0% | Município |  |  |  |  |  |  |
| 460 | 3.1.3.7.2.2 | Pleito BJGESCT01 - Aquisição de imóvel para implantação da Estação de Tratamento de Esgoto - ETE de Bom Jesus do Galho concluído | milestone | 0d | 2020-05-20 | 2020-05-20 | 459 |  |  | 2020-05-20 | 2020-05-20 | 0d | 2020-08-14 | 2020-08-14 | 858d | 558d |  | Verde | Verde | 0% | 0% | Compensatória | Verde | 0% | 0% | Município |  |  |  |  |  |  |
| 461 | 3.1.3.7.3 | **Pleito BJGESOB02 - Implantação do sistema de esgotamento sanitário da sede do município** |  | 553d | 2020-05-27 | 2022-08-12 |  |  |  | 2020-05-27 | 2022-08-12 | 553d | 2020-09-30 | 2023-01-02 | 300d |  |  | Verde | Verde | 0% | 0% | Compensatória | Verde | 0% | 0% |  |  |  |  |  |  |  |
| 462 | 3.1.3.7.3.1 | **Licitação da obra** |  | 76d | 2020-05-27 | 2020-09-14 |  |  |  | 2020-05-27 | 2020-09-14 | 76d | 2020-09-30 | 2021-01-21 | 300d |  |  | Verde | Verde | 0% | 0% | Compensatória | Verde | 0% | 0% |  |  |  |  |  |  |  |
| 463 | 3.1.3.7.3.1.1 | Licitação da obra do Pleito BJGESOB02 - Implantação do sistema de esgotamento sanitário da sede do município autorizada pelo banco | milestone | 0d | 2020-05-27 | 2020-05-27 | 448 |  |  | 2020-05-27 | 2020-05-27 | 0d | 2020-09-30 | 2020-09-30 | 300d | 0d |  | Verde | Verde | 0% | 0% | Compensatória | Verde | 0% | 0% | Banco |  |  |  |  |  |  |
| 464 | 3.1.3.7.3.1.2 | Licitar obra |  | 62d | 2020-05-28 | 2020-08-24 | 463 |  |  | 2020-05-28 | 2020-08-24 | 62d | 2020-10-01 | 2020-12-31 | 300d | 0d |  | Verde | Verde | 0% | 0% | Compensatória | Verde | 0% | 0% | Município |  |  |  |  |  |  |
| 465 | 3.1.3.7.3.1.3 | Analisar licitação da obra |  | 14d | 2020-08-25 | 2020-09-14 | 464 |  |  | 2020-08-25 | 2020-09-14 | 14d | 2021-01-04 | 2021-01-21 | 300d | 0d |  | Verde | Verde | 0% | 0% | Compensatória | Verde | 0% | 0% | Banco |  |  |  |  |  |  |
| 466 | 3.1.3.7.3.1.4 | Licitação da obra do Pleito BJGESOB02 - Implantação do sistema de esgotamento sanitário da sede do município concluída | milestone | 0d | 2020-09-14 | 2020-09-14 | 465 |  |  | 2020-09-14 | 2020-09-14 | 0d | 2021-01-21 | 2021-01-21 | 300d | 0d |  | Verde | Verde | 0% | 0% | Compensatória | Verde | 0% | 0% | Município |  |  |  |  |  |  |
| 467 | 3.1.3.7.3.2 | Executar obra |  | 332d | 2020-10-14 | 2022-02-10 | 466FS+20d |  |  | 2020-10-14 | 2022-02-10 | 332d | 2021-02-24 | 2022-06-22 | 300d | 0d |  | Verde | Verde | 0% | 0% | Compensatória | Verde | 0% | 0% | Município |  |  |  |  |  |  |
| 468 | 3.1.3.7.3.3 | Realizar processo de pré-operação |  | 120d | 2022-02-11 | 2022-08-05 | 467 |  |  | 2022-02-11 | 2022-08-05 | 120d | 2022-06-23 | 2022-12-26 | 300d | 0d |  | Verde | Verde | 0% | 0% | Compensatória | Verde | 0% | 0% | Município |  |  |  |  |  |  |
| 469 | 3.1.3.7.3.4 | Recurso da obra do Pleito BJGESOB02 - Implantação do sistema de esgotamento sanitário da sede do município repassado | milestone | 0d | 2022-08-12 | 2022-08-12 | 468FS+5d |  |  | 2022-08-12 | 2022-08-12 | 0d | 2023-01-02 | 2023-01-02 | 300d | 0d |  | Verde | Verde | 0% | 0% | Compensatória | Verde | 0% | 0% | Banco |  |  |  |  |  |  |
| 470 | 3.1.3.7.3.5 | Pleito BJGESOB02 - Implantação do sistema de esgotamento sanitário da sede do município de Bom Jesus do Galho concluído | milestone | 0d | 2022-08-12 | 2022-08-12 | 469 |  |  | 2022-08-12 | 2022-08-12 | 0d | 2023-01-02 | 2023-01-02 | 300d | 0d |  | Verde | Verde | 0% | 0% | Compensatória | Verde | 0% | 0% | Município |  |  |  |  |  |  |
| 471 | 3.1.3.7.4 | **Pleito BJGRSOB02 - Ampliação de aterro sanitário, incluindo uma Unidade de Triagem e Compostagem – UTC** |  | 621d | 2019-04-03 A | 2021-09-30 |  | 10% | 561.17d | 2019-04-03 | 2021-09-30 | 621d | 2019-04-03 | 2021-09-09 | 516d |  |  | Verde | Verde | 6% | 25% | Compensatória | Vermelho | 4% | 1% |  | 25 |  |  |  |  |  |
| 472 | 3.1.3.7.4.1 | **Aprovação do Projeto Executivo** |  | 87d | 2019-04-03 A | 2019-08-08 |  | 66% | 29.58d | 2019-04-03 | 2019-08-08 | 87d | 2019-04-03 | 2019-07-08 | 516d |  |  | Verde | Verde | 44% | 30% | Compensatória | Vermelho | 40% | 12% |  | 30 | 18 | 44 | 40 | 12 |  |
| 473 | 3.1.3.7.4.1.1 | Projeto do Pleito BJGRSOB02 - Ampliação de aterro sanitário, incluindo uma Unidade de Triagem e Compostagem – UTC apresentado ao banco | milestone | 0d | 2019-04-03 A | 2019-04-03 A |  | 100% |  | 2019-04-03 | 2019-04-03 | 0d | 2019-04-03 | 2019-04-03 |  |  | must start on 2019-04-03 | Verde | Verde | 100% | 100% | Compensatória | Verde | 100% | 100% | Município | 100 | 100 | 100 | 100 | 100 |  |
| 474 | 3.1.3.7.4.1.2 | Analisar projeto |  | 87d | 2019-04-04 A | 2019-08-08 | 473 | 66% | 29.58d | 2019-04-04 | 2019-08-08 | 87d | 2019-04-04 | 2019-05-06 | 516d | 0d |  | Verde | Verde | 79% | 32% | Compensatória | Vermelho | 79% | 25% | Banco | 32 | 35 | 79 | 79 | 25 | Conforme agendado |
| 475 | 3.1.3.7.4.1.3 | Projeto do Pleito BJGRSOB02 - Ampliação de aterro sanitário, incluindo uma Unidade de Triagem e Compostagem – UTC concluído | milestone | 0d | 2019-08-08 | 2019-08-08 | 474 |  |  | 2019-08-08 | 2019-08-08 | 0d | 2019-07-08 | 2019-07-08 | 516d | 0d |  | Verde | Verde | 0% | 0% | Compensatória | Verde | 0% | 0% | Município |  |  |  |  |  |  |

Notes:
- 473: Em 24/04/2019: conforme orientação da Cynthia foi inserido como início do processo o último contato do município para esclarecimento de informações ao banco.
- 474: 28/05/2019: no dia 14/05/2019 o banco informou que as declarações foram recebidas e repassadas para o Eng. Cláudio Soares. Considerado mais 1 mês para a análise do banco. / 01/07/2019: e-mail Luiz BDMG - Por se tratar do primeiro caso de análise em consórcio, tivemos algumas definições internas sobre escopo, o que alongou a análise. Vamos concluir nossa avaliação até 05/07.

| ID | WBS | Task | Type | Duration | Start | Finish | Predecessors | Complete | Remaining | Baseline start | Baseline finish | Baseline duration | Baseline 1 start | Baseline 1 finish | Total slack | Free slack | Text1 | Text2 | Text3 | Text6 | Text8 | Text12 | Text14 | Text16 | Text9 | Text18 | Text5 |
| --- | --- | --- | --- | --- | --- | --- | --- | --- | --- | --- | --- | --- | --- | --- | --- | --- | --- | --- | --- | --- | --- | --- | --- | --- | --- | --- | --- |
| 476 | 3.1.3.7.4.2 | **Licitação da obra** |  | 80d | 2019-08-08 | 2019-12-02 |  |  |  | 2019-08-08 | 2019-12-02 | 80d | 2019-07-08 | 2019-10-29 | 516d |  | Verde | Verde | 0% | 0% | Compensatória | Verde | 0% | 0% |  |  |  |
| 477 | 3.1.3.7.4.2.1 | Licitação da obra do Pleito BJGRSOB02 - Ampliação de aterro sanitário, incluindo uma Unidade de Triagem e Compostagem – UTC autorizada pelo banco | milestone | 0d | 2019-08-08 | 2019-08-08 | 475 |  |  | 2019-08-08 | 2019-08-08 | 0d | 2019-07-08 | 2019-07-08 | 516d | 0d | Verde | Verde | 0% | 0% | Compensatória | Verde | 0% | 0% | Banco |  |  |
| 478 | 3.1.3.7.4.2.2 | Licitar obra |  | 66d | 2019-08-09 | 2019-11-11 | 477 |  |  | 2019-08-09 | 2019-11-11 | 66d | 2019-07-09 | 2019-10-09 | 516d | 0d | Verde | Verde | 0% | 0% | Compensatória | Verde | 0% | 0% | Município | Critério FR |  |
| 479 | 3.1.3.7.4.2.3 | Analisar e emitir resultado da licitação da obra |  | 14d | 2019-11-12 | 2019-12-02 | 478 |  |  | 2019-11-12 | 2019-12-02 | 14d | 2019-10-10 | 2019-10-29 | 516d | 0d | Verde | Verde | 0% | 0% | Compensatória | Verde | 0% | 0% | Banco | Critério FR |  |
| 480 | 3.1.3.7.4.2.4 | Licitação da obra do Pleito BJGRSOB02 - Ampliação de aterro sanitário, incluindo uma Unidade de Triagem e Compostagem – UTC concluída | milestone | 0d | 2019-12-02 | 2019-12-02 | 479 |  |  | 2019-12-02 | 2019-12-02 | 0d | 2019-10-29 | 2019-10-29 | 516d | 0d | Verde | Verde | 0% | 0% | Compensatória | Verde | 0% | 0% | Município |  |  |
| 481 | 3.1.3.7.4.3 | Executar obra |  | 309d | 2020-01-06 | 2021-04-05 | 480FS+20d |  |  | 2020-01-06 | 2021-04-05 | 309d | 2019-11-28 | 2021-03-02 | 516d | 0d | Verde | Verde | 0% | 0% | Compensatória | Verde | 0% | 0% | Município |  |  |
| 482 | 3.1.3.7.4.4 | Realizar processo de pré-operação |  | 120d | 2021-04-06 | 2021-09-23 | 481 |  |  | 2021-04-06 | 2021-09-23 | 120d | 2021-03-03 | 2021-09-01 | 516d | 0d | Verde | Verde | 0% | 0% | Compensatória | Verde | 0% | 0% | Município |  |  |
| 483 | 3.1.3.7.4.5 | Recurso da obra do Pleito BJGRSOB02 - Ampliação de aterro sanitário, incluindo uma Unidade de Triagem e Compostagem – UTC repassado | milestone | 0d | 2021-09-30 | 2021-09-30 | 482FS+5d |  |  | 2021-09-30 | 2021-09-30 | 0d | 2021-09-09 | 2021-09-09 | 516d | 0d | Verde | Verde | 0% | 0% | Compensatória | Verde | 0% | 0% | Banco |  |  |
| 484 | 3.1.3.7.4.6 | Pleito BJGRSOB02 - Ampliação de aterro sanitário, incluindo uma Unidade de Triagem e Compostagem – UTC de Bom Jesus do Galho concluído | milestone | 0d | 2021-09-30 | 2021-09-30 | 483 |  |  | 2021-09-30 | 2021-09-30 | 0d | 2021-09-09 | 2021-09-09 | 516d | 216d | Verde | Verde | 0% | 0% | Compensatória | Verde | 0% | 0% | Município |  |  |
| 485 | 3.1.3.7.5 | Recursos de Bom Jesus do Galho repassados | milestone | 0d | 2022-08-12 | 2022-08-12 | 450, 460, 470, 484 |  |  | 2022-08-12 | 2022-08-12 | 0d | 2023-01-02 | 2023-01-02 | 300d |  | Verde | Verde | 0% | 0% | Compensatória | Verde | 0% | 0% | Banco |  |  |
| 486 | 3.1.3.8 | **Bugre** |  | 970d | 2018-12-03 A | 2022-10-25 |  | 6% | 913.57d | 2018-12-03 | 2022-04-22 | 842d | 2018-12-03 | 2022-01-25 | 251d |  | Verde | Verde | 14% | 0% | Compensatória | Vermelho | 0% | 0% |  |  | 14 |
| 487 | 3.1.3.8.1 | **Pleito BUGESPJ01 - Elaboração de projetos de sistema de esgotamento sanitário das localidades de Bugre, Boachá, São Lourenço, Livramento e São José do Bugre** |  | 249d | 2019-12-03 | 2020-12-04 |  |  |  | 2019-06-03 | 2020-06-03 | 249d | 2019-05-02 | 2020-03-09 | 251d |  | Verde | Verde | 0% | 0% | Compensatória | Verde | 0% | 0% |  |  |  |
| 488 | 3.1.3.8.1.1 | **Licitação do Projeto** |  | 14d | 2019-12-03 | 2019-12-26 |  |  |  | 2019-06-03 | 2019-06-24 | 14d | 2019-05-02 | 2019-05-22 | 251d |  | Verde | Verde | 0% | 0% | Compensatória | Verde | 0% | 0% |  |  |  |
| 489 | 3.1.3.8.1.1.1 | Documentação de licitação do Pleito BUGESPJ01 - Elaboração de projetos de sistema de esgotamento sanitário das localidades de Bugre, Boachá, São Lourenço, Livramento e São José do Bugre apresentada ao banco | milestone | 0d | 2019-12-03 | 2019-12-03 | 3019FS+331d |  |  | 2019-06-03 | 2019-06-03 | 0d | 2019-05-02 | 2019-05-02 | 251d | 0d | Verde | Verde | 0% | 0% | Compensatória | Verde | 0% | 0% | Município |  |  |
| 490 | 3.1.3.8.1.1.2 | Analisar e emitir resultado da licitação do projeto |  | 14d | 2019-12-04 | 2019-12-26 | 489 |  |  | 2019-06-04 | 2019-06-24 | 14d | 2019-05-03 | 2019-05-22 | 251d | 0d | Verde | Verde | 0% | 0% | Compensatória | Verde | 0% | 0% | Banco | Critério FR |  |
| 491 | 3.1.3.8.1.1.3 | Licitação do projeto do Pleito BUGESPJ01 - Elaboração de projetos de sistema de esgotamento sanitário das localidades de Bugre, Boachá, São Lourenço, Livramento e São José do Bugre concluída | milestone | 0d | 2019-12-26 | 2019-12-26 | 490 |  |  | 2019-06-24 | 2019-06-24 | 0d | 2019-05-22 | 2019-05-22 | 251d | 0d | Verde | Verde | 0% | 0% | Compensatória | Verde | 0% | 0% | Município |  |  |
| 492 | 3.1.3.8.1.2 | **Elaboração do Estudo de Concepção** |  | 105d | 2019-12-27 | 2020-06-01 |  |  |  | 2019-06-25 | 2019-11-20 | 105d |  |  | 251d |  | Verde | Verde | 0% | 0% | Compensatória | Verde | 0% | 0% |  |  |  |
| 493 | 3.1.3.8.1.2.1 | Elaborar estudo |  | 40d | 2019-12-27 | 2020-02-21 | 491 |  |  | 2019-06-25 | 2019-08-20 | 40d |  |  | 251d | 0d | Verde | Verde | 0% | 0% | Compensatória | Verde | 0% | 0% |  | Critério FR |  |
| 494 | 3.1.3.8.1.2.2 | Estudo de concepção do Pleito BUGESPJ01 - Elaboração de projetos de sistema de esgotamento sanitário das localidades de Bugre, Boachá, São Lourenço, Livramento e São José do Bugre apresentado ao banco | milestone | 0d | 2020-02-21 | 2020-02-21 | 493 |  |  | 2019-08-20 | 2019-08-20 | 0d |  |  | 371d | 0d | Verde | Verde | 0% | 0% | Compensatória | Verde | 0% | 0% |  |  |  |
| 495 | 3.1.3.8.1.2.3 | Analisar estudo |  | 60d | 2020-02-27 | 2020-05-25 | 494 |  |  | 2019-08-21 | 2019-11-12 | 60d |  |  | 371d | 0d | Verde | Verde | 0% | 0% | Compensatória | Verde | 0% | 0% |  | Critério FR |  |
| 496 | 3.1.3.8.1.2.4 | Estudo de concepção do Pleito BUGESPJ01 - Elaboração de projetos de sistema de esgotamento sanitário das localidades de Bugre, Boachá, São Lourenço, Livramento e São José do Bugre concluído | milestone | 0d | 2020-05-25 | 2020-05-25 | 495 |  |  | 2019-11-12 | 2019-11-12 | 0d |  |  | 371d | 0d | Verde | Verde | 0% | 0% | Compensatória | Verde | 0% | 0% |  |  |  |
| 497 | 3.1.3.8.1.2.5 | Recurso do estudo de concepção do Pleito BUGESPJ01 - Elaboração de projetos de sistema de esgotamento sanitário das localidades de Bugre, Boachá, São Lourenço, Livramento e São José do Bugre repassado | milestone | 0d | 2020-06-01 | 2020-06-01 | 496FS+5d |  |  | 2019-11-20 | 2019-11-20 | 0d |  |  | 371d | 43d | Verde | Verde | 0% | 0% | Compensatória | Verde | 0% | 0% |  |  |  |
| 498 | 3.1.3.8.1.3 | **Elaboração do Projeto Básico** |  | 113d | 2020-02-27 | 2020-08-07 |  |  |  | 2019-08-21 | 2020-01-31 | 113d | 2019-05-23 | 2019-11-04 | 251d |  | Verde | Verde | 0% | 0% | Compensatória | Verde | 0% | 0% |  |  |  |
| 499 | 3.1.3.8.1.3.1 | Elaborar Projeto Básico |  | 40d | 2020-02-27 | 2020-04-24 | 493 |  |  | 2019-08-21 | 2019-10-15 | 40d | 2019-05-23 | 2019-07-23 | 251d | 0d | Verde | Verde | 0% | 0% | Compensatória | Verde | 0% | 0% | Município | Critério FR |  |
| 500 | 3.1.3.8.1.3.2 | Projeto básico do Pleito BUGESPJ01 - Elaboração de projetos de sistema de esgotamento sanitário das localidades de Bugre, Boachá, São Lourenço, Livramento e São José do Bugre apresentado ao banco | milestone | 0d | 2020-04-24 | 2020-04-24 | 499 |  |  | 2019-10-15 | 2019-10-15 | 0d | 2019-07-23 | 2019-07-23 | 251d | 0d | Verde | Verde | 0% | 0% | Compensatória | Verde | 0% | 0% | Município |  |  |
| 501 | 3.1.3.8.1.3.3 | Analisar Projeto Básico |  | 68d | 2020-04-27 | 2020-07-31 | 500 |  |  | 2019-10-16 | 2020-01-24 | 68d | 2019-07-24 | 2019-08-23 | 328d | 0d | Verde | Verde | 0% | 0% | Compensatória | Verde | 0% | 0% | Banco | Critério FR |  |
| 502 | 3.1.3.8.1.3.4 | Projeto básico do Pleito BUGESPJ01 - Elaboração de projetos de sistema de esgotamento sanitário das localidades de Bugre, Boachá, São Lourenço, Livramento e São José do Bugre concluído | milestone | 0d | 2020-07-31 | 2020-07-31 | 497, 501 |  |  | 2020-01-24 | 2020-01-24 | 0d | 2019-10-28 | 2019-10-28 | 328d | 0d | Verde | Verde | 0% | 0% | Compensatória | Verde | 0% | 0% | Município |  |  |
| 503 | 3.1.3.8.1.3.5 | Recurso do projeto básico do Pleito BUGESPJ01 - Elaboração de projetos de sistema de esgotamento sanitário das localidades de Bugre, Boachá, São Lourenço, Livramento e São José do Bugre repassado | milestone | 0d | 2020-08-07 | 2020-08-07 | 502FS+5d |  |  | 2020-01-31 | 2020-01-31 | 0d | 2019-11-04 | 2019-11-04 | 328d | 77d | Verde | Verde | 0% | 0% | Compensatória | Verde | 0% | 0% | Banco |  |  |
| 504 | 3.1.3.8.1.4 | Realizar Licenciamento Ambiental |  | 150d | 2020-04-27 | 2020-11-27 | 500 |  |  | 2019-10-16 | 2020-05-27 | 150d | 2019-07-24 | 2020-03-02 | 251d | 0d | Verde | Verde | 0% | 0% | Compensatória | Verde | 0% | 0% | Município |  |  |

Notes:
- 481: Em 24/09/2019: o valor da obra do CIDESLESTE é R$ 5,9 milhões
- 485: Valor de recurso destinado ao munícipio: R$7.878.321,79
- 486: Bugre teve 100% dos pleitos de Esgotamento Sanitário aprovado (R$4.254.293,76), conforme Deliberação 75. / O pleito de resíduos sólido (10% do total do recurso destinado ao munícipio, R$472.699,30) foi aprovado na NT20. / Aderiu à ata de registro de preço. / Bugre não quer Apoio Técnico, o que dificulta a elaboração de um cronograma.
- 489: 21/05/2019: confirmar na reunião com o município se a licitação está em andamento / 29/05/2019: município não compareceu a reunião, por isso premissamos que o município entregará a licitação ao banco no mês seguinte.
- 493: 02/06/2019: na primeira reunião com o município, o mesmo solicitou 6 meses para elaboração do projeto (2 meses básico e 4 meses executivo). Alterada a premissa para incluir o estudo de concepção, considerando 2 meses para cada etapa.
- 499: 23/05/2019: município pactuou com a Renova 2 meses para elaboração do projeto básico

| ID | WBS | Task | Type | Duration | Start | Finish | Predecessors | Complete | Remaining | Baseline start | Baseline finish | Baseline duration | Baseline 1 start | Baseline 1 finish | Total slack | Free slack | Text1 | Text2 | Text3 | Text6 | Text8 | Text12 | Text14 | Text16 | Text9 | Text18 | Text4 | Text5 | Text15 | Text7 | Text17 |
| --- | --- | --- | --- | --- | --- | --- | --- | --- | --- | --- | --- | --- | --- | --- | --- | --- | --- | --- | --- | --- | --- | --- | --- | --- | --- | --- | --- | --- | --- | --- | --- |
| 505 | 3.1.3.8.1.5 | **Elaboração do Projeto Executivo** |  | 155d | 2020-04-27 | 2020-12-04 |  |  |  | 2019-10-16 | 2020-06-03 | 155d | 2019-07-24 | 2020-03-09 | 296d |  | Verde | Verde | 0% | 0% | Compensatória | Verde | 0% | 0% |  |  |  |  |  |  |  |
| 506 | 3.1.3.8.1.5.1 | Elaborar projeto executivo |  | 40d | 2020-04-27 | 2020-06-23 | 499 |  |  | 2019-10-16 | 2019-12-11 | 40d | 2019-07-24 | 2019-11-21 | 296d | 0d | Verde | Verde | 0% | 0% | Compensatória | Verde | 0% | 0% | Município | Critério FR |  |  |  |  |  |
| 507 | 3.1.3.8.1.5.2 | Projeto executivo do Pleito BUGESPJ01 - Elaboração de projetos de sistema de esgotamento sanitário das localidades de Bugre, Boachá, São Lourenço, Livramento e São José do Bugre apresentado ao banco | milestone | 0d | 2020-06-23 | 2020-06-23 | 506 |  |  | 2019-12-11 | 2019-12-11 | 0d | 2019-11-21 | 2019-11-21 | 296d | 0d | Verde | Verde | 0% | 0% | Compensatória | Verde | 0% | 0% | Município |  |  |  |  |  |  |
| 508 | 3.1.3.8.1.5.3 | Analisar projeto executivo |  | 65d | 2020-06-24 | 2020-09-23 | 507 |  |  | 2019-12-13 | 2020-03-20 | 65d | 2019-11-22 | 2019-12-23 | 296d | 45d | Verde | Verde | 0% | 0% | Compensatória | Verde | 0% | 0% | Banco |  |  |  |  |  |  |
| 509 | 3.1.3.8.1.5.4 | Projeto executivo do Pleito BUGESPJ01 - Elaboração de projetos de sistema de esgotamento sanitário das localidades de Bugre, Boachá, São Lourenço, Livramento e São José do Bugre concluído | milestone | 0d | 2020-11-27 | 2020-11-27 | 503, 504, 508 |  |  | 2020-05-27 | 2020-05-27 | 0d | 2020-03-02 | 2020-03-02 | 251d | 0d | Verde | Verde | 0% | 0% | Compensatória | Verde | 0% | 0% | Município |  |  |  |  |  |  |
| 510 | 3.1.3.8.1.5.5 | Recurso do projeto executivo do Pleito BUGESPJ01 - Elaboração de projetos de sistema de esgotamento sanitário das localidades de Bugre, Boachá, São Lourenço, Livramento e São José do Bugre repassado | milestone | 0d | 2020-12-04 | 2020-12-04 | 509FS+5d |  |  | 2020-06-03 | 2020-06-03 | 0d | 2020-03-09 | 2020-03-09 | 720d | 0d | Verde | Verde | 0% | 0% | Compensatória | Verde | 0% | 0% | Banco |  |  |  |  |  |  |
| 511 | 3.1.3.8.1.6 | Pleito BUGESPJ01 - Elaboração de projetos de sistema de esgotamento sanitário das localidades de Bugre, Boachá, São Lourenço, Livramento e São José do Bugre concluído | milestone | 0d | 2020-12-04 | 2020-12-04 | 510 |  |  | 2020-06-03 | 2020-06-03 | 0d | 2020-03-09 | 2020-03-09 | 720d | 469d | Verde | Verde | 0% | 0% | Compensatória | Verde | 0% | 0% | Município |  |  |  |  |  |  |
| 512 | 3.1.3.8.2 | **Pleito BUGESOB01 - Implantação de sistema de esgotamento sanitário das localidades de Bugre, Boachá, São Lourenço, Livramento e São José do Bugre** |  | 474d | 2020-11-27 | 2022-10-25 |  |  |  | 2020-05-27 | 2022-04-22 | 474d | 2020-03-02 | 2022-01-25 | 251d |  | Verde | Verde | 0% | 0% | Compensatória | Verde | 0% | 0% |  |  |  |  |  |  |  |
| 513 | 3.1.3.8.2.1 | **Licitação da obra** |  | 78d | 2020-11-27 | 2021-03-25 |  |  |  | 2020-05-27 | 2020-09-16 | 78d | 2020-03-02 | 2020-06-24 | 251d |  | Verde | Verde | 0% | 0% | Compensatória | Verde | 0% | 0% |  |  |  |  |  |  |  |
| 514 | 3.1.3.8.2.1.1 | Licitação da obra do Pleito BUGESOB01 - Implantação de sistema de esgotamento sanitário das localidades de Bugre, Boachá, São Lourenço, Livramento e São José do Bugre autorizada pelo banco | milestone | 0d | 2020-11-27 | 2020-11-27 | 509 |  |  | 2020-05-27 | 2020-05-27 | 0d | 2020-03-02 | 2020-03-02 | 251d | 0d | Verde | Verde | 0% | 0% | Compensatória | Verde | 0% | 0% | Banco |  |  |  |  |  |  |
| 515 | 3.1.3.8.2.1.2 | Licitar obra |  | 64d | 2020-11-30 | 2021-03-05 | 514 |  |  | 2020-05-28 | 2020-08-26 | 64d | 2020-03-03 | 2020-06-03 | 251d | 0d | Verde | Verde | 0% | 0% | Compensatória | Verde | 0% | 0% | Município |  |  |  |  |  |  |
| 516 | 3.1.3.8.2.1.3 | Analisar e emitir resultado da licitação da obra |  | 14d | 2021-03-08 | 2021-03-25 | 515 |  |  | 2020-08-27 | 2020-09-16 | 14d | 2020-06-04 | 2020-06-24 | 251d | 0d | Verde | Verde | 0% | 0% | Compensatória | Verde | 0% | 0% | Banco |  |  |  |  |  |  |
| 517 | 3.1.3.8.2.1.4 | Licitação da obra do Pleito BUGESOB01 - Implantação de sistema de esgotamento sanitário das localidades de Bugre, Boachá, São Lourenço, Livramento e São José do Bugre concluída | milestone | 0d | 2021-03-25 | 2021-03-25 | 516 |  |  | 2020-09-16 | 2020-09-16 | 0d | 2020-06-24 | 2020-06-24 | 251d | 0d | Verde | Verde | 0% | 0% | Compensatória | Verde | 0% | 0% | Município |  |  |  |  |  |  |
| 518 | 3.1.3.8.2.2 | Executar obra |  | 250d | 2021-04-28 | 2022-04-27 | 517FS+21d |  |  | 2020-10-19 | 2021-10-19 | 250d | 2020-06-25 | 2021-07-15 | 251d | 0d | Verde | Verde | 0% | 0% | Compensatória | Verde | 0% | 0% | Município |  |  |  |  |  |  |
| 519 | 3.1.3.8.2.3 | Realizar processo de pré-operação |  | 120d | 2022-04-28 | 2022-10-18 | 518 |  |  | 2021-10-20 | 2022-04-13 | 120d | 2021-07-16 | 2022-01-18 | 251d | 0d | Verde | Verde | 0% | 0% | Compensatória | Verde | 0% | 0% | Município |  |  |  |  |  |  |
| 520 | 3.1.3.8.2.4 | Recurso da obra do Pleito BUGESOB01 - Implantação de sistema de esgotamento sanitário das localidades de Bugre, Boachá, São Lourenço, Livramento e São José do Bugre repassado | milestone | 0d | 2022-10-25 | 2022-10-25 | 519FS+5d |  |  | 2022-04-22 | 2022-04-22 | 0d | 2022-01-25 | 2022-01-25 | 251d | 0d | Verde | Verde | 0% | 0% | Compensatória | Verde | 0% | 0% | Banco |  |  |  |  |  |  |
| 521 | 3.1.3.8.2.5 | Pleito BUGESOB01 - Implantação de sistema de esgotamento sanitário das localidades de Bugre, Boachá, São Lourenço, Livramento e São José do Bugre concluído | milestone | 0d | 2022-10-25 | 2022-10-25 | 520 |  |  | 2022-04-22 | 2022-04-22 | 0d | 2022-01-25 | 2022-01-25 | 251d | 0d | Verde | Verde | 0% | 0% | Compensatória | Verde | 0% | 0% | Município |  |  |  |  |  |  |
| 522 | 3.1.3.8.3 | **Pleito BUGRSPM01 - Elaboração de estudos ambientais para implantação de aterro sanitário** |  | 382d | 2018-12-03 A | 2020-06-17 |  | 27% | 278.47d | 2018-12-03 | 2020-06-17 | 382d | 2018-12-03 | 2019-10-09 | 839d |  | Verde | Verde | 32% | 0% | Compensatória | Vermelho | 8% | 0% |  |  | 27 | 32 |  |  |  |
| 523 | 3.1.3.8.3.1 | **Licitação de Empresa para Licenciamento Ambiental** |  | 329d | 2018-12-03 A | 2020-03-30 |  | 31% | 226.62d | 2018-12-03 | 2020-03-30 | 329d | 2018-12-03 | 2019-07-25 | 453d |  | Verde | Verde | 37% | 0% | Compensatória | Vermelho | 20% | 0% |  |  | 31 | 37 | 20 |  |  |
| 524 | 3.1.3.8.3.1.1 | Licitação da empresa para Licenciamento Ambiental do Pleito BUGRSPM01 - Elaboração de estudos ambientais para implantação de aterro sanitário autorizada pelo banco | milestone | 0d | 2018-12-03 A | 2018-12-03 A | 3052FS-8d | 100% |  | 2018-12-03 | 2018-12-03 | 0d | 2018-12-03 | 2018-12-03 |  |  | Verde | Verde | 100% | 100% | Compensatória | Verde | 100% | 100% | Banco |  | 100 | 100 | 100 | 100 | 100 |
| 525 | 3.1.3.8.3.1.2 | Licitar empresa para Licenciamento Ambiental |  | 310d | 2018-12-03 A | 2020-03-03 | 524 | 33% | 209.18d | 2018-12-03 | 2020-03-03 | 310d | 2018-12-03 | 2019-06-28 | 453d | 0d | Verde | Verde | 39% | 0% | Compensatória | Vermelho | 39% | 0% | Município |  | 33 | 39 | 39 |  |  |
| 526 | 3.1.3.8.3.1.3 | Documentação de licitação da empresa para Licenciamento Ambiental do Pleito BUGRSPM01 - Elaboração de estudos ambientais para implantação de aterro sanitário apresentada ao banco | milestone | 0d | 2020-03-10 | 2020-03-10 | 525FS+5d |  |  | 2020-03-10 | 2020-03-10 | 0d | 2019-07-05 | 2019-07-05 | 453d | 0d | Verde | Verde | 0% | 0% | Compensatória | Verde | 0% | 0% | Município |  |  |  |  |  |  |
| 527 | 3.1.3.8.3.1.4 | Analisar e emitir resultado da licitação do empresa para Licenciamento Ambiental |  | 14d | 2020-03-11 | 2020-03-30 | 526 |  |  | 2020-03-11 | 2020-03-30 | 14d | 2019-07-08 | 2019-07-25 | 453d | 0d | Verde | Verde | 0% | 0% | Compensatória | Verde | 0% | 0% | Banco |  |  |  |  |  |  |
| 528 | 3.1.3.8.3.1.5 | Licitação da empresa para Licenciamento Ambiental do Pleito BUGRSPM01 - Elaboração de estudos ambientais para implantação de aterro sanitário concluída | milestone | 0d | 2020-03-30 | 2020-03-30 | 527 |  |  | 2020-03-30 | 2020-03-30 | 0d | 2019-07-25 | 2019-07-25 | 453d | 0d | Verde | Verde | 0% | 0% | Compensatória | Verde | 0% | 0% | Município |  |  |  |  |  |  |
| 529 | 3.1.3.8.3.2 | Executar o Licenciamento Ambiental |  | 48d | 2020-03-31 | 2020-06-09 | 528 |  |  | 2020-03-31 | 2020-06-09 | 48d | 2019-07-26 | 2019-10-02 | 453d | 0d | Verde | Verde | 0% | 0% | Compensatória | Verde | 0% | 0% | Município |  |  |  |  |  |  |
| 530 | 3.1.3.8.3.3 | Recurso do serviço do Pleito BUGRSPM01 - Elaboração de estudos ambientais para implantação de aterro sanitário repassado | milestone | 0d | 2020-06-17 | 2020-06-17 | 529FS+5d |  |  | 2020-06-17 | 2020-06-17 | 0d | 2019-10-09 | 2019-10-09 | 839d | 0d | Verde | Verde | 0% | 0% | Compensatória | Verde | 0% | 0% | Banco |  |  |  |  |  |  |
| 531 | 3.1.3.8.3.4 | Pleito BUGRSPM01 - Elaboração de estudos ambientais para implantação de aterro sanitário de Bugre concluído | milestone | 0d | 2020-06-17 | 2020-06-17 | 530 |  |  | 2020-06-17 | 2020-06-17 | 0d | 2019-10-09 | 2019-10-09 | 839d | 588d | Verde | Verde | 0% | 0% | Compensatória | Verde | 0% | 0% | Município |  |  |  |  |  |  |

Notes:
- 518: 22/05/2019: valor da obra 4.126.664,95 - 12 meses
- 524: Em 24/04/2019: na planilha do plano de aceleração de dezembro de 2018 foi encontrado o primeiro relato de início de elaboração de TR para contratação da empresa de licenciamento ambiental
- 525: Em 24/04/2019: em virtude do recorrente atraso na elaboração do TR de contratação da empresa para licenciamento e da dificuldade de aceitação do apoio técnico pelo consórcio, Sara V. estimou mais dois meses para a conclusão do processo. / Em 29/04/2019: atualizado como agendado / 21/05/2019: na reunião do consórcio município informou que terminou TR; / 29/05/2019: município Iapu mostrou interesse em alterar pleito para fazer aquisição de equipamentos, Ipaba e Bugre não compareceram na reunião e consórcio CIMVA1 não foi citado na reunião dos consórcios. Portanto, a duração dessa tarefa foi alterada até que se tenha algum encaminhamento.

| ID | WBS | Task | Type | Duration | Start | Finish | Predecessors | Complete | Remaining | Baseline start | Baseline finish | Baseline duration | Baseline 1 start | Baseline 1 finish | Total slack | Free slack | Text1 | Text2 | Text3 | Text6 | Text8 | Text12 | Text14 | Text16 | Text9 | Text18 | Text5 | Text7 | Text15 | Text17 | Text4 |
| --- | --- | --- | --- | --- | --- | --- | --- | --- | --- | --- | --- | --- | --- | --- | --- | --- | --- | --- | --- | --- | --- | --- | --- | --- | --- | --- | --- | --- | --- | --- | --- |
| 532 | 3.1.3.8.4 | **Pleito BUGRSOB02 - Implantação do aterro sanitário compartilhado** |  | 625d | 2019-07-01 | 2022-01-03 |  |  |  | 2019-06-28 | 2022-01-03 | 626d | 2019-06-28 | 2021-05-17 | 453d |  | Verde | Verde | 0% | 0% | Compensatória | Verde | 0% | 0% |  |  |  |  |  |  |  |
| 533 | 3.1.3.8.4.1 | **Aprovação do Projeto Executivo** |  | 234d | 2019-07-01 | 2020-06-09 |  |  |  | 2019-06-28 | 2020-06-09 | 235d | 2019-06-28 | 2019-10-03 | 453d |  | Verde | Verde | 0% | 0% | Compensatória | Verde | 0% | 0% |  |  |  |  |  |  |  |
| 534 | 3.1.3.8.4.1.1 | Projeto do Pleito BUGRSOB02 - Implantação do aterro sanitário compartilhado apresentado ao banco | milestone | 0d | 2019-07-01 | 2019-07-01 | 3052FS+135d |  |  | 2019-06-28 | 2019-06-28 | 0d | 2019-06-28 | 2019-06-28 | 619d | 0d | Verde | Verde | 0% | 0% | Compensatória | Verde | 0% | 0% | Município |  |  |  |  |  |  |
| 535 | 3.1.3.8.4.1.2 | Analisar projeto |  | 68d | 2019-07-02 | 2019-10-04 | 534 |  |  | 2019-07-01 | 2019-10-03 | 68d | 2019-07-01 | 2019-07-30 | 619d | 166d | Verde | Verde | 0% | 0% | Compensatória | Verde | 0% | 0% | Banco | Critério FR |  |  |  |  |  |
| 536 | 3.1.3.8.4.1.3 | Projeto do Pleito BUGRSOB02 - Implantação do aterro sanitário compartilhado concluído | milestone | 0d | 2020-06-09 | 2020-06-09 | 529, 535 |  |  | 2020-06-09 | 2020-06-09 | 0d | 2019-10-03 | 2019-10-03 | 453d | 0d | Verde | Verde | 0% | 0% | Compensatória | Verde | 0% | 0% | Município |  |  |  |  |  |  |
| 537 | 3.1.3.8.4.2 | **Licitação da obra** |  | 80d | 2020-06-09 | 2020-10-01 |  |  |  | 2020-06-09 | 2020-10-01 | 80d | 2019-10-03 | 2020-01-30 | 453d |  | Verde | Verde | 0% | 0% | Compensatória | Verde | 0% | 0% |  |  |  |  |  |  |  |
| 538 | 3.1.3.8.4.2.1 | Licitação da obra do Pleito BUGRSOB02 - Implantação do aterro sanitário compartilhado autorizada pelo banco | milestone | 0d | 2020-06-09 | 2020-06-09 | 536 |  |  | 2020-06-09 | 2020-06-09 | 0d | 2019-10-03 | 2019-10-03 | 453d | 0d | Verde | Verde | 0% | 0% | Compensatória | Verde | 0% | 0% | Banco |  |  |  |  |  |  |
| 539 | 3.1.3.8.4.2.2 | Licitar obra |  | 66d | 2020-06-10 | 2020-09-11 | 538 |  |  | 2020-06-10 | 2020-09-11 | 66d | 2019-10-04 | 2020-01-10 | 453d | 0d | Verde | Verde | 0% | 0% | Compensatória | Verde | 0% | 0% | Município |  |  |  |  |  |  |
| 540 | 3.1.3.8.4.2.3 | Analisar e emitir resultado da licitação da obra |  | 14d | 2020-09-14 | 2020-10-01 | 539 |  |  | 2020-09-14 | 2020-10-01 | 14d | 2020-01-13 | 2020-01-30 | 453d | 0d | Verde | Verde | 0% | 0% | Compensatória | Verde | 0% | 0% | Banco |  |  |  |  |  |  |
| 541 | 3.1.3.8.4.2.4 | Licitação da obra do Pleito BUGRSOB02 - Implantação do aterro sanitário compartilhado concluída | milestone | 0d | 2020-10-01 | 2020-10-01 | 540 |  |  | 2020-10-01 | 2020-10-01 | 0d | 2020-01-30 | 2020-01-30 | 453d | 0d | Verde | Verde | 0% | 0% | Compensatória | Verde | 0% | 0% | Município |  |  |  |  |  |  |
| 542 | 3.1.3.8.4.3 | Executar obra |  | 168d | 2020-10-29 | 2021-07-05 | 541FS+18d |  |  | 2020-10-29 | 2021-07-05 | 168d | 2020-03-02 | 2020-10-29 | 453d | 0d | Verde | Verde | 0% | 0% | Compensatória | Verde | 0% | 0% | Município |  |  |  |  |  |  |
| 543 | 3.1.3.8.4.4 | Realizar processo de pré-operação |  | 120d | 2021-07-06 | 2021-12-27 | 542 |  |  | 2021-07-06 | 2021-12-27 | 120d | 2020-10-30 | 2021-05-10 | 453d | 0d | Verde | Verde | 0% | 0% | Compensatória | Verde | 0% | 0% | Município |  |  |  |  |  |  |
| 544 | 3.1.3.8.4.5 | Recurso da obra do Pleito BUGRSOB02 - Implantação do aterro sanitário compartilhado repassado | milestone | 0d | 2022-01-03 | 2022-01-03 | 543FS+5d |  |  | 2022-01-03 | 2022-01-03 | 0d | 2021-05-17 | 2021-05-17 | 453d | 0d | Verde | Verde | 0% | 0% | Compensatória | Verde | 0% | 0% | Banco |  |  |  |  |  |  |
| 545 | 3.1.3.8.4.6 | Pleito BUGRSOB02 - Implantação do aterro sanitário compartilhado de Bugre concluído | milestone | 0d | 2022-01-03 | 2022-01-03 | 544 |  |  | 2022-01-03 | 2022-01-03 | 0d | 2021-05-17 | 2021-05-17 | 453d | 202d | Verde | Verde | 0% | 0% | Compensatória | Verde | 0% | 0% | Município |  |  |  |  |  |  |
| 546 | 3.1.3.8.5 | Recursos de Bugre repassados | milestone | 0d | 2022-10-25 | 2022-10-25 | 511, 521, 531, 545 |  |  | 2022-04-22 | 2022-04-22 | 0d | 2022-01-25 | 2022-01-25 | 251d |  | Verde | Verde | 0% | 0% | Compensatória | Verde | 0% | 0% | Banco |  |  |  |  |  |  |
| 547 | 3.1.3.9 | **Caratinga** |  | 720d | 2019-04-03 A | 2022-02-21 |  | 2% | 704.66d | 2019-04-03 | 2022-02-01 | 706d | 2019-04-03 | 2021-12-28 | 418d |  | Verde | Verde | 5% | 0% | Compensatória | Vermelho | 1% | 0% |  |  |  |  |  |  |  |
| 548 | 3.1.3.9.1 | **Pleito CARESPJ01 - Elaboração de projeto técnico para instalação de ETE nos 10 distritos do município** |  | 241d | 2019-04-16 A | 2020-04-03 |  | 2% | 236.55d | 2019-04-16 | 2020-03-16 | 227d | 2019-04-16 | 2019-08-27 | 888d |  | Verde | Verde | 13% | 100% | Compensatória | Verde | 11% | 11% |  |  | 13 | 100 | 11 | 11 |  |
| 549 | 3.1.3.9.1.1 | Alteração do Pleito CARESPJ01 - Elaboração de projeto técnico para instalação de ETE nos 10 distritos do município aprovada | milestone | 0d | 2019-07-31 | 2019-07-31 | 3052FS+157d |  |  | 2019-07-31 | 2019-07-31 | 0d | 2019-05-31 | 2019-05-31 | 576d | 48d | Verde | Verde | 0% | 0% | Compensatória | Verde | 0% | 0% | CT/CIF |  |  |  |  |  |  |
| 550 | 3.1.3.9.1.2 | **Licitação do Projeto** |  | 7d | 2019-04-16 A | 2019-04-26 A |  | 100% |  | 2019-04-16 | 2019-04-26 | 7d | 2019-04-16 | 2019-05-15 |  |  | Verde | Verde | 100% | 100% | Compensatória | Verde | 100% | 100% |  |  | 100 | 100 | 100 | 100 | 100 |
| 551 | 3.1.3.9.1.2.1 | Analisar e emitir resultado da licitação do projeto |  | 7d | 2019-04-16 A | 2019-04-26 A | 3052FS+84d | 100% |  | 2019-04-16 | 2019-04-26 | 7d | 2019-04-16 | 2019-05-15 |  |  | Verde | Verde | 100% | 100% | Compensatória | Verde | 100% | 100% | Banco |  | 100 | 100 | 100 | 100 | 100 |
| 552 | 3.1.3.9.1.2.2 | Licitação do projeto do Pleito CARESPJ01 - Elaboração de projeto técnico para instalação de ETE nos 10 distritos do município concluída | milestone | 0d | 2019-04-26 A | 2019-04-26 A | 551 | 100% |  | 2019-04-26 | 2019-04-26 | 0d | 2019-05-15 | 2019-05-15 |  |  | Verde | Verde | 100% | 100% | Compensatória | Verde | 100% | 100% | Município |  | 100 | 100 | 100 | 100 | 100 |
| 553 | 3.1.3.9.1.3 | **Aprovação do Projeto** |  | 212d | 2019-05-29 A | 2020-04-03 |  |  | 212d | 2019-06-07 | 2020-03-16 | 191d | 2019-05-15 | 2019-08-27 | 888d |  | Verde | Verde | 0% | 0% | Compensatória | Verde | 0% | 0% |  |  |  |  |  |  |  |
| 554 | 3.1.3.9.1.3.1 | Quatro projetos que serão pagos no primeiro momento informados ao banco | milestone | 0d | 2019-05-29 A | 2019-05-29 A | 552FS+22d | 100% |  | 2019-06-07 | 2019-06-07 | 0d | 2019-05-15 | 2019-05-15 |  |  | Verde | Verde | 0% | 0% | Compensatória | Verde | 0% | 0% | Município |  |  |  |  |  |  |
| 555 | 3.1.3.9.1.3.2 | Analisar estudo |  | 66d | 2019-07-01 | 2019-10-01 | 554FS+21d |  |  | 2019-06-10 | 2019-09-11 | 66d |  |  | 418d | 0d | Verde | Verde | 0% | 0% | Compensatória | Verde | 0% | 0% |  | Critério FR |  |  |  |  |  |
| 556 | 3.1.3.9.1.3.3 | Estudo de concepção do Pleito CARESPJ01 - Elaboração de projeto técnico para instalação de ETE nos 10 distritos do município aprovado | milestone | 0d | 2019-10-01 | 2019-10-01 | 555 |  |  | 2019-09-11 | 2019-09-11 | 0d |  |  | 528d | 0d | Verde | Verde | 0% | 0% | Compensatória | Verde | 0% | 0% |  |  |  |  |  |  |  |
| 557 | 3.1.3.9.1.3.4 | Recurso do estudo de concepção do Pleito CARESPJ01 - Elaboração de projeto técnico para instalação de ETE nos 10 distritos do município repassado | milestone | 0d | 2019-10-08 | 2019-10-08 | 549, 556FS+5d |  |  | 2019-09-18 | 2019-09-18 | 0d |  |  | 528d | 55d | Verde | Verde | 0% | 0% | Compensatória | Verde | 0% | 0% |  |  |  |  |  |  |  |
| 558 | 3.1.3.9.1.3.5 | Analisar projeto básico |  | 60d | 2019-10-02 | 2019-12-30 | 555 |  |  | 2019-09-12 | 2019-12-05 | 60d |  |  | 418d | 0d | Verde | Verde | 0% | 0% | Compensatória | Verde | 0% | 0% |  | Critério FR |  |  |  |  |  |
| 559 | 3.1.3.9.1.3.6 | Projeto básico do Pleito CARESPJ01 - Elaboração de projeto técnico para instalação de ETE nos 10 distritos do município aprovado | milestone | 0d | 2019-12-30 | 2019-12-30 | 557, 558 |  |  | 2019-12-05 | 2019-12-05 | 0d |  |  | 473d | 0d | Verde | Verde | 0% | 0% | Compensatória | Verde | 0% | 0% |  |  |  |  |  |  |  |
| 560 | 3.1.3.9.1.3.7 | Recurso do projeto básico do Pleito CARESPJ01 - Elaboração de projeto técnico para instalação de ETE nos 10 distritos do município repassado | milestone | 0d | 2020-01-07 | 2020-01-07 | 559FS+5d |  |  | 2019-12-13 | 2019-12-13 | 0d |  |  | 473d | 55d | Verde | Verde | 0% | 0% | Compensatória | Verde | 0% | 0% |  |  |  |  |  |  |  |
| 561 | 3.1.3.9.1.3.8 | Analisar projeto executivo |  | 60d | 2019-12-31 | 2020-03-27 | 558 |  |  | 2019-12-06 | 2020-03-09 | 60d | 2019-05-16 | 2019-06-14 | 418d | 0d | Verde | Verde | 0% | 0% | Compensatória | Verde | 0% | 0% | Banco |  |  |  |  |  |  |
| 562 | 3.1.3.9.1.3.9 | Projeto executivo do Pleito CARESPJ01 - Elaboração de projeto técnico para instalação de ETE nos 10 distritos do município aprovado | milestone | 0d | 2020-03-27 | 2020-03-27 | 564, 560, 561 |  |  | 2020-03-09 | 2020-03-09 | 0d | 2019-08-20 | 2019-08-20 | 418d | 0d | Verde | Verde | 0% | 0% | Compensatória | Verde | 0% | 0% | Município |  |  |  |  |  |  |
| 563 | 3.1.3.9.1.3.10 | Recurso do projeto executivo do Pleito CARESPJ01 - Elaboração de projeto técnico para instalação de ETE nos 10 distritos do município repassado | milestone | 0d | 2020-04-03 | 2020-04-03 | 562FS+5d |  |  | 2020-03-16 | 2020-03-16 | 0d | 2019-08-27 | 2019-08-27 | 888d | 0d | Verde | Verde | 0% | 0% | Compensatória | Verde | 0% | 0% | Banco |  |  |  |  |  |  |
| 564 | 3.1.3.9.1.4 | Realizar Licenciamento Ambiental |  | 186d | 2019-07-01 | 2020-03-27 | 554FS+21d |  |  | 2019-06-10 | 2020-03-09 | 186d | 2019-06-03 | 2019-08-20 | 418d | 0d | Verde | Verde | 0% | 0% | Compensatória | Verde | 0% | 0% | Município |  |  |  |  |  |  |
| 565 | 3.1.3.9.1.5 | Pleito CARESPJ01 - Elaboração de projeto técnico para instalação de ETE nos 10 distritos do município de Caratinga concluído | milestone | 0d | 2020-04-03 | 2020-04-03 | 563 |  |  | 2020-03-16 | 2020-03-16 | 0d | 2019-08-27 | 2019-08-27 | 888d | 470d | Verde | Verde | 0% | 0% | Compensatória | Verde | 0% | 0% | Município |  |  |  |  |  |  |

Notes:
- 534: 24/09/2019: em virtude de ainda não ter sido discutido cronograma com os consórcios e devido aos recorrentes atrasos do CIMVA 1, Sara V. estimou a apresentação do projeto em até 2 meses considerando que foi reportado que o projeto está concluído desde meados de 2018. / 01/07/2019: como o município não quer apoio técnico, não se tem informações sobre o andamento do pleito (e-mail Carlos)
- 542: Em 24/04/2019: o valor da obra de CIMVA1 é de R$ 1,8 milhões
- 546: Valor de recurso destinado ao munícipio: R$4.726.993,07
- 547: Caratinga teve 70,0% (R$15.441.510,07) dos recursos destinado para Esgotamento Sanitário aprovado, conforme Deliberação 75. / O município teve o pleito de resíduos sólidos negado (R$2.205.930,10 equivalente a 10% do total do recurso,). / Caratinga solicitou mudança de pleito, mas ainda não foi autorizado pelo CIF. / · Destinação de 13% do teto de esgotamento sanitário para resíduos sólidos. / Aderiu à ata de registro de preço.
- 549: Em 25/04/2019: o ofício 37/2019 de alteração de pleito foi enviado dia 22/04/2019 e provavelmente será aprovado no CIF de 31/05/2019. / 28/05/2019: o município pedirá a alteração de pleito para custear todos os projetos que ultrapassam o valor do pleito de 440 mil.
- 551: 25/04/2019: o município protocolou 16/04/2019 o processo licitatório completo no banco, após primeira negativa do banco do processo de licitação em 21/03/2019. / 02/06/2019: banco considerou processo licitatório conforme no dia 26/04/2019 conforme planilha Controle Gerencial Renova.
- 552: 02/06/2019: banco considerou processo licitatório conforme no dia 26/04/2019 conforme planilha Controle Gerencial Renova.
- 554: 21/05/2019: projeto está no banco e será analisado (Cynthia) / 23/05/2019: confirmar com o município semana que vem a situação (26/04 Banco aprovou licitação e autorizou projeto. O Município precisa explicar o que vai ser analisado ontem foi reenviado e-mail cobrando.) (fonte: e-mail Gislaine) / 28/05/2019: definir projetos que serão pagos no primeiro momento / 01/07/2019: No dia 27/05/2019 A Srt. Micheli informou que foi suprimido o Projeto do Distrito de Santo Antonio do Manhuaçu e dia 29/05/2019 foi enviado e-mail ao município solicitando planilha com preços por projeto conforme planilha Controle Gerencial Renova.
- 555: 01/07/2019: e-mail Gislaine dia 19/06/2019 - ...necessitamos de esclarecimento na divergência de valores~ no pleito de projetos, aguardamos o posicionamento do município para darmos andamento na verificação dos mesmos.

| ID | WBS | Task | Type | Duration | Start | Finish | Predecessors | Complete | Remaining | Baseline start | Baseline finish | Baseline duration | Baseline 1 start | Baseline 1 finish | Total slack | Free slack | Constraint | Text1 | Text2 | Text3 | Text6 | Text8 | Text12 | Text14 | Text16 | Text9 | Text7 | Text4 | Text5 | Text15 | Text17 | Text18 |
| --- | --- | --- | --- | --- | --- | --- | --- | --- | --- | --- | --- | --- | --- | --- | --- | --- | --- | --- | --- | --- | --- | --- | --- | --- | --- | --- | --- | --- | --- | --- | --- | --- |
| 566 | 3.1.3.9.2 | **Pleito CARESOB01 - Instalação de ETEs nos 10 distritos de Caratinga** |  | 638d | 2019-07-31 | 2022-02-21 |  |  |  | 2019-07-31 | 2022-02-01 | 624d | 2019-05-31 | 2021-07-29 | 418d |  |  | Verde | Verde | 0% | 0% | Compensatória | Verde | 0% | 0% |  |  |  |  |  |  |  |
| 567 | 3.1.3.9.2.1 | Alteração do Pleito CARESOB01 - Instalação de ETEs nos 10 distritos de Caratinga aprovada | milestone | 0d | 2019-07-31 | 2019-07-31 | 3052FS+157d |  |  | 2019-07-31 | 2019-07-31 | 0d | 2019-05-31 | 2019-05-31 | 581d | 163d |  | Verde | Verde | 0% | 0% | Compensatória | Verde | 0% | 0% | CT/CIF |  |  |  |  |  |  |
| 568 | 3.1.3.9.2.2 | **Licitação da obra** |  | 80d | 2020-03-27 | 2020-07-23 |  |  |  | 2020-03-09 | 2020-07-03 | 80d | 2019-08-20 | 2019-12-11 | 418d |  |  | Verde | Verde | 0% | 0% | Compensatória | Verde | 0% | 0% |  |  |  |  |  |  |  |
| 569 | 3.1.3.9.2.2.1 | Licitação da obra do Pleito CARESOB01 - Instalação de ETEs nos 10 distritos de Caratinga autorizada pelo banco | milestone | 0d | 2020-03-27 | 2020-03-27 | 562, 567 |  |  | 2020-03-09 | 2020-03-09 | 0d | 2019-08-20 | 2019-08-20 | 418d | 0d |  | Verde | Verde | 0% | 0% | Compensatória | Verde | 0% | 0% | Banco |  |  |  |  |  |  |
| 570 | 3.1.3.9.2.2.2 | Licitar obra |  | 66d | 2020-03-30 | 2020-07-03 | 569 |  |  | 2020-03-10 | 2020-06-15 | 66d | 2019-08-21 | 2019-11-21 | 418d | 0d |  | Verde | Verde | 0% | 0% | Compensatória | Verde | 0% | 0% | Município |  |  |  |  |  |  |
| 571 | 3.1.3.9.2.2.3 | Analisar licitação da obra |  | 14d | 2020-07-06 | 2020-07-23 | 570 |  |  | 2020-06-16 | 2020-07-03 | 14d | 2019-11-22 | 2019-12-11 | 418d | 0d |  | Verde | Verde | 0% | 0% | Compensatória | Verde | 0% | 0% | Banco |  |  |  |  |  |  |
| 572 | 3.1.3.9.2.2.4 | Licitação da obra do Pleito CARESOB01 - Instalação de ETEs nos 10 distritos de Caratinga concluída | milestone | 0d | 2020-07-23 | 2020-07-23 | 571 |  |  | 2020-07-03 | 2020-07-03 | 0d | 2019-12-11 | 2019-12-11 | 418d | 0d |  | Verde | Verde | 0% | 0% | Compensatória | Verde | 0% | 0% | Município |  |  |  |  |  |  |
| 573 | 3.1.3.9.2.3 | Executar obra |  | 250d | 2020-08-21 | 2021-08-23 | 572FS+20d |  |  | 2020-08-03 | 2021-08-03 | 250d | 2020-01-15 | 2021-01-15 | 418d | 0d |  | Verde | Verde | 0% | 0% | Compensatória | Verde | 0% | 0% | Município |  |  |  |  |  |  |
| 574 | 3.1.3.9.2.4 | Realizar processo de pré-operação |  | 120d | 2021-08-24 | 2022-02-14 | 573 |  |  | 2021-08-04 | 2022-01-25 | 120d | 2021-01-18 | 2021-07-22 | 418d | 0d |  | Verde | Verde | 0% | 0% | Compensatória | Verde | 0% | 0% | Município |  |  |  |  |  |  |
| 575 | 3.1.3.9.2.5 | Recurso da obra do Pleito CARESOB01 - Instalação de ETEs nos 10 distritos de Caratinga repassado | milestone | 0d | 2022-02-21 | 2022-02-21 | 574FS+5d |  |  | 2022-02-01 | 2022-02-01 | 0d | 2021-07-29 | 2021-07-29 | 418d | 0d |  | Verde | Verde | 0% | 0% | Compensatória | Verde | 0% | 0% | Banco |  |  |  |  |  |  |
| 576 | 3.1.3.9.2.6 | Pleito CARESOB01 - Instalação de ETEs nos 10 distritos de Caratinga concluído | milestone | 0d | 2022-02-21 | 2022-02-21 | 575 |  |  | 2022-02-01 | 2022-02-01 | 0d | 2021-07-29 | 2021-07-29 | 418d | 0d |  | Verde | Verde | 0% | 0% | Compensatória | Verde | 0% | 0% | Município |  |  |  |  |  |  |
| 577 | 3.1.3.9.3 | **Pleito CARRSOB02 - Ampliação do aterro sanitário de Caratinga, incluindo uma Unidade de Triagem e Compostagem - UTC** |  | 628d | 2019-04-03 A | 2021-10-08 |  | 4% | 603.53d | 2019-04-03 | 2021-10-08 | 628d | 2019-04-03 | 2021-12-28 | 510d |  |  | Verde | Verde | 6% | 33% | Compensatória | Vermelho | 3% | 1% |  | 33 |  |  |  |  |  |
| 578 | 3.1.3.9.3.1 | **Aprovação do Projeto Executivo** |  | 94d | 2019-04-03 A | 2019-08-19 |  | 25% | 70.5d | 2019-04-03 | 2019-08-19 | 94d | 2019-04-03 | 2019-10-21 | 510d |  |  | Verde | Verde | 42% | 39% | Compensatória | Vermelho | 28% | 11% |  | 39 | 19 | 42 | 28 | 11 |  |
| 579 | 3.1.3.9.3.1.1 | Projeto do Pleito CARRSOB02 - Ampliação do aterro sanitário de Caratinga, incluindo uma Unidade de Triagem e Compostagem - UTC apresentado ao banco | milestone | 0d | 2019-04-03 A | 2019-04-03 A |  | 100% |  | 2019-04-03 | 2019-04-03 | 0d | 2019-04-03 | 2019-04-03 |  |  | must start on 2019-04-03 | Verde | Verde | 100% | 100% | Compensatória | Verde | 100% | 100% | Município | 100 | 100 | 100 | 100 | 100 |  |
| 580 | 3.1.3.9.3.1.2 | Analisar projeto |  | 94d | 2019-04-03 A | 2019-08-19 | 579 | 25% | 70.5d | 2019-04-03 | 2019-08-19 | 94d | 2019-04-03 | 2019-08-20 | 510d | 0d |  | Verde | Verde | 80% | 40% | Compensatória | Vermelho | 80% | 32% | Banco | 40 | 36 | 80 | 80 | 32 | Conforme agendado |
| 581 | 3.1.3.9.3.1.3 | Projeto do Pleito CARRSOB02 - Ampliação do aterro sanitário de Caratinga, incluindo uma Unidade de Triagem e Compostagem - UTC concluído | milestone | 0d | 2019-08-19 | 2019-08-19 | 580 |  |  | 2019-08-19 | 2019-08-19 | 0d | 2019-10-21 | 2019-10-21 | 510d | 0d |  | Verde | Verde | 0% | 0% | Compensatória | Verde | 0% | 0% | Município |  |  |  |  |  |  |
| 582 | 3.1.3.9.3.2 | **Licitação da obra** |  | 80d | 2019-08-19 | 2019-12-10 |  |  |  | 2019-08-19 | 2019-12-10 | 80d | 2019-10-21 | 2020-02-17 | 510d |  |  | Verde | Verde | 0% | 0% | Compensatória | Verde | 0% | 0% |  |  |  |  |  |  |  |
| 583 | 3.1.3.9.3.2.1 | Licitação da obra do Pleito CARRSOB02 - Ampliação do aterro sanitário de Caratinga, incluindo uma Unidade de Triagem e Compostagem - UTC autorizada pelo banco | milestone | 0d | 2019-08-19 | 2019-08-19 | 581 |  |  | 2019-08-19 | 2019-08-19 | 0d | 2019-10-21 | 2019-10-21 | 510d | 0d |  | Verde | Verde | 0% | 0% | Compensatória | Verde | 0% | 0% | Banco |  |  |  |  |  |  |
| 584 | 3.1.3.9.3.2.2 | Licitar obra |  | 66d | 2019-08-20 | 2019-11-20 | 583 |  |  | 2019-08-20 | 2019-11-20 | 66d | 2019-10-22 | 2020-01-28 | 510d | 0d |  | Verde | Verde | 0% | 0% | Compensatória | Verde | 0% | 0% | Município |  |  |  |  |  | Critério FR |
| 585 | 3.1.3.9.3.2.3 | Analisar e emitir resultado da licitação da obra |  | 14d | 2019-11-21 | 2019-12-10 | 584 |  |  | 2019-11-21 | 2019-12-10 | 14d | 2020-01-29 | 2020-02-17 | 510d | 0d |  | Verde | Verde | 0% | 0% | Compensatória | Verde | 0% | 0% | Banco |  |  |  |  |  | Critério FR |
| 586 | 3.1.3.9.3.2.4 | Licitação da obra do Pleito CARRSOB02 - Ampliação do aterro sanitário de Caratinga, incluindo uma Unidade de Triagem e Compostagem - UTC concluída | milestone | 0d | 2019-12-10 | 2019-12-10 | 585 |  |  | 2019-12-10 | 2019-12-10 | 0d | 2020-02-17 | 2020-02-17 | 510d | 0d |  | Verde | Verde | 0% | 0% | Compensatória | Verde | 0% | 0% | Município |  |  |  |  |  |  |
| 587 | 3.1.3.9.3.3 | Executar obra |  | 309d | 2020-01-14 | 2021-04-13 | 586FS+20d |  |  | 2020-01-14 | 2021-04-13 | 309d | 2020-03-20 | 2021-06-17 | 510d | 0d |  | Verde | Verde | 0% | 0% | Compensatória | Verde | 0% | 0% | Município |  |  |  |  |  |  |
| 588 | 3.1.3.9.3.4 | Realizar processo de pré-operação |  | 120d | 2021-04-14 | 2021-10-01 | 587 |  |  | 2021-04-14 | 2021-10-01 | 120d | 2021-06-18 | 2021-12-20 | 510d | 0d |  | Verde | Verde | 0% | 0% | Compensatória | Verde | 0% | 0% | Município |  |  |  |  |  |  |
| 589 | 3.1.3.9.3.5 | Recurso da obra do Pleito CARRSOB02 - Ampliação do aterro sanitário de Caratinga, incluindo uma Unidade de Triagem e Compostagem - UTC repassado | milestone | 0d | 2021-10-08 | 2021-10-08 | 588FS+5d |  |  | 2021-10-08 | 2021-10-08 | 0d | 2021-12-28 | 2021-12-28 | 510d | 0d |  | Verde | Verde | 0% | 0% | Compensatória | Verde | 0% | 0% | Banco |  |  |  |  |  |  |
| 590 | 3.1.3.9.3.6 | Pleito CARRSOB02 - Ampliação do aterro sanitário de Caratinga, incluindo uma Unidade de Triagem e Compostagem - UTC de Caratinga concluído | milestone | 0d | 2021-10-08 | 2021-10-08 | 589 |  |  | 2021-10-08 | 2021-10-08 | 0d | 2021-12-28 | 2021-12-28 | 510d | 92d |  | Verde | Verde | 0% | 0% | Compensatória | Verde | 0% | 0% | Município |  |  |  |  |  |  |
| 591 | 3.1.3.9.4 | Recursos de Caratinga repassados | milestone | 0d | 2022-02-21 | 2022-02-21 | 565, 576, 590 |  |  | 2022-02-01 | 2022-02-01 | 0d | 2021-12-28 | 2021-12-28 | 418d |  |  | Verde | Verde | 0% | 0% | Compensatória | Verde | 0% | 0% | Banco |  |  |  |  |  |  |

Notes:
- 573: Em 25/04/2019: valor total das obras 15 milhões, foi considerado que as quatro obras ocorrerão em paralelo com valores iguais (3,75 milhões) - 12 meses
- 579: 06/02/2019: dia 03/04/2019 por telefone, Jayder (Sercretário do Meio Ambiente), esclareceu que os documentos encaminhados recentemente substituem os encaminhados anteriormente conforme planilha Controle Gerencial Renova
- 580: 21/05/2019: no dia 14/05/2019 o banco informou que as declarações foram recebidas e repassadas para o Eng. Cláudio Soares. Considerado mais 1 mês para a análise do banco. / 01/07/2019: e-mail Luiz BDMG - Por se tratar do primeiro caso de análise em consórcio, tivemos algumas definições internas sobre escopo, o que alongou a análise. Vamos concluir nossa avaliação até 05/07.
- 587: Em 24/09/2019: o valor da obra do CIDESLESTE é R$ 5,9 milhões
- 591: Valor de recurso destinado ao munícipio: R$22.059.301,00

| ID | WBS | Task | Type | Duration | Start | Finish | Predecessors | Complete | Remaining | Baseline start | Baseline finish | Baseline duration | Baseline 1 start | Baseline 1 finish | Total slack | Free slack | Text1 | Text2 | Text3 | Text6 | Text7 | Text8 | Text12 | Text14 | Text16 | Text4 | Text5 | Text15 | Text17 | Text9 | Text18 |
| --- | --- | --- | --- | --- | --- | --- | --- | --- | --- | --- | --- | --- | --- | --- | --- | --- | --- | --- | --- | --- | --- | --- | --- | --- | --- | --- | --- | --- | --- | --- | --- |
| 592 | 3.1.3.10 | **Colatina** |  | 993d | 2019-03-14 A | 2023-03-13 |  | 2% | 974.65d | 2019-03-14 | 2023-03-13 | 993d | 2019-03-14 | 2022-09-14 | 181d |  | Verde | Verde | 5% | 75% | 75 | Compensatória | Vermelho | 4% | 3% |  |  |  |  |  |  |
| 593 | 3.1.3.10.1 | **Pleito COLESOB26 - Complementação de recursos de contrapartida para implantação de 1ª etapa ETE (Valor orçado para conclusão, obra em execução)** |  | 274d | 2019-04-01 A | 2020-05-08 |  | 16% | 230.13d | 2019-04-01 | 2020-05-08 | 274d | 2019-03-14 | 2020-05-20 | 866d |  | Verde | Verde | 15% | 100% | 100 | Compensatória | Verde | 14% | 14% | 15 | 15 | 14 | 14 |  |  |
| 594 | 3.1.3.10.1.1 | Reembolso do Pleito COLESOB26 - Complementação de recursos de contrapartida para implantação de 1ª etapa ETE (Valor orçado para conclusão, obra em execução) aprovado | milestone | 0d | 2019-05-28 A | 2019-05-28 A | 3052FS+112d | 100% |  | 2019-05-28 | 2019-05-28 | 0d | 2019-05-31 | 2019-05-31 |  |  | Verde | Verde | 100% | 100% | 100 | Compensatória | Verde | 100% | 100% | 100 | 100 | 100 | 100 | CT/CIF |  |
| 595 | 3.1.3.10.1.2 | Analisar medições do reembolso da obra |  | 15d | 2019-06-10 A | 2019-07-01 | 594FS+8d | 25% | 11.25d | 2019-06-10 | 2019-06-24 | 10d |  |  | 1073d | 0d | Verde | Verde | 0% | 0% |  | Compensatória | Verde | 0% | 0% |  |  |  |  |  |  |
| 596 | 3.1.3.10.1.3 | Recurso parcial do Pleito COLESOB26 - Complementação de recursos de contrapartida para implantação de 1ª etapa ETE (Valor orçado para conclusão, obra em execução) repassado | milestone | 0d | 2019-07-08 | 2019-07-08 | 595FS+5d |  |  | 2019-07-01 | 2019-07-01 | 0d | 2019-06-07 | 2019-06-07 | 1073d | 207d | Verde | Verde | 0% | 0% |  | Compensatória | Verde | 0% | 0% |  |  |  |  | Banco |  |
| 597 | 3.1.3.10.1.4 | Alteração do Pleito COLESOB26 - Complementação de recursos de contrapartida para implantação de 1ª etapa ETE (Valor orçado para conclusão, obra em execução) aprovado pela Renova | milestone | 0d | 2019-06-10 A | 2019-06-10 A | 594FS+9d | 100% |  | 2019-06-14 | 2019-06-14 | 0d |  |  |  |  | Verde | Verde | 0% | 0% |  | Compensatória | Verde | 0% | 0% |  |  |  |  |  |  |
| 598 | 3.1.3.10.1.5 | Executar obra - parte Renova |  | 149d | 2019-04-01 A | 2019-10-31 | 594FS-39d | 28% | 107.28d | 2019-04-01 | 2019-10-31 | 149d | 2019-03-14 | 2019-10-31 | 866d | 0d | Verde | Verde | 28% | 100% | 100 | Compensatória | Verde | 28% | 28% | 28 | 28 | 28 | 28 | Município | Conforme agendado |
| 599 | 3.1.3.10.1.6 | Realizar processo de pré-operação |  | 120d | 2019-11-01 | 2020-04-30 | 598 |  |  | 2019-11-01 | 2020-04-30 | 120d | 2019-11-01 | 2020-05-13 | 866d | 0d | Verde | Verde | 0% | 0% |  | Compensatória | Verde | 0% | 0% |  |  |  |  | Município | Critério FR |
| 600 | 3.1.3.10.1.7 | Recurso da obra do Pleito COLESOB26 - Complementação de recursos de contrapartida para implantação de 1ª etapa ETE (Valor orçado para conclusão, obra em execução) repassado | milestone | 0d | 2020-05-08 | 2020-05-08 | 599FS+5d, 597 |  |  | 2020-05-08 | 2020-05-08 | 0d | 2020-05-20 | 2020-05-20 | 866d | 0d | Verde | Verde | 0% | 0% |  | Compensatória | Verde | 0% | 0% |  |  |  |  | Banco |  |
| 601 | 3.1.3.10.1.8 | Pleito COLESOB26 - Complementação de recursos de contrapartida para implantação de 1ª etapa ETE (Valor orçado para conclusão, obra em execução) de Colatina concluído | milestone | 0d | 2020-05-08 | 2020-05-08 | 600, 596 |  |  | 2020-05-08 | 2020-05-08 | 0d | 2020-05-20 | 2020-05-20 | 866d | 708d | Verde | Verde | 0% | 0% |  | Compensatória | Verde | 0% | 0% |  |  |  |  | Município |  |
| 602 | 3.1.3.10.2 | **Pleito COLESOB24 - Complementação de recursos de contrapartida para implantação da LR S03, parte integrante do SES do Lado Sul (em execução)** |  | 91d | 2019-03-25 A | 2019-08-02 |  | 71% | 26.25d | 2019-03-25 | 2019-08-07 | 94d | 2019-03-25 | 2019-07-10 | 1077d |  | Verde | Verde | 50% | 78% | 78 | Compensatória | Vermelho | 45% | 35% | 47 | 50 | 45 | 35 |  |  |
| 603 | 3.1.3.10.2.1 | Alteração do Pleito COLESOB24 - Complementação de recursos de contrapartida para implantação da LR S03, parte integrante do SES do Lado Sul (em execução) aprovado | milestone | 0d | 2019-06-10 A | 2019-06-10 A | 3052FS+121d | 100% |  | 2019-06-14 | 2019-06-14 | 0d |  |  |  |  | Verde | Verde | 0% | 0% |  | Compensatória | Verde | 0% | 0% |  |  |  |  |  |  |
| 604 | 3.1.3.10.2.2 | Reembolso do Pleito COLESOB24 - Complementação de recursos de contrapartida para implantação da LR S03, parte integrante do SES do Lado Sul (em execução) aprovado | milestone | 0d | 2019-07-26 | 2019-07-26 | 603FS+33d |  |  | 2019-08-01 | 2019-08-01 | 0d | 2019-05-31 | 2019-05-31 | 1082d |  | Verde | Verde | 0% | 0% |  | Compensatória | Verde | 0% | 0% |  |  |  |  | CT/CIF |  |
| 605 | 3.1.3.10.2.3 | Protocolar documentação de reembolso |  | 32d | 2019-03-25 A | 2019-06-05 A | 604FS-45d | 100% |  | 2019-03-25 | 2019-06-25 | 43d | 2019-03-25 | 2019-05-27 |  |  | Verde | Verde | 74% | 77% | 77 | Compensatória | Vermelho | 74% | 57% | 58 | 74 | 74 | 57 | Município | Conforme agendado |
| 606 | 3.1.3.10.2.4 | Analisar documentação de reembolso |  | 20d | 2019-06-06 A | 2019-07-04 | 605 | 25% | 15d | 2019-06-26 | 2019-07-09 | 10d | 2019-05-28 | 2019-06-10 | 1054d | 0d | Verde | Verde | 0% | 0% |  | Compensatória | Verde | 0% | 0% |  |  |  |  | Banco | Critério FR |
| 607 | 3.1.3.10.2.5 | Recurso do reembolso do Pleito COLESOB24 - Complementação de recursos de contrapartida para implantação da LR S03, parte integrante do SES do Lado Sul (em execução) repassado | milestone | 0d | 2019-08-02 | 2019-08-02 | 606FS+21d |  |  | 2019-08-07 | 2019-08-07 | 0d | 2019-07-10 | 2019-07-10 | 1054d | 0d | Verde | Verde | 0% | 0% |  | Compensatória | Verde | 0% | 0% |  |  |  |  | Banco |  |
| 608 | 3.1.3.10.2.6 | Pleito COLESOB24 - Complementação de recursos de contrapartida para implantação da LR S03, parte integrante do SES do Lado Sul (em execução) de Colatina concluído | milestone | 0d | 2019-08-02 | 2019-08-02 | 607 |  |  | 2019-08-07 | 2019-08-07 | 0d | 2019-07-10 | 2019-07-10 | 1054d | 896d | Verde | Verde | 0% | 0% |  | Compensatória | Verde | 0% | 0% |  |  |  |  | Município |  |
| 609 | 3.1.3.10.3 | **Pleito COLESOB25 - Complementação de recursos de contrapartida para implantação da EEE S02 e EEE S04, parte integrante do SES do Lado Sul (em execução)** |  | 91d | 2019-03-25 A | 2019-08-02 |  | 72% | 25.28d | 2019-03-25 | 2019-08-07 | 94d | 2019-03-25 | 2019-07-10 | 1077d |  | Verde | Verde | 50% | 77% | 77 | Compensatória | Vermelho | 44% | 34% | 47 | 50 | 44 | 34 |  |  |
| 610 | 3.1.3.10.3.1 | Alteração do Pleito COLESOB25 - Complementação de recursos de contrapartida para implantação da EEE S02 e EEE S04, parte integrante do SES do Lado Sul aprovada | milestone | 0d | 2019-06-10 A | 2019-06-10 A | 3052FS+121d | 100% |  | 2019-06-14 | 2019-06-14 | 0d |  |  |  |  | Verde | Verde | 0% | 0% |  | Compensatória | Verde | 0% | 0% |  |  |  |  |  |  |
| 611 | 3.1.3.10.3.2 | Reembolso do Pleito COLESOB25 - Complementação de recursos de contrapartida para implantação da EEE S02 e EEE S04, parte integrante do SES do Lado Sul (em execução) aprovado | milestone | 0d | 2019-07-26 | 2019-07-26 | 610FS+33d |  |  | 2019-08-01 | 2019-08-01 | 0d | 2019-05-31 | 2019-05-31 | 1082d |  | Verde | Verde | 0% | 0% |  | Compensatória | Verde | 0% | 0% |  |  |  |  | CT/CIF |  |
| 612 | 3.1.3.10.3.3 | Protocolar documentação de reembolso |  | 34d | 2019-03-25 A | 2019-06-05 A | 611FS-45d | 100% |  | 2019-03-25 | 2019-06-25 | 43d | 2019-03-25 | 2019-05-27 |  |  | Verde | Verde | 74% | 77% | 77 | Compensatória | Vermelho | 74% | 57% | 58 | 74 | 74 | 57 | Município | Conforme agendado |
| 613 | 3.1.3.10.3.4 | Analisar documentação de reembolso |  | 20d | 2019-06-06 A | 2019-07-04 | 612 | 25% | 15d | 2019-06-26 | 2019-07-09 | 10d | 2019-05-28 | 2019-06-10 | 1054d | 0d | Verde | Verde | 0% | 0% |  | Compensatória | Verde | 0% | 0% |  |  |  |  | Banco | Critério FR |
| 614 | 3.1.3.10.3.5 | Recurso do reembolso do Pleito COLESOB25 - Complementação de recursos de contrapartida para implantação da EEE S02 e EEE S04, parte integrante do SES do Lado Sul (em execução) repassado | milestone | 0d | 2019-08-02 | 2019-08-02 | 613FS+21d |  |  | 2019-08-07 | 2019-08-07 | 0d | 2019-07-10 | 2019-07-10 | 1054d | 0d | Verde | Verde | 0% | 0% |  | Compensatória | Verde | 0% | 0% |  |  |  |  | Banco |  |
| 615 | 3.1.3.10.3.6 | Pleito COLESOB25 - Complementação de recursos de contrapartida para implantação da EEE S02 e EEE S04, parte integrante do SES do Lado Sul (em execução) de Colatina concluído | milestone | 0d | 2019-08-02 | 2019-08-02 | 614 |  |  | 2019-08-07 | 2019-08-07 | 0d | 2019-07-10 | 2019-07-10 | 1054d | 896d | Verde | Verde | 0% | 0% |  | Compensatória | Verde | 0% | 0% |  |  |  |  | Município |  |

Notes:
- 592: Colatina teve 100% dos pleitos de Esgotamento Sanitário Aprovado. / O pleito de resíduos sólido (10% do total do recurso destinado ao munícipio) foi aprovado. / Colatina tem obras na prioridade 2, 3 e 5. / Para a prioridade 3 ainda não temos informações de como está o licenciamento ambiental, o que poderá impactar a programação destas obras.
- 593: Cronograma 1
- 594: Em 16/04/2019: o município enviou o ofício de alteração de pleito no dia 20/03/2019 para receber o reembolso do % executado das obras com recurso da renova. A análise do pleito não foi realizada na câmara técnica de 2/04/2019 ficando para o dia 07/05/2019 e CIF no dia 31/05/2019. / 05/06/2019: a NT 39 foi aprovada pelo CIF no dia 28/05/2019.
- 595: 01/07/2019: a análise das medições do reembolso da obra começou após a reunião com o município da 2a rodada, porém estão faltando algumas informações que foram solicitadas ao município. O banco estava aguardando a Ata da reunião do CIF recebida em junho. Atividade foi reprogramada para o próximo ciclo.
- 596: Em 16/04/2019: R$ 795.048,64 reembolso
- 597: 07/06/2019: ofício de alteração do valor do pleito de R$ 2.128.291,87 para R$ 2.015.010,84 foi enviado a Fundação Renova e será aprovado até o dia 14/06/2019 / 13/06/2019: Renova aprovou a alteração do pleito dia 10/06 (ofício 052019.6752-01)
- 598: Em 16/04/2019: premissa - início de obra (início de uso do recurso da Renova) 30 dias antes do envio da primeira medição / Em 29/04/2019: atualizado como agendado / 05/06/2019: município informou que a obra com o recurso da Renova começou dia 01/04/2019
- 603: 05/06/2019: município encaminhou à Renova o pedido de alteração do valor do pleito para R$ 2.173.835, que será aprovado pela Renova até o dia 14/06/2019. / 13/06/2019: Renova aprovou a alteração do pleito dia 10/06 (ofício 052019.6752-01)
- 604: Em 16/04/2019: a alteração do pleito será aprovada no dia 30/05 pelo CIF. / 05/06/2019: o município irá protocolar a documentação até o dia 17/06/2019.
- 605: 16/04/2019: na reunião do dia 25/03 município informou que parte da documentação foi apresentada ao banco (projeto). Foi constatado durante a reunião a necessidade de apresentação de outros documentos (licença, terreno, etc.), por isso a data foi postergada até final de maio. / 31/05/2019: conforme e-mail da Mônica o município ainda não protocolou documentação, pois falta a assinatura do prefeito. / 01/07/2019: município protocolou documentação no dia da reunião da 2a rodada de reuniões (05/06/2019). Banco solicitou outros documentos conforme e-mail do Luiz.
- 606: 01/07/2019: município protocolou documentação no dia da reunião da 2a rodada de reuniões (05/06/2019). Banco solicitou outros documentos conforme e-mail do Luiz. A aprovação do reembolso depende da aprovação do CIF.
- 610: 13/06/2019: Renova aprovou a alteração do pleito dia 10/06 (ofício 052019.6752-01)
- 612: 31/05/2019: conforme e-mail da Mônica o município ainda não protocolou documentação, pois falta a assinatura do prefeito. / 01/07/2019: município protocolou documentação no dia da reunião da 2a rodada de reuniões (05/06/2019). Banco solicitou outros documentos conforme e-mail do Luiz.
- 613: 01/07/2019: município protocolou documentação no dia da reunião da 2a rodada de reuniões (05/06/2019). Banco solicitou outros documentos conforme e-mail do Luiz. A aprovação do reembolso depende da aprovação do CIF.

| ID | WBS | Task | Type | Duration | Start | Finish | Predecessors | Complete | Remaining | Baseline start | Baseline finish | Baseline duration | Baseline 1 start | Baseline 1 finish | Total slack | Free slack | Text1 | Text2 | Text3 | Text6 | Text7 | Text8 | Text12 | Text14 | Text16 | Text9 | Text4 | Text5 | Text15 | Text17 | Text18 |
| --- | --- | --- | --- | --- | --- | --- | --- | --- | --- | --- | --- | --- | --- | --- | --- | --- | --- | --- | --- | --- | --- | --- | --- | --- | --- | --- | --- | --- | --- | --- | --- |
| 616 | 3.1.3.10.4 | **Pleito COLESOB27 - Implantação da 2ª etapa do SES do Lado Norte da sede municipal - EEEs e LRs** |  | 482d | 2019-03-25 A | 2021-03-03 |  | 15% | 411.62d | 2019-03-25 | 2021-02-19 | 474d | 2019-03-25 | 2021-02-18 | 663d |  | Verde | Verde | 9% | 50% | 50 | Compensatória | Vermelho | 6% | 3% |  |  |  |  |  |  |
| 617 | 3.1.3.10.4.1 | Alteração do Pleito COLESOB27 - Implantação da 2ª etapa do SES do Lado Norte da sede municipal - EEEs e LRs aprovada | milestone | 0d | 2019-06-10 A | 2019-06-10 A | 3052FS+121d | 100% |  | 2019-06-14 | 2019-06-14 | 0d | 2019-06-27 | 2019-06-27 |  |  | Verde | Verde | 0% | 0% |  | Compensatória | Verde | 0% | 0% | CT/CIF |  |  |  |  |  |
| 618 | 3.1.3.10.4.2 | **Apresentação do Projeto** |  | 82d | 2019-03-25 A | 2019-07-22 |  | 80% | 16d | 2019-03-25 | 2019-07-10 | 74d | 2019-03-25 | 2019-06-27 | 663d |  | Verde | Verde | 63% | 48% | 48 | Compensatória | Vermelho | 61% | 29% |  | 40 | 63 | 61 | 29 |  |
| 619 | 3.1.3.10.4.2.1 | Atualizar documentos do projeto |  | 68d | 2019-03-25 A | 2019-07-02 | 3052FS+68d | 97% | 2d | 2019-03-25 | 2019-06-03 | 48d | 2019-03-25 | 2019-05-31 | 663d | 0d | Verde | Verde | 97% | 48% | 48 | Compensatória | Vermelho | 97% | 47% | Município | 52 | 97 | 97 | 47 | Conforme agendado |
| 620 | 3.1.3.10.4.2.2 | Projeto do Pleito COLESOB27 - Implantação da 2ª etapa do SES do Lado Norte da sede municipal - EEEs e LRs apresentado ao banco | milestone | 0d | 2019-07-02 | 2019-07-02 | 617FS+3d, 619 |  |  | 2019-06-19 | 2019-06-19 | 0d | 2019-05-31 | 2019-05-31 | 663d | 0d | Verde | Verde | 0% | 0% |  | Compensatória | Verde | 0% | 0% | Município |  |  |  |  |  |
| 621 | 3.1.3.10.4.2.3 | Analisar projeto |  | 14d | 2019-07-03 | 2019-07-22 | 620, 617FF |  |  | 2019-06-21 | 2019-07-10 | 14d | 2019-06-07 | 2019-06-27 | 663d | 0d | Verde | Verde | 0% | 0% |  | Compensatória | Verde | 0% | 0% | Banco |  |  |  |  | Critério FR |
| 622 | 3.1.3.10.4.2.4 | Projeto do Pleito COLESOB27 - Implantação da 2ª etapa do SES do Lado Norte da sede municipal - EEEs e LRs aprovado | milestone | 0d | 2019-07-22 | 2019-07-22 | 621 |  |  | 2019-07-10 | 2019-07-10 | 0d | 2019-06-27 | 2019-06-27 | 663d | 0d | Verde | Verde | 0% | 0% |  | Compensatória | Verde | 0% | 0% | Município |  |  |  |  |  |
| 623 | 3.1.3.10.4.3 | **Licitação da obra** |  | 74d | 2019-07-29 | 2019-11-11 |  |  |  | 2019-07-17 | 2019-10-30 | 74d | 2019-07-04 | 2019-10-17 | 663d |  | Verde | Verde | 0% | 0% |  | Compensatória | Verde | 0% | 0% |  |  |  |  |  |  |
| 624 | 3.1.3.10.4.3.1 | Licitação da obra do Pleito COLESOB27 - Implantação da 2ª etapa do SES do Lado Norte da sede municipal - EEEs e LRs autorizada pelo banco | milestone | 0d | 2019-07-29 | 2019-07-29 | 622FS+5d |  |  | 2019-07-17 | 2019-07-17 | 0d | 2019-07-04 | 2019-07-04 | 663d | 0d | Verde | Verde | 0% | 0% |  | Compensatória | Verde | 0% | 0% | Banco |  |  |  |  |  |
| 625 | 3.1.3.10.4.3.2 | Licitar obra |  | 66d | 2019-07-30 | 2019-10-30 | 624 |  |  | 2019-07-18 | 2019-10-18 | 66d | 2019-07-05 | 2019-10-07 | 663d | 0d | Verde | Verde | 0% | 0% |  | Compensatória | Verde | 0% | 0% | Município |  |  |  |  | Critério FR |
| 626 | 3.1.3.10.4.3.3 | Analisar e emitir resultado da licitação da obra |  | 8d | 2019-10-31 | 2019-11-11 | 625 |  |  | 2019-10-21 | 2019-10-30 | 8d | 2019-10-08 | 2019-10-17 | 663d | 0d | Verde | Verde | 0% | 0% |  | Compensatória | Verde | 0% | 0% | Banco |  |  |  |  | Critério FR |
| 627 | 3.1.3.10.4.3.4 | Licitação da obra do Pleito COLESOB27 - Implantação da 2ª etapa do SES do Lado Norte da sede municipal - EEEs e LRs concluída | milestone | 0d | 2019-11-11 | 2019-11-11 | 626 |  |  | 2019-10-30 | 2019-10-30 | 0d | 2019-10-17 | 2019-10-17 | 663d | 0d | Verde | Verde | 0% | 0% |  | Compensatória | Verde | 0% | 0% | Município |  |  |  |  |  |
| 628 | 3.1.3.10.4.4 | Executar obra |  | 176d | 2019-12-11 | 2020-08-27 | 627FS+20d |  |  | 2019-11-29 | 2020-08-17 | 176d | 2019-11-18 | 2020-08-04 | 663d | 0d | Verde | Verde | 0% | 0% |  | Compensatória | Verde | 0% | 0% | Município |  |  |  |  |  |
| 629 | 3.1.3.10.4.5 | Realizar processo de pré-operação |  | 120d | 2020-08-28 | 2021-02-24 | 628 |  |  | 2020-08-18 | 2021-02-09 | 120d | 2020-08-05 | 2021-02-08 | 663d | 0d | Verde | Verde | 0% | 0% |  | Compensatória | Verde | 0% | 0% | Município |  |  |  |  |  |
| 630 | 3.1.3.10.4.6 | Recurso da obra do Pleito COLESOB27 - Implantação da 2ª etapa do SES do Lado Norte da sede municipal - EEEs e LRs repassado | milestone | 0d | 2021-03-03 | 2021-03-03 | 629FS+5d |  |  | 2021-02-19 | 2021-02-19 | 0d | 2021-02-18 | 2021-02-18 | 663d | 0d | Verde | Verde | 0% | 0% |  | Compensatória | Verde | 0% | 0% | Banco |  |  |  |  |  |
| 631 | 3.1.3.10.4.7 | Pleito COLESOB27 - Implantação da 2ª etapa do SES do Lado Norte da sede municipal - EEEs e LRs de Colatina concluído | milestone | 0d | 2021-03-03 | 2021-03-03 | 630 |  |  | 2021-02-19 | 2021-02-19 | 0d | 2021-02-18 | 2021-02-18 | 663d | 505d | Verde | Verde | 0% | 0% |  | Compensatória | Verde | 0% | 0% | Município |  |  |  |  |  |
| 632 | 3.1.3.10.5 | **Pleito COLESOB06 - Complementação do SES do Lado Norte da sede municipal - EEEs, LRs e interceptor** |  | 760d | 2019-11-29 | 2022-12-22 |  |  |  | 2019-11-29 | 2022-12-22 | 760d | 2019-03-25 | 2022-06-10 | 212d |  | Verde | Verde | 0% | 0% |  | Compensatória | Verde | 0% | 0% |  |  |  |  |  |  |
| 633 | 3.1.3.10.5.1 | **Aprovação do Projeto** |  | 103d | 2019-11-29 | 2020-05-05 |  |  |  | 2019-11-29 | 2020-05-05 | 103d | 2019-03-25 | 2019-08-30 | 212d |  | Verde | Verde | 0% | 0% |  | Compensatória | Verde | 0% | 0% |  |  |  |  |  |  |
| 634 | 3.1.3.10.5.1.1 | Atualizar planilha orçamentária do projeto |  | 89d | 2019-11-29 | 2020-04-13 | 3052FS+241d |  |  | 2019-11-29 | 2020-04-13 | 89d | 2019-03-25 | 2019-07-31 | 212d | 0d | Verde | Verde | 0% | 0% |  | Compensatória | Verde | 0% | 0% | Município |  |  |  |  | Conforme agendado |
| 635 | 3.1.3.10.5.1.2 | Projeto do Pleito COLESOB06 - Complementação do SES do Lado Norte da sede municipal - EEEs, LRs e interceptor apresentado ao banco | milestone | 0d | 2020-04-13 | 2020-04-13 | 634 |  |  | 2020-04-13 | 2020-04-13 | 0d | 2019-07-31 | 2019-07-31 | 212d | 0d | Verde | Verde | 0% | 0% |  | Compensatória | Verde | 0% | 0% | Município |  |  |  |  |  |
| 636 | 3.1.3.10.5.1.3 | Analisar projeto |  | 14d | 2020-04-14 | 2020-05-05 | 635 |  |  | 2020-04-14 | 2020-05-05 | 14d | 2019-08-12 | 2019-08-30 | 212d | 0d | Verde | Verde | 0% | 0% |  | Compensatória | Verde | 0% | 0% | Banco |  |  |  |  | Critério FR |
| 637 | 3.1.3.10.5.1.4 | Projeto do Pleito COLESOB06 - Complementação do SES do Lado Norte da sede municipal - EEEs, LRs e interceptor concluído | milestone | 0d | 2020-05-05 | 2020-05-05 | 636 |  |  | 2020-05-05 | 2020-05-05 | 0d | 2019-08-30 | 2019-08-30 | 212d | 0d | Verde | Verde | 0% | 0% |  | Compensatória | Verde | 0% | 0% | Município |  |  |  |  |  |
| 638 | 3.1.3.10.5.2 | **Licitação da obra** |  | 92d | 2020-05-12 | 2020-09-21 |  |  |  | 2020-05-12 | 2020-09-21 | 92d | 2019-09-06 | 2020-01-21 | 212d |  | Verde | Verde | 0% | 0% |  | Compensatória | Verde | 0% | 0% |  |  |  |  |  |  |
| 639 | 3.1.3.10.5.2.1 | Licitação da obra do Pleito COLESOB06 - Complementação do SES do Lado Norte da sede municipal - EEEs, LRs e interceptor autorizada pelo banco | milestone | 0d | 2020-05-12 | 2020-05-12 | 637FS+5d |  |  | 2020-05-12 | 2020-05-12 | 0d | 2019-09-06 | 2019-09-06 | 212d | 0d | Verde | Verde | 0% | 0% |  | Compensatória | Verde | 0% | 0% | Banco |  |  |  |  |  |
| 640 | 3.1.3.10.5.2.2 | Licitar obra |  | 86d | 2020-05-13 | 2020-09-11 | 639 |  |  | 2020-05-13 | 2020-09-11 | 86d | 2019-09-09 | 2020-01-13 | 212d | 0d | Verde | Verde | 0% | 0% |  | Compensatória | Verde | 0% | 0% | Município |  |  |  |  |  |
| 641 | 3.1.3.10.5.2.3 | Analisar e emitir resultado da licitação da obra |  | 6d | 2020-09-14 | 2020-09-21 | 640 |  |  | 2020-09-14 | 2020-09-21 | 6d | 2020-01-14 | 2020-01-21 | 212d | 0d | Verde | Verde | 0% | 0% |  | Compensatória | Verde | 0% | 0% | Banco |  |  |  |  |  |
| 642 | 3.1.3.10.5.2.4 | Licitação da obra do Pleito COLESOB06 - Complementação do SES do Lado Norte da sede municipal - EEEs, LRs e interceptor concluída | milestone | 0d | 2020-09-21 | 2020-09-21 | 641 |  |  | 2020-09-21 | 2020-09-21 | 0d | 2020-01-21 | 2020-01-21 | 212d | 0d | Verde | Verde | 0% | 0% |  | Compensatória | Verde | 0% | 0% | Município |  |  |  |  |  |
| 643 | 3.1.3.10.5.3 | Executar obra |  | 414d | 2020-10-22 | 2022-06-22 | 642FS+21d |  |  | 2020-10-22 | 2022-06-22 | 414d | 2020-02-20 | 2021-11-29 | 212d | 0d | Verde | Verde | 0% | 0% |  | Compensatória | Verde | 0% | 0% | Município |  |  |  |  |  |
| 644 | 3.1.3.10.5.4 | Realizar processo de pré-operação |  | 120d | 2022-06-23 | 2022-12-15 | 643 |  |  | 2022-06-23 | 2022-12-15 | 120d | 2021-11-30 | 2022-06-03 | 212d | 0d | Verde | Verde | 0% | 0% |  | Compensatória | Verde | 0% | 0% | Município |  |  |  |  |  |
| 645 | 3.1.3.10.5.5 | Recurso da obra do Pleito COLESOB06 - Complementação do SES do Lado Norte da sede municipal - EEEs, LRs e interceptor repassado | milestone | 0d | 2022-12-22 | 2022-12-22 | 644FS+5d |  |  | 2022-12-22 | 2022-12-22 | 0d | 2022-06-10 | 2022-06-10 | 212d | 0d | Verde | Verde | 0% | 0% |  | Compensatória | Verde | 0% | 0% | Banco |  |  |  |  |  |
| 646 | 3.1.3.10.5.6 | Pleito COLESOB06 - Complementação do SES do Lado Norte da sede municipal - EEEs, LRs e interceptor de Colatina concluído | milestone | 0d | 2022-12-22 | 2022-12-22 | 645 |  |  | 2022-12-22 | 2022-12-22 | 0d | 2022-06-10 | 2022-06-10 | 212d | 54d | Verde | Verde | 0% | 0% |  | Compensatória | Verde | 0% | 0% | Município |  |  |  |  |  |

Notes:
- 617: 16/04/2019: o processo de alteração e aprovação do pleito será realizado em paralelo com a elaboração do projeto / 05/06/2019: município enviou o ofício para a Renova com o pedido de alteração do valor do pleito da obra, que será aprovado dia 14/06/2019. / 13/06/2019: Renova aprovou a alteração do pleito dia 10/06 (ofício 052019.6752-01)
- 619: 29/04/2019: município está finalizando o projeto (fonte: Cynthia). / 02/07/2019: Luiz informou que o município terminou os ajustes e vai enviar ao banco hoje.
- 634: 05/06/2019: não é prioridade do município. Foi premissado que a atualização começa final de novembro.

| ID | WBS | Task | Type | Duration | Start | Finish | Predecessors | Baseline start | Baseline finish | Baseline duration | Baseline 1 start | Baseline 1 finish | Total slack | Free slack | Text1 | Text2 | Text3 | Text6 | Text8 | Text12 | Text14 | Text16 | Text9 |
| --- | --- | --- | --- | --- | --- | --- | --- | --- | --- | --- | --- | --- | --- | --- | --- | --- | --- | --- | --- | --- | --- | --- | --- |
| 647 | 3.1.3.10.6 | **Pleito COLESPJ01 - Elaboração de projetos executivos de recuperação da ETE do bairro Columbia** |  | 277d | 2019-12-02 | 2021-01-14 |  | 2019-12-02 | 2021-01-14 | 277d | 2019-12-02 | 2021-01-14 | 303d |  | Verde | Verde | 0% | 0% | Compensatória | Verde | 0% | 0% |  |
| 648 | 3.1.3.10.6.1 | **Licitação do Projeto** |  | 61d | 2019-12-02 | 2020-03-04 |  | 2019-12-02 | 2020-03-04 | 61d | 2019-12-02 | 2020-03-04 | 303d |  | Verde | Verde | 0% | 0% | Compensatória | Verde | 0% | 0% |  |
| 649 | 3.1.3.10.6.1.1 | Licitar projeto |  | 42d | 2019-12-02 | 2020-02-03 | 3052FS+242d | 2019-12-02 | 2020-02-03 | 42d | 2019-12-02 | 2020-02-03 | 303d | 0d | Verde | Verde | 0% | 0% | Compensatória | Verde | 0% | 0% | Município |
| 650 | 3.1.3.10.6.1.2 | Documentação de licitação do Pleito COLESPJ01 - Elaboração de projetos executivos de recuperação da ETE do bairro Columbia apresentada ao banco | milestone | 0d | 2020-02-10 | 2020-02-10 | 649FS+5d | 2020-02-10 | 2020-02-10 | 0d | 2020-02-10 | 2020-02-10 | 303d | 0d | Verde | Verde | 0% | 0% | Compensatória | Verde | 0% | 0% | Município |
| 651 | 3.1.3.10.6.1.3 | Analisar e emitir resultado da licitação do projeto |  | 14d | 2020-02-11 | 2020-03-04 | 650 | 2020-02-11 | 2020-03-04 | 14d | 2020-02-11 | 2020-03-04 | 303d | 0d | Verde | Verde | 0% | 0% | Compensatória | Verde | 0% | 0% | Banco |
| 652 | 3.1.3.10.6.1.4 | Licitação do projeto do Pleito COLESPJ01 - Elaboração de projetos executivos de recuperação da ETE do bairro Columbia concluída | milestone | 0d | 2020-03-04 | 2020-03-04 | 651 | 2020-03-04 | 2020-03-04 | 0d | 2020-03-04 | 2020-03-04 | 303d | 0d | Verde | Verde | 0% | 0% | Compensatória | Verde | 0% | 0% | Município |
| 653 | 3.1.3.10.6.2 | **Elaboração do Projeto Básico** |  | 134d | 2020-03-05 | 2020-09-15 |  | 2020-03-05 | 2020-09-15 | 134d | 2020-03-05 | 2020-09-15 | 303d |  | Verde | Verde | 0% | 0% | Compensatória | Verde | 0% | 0% |  |
| 654 | 3.1.3.10.6.2.1 | Elaborar Projeto Básico |  | 62d | 2020-03-05 | 2020-06-03 | 652 | 2020-03-05 | 2020-06-03 | 62d | 2020-03-05 | 2020-06-03 | 303d | 0d | Verde | Verde | 0% | 0% | Compensatória | Verde | 0% | 0% | Município |
| 655 | 3.1.3.10.6.2.2 | Projeto básico do Pleito COLESPJ01 - Elaboração de projetos executivos de recuperação da ETE do bairro Columbia apresentado ao banco | milestone | 0d | 2020-06-03 | 2020-06-03 | 654 | 2020-06-03 | 2020-06-03 | 0d | 2020-06-03 | 2020-06-03 | 303d | 0d | Verde | Verde | 0% | 0% | Compensatória | Verde | 0% | 0% | Município |
| 656 | 3.1.3.10.6.2.3 | Analisar Projeto Básico |  | 67d | 2020-06-04 | 2020-09-08 | 655 | 2020-06-04 | 2020-09-08 | 67d | 2020-06-04 | 2020-07-06 | 380d | 0d | Verde | Verde | 0% | 0% | Compensatória | Verde | 0% | 0% | Banco |
| 657 | 3.1.3.10.6.2.4 | Projeto básico do Pleito COLESPJ01 - Elaboração de projetos executivos de recuperação da ETE do bairro Columbia concluído | milestone | 0d | 2020-09-08 | 2020-09-08 | 656 | 2020-09-08 | 2020-09-08 | 0d | 2020-09-08 | 2020-09-08 | 380d | 0d | Verde | Verde | 0% | 0% | Compensatória | Verde | 0% | 0% | Município |
| 658 | 3.1.3.10.6.2.5 | Recurso do projeto básico do Pleito COLESPJ01 - Elaboração de projetos executivos de recuperação da ETE do bairro Columbia repassado | milestone | 0d | 2020-09-15 | 2020-09-15 | 657FS+5d | 2020-09-15 | 2020-09-15 | 0d | 2020-09-15 | 2020-09-15 | 380d | 77d | Verde | Verde | 0% | 0% | Compensatória | Verde | 0% | 0% | Banco |
| 659 | 3.1.3.10.6.3 | Realizar Licenciamento Ambiental |  | 149d | 2020-06-04 | 2021-01-07 | 655 | 2020-06-04 | 2021-01-07 | 149d | 2020-06-04 | 2021-01-07 | 303d | 0d | Verde | Verde | 0% | 0% | Compensatória | Verde | 0% | 0% | Município |
| 660 | 3.1.3.10.6.4 | **Elaboração do Projeto Executivo** |  | 154d | 2020-06-04 | 2021-01-14 |  | 2020-06-04 | 2021-01-14 | 154d | 2020-06-04 | 2021-01-14 | 303d |  | Verde | Verde | 0% | 0% | Compensatória | Verde | 0% | 0% |  |
| 661 | 3.1.3.10.6.4.1 | Elaborar Projeto Executivo |  | 84d | 2020-06-04 | 2020-10-01 | 655 | 2020-06-04 | 2020-10-01 | 84d | 2020-06-04 | 2020-10-01 | 303d | 0d | Verde | Verde | 0% | 0% | Compensatória | Verde | 0% | 0% | Município |
| 662 | 3.1.3.10.6.4.2 | Projeto executivo do Pleito COLESPJ01 - Elaboração de projetos executivos de recuperação da ETE do bairro Columbia apresentado ao banco | milestone | 0d | 2020-10-01 | 2020-10-01 | 661 | 2020-10-01 | 2020-10-01 | 0d | 2020-10-01 | 2020-10-01 | 303d | 0d | Verde | Verde | 0% | 0% | Compensatória | Verde | 0% | 0% | Município |
| 663 | 3.1.3.10.6.4.3 | Analisar projeto executivo |  | 65d | 2020-10-02 | 2021-01-07 | 662 | 2020-10-02 | 2021-01-07 | 65d | 2020-10-02 | 2020-11-06 | 303d | 0d | Verde | Verde | 0% | 0% | Compensatória | Verde | 0% | 0% | Banco |
| 664 | 3.1.3.10.6.4.4 | Projeto executivo do Pleito COLESPJ01 - Elaboração de projetos executivos de recuperação da ETE do bairro Columbia concluído | milestone | 0d | 2021-01-07 | 2021-01-07 | 659, 658, 663 | 2021-01-07 | 2021-01-07 | 0d | 2021-01-07 | 2021-01-07 | 303d | 0d | Verde | Verde | 0% | 0% | Compensatória | Verde | 0% | 0% | Município |
| 665 | 3.1.3.10.6.4.5 | Recurso do projeto executivo do Pleito COLESPJ01 - Elaboração de projetos executivos de recuperação da ETE do bairro Columbia repassado | milestone | 0d | 2021-01-14 | 2021-01-14 | 664FS+5d | 2021-01-14 | 2021-01-14 | 0d | 2021-01-14 | 2021-01-14 | 303d | 0d | Verde | Verde | 0% | 0% | Compensatória | Verde | 0% | 0% | Banco |
| 666 | 3.1.3.10.6.5 | Pleito COLESPJ01 - Elaboração de projetos executivos de recuperação da ETE do bairro Columbia de Colatina concluído | milestone | 0d | 2021-01-14 | 2021-01-14 | 665 | 2021-01-14 | 2021-01-14 | 0d | 2021-01-14 | 2021-01-14 | 303d | 0d | Verde | Verde | 0% | 0% | Compensatória | Verde | 0% | 0% | Município |
| 667 | 3.1.3.10.7 | **Pleito COLESOB08 - Recuperação da ETE do Bairro Columbia** |  | 391d | 2021-01-14 | 2022-08-09 |  | 2021-01-14 | 2022-08-09 | 391d | 2021-01-14 | 2022-08-22 | 303d |  | Verde | Verde | 0% | 0% | Compensatória | Verde | 0% | 0% |  |
| 668 | 3.1.3.10.7.1 | **Licitação da Obra** |  | 75d | 2021-01-14 | 2021-05-06 |  | 2021-01-14 | 2021-05-06 | 75d | 2021-01-14 | 2021-05-06 | 303d |  | Verde | Verde | 0% | 0% | Compensatória | Verde | 0% | 0% |  |
| 669 | 3.1.3.10.7.1.1 | Licitação da obra do Pleito COLESOB08 - Recuperação da ETE do Bairro Columbia autorizada pelo banco | milestone | 0d | 2021-01-14 | 2021-01-14 | 666 | 2021-01-14 | 2021-01-14 | 0d | 2021-01-14 | 2021-01-14 | 303d | 0d | Verde | Verde | 0% | 0% | Compensatória | Verde | 0% | 0% | Banco |
| 670 | 3.1.3.10.7.1.2 | Licitar Obra |  | 61d | 2021-01-15 | 2021-04-15 | 669 | 2021-01-15 | 2021-04-15 | 61d | 2021-01-15 | 2021-04-15 | 303d | 0d | Verde | Verde | 0% | 0% | Compensatória | Verde | 0% | 0% | Município |
| 671 | 3.1.3.10.7.1.3 | Analisar e emitir resultado da licitação da obra |  | 14d | 2021-04-16 | 2021-05-06 | 670 | 2021-04-16 | 2021-05-06 | 14d | 2021-04-16 | 2021-05-06 | 303d | 0d | Verde | Verde | 0% | 0% | Compensatória | Verde | 0% | 0% | Banco |
| 672 | 3.1.3.10.7.1.4 | Licitação da obra Pleito COLESOB08 - Recuperação da ETE do Bairro Columbia concluída | milestone | 0d | 2021-05-06 | 2021-05-06 | 671 | 2021-05-06 | 2021-05-06 | 0d | 2021-05-06 | 2021-05-06 | 303d | 0d | Verde | Verde | 0% | 0% | Compensatória | Verde | 0% | 0% | Município |
| 673 | 3.1.3.10.7.2 | Executar obra |  | 171d | 2021-06-07 | 2022-02-07 | 672FS+20d | 2021-06-07 | 2022-02-07 | 171d | 2021-06-07 | 2022-02-07 | 303d | 0d | Verde | Verde | 0% | 0% | Compensatória | Verde | 0% | 0% | Município |
| 674 | 3.1.3.10.7.3 | Realizar processo de pré-operação |  | 120d | 2022-02-08 | 2022-08-02 | 673 | 2022-02-08 | 2022-08-02 | 120d | 2022-02-08 | 2022-08-12 | 303d | 0d | Verde | Verde | 0% | 0% | Compensatória | Verde | 0% | 0% | Município |
| 675 | 3.1.3.10.7.4 | Recurso da obra do Pleito COLESOB08 - Recuperação da ETE do Bairro Columbia repassado | milestone | 0d | 2022-08-09 | 2022-08-09 | 674FS+5d | 2022-08-09 | 2022-08-09 | 0d | 2022-08-22 | 2022-08-22 | 303d | 0d | Verde | Verde | 0% | 0% | Compensatória | Verde | 0% | 0% | Banco |
| 676 | 3.1.3.10.7.5 | Pleito COLESOB08 - Recuperação da ETE do Bairro Columbia de Colatina concluído | milestone | 0d | 2022-08-09 | 2022-08-09 | 675 | 2022-08-09 | 2022-08-09 | 0d | 2022-08-22 | 2022-08-22 | 303d | 145d | Verde | Verde | 0% | 0% | Compensatória | Verde | 0% | 0% | Município |

| ID | WBS | Task | Type | Duration | Start | Finish | Predecessors | Baseline start | Baseline finish | Baseline duration | Baseline 1 start | Baseline 1 finish | Total slack | Free slack | Text1 | Text2 | Text3 | Text6 | Text8 | Text12 | Text14 | Text16 | Text9 |
| --- | --- | --- | --- | --- | --- | --- | --- | --- | --- | --- | --- | --- | --- | --- | --- | --- | --- | --- | --- | --- | --- | --- | --- |
| 677 | 3.1.3.10.8 | **Pleito COLESPJ02 - Elaboração de projetos executivos de recuperação da ETE do bairro Luiz Iglesias (Acampamento)** |  | 282d | 2019-12-02 | 2021-01-21 |  | 2019-12-02 | 2021-01-21 | 282d | 2019-12-02 | 2021-01-14 | 341d |  | Verde | Verde | 0% | 0% | Compensatória | Verde | 0% | 0% |  |
| 678 | 3.1.3.10.8.1 | **Licitação do Projeto** |  | 61d | 2019-12-02 | 2020-03-04 |  | 2019-12-02 | 2020-03-04 | 61d | 2019-12-02 | 2020-02-21 | 341d |  | Verde | Verde | 0% | 0% | Compensatória | Verde | 0% | 0% |  |
| 679 | 3.1.3.10.8.1.1 | Licitar projeto |  | 42d | 2019-12-02 | 2020-02-03 | 3052FS+242d | 2019-12-02 | 2020-02-03 | 42d | 2019-12-02 | 2020-02-03 | 341d | 0d | Verde | Verde | 0% | 0% | Compensatória | Verde | 0% | 0% | Município |
| 680 | 3.1.3.10.8.1.2 | Documentação de licitação do Pleito COLESPJ02 - Elaboração de projetos executivos de recuperação da ETE do bairro Luiz Iglesias (Acampamento) apresentada ao banco | milestone | 0d | 2020-02-10 | 2020-02-10 | 679FS+5d | 2020-02-10 | 2020-02-10 | 0d | 2020-02-03 | 2020-02-03 | 341d | 0d | Verde | Verde | 0% | 0% | Compensatória | Verde | 0% | 0% | Município |
| 681 | 3.1.3.10.8.1.3 | Analisar e emitir resultado da licitação do projeto |  | 14d | 2020-02-11 | 2020-03-04 | 680 | 2020-02-11 | 2020-03-04 | 14d | 2020-02-04 | 2020-02-21 | 341d | 0d | Verde | Verde | 0% | 0% | Compensatória | Verde | 0% | 0% | Banco |
| 682 | 3.1.3.10.8.1.4 | Licitação do projeto do Pleito COLESPJ02 - Elaboração de projetos executivos de recuperação da ETE do bairro Luiz Iglesias (Acampamento) concluída | milestone | 0d | 2020-03-04 | 2020-03-04 | 681 | 2020-03-04 | 2020-03-04 | 0d | 2020-02-21 | 2020-02-21 | 341d | 0d | Verde | Verde | 0% | 0% | Compensatória | Verde | 0% | 0% | Município |
| 683 | 3.1.3.10.8.2 | **Elaboração do Projeto Básico** |  | 134d | 2020-03-05 | 2020-09-15 |  | 2020-03-05 | 2020-09-15 | 134d | 2020-02-27 | 2020-09-08 | 341d |  | Verde | Verde | 0% | 0% | Compensatória | Verde | 0% | 0% |  |
| 684 | 3.1.3.10.8.2.1 | Elaborar Projeto Básico |  | 62d | 2020-03-05 | 2020-06-03 | 682 | 2020-03-05 | 2020-06-03 | 62d | 2020-02-27 | 2020-05-27 | 341d | 0d | Verde | Verde | 0% | 0% | Compensatória | Verde | 0% | 0% | Município |
| 685 | 3.1.3.10.8.2.2 | Projeto básico do Pleito COLESPJ02 - Elaboração de projetos executivos de recuperação da ETE do bairro Luiz Iglesias (Acampamento) apresentado ao banco | milestone | 0d | 2020-06-03 | 2020-06-03 | 684 | 2020-06-03 | 2020-06-03 | 0d | 2020-05-27 | 2020-05-27 | 341d | 0d | Verde | Verde | 0% | 0% | Compensatória | Verde | 0% | 0% | Município |
| 686 | 3.1.3.10.8.2.3 | Analisar Projeto Básico |  | 67d | 2020-06-04 | 2020-09-08 | 685 | 2020-06-04 | 2020-09-08 | 67d | 2020-05-28 | 2020-06-29 | 423d | 0d | Verde | Verde | 0% | 0% | Compensatória | Verde | 0% | 0% | Banco |
| 687 | 3.1.3.10.8.2.4 | Projeto básico do Pleito COLESPJ02 - Elaboração de projetos executivos de recuperação da ETE do bairro Luiz Iglesias (Acampamento) concluído | milestone | 0d | 2020-09-08 | 2020-09-08 | 686 | 2020-09-08 | 2020-09-08 | 0d | 2020-08-31 | 2020-08-31 | 423d | 0d | Verde | Verde | 0% | 0% | Compensatória | Verde | 0% | 0% | Município |
| 688 | 3.1.3.10.8.2.5 | Recurso do projeto básico do Pleito COLESPJ02 - Elaboração de projetos executivos de recuperação da ETE do bairro Luiz Iglesias (Acampamento) repassado | milestone | 0d | 2020-09-15 | 2020-09-15 | 687FS+5d | 2020-09-15 | 2020-09-15 | 0d | 2020-09-08 | 2020-09-08 | 423d | 82d | Verde | Verde | 0% | 0% | Compensatória | Verde | 0% | 0% | Banco |
| 689 | 3.1.3.10.8.3 | Realizar Licenciamento Ambiental |  | 149d | 2020-06-04 | 2021-01-07 | 685 | 2020-06-04 | 2021-01-07 | 149d | 2020-05-28 | 2020-12-30 | 346d | 5d | Verde | Verde | 0% | 0% | Compensatória | Verde | 0% | 0% | Município |
| 690 | 3.1.3.10.8.4 | **Elaboração do Projeto Executivo** |  | 159d | 2020-06-04 | 2021-01-21 |  | 2020-06-04 | 2021-01-21 | 159d | 2020-05-28 | 2021-01-14 | 341d |  | Verde | Verde | 0% | 0% | Compensatória | Verde | 0% | 0% |  |
| 691 | 3.1.3.10.8.4.1 | Elaborar Projeto Executivo |  | 88d | 2020-06-04 | 2020-10-07 | 685 | 2020-06-04 | 2020-10-07 | 88d | 2020-05-28 | 2020-09-30 | 341d | 0d | Verde | Verde | 0% | 0% | Compensatória | Verde | 0% | 0% | Município |
| 692 | 3.1.3.10.8.4.2 | Projeto executivo do Pleito COLESPJ02 - Elaboração de projetos executivos de recuperação da ETE do bairro Luiz Iglesias (Acampamento) apresentado ao banco | milestone | 0d | 2020-10-07 | 2020-10-07 | 691 | 2020-10-07 | 2020-10-07 | 0d | 2020-09-30 | 2020-09-30 | 341d | 0d | Verde | Verde | 0% | 0% | Compensatória | Verde | 0% | 0% | Município |
| 693 | 3.1.3.10.8.4.3 | Analisar projeto executivo |  | 66d | 2020-10-08 | 2021-01-14 | 692 | 2020-10-08 | 2021-01-14 | 66d | 2020-10-01 | 2020-11-03 | 341d | 0d | Verde | Verde | 0% | 0% | Compensatória | Verde | 0% | 0% | Banco |
| 694 | 3.1.3.10.8.4.4 | Projeto executivo do Pleito COLESPJ02 - Elaboração de projetos executivos de recuperação da ETE do bairro Luiz Iglesias (Acampamento) concluído | milestone | 0d | 2021-01-14 | 2021-01-14 | 689, 688, 693 | 2021-01-14 | 2021-01-14 | 0d | 2021-01-07 | 2021-01-07 | 341d | 0d | Verde | Verde | 0% | 0% | Compensatória | Verde | 0% | 0% | Município |
| 695 | 3.1.3.10.8.4.5 | Recurso do projeto executivo do Pleito COLESPJ02 - Elaboração de projetos executivos de recuperação da ETE do bairro Luiz Iglesias (Acampamento) repassado | milestone | 0d | 2021-01-21 | 2021-01-21 | 694FS+5d | 2021-01-21 | 2021-01-21 | 0d | 2021-01-14 | 2021-01-14 | 341d | 0d | Verde | Verde | 0% | 0% | Compensatória | Verde | 0% | 0% | Banco |
| 696 | 3.1.3.10.8.5 | Pleito COLESPJ02 - Elaboração de projetos executivos de recuperação da ETE do bairro Luiz Iglesias (Acampamento) de Colatina concluído | milestone | 0d | 2021-01-21 | 2021-01-21 | 695 | 2021-01-21 | 2021-01-21 | 0d | 2021-01-14 | 2021-01-14 | 341d | 0d | Verde | Verde | 0% | 0% | Compensatória | Verde | 0% | 0% | Município |
| 697 | 3.1.3.10.9 | **Pleito COLESOB09 - Recuperação da ETE do bairro Luiz Iglesias (Acampamento)** |  | 348d | 2021-01-21 | 2022-06-15 |  | 2021-01-21 | 2022-06-15 | 348d | 2021-01-14 | 2022-06-21 | 341d |  | Verde | Verde | 0% | 0% | Compensatória | Verde | 0% | 0% |  |
| 698 | 3.1.3.10.9.1 | **Licitação da Obra** |  | 75d | 2021-01-21 | 2021-05-13 |  | 2021-01-21 | 2021-05-13 | 75d | 2021-01-14 | 2021-05-06 | 341d |  | Verde | Verde | 0% | 0% | Compensatória | Verde | 0% | 0% |  |
| 699 | 3.1.3.10.9.1.1 | Licitação da obra do Pleito COLESOB09 - Recuperação da ETE do bairro Luiz Iglesias (Acampamento) autorizada pelo banco | milestone | 0d | 2021-01-21 | 2021-01-21 | 696 | 2021-01-21 | 2021-01-21 | 0d | 2021-01-14 | 2021-01-14 | 341d | 0d | Verde | Verde | 0% | 0% | Compensatória | Verde | 0% | 0% | Banco |
| 700 | 3.1.3.10.9.1.2 | Licitar Obra |  | 61d | 2021-01-22 | 2021-04-23 | 699 | 2021-01-22 | 2021-04-23 | 61d | 2021-01-15 | 2021-04-15 | 341d | 0d | Verde | Verde | 0% | 0% | Compensatória | Verde | 0% | 0% | Município |
| 701 | 3.1.3.10.9.1.3 | Analisar e emitir resultado da licitação da obra |  | 14d | 2021-04-26 | 2021-05-13 | 700 | 2021-04-26 | 2021-05-13 | 14d | 2021-04-16 | 2021-05-06 | 341d | 0d | Verde | Verde | 0% | 0% | Compensatória | Verde | 0% | 0% | Banco |
| 702 | 3.1.3.10.9.1.4 | Licitação da obra do Pleito COLESOB09 - Recuperação da ETE do bairro Luiz Iglesias (Acampamento) concluída | milestone | 0d | 2021-05-13 | 2021-05-13 | 701 | 2021-05-13 | 2021-05-13 | 0d | 2021-05-06 | 2021-05-06 | 341d | 0d | Verde | Verde | 0% | 0% | Compensatória | Verde | 0% | 0% | Município |
| 703 | 3.1.3.10.9.2 | Executar obra |  | 128d | 2021-06-14 | 2021-12-14 | 702FS+20d | 2021-06-14 | 2021-12-14 | 128d | 2021-06-07 | 2021-12-07 | 341d | 0d | Verde | Verde | 0% | 0% | Compensatória | Verde | 0% | 0% | Município |
| 704 | 3.1.3.10.9.3 | Realizar processo de pré-operação |  | 120d | 2021-12-15 | 2022-06-08 | 703 | 2021-12-15 | 2022-06-08 | 120d | 2021-12-08 | 2022-06-13 | 341d | 0d | Verde | Verde | 0% | 0% | Compensatória | Verde | 0% | 0% | Município |
| 705 | 3.1.3.10.9.4 | Recurso da obra do Pleito COLESOB09 - Recuperação da ETE do bairro Luiz Iglesias (Acampamento) repassado | milestone | 0d | 2022-06-15 | 2022-06-15 | 704FS+5d | 2022-06-15 | 2022-06-15 | 0d | 2022-06-21 | 2022-06-21 | 341d | 0d | Verde | Verde | 0% | 0% | Compensatória | Verde | 0% | 0% | Banco |
| 706 | 3.1.3.10.9.5 | Pleito COLESOB09 - Recuperação da ETE do bairro Luiz Iglesias (Acampamento) de Colatina concluído | milestone | 0d | 2022-06-15 | 2022-06-15 | 705 | 2022-06-15 | 2022-06-15 | 0d | 2022-06-21 | 2022-06-21 | 341d | 183d | Verde | Verde | 0% | 0% | Compensatória | Verde | 0% | 0% | Município |

| ID | WBS | Task | Type | Duration | Start | Finish | Predecessors | Baseline start | Baseline finish | Baseline duration | Baseline 1 start | Baseline 1 finish | Total slack | Free slack | Text1 | Text2 | Text3 | Text6 | Text8 | Text12 | Text14 | Text16 | Text9 |
| --- | --- | --- | --- | --- | --- | --- | --- | --- | --- | --- | --- | --- | --- | --- | --- | --- | --- | --- | --- | --- | --- | --- | --- |
| 707 | 3.1.3.10.10 | **Pleito COLESPJ03 - Elaboração de projeto executivo de complementação do SES do distrito de Itapina** |  | 277d | 2019-12-02 | 2021-01-14 |  | 2019-12-02 | 2021-01-14 | 277d | 2019-12-02 | 2021-01-14 | 346d |  | Verde | Verde | 0% | 0% | Compensatória | Verde | 0% | 0% |  |
| 708 | 3.1.3.10.10.1 | **Licitação do Projeto** |  | 61d | 2019-12-02 | 2020-03-04 |  | 2019-12-02 | 2020-03-04 | 61d | 2019-12-02 | 2020-03-04 | 346d |  | Verde | Verde | 0% | 0% | Compensatória | Verde | 0% | 0% |  |
| 709 | 3.1.3.10.10.1.1 | Licitar projeto |  | 42d | 2019-12-02 | 2020-02-03 | 3052FS+242d | 2019-12-02 | 2020-02-03 | 42d | 2019-12-02 | 2020-02-03 | 346d | 0d | Verde | Verde | 0% | 0% | Compensatória | Verde | 0% | 0% | Município |
| 710 | 3.1.3.10.10.1.2 | Documentação de licitação do Pleito COLESPJ03 - Elaboração de projeto executivo de complementação do SES do distrito de Itapina apresentada ao banco | milestone | 0d | 2020-02-10 | 2020-02-10 | 709FS+5d | 2020-02-10 | 2020-02-10 | 0d | 2020-02-10 | 2020-02-10 | 346d | 0d | Verde | Verde | 0% | 0% | Compensatória | Verde | 0% | 0% | Município |
| 711 | 3.1.3.10.10.1.3 | Analisar e emitir resultado da licitação do projeto |  | 14d | 2020-02-11 | 2020-03-04 | 710 | 2020-02-11 | 2020-03-04 | 14d | 2020-02-11 | 2020-03-04 | 346d | 0d | Verde | Verde | 0% | 0% | Compensatória | Verde | 0% | 0% | Banco |
| 712 | 3.1.3.10.10.1.4 | Licitação do projeto do Pleito COLESPJ03 - Elaboração de projeto executivo de complementação do SES do distrito de Itapina concluída | milestone | 0d | 2020-03-04 | 2020-03-04 | 711 | 2020-03-04 | 2020-03-04 | 0d | 2020-03-04 | 2020-03-04 | 346d | 0d | Verde | Verde | 0% | 0% | Compensatória | Verde | 0% | 0% | Município |
| 713 | 3.1.3.10.10.2 | **Elaboração do Projeto Básico** |  | 134d | 2020-03-05 | 2020-09-15 |  | 2020-03-05 | 2020-09-15 | 134d | 2020-03-05 | 2020-09-15 | 346d |  | Verde | Verde | 0% | 0% | Compensatória | Verde | 0% | 0% |  |
| 714 | 3.1.3.10.10.2.1 | Elaborar Projeto Básico |  | 62d | 2020-03-05 | 2020-06-03 | 712 | 2020-03-05 | 2020-06-03 | 62d | 2020-03-05 | 2020-06-03 | 346d | 0d | Verde | Verde | 0% | 0% | Compensatória | Verde | 0% | 0% | Município |
| 715 | 3.1.3.10.10.2.2 | Projeto básico do Pleito COLESPJ03 - Elaboração de projeto executivo de complementação do SES do distrito de Itapina apresentado ao banco | milestone | 0d | 2020-06-03 | 2020-06-03 | 714 | 2020-06-03 | 2020-06-03 | 0d | 2020-06-03 | 2020-06-03 | 346d | 0d | Verde | Verde | 0% | 0% | Compensatória | Verde | 0% | 0% | Município |
| 716 | 3.1.3.10.10.2.3 | Analisar Projeto Básico |  | 67d | 2020-06-04 | 2020-09-08 | 715 | 2020-06-04 | 2020-09-08 | 67d | 2020-06-04 | 2020-07-06 | 423d | 0d | Verde | Verde | 0% | 0% | Compensatória | Verde | 0% | 0% | Banco |
| 717 | 3.1.3.10.10.2.4 | Projeto básico do Pleito COLESPJ03 - Elaboração de projeto executivo de complementação do SES do distrito de Itapina concluído | milestone | 0d | 2020-09-08 | 2020-09-08 | 716 | 2020-09-08 | 2020-09-08 | 0d | 2020-09-08 | 2020-09-08 | 423d | 0d | Verde | Verde | 0% | 0% | Compensatória | Verde | 0% | 0% | Município |
| 718 | 3.1.3.10.10.2.5 | Recurso do projeto básico do Pleito COLESPJ03 - Elaboração de projeto executivo de complementação do SES do distrito de Itapina repassado | milestone | 0d | 2020-09-15 | 2020-09-15 | 717FS+5d | 2020-09-15 | 2020-09-15 | 0d | 2020-09-15 | 2020-09-15 | 423d | 77d | Verde | Verde | 0% | 0% | Compensatória | Verde | 0% | 0% | Banco |
| 719 | 3.1.3.10.10.3 | Realizar Licenciamento Ambiental |  | 149d | 2020-06-04 | 2021-01-07 | 715 | 2020-06-04 | 2021-01-07 | 149d | 2020-06-04 | 2021-01-07 | 346d | 0d | Verde | Verde | 0% | 0% | Compensatória | Verde | 0% | 0% | Município |
| 720 | 3.1.3.10.10.4 | **Elaboração do Projeto Executivo** |  | 154d | 2020-06-04 | 2021-01-14 |  | 2020-06-04 | 2021-01-14 | 154d | 2020-06-04 | 2021-01-14 | 346d |  | Verde | Verde | 0% | 0% | Compensatória | Verde | 0% | 0% |  |
| 721 | 3.1.3.10.10.4.1 | Elaborar Projeto Executivo |  | 84d | 2020-06-04 | 2020-10-01 | 715 | 2020-06-04 | 2020-10-01 | 84d | 2020-06-04 | 2020-10-01 | 346d | 0d | Verde | Verde | 0% | 0% | Compensatória | Verde | 0% | 0% | Município |
| 722 | 3.1.3.10.10.4.2 | Projeto executivo do Pleito COLESPJ03 - Elaboração de projeto executivo de complementação do SES do distrito de Itapina apresentado ao banco | milestone | 0d | 2020-10-01 | 2020-10-01 | 721 | 2020-10-01 | 2020-10-01 | 0d | 2020-10-01 | 2020-10-01 | 346d | 0d | Verde | Verde | 0% | 0% | Compensatória | Verde | 0% | 0% | Município |
| 723 | 3.1.3.10.10.4.3 | Analisar projeto executivo |  | 65d | 2020-10-02 | 2021-01-07 | 722 | 2020-10-02 | 2021-01-07 | 65d | 2020-10-02 | 2020-11-06 | 346d | 0d | Verde | Verde | 0% | 0% | Compensatória | Verde | 0% | 0% | Banco |
| 724 | 3.1.3.10.10.4.4 | Projeto executivo do Pleito COLESPJ03 - Elaboração de projeto executivo de complementação do SES do distrito de Itapina concluído | milestone | 0d | 2021-01-07 | 2021-01-07 | 719, 718, 723 | 2021-01-07 | 2021-01-07 | 0d | 2021-01-07 | 2021-01-07 | 346d | 0d | Verde | Verde | 0% | 0% | Compensatória | Verde | 0% | 0% | Município |
| 725 | 3.1.3.10.10.4.5 | Recurso do projeto executivo do Pleito COLESPJ03 - Elaboração de projeto executivo de complementação do SES do distrito de Itapina repassado | milestone | 0d | 2021-01-14 | 2021-01-14 | 724FS+5d | 2021-01-14 | 2021-01-14 | 0d | 2021-01-14 | 2021-01-14 | 346d | 0d | Verde | Verde | 0% | 0% | Compensatória | Verde | 0% | 0% | Banco |
| 726 | 3.1.3.10.10.5 | Pleito COLESPJ03 - Elaboração de projeto executivo de complementação do SES do distrito de Itapina de Colatina concluído | milestone | 0d | 2021-01-14 | 2021-01-14 | 725 | 2021-01-14 | 2021-01-14 | 0d | 2021-01-14 | 2021-01-14 | 346d | 0d | Verde | Verde | 0% | 0% | Compensatória | Verde | 0% | 0% | Município |
| 727 | 3.1.3.10.11 | **Pleito COLESOB10 - Complementação do SES do distrito de Itapina** |  | 348d | 2021-01-14 | 2022-06-08 |  | 2021-01-14 | 2022-06-08 | 348d | 2021-01-14 | 2022-06-21 | 346d |  | Verde | Verde | 0% | 0% | Compensatória | Verde | 0% | 0% |  |
| 728 | 3.1.3.10.11.1 | **Licitação da Obra** |  | 75d | 2021-01-14 | 2021-05-06 |  | 2021-01-14 | 2021-05-06 | 75d | 2021-01-14 | 2021-05-06 | 346d |  | Verde | Verde | 0% | 0% | Compensatória | Verde | 0% | 0% |  |
| 729 | 3.1.3.10.11.1.1 | Licitação da obra do Pleito COLESOB10 - Complementação do SES do distrito de Itapina autorizada pelo banco | milestone | 0d | 2021-01-14 | 2021-01-14 | 726 | 2021-01-14 | 2021-01-14 | 0d | 2021-01-14 | 2021-01-14 | 346d | 0d | Verde | Verde | 0% | 0% | Compensatória | Verde | 0% | 0% | Banco |
| 730 | 3.1.3.10.11.1.2 | Licitar Obra |  | 61d | 2021-01-15 | 2021-04-15 | 729 | 2021-01-15 | 2021-04-15 | 61d | 2021-01-15 | 2021-04-15 | 346d | 0d | Verde | Verde | 0% | 0% | Compensatória | Verde | 0% | 0% | Município |
| 731 | 3.1.3.10.11.1.3 | Analisar e emitir resultado da licitação da obra |  | 14d | 2021-04-16 | 2021-05-06 | 730 | 2021-04-16 | 2021-05-06 | 14d | 2021-04-16 | 2021-05-06 | 346d | 0d | Verde | Verde | 0% | 0% | Compensatória | Verde | 0% | 0% | Banco |
| 732 | 3.1.3.10.11.1.4 | Licitação da obra do Pleito COLESOB10 - Complementação do SES do distrito de Itapina concluída | milestone | 0d | 2021-05-06 | 2021-05-06 | 731 | 2021-05-06 | 2021-05-06 | 0d | 2021-05-06 | 2021-05-06 | 346d | 0d | Verde | Verde | 0% | 0% | Compensatória | Verde | 0% | 0% | Município |
| 733 | 3.1.3.10.11.2 | Executar obra |  | 128d | 2021-06-07 | 2021-12-07 | 732FS+20d | 2021-06-07 | 2021-12-07 | 128d | 2021-06-07 | 2021-12-07 | 346d | 0d | Verde | Verde | 0% | 0% | Compensatória | Verde | 0% | 0% | Município |
| 734 | 3.1.3.10.11.3 | Realizar processo de pré-operação |  | 120d | 2021-12-08 | 2022-06-01 | 733 | 2021-12-08 | 2022-06-01 | 120d | 2021-12-08 | 2022-06-13 | 346d | 0d | Verde | Verde | 0% | 0% | Compensatória | Verde | 0% | 0% | Município |
| 735 | 3.1.3.10.11.4 | Recurso da obra do Pleito COLESOB10 - Complementação do SES do distrito de Itapina repassado | milestone | 0d | 2022-06-08 | 2022-06-08 | 734FS+5d | 2022-06-08 | 2022-06-08 | 0d | 2022-06-21 | 2022-06-21 | 346d | 0d | Verde | Verde | 0% | 0% | Compensatória | Verde | 0% | 0% | Banco |
| 736 | 3.1.3.10.11.5 | Pleito COLESOB10 - Complementação do SES do distrito de Itapina de Colatina concluído | milestone | 0d | 2022-06-08 | 2022-06-08 | 735 | 2022-06-08 | 2022-06-08 | 0d | 2022-06-21 | 2022-06-21 | 346d | 188d | Verde | Verde | 0% | 0% | Compensatória | Verde | 0% | 0% | Município |

| ID | WBS | Task | Type | Duration | Start | Finish | Predecessors | Baseline start | Baseline finish | Baseline duration | Baseline 1 start | Baseline 1 finish | Total slack | Free slack | Text1 | Text2 | Text3 | Text6 | Text8 | Text12 | Text14 | Text16 | Text9 |
| --- | --- | --- | --- | --- | --- | --- | --- | --- | --- | --- | --- | --- | --- | --- | --- | --- | --- | --- | --- | --- | --- | --- | --- |
| 737 | 3.1.3.10.12 | **Pleito COLESPJ04 - Elaboração de projeto executivo de complementação do SES do distrito de Boapaba** |  | 277d | 2019-12-02 | 2021-01-14 |  | 2019-12-02 | 2021-01-14 | 277d | 2019-12-02 | 2021-01-14 | 346d |  | Verde | Verde | 0% | 0% | Compensatória | Verde | 0% | 0% |  |
| 738 | 3.1.3.10.12.1 | **Licitação do Projeto** |  | 61d | 2019-12-02 | 2020-03-04 |  | 2019-12-02 | 2020-03-04 | 61d | 2019-12-02 | 2020-03-04 | 346d |  | Verde | Verde | 0% | 0% | Compensatória | Verde | 0% | 0% |  |
| 739 | 3.1.3.10.12.1.1 | Licitar projeto |  | 42d | 2019-12-02 | 2020-02-03 | 3052FS+242d | 2019-12-02 | 2020-02-03 | 42d | 2019-12-02 | 2020-02-03 | 346d | 0d | Verde | Verde | 0% | 0% | Compensatória | Verde | 0% | 0% | Município |
| 740 | 3.1.3.10.12.1.2 | Documentação de licitação do Pleito COLESPJ04 - Elaboração de projeto executivo de complementação do SES do distrito de Boapaba apresentada ao banco | milestone | 0d | 2020-02-10 | 2020-02-10 | 739FS+5d | 2020-02-10 | 2020-02-10 | 0d | 2020-02-10 | 2020-02-10 | 346d | 0d | Verde | Verde | 0% | 0% | Compensatória | Verde | 0% | 0% | Município |
| 741 | 3.1.3.10.12.1.3 | Analisar e emitir resultado da licitação do projeto |  | 14d | 2020-02-11 | 2020-03-04 | 740 | 2020-02-11 | 2020-03-04 | 14d | 2020-02-11 | 2020-03-04 | 346d | 0d | Verde | Verde | 0% | 0% | Compensatória | Verde | 0% | 0% | Banco |
| 742 | 3.1.3.10.12.1.4 | Licitação do projeto do Pleito COLESPJ04 - Elaboração de projeto executivo de complementação do SES do distrito de Boapaba concluída | milestone | 0d | 2020-03-04 | 2020-03-04 | 741 | 2020-03-04 | 2020-03-04 | 0d | 2020-03-04 | 2020-03-04 | 346d | 0d | Verde | Verde | 0% | 0% | Compensatória | Verde | 0% | 0% | Município |
| 743 | 3.1.3.10.12.2 | **Elaboração do Projeto Básico** |  | 134d | 2020-03-05 | 2020-09-15 |  | 2020-03-05 | 2020-09-15 | 134d | 2020-03-05 | 2020-09-15 | 346d |  | Verde | Verde | 0% | 0% | Compensatória | Verde | 0% | 0% |  |
| 744 | 3.1.3.10.12.2.1 | Elaborar Projeto Básico |  | 62d | 2020-03-05 | 2020-06-03 | 742 | 2020-03-05 | 2020-06-03 | 62d | 2020-03-05 | 2020-06-03 | 346d | 0d | Verde | Verde | 0% | 0% | Compensatória | Verde | 0% | 0% | Município |
| 745 | 3.1.3.10.12.2.2 | Projeto básico do Pleito COLESPJ04 - Elaboração de projeto executivo de complementação do SES do distrito de Boapaba apresentado ao banco | milestone | 0d | 2020-06-03 | 2020-06-03 | 744 | 2020-06-03 | 2020-06-03 | 0d | 2020-06-03 | 2020-06-03 | 346d | 0d | Verde | Verde | 0% | 0% | Compensatória | Verde | 0% | 0% | Município |
| 746 | 3.1.3.10.12.2.3 | Analisar Projeto Básico |  | 67d | 2020-06-04 | 2020-09-08 | 745 | 2020-06-04 | 2020-09-08 | 67d | 2020-06-04 | 2020-07-06 | 428d | 0d | Verde | Verde | 0% | 0% | Compensatória | Verde | 0% | 0% | Banco |
| 747 | 3.1.3.10.12.2.4 | Projeto básico do Pleito COLESPJ04 - Elaboração de projeto executivo de complementação do SES do distrito de Boapaba concluído | milestone | 0d | 2020-09-08 | 2020-09-08 | 746 | 2020-09-08 | 2020-09-08 | 0d | 2020-09-08 | 2020-09-08 | 428d | 0d | Verde | Verde | 0% | 0% | Compensatória | Verde | 0% | 0% | Município |
| 748 | 3.1.3.10.12.2.5 | Recurso do projeto básico do Pleito COLESPJ04 - Elaboração de projeto executivo de complementação do SES do distrito de Boapaba repassado | milestone | 0d | 2020-09-15 | 2020-09-15 | 747FS+5d | 2020-09-15 | 2020-09-15 | 0d | 2020-09-15 | 2020-09-15 | 428d | 82d | Verde | Verde | 0% | 0% | Compensatória | Verde | 0% | 0% | Banco |
| 749 | 3.1.3.10.12.3 | Realizar Licenciamento Ambiental |  | 149d | 2020-06-04 | 2021-01-07 | 745 | 2020-06-04 | 2021-01-07 | 149d | 2020-06-04 | 2021-01-07 | 351d | 5d | Verde | Verde | 0% | 0% | Compensatória | Verde | 0% | 0% | Município |
| 750 | 3.1.3.10.12.4 | **Elaboração do Projeto Executivo** |  | 154d | 2020-06-04 | 2021-01-14 |  | 2020-06-04 | 2021-01-14 | 154d | 2020-06-04 | 2021-01-14 | 346d |  | Verde | Verde | 0% | 0% | Compensatória | Verde | 0% | 0% |  |
| 751 | 3.1.3.10.12.4.1 | Elaborar Projeto Executivo |  | 84d | 2020-06-04 | 2020-10-01 | 745 | 2020-06-04 | 2020-10-01 | 84d | 2020-06-04 | 2020-10-01 | 346d | 0d | Verde | Verde | 0% | 0% | Compensatória | Verde | 0% | 0% | Município |
| 752 | 3.1.3.10.12.4.2 | Projeto executivo do Pleito COLESPJ04 - Elaboração de projeto executivo de complementação do SES do distrito de Boapaba apresentado ao banco | milestone | 0d | 2020-10-01 | 2020-10-01 | 751 | 2020-10-01 | 2020-10-01 | 0d | 2020-10-01 | 2020-10-01 | 346d | 0d | Verde | Verde | 0% | 0% | Compensatória | Verde | 0% | 0% | Município |
| 753 | 3.1.3.10.12.4.3 | Analisar projeto executivo |  | 65d | 2020-10-02 | 2021-01-07 | 752 | 2020-10-02 | 2021-01-07 | 65d | 2020-10-02 | 2020-11-06 | 346d | 0d | Verde | Verde | 0% | 0% | Compensatória | Verde | 0% | 0% | Banco |
| 754 | 3.1.3.10.12.4.4 | Projeto executivo do Pleito COLESPJ04 - Elaboração de projeto executivo de complementação do SES do distrito de Boapaba concluído | milestone | 0d | 2021-01-07 | 2021-01-07 | 753 | 2021-01-07 | 2021-01-07 | 0d | 2021-01-07 | 2021-01-07 | 346d | 0d | Verde | Verde | 0% | 0% | Compensatória | Verde | 0% | 0% | Município |
| 755 | 3.1.3.10.12.4.5 | Recurso do projeto executivo do Pleito COLESPJ04 - Elaboração de projeto executivo de complementação do SES do distrito de Boapaba repassado | milestone | 0d | 2021-01-14 | 2021-01-14 | 754FS+5d | 2021-01-14 | 2021-01-14 | 0d | 2021-01-14 | 2021-01-14 | 346d | 0d | Verde | Verde | 0% | 0% | Compensatória | Verde | 0% | 0% | Banco |
| 756 | 3.1.3.10.12.5 | Pleito COLESPJ04 - Elaboração de projeto executivo de complementação do SES do distrito de Boapaba de Colatina concluído | milestone | 0d | 2021-01-14 | 2021-01-14 | 748, 749, 755 | 2021-01-14 | 2021-01-14 | 0d | 2021-01-14 | 2021-01-14 | 346d | 0d | Verde | Verde | 0% | 0% | Compensatória | Verde | 0% | 0% | Município |
| 757 | 3.1.3.10.13 | **Pleito COLESOB11 - Complementação do SES do distrito de Boapaba** |  | 348d | 2021-01-14 | 2022-06-08 |  | 2021-01-14 | 2022-06-08 | 348d | 2021-01-14 | 2022-06-21 | 346d |  | Verde | Verde | 0% | 0% | Compensatória | Verde | 0% | 0% |  |
| 758 | 3.1.3.10.13.1 | **Licitação da Obra** |  | 75d | 2021-01-14 | 2021-05-06 |  | 2021-01-14 | 2021-05-06 | 75d | 2021-01-14 | 2021-05-06 | 346d |  | Verde | Verde | 0% | 0% | Compensatória | Verde | 0% | 0% |  |
| 759 | 3.1.3.10.13.1.1 | Licitação da obra do Pleito COLESOB11 - Complementação do SES do distrito de Boapaba autorizada pelo banco | milestone | 0d | 2021-01-14 | 2021-01-14 | 756 | 2021-01-14 | 2021-01-14 | 0d | 2021-01-14 | 2021-01-14 | 346d | 0d | Verde | Verde | 0% | 0% | Compensatória | Verde | 0% | 0% | Banco |
| 760 | 3.1.3.10.13.1.2 | Licitar Obra |  | 61d | 2021-01-15 | 2021-04-15 | 759 | 2021-01-15 | 2021-04-15 | 61d | 2021-01-15 | 2021-04-15 | 346d | 0d | Verde | Verde | 0% | 0% | Compensatória | Verde | 0% | 0% | Município |
| 761 | 3.1.3.10.13.1.3 | Analisar e emitir resultado da licitação da obra |  | 14d | 2021-04-16 | 2021-05-06 | 760 | 2021-04-16 | 2021-05-06 | 14d | 2021-04-16 | 2021-05-06 | 346d | 0d | Verde | Verde | 0% | 0% | Compensatória | Verde | 0% | 0% | Banco |
| 762 | 3.1.3.10.13.1.4 | Licitação da obra do Pleito COLESOB11 - Complementação do SES do distrito de Boapaba concluída | milestone | 0d | 2021-05-06 | 2021-05-06 | 761 | 2021-05-06 | 2021-05-06 | 0d | 2021-05-06 | 2021-05-06 | 346d | 0d | Verde | Verde | 0% | 0% | Compensatória | Verde | 0% | 0% | Município |
| 763 | 3.1.3.10.13.2 | Executar obra |  | 128d | 2021-06-07 | 2021-12-07 | 762FS+20d | 2021-06-07 | 2021-12-07 | 128d | 2021-06-07 | 2021-12-07 | 346d | 0d | Verde | Verde | 0% | 0% | Compensatória | Verde | 0% | 0% | Município |
| 764 | 3.1.3.10.13.3 | Realizar processo de pré-operação |  | 120d | 2021-12-08 | 2022-06-01 | 763 | 2021-12-08 | 2022-06-01 | 120d | 2021-12-08 | 2022-06-13 | 346d | 0d | Verde | Verde | 0% | 0% | Compensatória | Verde | 0% | 0% | Município |
| 765 | 3.1.3.10.13.4 | Recurso da obra do Pleito COLESOB11 - Complementação do SES do distrito de Boapaba repassado | milestone | 0d | 2022-06-08 | 2022-06-08 | 764FS+5d | 2022-06-08 | 2022-06-08 | 0d | 2022-06-21 | 2022-06-21 | 346d | 0d | Verde | Verde | 0% | 0% | Compensatória | Verde | 0% | 0% | Banco |
| 766 | 3.1.3.10.13.5 | Pleito COLESOB11 - Complementação do SES do distrito de Boapaba de Colatina concluído | milestone | 0d | 2022-06-08 | 2022-06-08 | 765 | 2022-06-08 | 2022-06-08 | 0d | 2022-06-21 | 2022-06-21 | 346d | 188d | Verde | Verde | 0% | 0% | Compensatória | Verde | 0% | 0% | Município |

| ID | WBS | Task | Type | Duration | Start | Finish | Predecessors | Baseline start | Baseline finish | Baseline duration | Baseline 1 start | Baseline 1 finish | Total slack | Free slack | Text1 | Text2 | Text3 | Text6 | Text8 | Text12 | Text14 | Text16 | Text9 |
| --- | --- | --- | --- | --- | --- | --- | --- | --- | --- | --- | --- | --- | --- | --- | --- | --- | --- | --- | --- | --- | --- | --- | --- |
| 767 | 3.1.3.10.14 | **Pleito COLESPJ05 - Elaboração de projeto executivo de complementação do SES do bairro Gordiana Guimarães (Ponte do Pancas)** |  | 277d | 2019-12-02 | 2021-01-14 |  | 2019-12-02 | 2021-01-14 | 277d | 2019-12-02 | 2021-01-14 | 346d |  | Verde | Verde | 0% | 0% | Compensatória | Verde | 0% | 0% |  |
| 768 | 3.1.3.10.14.1 | **Licitação do Projeto** |  | 61d | 2019-12-02 | 2020-03-04 |  | 2019-12-02 | 2020-03-04 | 61d | 2019-12-02 | 2020-03-04 | 346d |  | Verde | Verde | 0% | 0% | Compensatória | Verde | 0% | 0% |  |
| 769 | 3.1.3.10.14.1.1 | Licitar projeto |  | 42d | 2019-12-02 | 2020-02-03 | 3052FS+242d | 2019-12-02 | 2020-02-03 | 42d | 2019-12-02 | 2020-02-03 | 346d | 0d | Verde | Verde | 0% | 0% | Compensatória | Verde | 0% | 0% | Município |
| 770 | 3.1.3.10.14.1.2 | Documentação de licitação do Pleito COLESPJ05 - Elaboração de projeto executivo de complementação do SES do bairro Gordiana Guimarães (Ponte do Pancas) apresentada ao banco | milestone | 0d | 2020-02-10 | 2020-02-10 | 769FS+5d | 2020-02-10 | 2020-02-10 | 0d | 2020-02-10 | 2020-02-10 | 346d | 0d | Verde | Verde | 0% | 0% | Compensatória | Verde | 0% | 0% | Município |
| 771 | 3.1.3.10.14.1.3 | Analisar e emitir resultado da licitação do projeto |  | 14d | 2020-02-11 | 2020-03-04 | 770 | 2020-02-11 | 2020-03-04 | 14d | 2020-02-11 | 2020-03-04 | 346d | 0d | Verde | Verde | 0% | 0% | Compensatória | Verde | 0% | 0% | Banco |
| 772 | 3.1.3.10.14.1.4 | Licitação do projeto do Pleito COLESPJ05 - Elaboração de projeto executivo de complementação do SES do bairro Gordiana Guimarães (Ponte do Pancas) concluída | milestone | 0d | 2020-03-04 | 2020-03-04 | 771 | 2020-03-04 | 2020-03-04 | 0d | 2020-03-04 | 2020-03-04 | 346d | 0d | Verde | Verde | 0% | 0% | Compensatória | Verde | 0% | 0% | Município |
| 773 | 3.1.3.10.14.2 | **Elaboração do Projeto Básico** |  | 134d | 2020-03-05 | 2020-09-15 |  | 2020-03-05 | 2020-09-15 | 134d | 2020-03-05 | 2020-09-15 | 346d |  | Verde | Verde | 0% | 0% | Compensatória | Verde | 0% | 0% |  |
| 774 | 3.1.3.10.14.2.1 | Elaborar Projeto Básico |  | 62d | 2020-03-05 | 2020-06-03 | 772 | 2020-03-05 | 2020-06-03 | 62d | 2020-03-05 | 2020-06-03 | 346d | 0d | Verde | Verde | 0% | 0% | Compensatória | Verde | 0% | 0% | Município |
| 775 | 3.1.3.10.14.2.2 | Projeto básico do Pleito COLESPJ05 - Elaboração de projeto executivo de complementação do SES do bairro Gordiana Guimarães (Ponte do Pancas) apresentado ao banco | milestone | 0d | 2020-06-03 | 2020-06-03 | 774 | 2020-06-03 | 2020-06-03 | 0d | 2020-06-03 | 2020-06-03 | 346d | 0d | Verde | Verde | 0% | 0% | Compensatória | Verde | 0% | 0% | Município |
| 776 | 3.1.3.10.14.2.3 | Analisar Projeto Básico |  | 67d | 2020-06-04 | 2020-09-08 | 775 | 2020-06-04 | 2020-09-08 | 67d | 2020-06-04 | 2020-07-06 | 428d | 0d | Verde | Verde | 0% | 0% | Compensatória | Verde | 0% | 0% | Banco |
| 777 | 3.1.3.10.14.2.4 | Projeto básico do Pleito COLESPJ05 - Elaboração de projeto executivo de complementação do SES do bairro Gordiana Guimarães (Ponte do Pancas) concluído | milestone | 0d | 2020-09-08 | 2020-09-08 | 776 | 2020-09-08 | 2020-09-08 | 0d | 2020-09-08 | 2020-09-08 | 428d | 0d | Verde | Verde | 0% | 0% | Compensatória | Verde | 0% | 0% | Município |
| 778 | 3.1.3.10.14.2.5 | Recurso do projeto básico do Pleito COLESPJ05 - Elaboração de projeto executivo de complementação do SES do bairro Gordiana Guimarães (Ponte do Pancas) repassado | milestone | 0d | 2020-09-15 | 2020-09-15 | 777FS+5d | 2020-09-15 | 2020-09-15 | 0d | 2020-09-15 | 2020-09-15 | 428d | 82d | Verde | Verde | 0% | 0% | Compensatória | Verde | 0% | 0% | Banco |
| 779 | 3.1.3.10.14.3 | Realizar Licenciamento Ambiental |  | 149d | 2020-06-04 | 2021-01-07 | 775 | 2020-06-04 | 2021-01-07 | 149d | 2020-06-04 | 2021-01-07 | 351d | 5d | Verde | Verde | 0% | 0% | Compensatória | Verde | 0% | 0% | Município |
| 780 | 3.1.3.10.14.4 | **Elaboração do Projeto Executivo** |  | 154d | 2020-06-04 | 2021-01-14 |  | 2020-06-04 | 2021-01-14 | 154d | 2020-06-04 | 2021-01-14 | 346d |  | Verde | Verde | 0% | 0% | Compensatória | Verde | 0% | 0% |  |
| 781 | 3.1.3.10.14.4.1 | Elaborar Projeto Executivo |  | 84d | 2020-06-04 | 2020-10-01 | 775 | 2020-06-04 | 2020-10-01 | 84d | 2020-06-04 | 2020-10-01 | 346d | 0d | Verde | Verde | 0% | 0% | Compensatória | Verde | 0% | 0% | Município |
| 782 | 3.1.3.10.14.4.2 | Projeto executivo do Pleito COLESPJ05 - Elaboração de projeto executivo de complementação do SES do bairro Gordiana Guimarães (Ponte do Pancas) apresentado ao banco | milestone | 0d | 2020-10-01 | 2020-10-01 | 781 | 2020-10-01 | 2020-10-01 | 0d | 2020-10-01 | 2020-10-01 | 346d | 0d | Verde | Verde | 0% | 0% | Compensatória | Verde | 0% | 0% | Município |
| 783 | 3.1.3.10.14.4.3 | Analisar projeto executivo |  | 65d | 2020-10-02 | 2021-01-07 | 782 | 2020-10-02 | 2021-01-07 | 65d | 2020-10-02 | 2020-11-06 | 346d | 0d | Verde | Verde | 0% | 0% | Compensatória | Verde | 0% | 0% | Banco |
| 784 | 3.1.3.10.14.4.4 | Projeto executivo do Pleito COLESPJ05 - Elaboração de projeto executivo de complementação do SES do bairro Gordiana Guimarães (Ponte do Pancas) concluído | milestone | 0d | 2021-01-07 | 2021-01-07 | 783 | 2021-01-07 | 2021-01-07 | 0d | 2021-01-07 | 2021-01-07 | 346d | 0d | Verde | Verde | 0% | 0% | Compensatória | Verde | 0% | 0% | Município |
| 785 | 3.1.3.10.14.4.5 | Recurso do projeto executivo do Pleito COLESPJ05 - Elaboração de projeto executivo de complementação do SES do bairro Gordiana Guimarães (Ponte do Pancas) repassado | milestone | 0d | 2021-01-14 | 2021-01-14 | 784FS+5d | 2021-01-14 | 2021-01-14 | 0d | 2021-01-14 | 2021-01-14 | 346d | 0d | Verde | Verde | 0% | 0% | Compensatória | Verde | 0% | 0% | Banco |
| 786 | 3.1.3.10.14.5 | Pleito COLESPJ05 - Elaboração de projeto executivo de complementação do SES do bairro Gordiana Guimarães (Ponte do Pancas) de Colatina concluído | milestone | 0d | 2021-01-14 | 2021-01-14 | 778, 779, 785 | 2021-01-14 | 2021-01-14 | 0d | 2021-01-14 | 2021-01-14 | 346d | 0d | Verde | Verde | 0% | 0% | Compensatória | Verde | 0% | 0% | Município |
| 787 | 3.1.3.10.15 | **Pleito COLESOB12 - Complementação do SES do bairro Gordiano Guimarães (Ponte dos Pancas)** |  | 348d | 2021-01-14 | 2022-06-08 |  | 2021-01-14 | 2022-06-08 | 348d | 2021-01-14 | 2022-07-05 | 346d |  | Verde | Verde | 0% | 0% | Compensatória | Verde | 0% | 0% |  |
| 788 | 3.1.3.10.15.1 | **Licitação da Obra** |  | 75d | 2021-01-14 | 2021-05-06 |  | 2021-01-14 | 2021-05-06 | 75d | 2021-01-14 | 2021-05-06 | 346d |  | Verde | Verde | 0% | 0% | Compensatória | Verde | 0% | 0% |  |
| 789 | 3.1.3.10.15.1.1 | Licitação da obra do Pleito COLESOB12 - Complementação do SES do bairro Gordiano Guimarães (Ponte dos Pancas) autorizada pelo banco | milestone | 0d | 2021-01-14 | 2021-01-14 | 786 | 2021-01-14 | 2021-01-14 | 0d | 2021-01-14 | 2021-01-14 | 346d | 0d | Verde | Verde | 0% | 0% | Compensatória | Verde | 0% | 0% | Banco |
| 790 | 3.1.3.10.15.1.2 | Licitar Obra |  | 61d | 2021-01-15 | 2021-04-15 | 789 | 2021-01-15 | 2021-04-15 | 61d | 2021-01-15 | 2021-04-15 | 346d | 0d | Verde | Verde | 0% | 0% | Compensatória | Verde | 0% | 0% | Município |
| 791 | 3.1.3.10.15.1.3 | Analisar e emitir resultado da licitação da obra |  | 14d | 2021-04-16 | 2021-05-06 | 790 | 2021-04-16 | 2021-05-06 | 14d | 2021-04-16 | 2021-05-06 | 346d | 0d | Verde | Verde | 0% | 0% | Compensatória | Verde | 0% | 0% | Banco |
| 792 | 3.1.3.10.15.1.4 | Licitação da obra do Pleito COLESOB12 - Complementação do SES do bairro Gordiano Guimarães (Ponte dos Pancas) concluída | milestone | 0d | 2021-05-06 | 2021-05-06 | 791 | 2021-05-06 | 2021-05-06 | 0d | 2021-05-06 | 2021-05-06 | 346d | 0d | Verde | Verde | 0% | 0% | Compensatória | Verde | 0% | 0% | Município |
| 793 | 3.1.3.10.15.2 | Executar obra |  | 128d | 2021-06-07 | 2021-12-07 | 792FS+20d | 2021-06-07 | 2021-12-07 | 128d | 2021-06-21 | 2021-12-21 | 346d | 0d | Verde | Verde | 0% | 0% | Compensatória | Verde | 0% | 0% | Município |
| 794 | 3.1.3.10.15.3 | Realizar processo de pré-operação |  | 120d | 2021-12-08 | 2022-06-01 | 793 | 2021-12-08 | 2022-06-01 | 120d | 2021-12-22 | 2022-06-28 | 346d | 0d | Verde | Verde | 0% | 0% | Compensatória | Verde | 0% | 0% | Município |
| 795 | 3.1.3.10.15.4 | Recurso da obra do Pleito COLESOB12 - Complementação do SES do bairro Gordiano Guimarães (Ponte dos Pancas) repassado | milestone | 0d | 2022-06-08 | 2022-06-08 | 794FS+5d | 2022-06-08 | 2022-06-08 | 0d | 2022-07-05 | 2022-07-05 | 346d | 0d | Verde | Verde | 0% | 0% | Compensatória | Verde | 0% | 0% | Banco |
| 796 | 3.1.3.10.15.5 | Pleito COLESOB12 - Complementação do SES do bairro Gordiano Guimarães (Ponte dos Pancas) de Colatina concluído | milestone | 0d | 2022-06-08 | 2022-06-08 | 795 | 2022-06-08 | 2022-06-08 | 0d | 2022-07-05 | 2022-07-05 | 346d | 188d | Verde | Verde | 0% | 0% | Compensatória | Verde | 0% | 0% | Município |

| ID | WBS | Task | Type | Duration | Start | Finish | Predecessors | Baseline start | Baseline finish | Baseline duration | Baseline 1 start | Baseline 1 finish | Total slack | Free slack | Text1 | Text2 | Text3 | Text6 | Text8 | Text12 | Text14 | Text16 | Text9 |
| --- | --- | --- | --- | --- | --- | --- | --- | --- | --- | --- | --- | --- | --- | --- | --- | --- | --- | --- | --- | --- | --- | --- | --- |
| 797 | 3.1.3.10.16 | **Pleito COLESPJ06 - Elaboração de projeto executivo de complementação do SES do bairro XV de Outubro (Campestre)** |  | 277d | 2019-12-02 | 2021-01-14 |  | 2019-12-02 | 2021-01-14 | 277d | 2019-12-02 | 2021-01-14 | 303d |  | Verde | Verde | 0% | 0% | Compensatória | Verde | 0% | 0% |  |
| 798 | 3.1.3.10.16.1 | **Licitação do Projeto** |  | 61d | 2019-12-02 | 2020-03-04 |  | 2019-12-02 | 2020-03-04 | 61d | 2019-12-02 | 2020-03-04 | 303d |  | Verde | Verde | 0% | 0% | Compensatória | Verde | 0% | 0% |  |
| 799 | 3.1.3.10.16.1.1 | Licitar projeto |  | 42d | 2019-12-02 | 2020-02-03 | 3021FS+242d | 2019-12-02 | 2020-02-03 | 42d | 2019-12-02 | 2020-02-03 | 303d | 0d | Verde | Verde | 0% | 0% | Compensatória | Verde | 0% | 0% | Município |
| 800 | 3.1.3.10.16.1.2 | Documentação de licitação do Pleito COLESPJ06 - Elaboração de projeto executivo de complementação do SES do bairro XV de Outubro (Campestre) apresentada ao banco | milestone | 0d | 2020-02-10 | 2020-02-10 | 799FS+5d | 2020-02-10 | 2020-02-10 | 0d | 2020-02-10 | 2020-02-10 | 303d | 0d | Verde | Verde | 0% | 0% | Compensatória | Verde | 0% | 0% | Município |
| 801 | 3.1.3.10.16.1.3 | Analisar e emitir resultado da licitação do projeto |  | 14d | 2020-02-11 | 2020-03-04 | 800 | 2020-02-11 | 2020-03-04 | 14d | 2020-02-11 | 2020-03-04 | 303d | 0d | Verde | Verde | 0% | 0% | Compensatória | Verde | 0% | 0% | Banco |
| 802 | 3.1.3.10.16.1.4 | Licitação do projeto do Pleito COLESPJ06 - Elaboração de projeto executivo de complementação do SES do bairro XV de Outubro (Campestre) concluída | milestone | 0d | 2020-03-04 | 2020-03-04 | 801 | 2020-03-04 | 2020-03-04 | 0d | 2020-03-04 | 2020-03-04 | 303d | 0d | Verde | Verde | 0% | 0% | Compensatória | Verde | 0% | 0% | Município |
| 803 | 3.1.3.10.16.2 | **Elaboração do Projeto Básico** |  | 134d | 2020-03-05 | 2020-09-15 |  | 2020-03-05 | 2020-09-15 | 134d | 2020-03-05 | 2020-09-15 | 303d |  | Verde | Verde | 0% | 0% | Compensatória | Verde | 0% | 0% |  |
| 804 | 3.1.3.10.16.2.1 | Elaborar Projeto Básico |  | 62d | 2020-03-05 | 2020-06-03 | 802 | 2020-03-05 | 2020-06-03 | 62d | 2020-03-05 | 2020-06-03 | 303d | 0d | Verde | Verde | 0% | 0% | Compensatória | Verde | 0% | 0% | Município |
| 805 | 3.1.3.10.16.2.2 | Projeto básico do Pleito COLESPJ06 - Elaboração de projeto executivo de complementação do SES do bairro XV de Outubro (Campestre) apresentado ao banco | milestone | 0d | 2020-06-03 | 2020-06-03 | 804 | 2020-06-03 | 2020-06-03 | 0d | 2020-06-03 | 2020-06-03 | 303d | 0d | Verde | Verde | 0% | 0% | Compensatória | Verde | 0% | 0% | Município |
| 806 | 3.1.3.10.16.2.3 | Analisar Projeto Básico |  | 67d | 2020-06-04 | 2020-09-08 | 805 | 2020-06-04 | 2020-09-08 | 67d | 2020-06-04 | 2020-07-06 | 385d | 0d | Verde | Verde | 0% | 0% | Compensatória | Verde | 0% | 0% | Banco |
| 807 | 3.1.3.10.16.2.4 | Projeto básico do Pleito COLESPJ06 - Elaboração de projeto executivo de complementação do SES do bairro XV de Outubro (Campestre) concluído | milestone | 0d | 2020-09-08 | 2020-09-08 | 806 | 2020-09-08 | 2020-09-08 | 0d | 2020-09-08 | 2020-09-08 | 385d | 0d | Verde | Verde | 0% | 0% | Compensatória | Verde | 0% | 0% | Município |
| 808 | 3.1.3.10.16.2.5 | Recurso do projeto básico do Pleito COLESPJ06 - Elaboração de projeto executivo de complementação do SES do bairro XV de Outubro (Campestre) repassado | milestone | 0d | 2020-09-15 | 2020-09-15 | 807FS+5d | 2020-09-15 | 2020-09-15 | 0d | 2020-09-15 | 2020-09-15 | 385d | 82d | Verde | Verde | 0% | 0% | Compensatória | Verde | 0% | 0% | Banco |
| 809 | 3.1.3.10.16.3 | Realizar Licenciamento Ambiental |  | 149d | 2020-06-04 | 2021-01-07 | 805 | 2020-06-04 | 2021-01-07 | 149d | 2020-06-04 | 2021-01-07 | 308d | 5d | Verde | Verde | 0% | 0% | Compensatória | Verde | 0% | 0% | Município |
| 810 | 3.1.3.10.16.4 | **Elaboração do Projeto Executivo** |  | 154d | 2020-06-04 | 2021-01-14 |  | 2020-06-04 | 2021-01-14 | 154d | 2020-06-04 | 2021-01-14 | 303d |  | Verde | Verde | 0% | 0% | Compensatória | Verde | 0% | 0% |  |
| 811 | 3.1.3.10.16.4.1 | Elaborar Projeto Executivo |  | 84d | 2020-06-04 | 2020-10-01 | 805 | 2020-06-04 | 2020-10-01 | 84d | 2020-06-04 | 2020-10-01 | 303d | 0d | Verde | Verde | 0% | 0% | Compensatória | Verde | 0% | 0% | Município |
| 812 | 3.1.3.10.16.4.2 | Projeto executivo do Pleito COLESPJ06 - Elaboração de projeto executivo de complementação do SES do bairro XV de Outubro (Campestre) apresentado ao banco | milestone | 0d | 2020-10-01 | 2020-10-01 | 811 | 2020-10-01 | 2020-10-01 | 0d | 2020-10-01 | 2020-10-01 | 303d | 0d | Verde | Verde | 0% | 0% | Compensatória | Verde | 0% | 0% | Município |
| 813 | 3.1.3.10.16.4.3 | Analisar projeto executivo |  | 65d | 2020-10-02 | 2021-01-07 | 812 | 2020-10-02 | 2021-01-07 | 65d | 2020-10-02 | 2020-11-06 | 303d | 0d | Verde | Verde | 0% | 0% | Compensatória | Verde | 0% | 0% | Banco |
| 814 | 3.1.3.10.16.4.4 | Projeto executivo do Pleito COLESPJ06 - Elaboração de projeto executivo de complementação do SES do bairro XV de Outubro (Campestre) concluído | milestone | 0d | 2021-01-07 | 2021-01-07 | 813 | 2021-01-07 | 2021-01-07 | 0d | 2021-01-07 | 2021-01-07 | 303d | 0d | Verde | Verde | 0% | 0% | Compensatória | Verde | 0% | 0% | Município |
| 815 | 3.1.3.10.16.4.5 | Recurso do projeto executivo do Pleito COLESPJ06 - Elaboração de projeto executivo de complementação do SES do bairro XV de Outubro (Campestre) repassado | milestone | 0d | 2021-01-14 | 2021-01-14 | 814FS+5d | 2021-01-14 | 2021-01-14 | 0d | 2021-01-14 | 2021-01-14 | 303d | 0d | Verde | Verde | 0% | 0% | Compensatória | Verde | 0% | 0% | Banco |
| 816 | 3.1.3.10.16.5 | Pleito COLESPJ06 - Elaboração de projeto executivo de complementação do SES do bairro XV de Outubro (Campestre) de Colatina concluído | milestone | 0d | 2021-01-14 | 2021-01-14 | 808, 809, 815 | 2021-01-14 | 2021-01-14 | 0d | 2021-01-14 | 2021-01-14 | 303d | 0d | Verde | Verde | 0% | 0% | Compensatória | Verde | 0% | 0% | Município |
| 817 | 3.1.3.10.17 | **Pleito COLESOB13 - Complementação do SES do bairro XV de outubro (Campestre)** |  | 391d | 2021-01-14 | 2022-08-09 |  | 2021-01-14 | 2022-08-09 | 391d | 2021-01-14 | 2022-09-05 | 303d |  | Verde | Verde | 0% | 0% | Compensatória | Verde | 0% | 0% |  |
| 818 | 3.1.3.10.17.1 | **Licitação da Obra** |  | 75d | 2021-01-14 | 2021-05-06 |  | 2021-01-14 | 2021-05-06 | 75d | 2021-01-14 | 2021-05-06 | 303d |  | Verde | Verde | 0% | 0% | Compensatória | Verde | 0% | 0% |  |
| 819 | 3.1.3.10.17.1.1 | Licitação da obra do Pleito COLESOB13 - Complementação do SES do bairro XV de outubro (Campestre) autorizada pelo banco | milestone | 0d | 2021-01-14 | 2021-01-14 | 816 | 2021-01-14 | 2021-01-14 | 0d | 2021-01-14 | 2021-01-14 | 303d | 0d | Verde | Verde | 0% | 0% | Compensatória | Verde | 0% | 0% | Banco |
| 820 | 3.1.3.10.17.1.2 | Licitar Obra |  | 61d | 2021-01-15 | 2021-04-15 | 819 | 2021-01-15 | 2021-04-15 | 61d | 2021-01-15 | 2021-04-15 | 303d | 0d | Verde | Verde | 0% | 0% | Compensatória | Verde | 0% | 0% | Município |
| 821 | 3.1.3.10.17.1.3 | Analisar e emitir resultado da licitação da obra |  | 14d | 2021-04-16 | 2021-05-06 | 820 | 2021-04-16 | 2021-05-06 | 14d | 2021-04-16 | 2021-05-06 | 303d | 0d | Verde | Verde | 0% | 0% | Compensatória | Verde | 0% | 0% | Banco |
| 822 | 3.1.3.10.17.1.4 | Licitação da obra do Pleito COLESOB13 - Complementação do SES do bairro XV de outubro (Campestre) concluída | milestone | 0d | 2021-05-06 | 2021-05-06 | 821 | 2021-05-06 | 2021-05-06 | 0d | 2021-05-06 | 2021-05-06 | 303d | 0d | Verde | Verde | 0% | 0% | Compensatória | Verde | 0% | 0% | Município |
| 823 | 3.1.3.10.17.2 | Executar obra |  | 171d | 2021-06-07 | 2022-02-07 | 822FS+20d | 2021-06-07 | 2022-02-07 | 171d | 2021-06-21 | 2022-02-21 | 303d | 0d | Verde | Verde | 0% | 0% | Compensatória | Verde | 0% | 0% | Município |
| 824 | 3.1.3.10.17.3 | Realizar processo de pré-operação |  | 120d | 2022-02-08 | 2022-08-02 | 823 | 2022-02-08 | 2022-08-02 | 120d | 2022-02-22 | 2022-08-29 | 303d | 0d | Verde | Verde | 0% | 0% | Compensatória | Verde | 0% | 0% | Município |
| 825 | 3.1.3.10.17.4 | Recurso da obra do Pleito COLESOB13 - Complementação do SES do bairro XV de outubro (Campestre) repassado | milestone | 0d | 2022-08-09 | 2022-08-09 | 824FS+5d | 2022-08-09 | 2022-08-09 | 0d | 2022-09-05 | 2022-09-05 | 303d | 0d | Verde | Verde | 0% | 0% | Compensatória | Verde | 0% | 0% | Banco |
| 826 | 3.1.3.10.17.5 | Pleito COLESOB13 - Complementação do SES do bairro XV de outubro (Campestre) de Colatina concluído | milestone | 0d | 2022-08-09 | 2022-08-09 | 825 | 2022-08-09 | 2022-08-09 | 0d | 2022-09-05 | 2022-09-05 | 303d | 145d | Verde | Verde | 0% | 0% | Compensatória | Verde | 0% | 0% | Município |

| ID | WBS | Task | Type | Duration | Start | Finish | Predecessors | Baseline start | Baseline finish | Baseline duration | Baseline 1 start | Baseline 1 finish | Total slack | Free slack | Text1 | Text2 | Text3 | Text6 | Text8 | Text12 | Text14 | Text16 | Text9 |
| --- | --- | --- | --- | --- | --- | --- | --- | --- | --- | --- | --- | --- | --- | --- | --- | --- | --- | --- | --- | --- | --- | --- | --- |
| 827 | 3.1.3.10.18 | **Pleito COLESPJ07 - Elaboração do projeto executivo do SES da localidade Maria Ortiz** |  | 277d | 2019-12-02 | 2021-01-14 |  | 2019-12-02 | 2021-01-14 | 277d | 2019-12-02 | 2021-01-14 | 346d |  | Verde | Verde | 0% | 0% | Compensatória | Verde | 0% | 0% |  |
| 828 | 3.1.3.10.18.1 | **Licitação do Projeto** |  | 61d | 2019-12-02 | 2020-03-04 |  | 2019-12-02 | 2020-03-04 | 61d | 2019-12-02 | 2020-03-04 | 346d |  | Verde | Verde | 0% | 0% | Compensatória | Verde | 0% | 0% |  |
| 829 | 3.1.3.10.18.1.1 | Licitar projeto |  | 42d | 2019-12-02 | 2020-02-03 | 3021FS+242d | 2019-12-02 | 2020-02-03 | 42d | 2019-12-02 | 2020-02-03 | 346d | 0d | Verde | Verde | 0% | 0% | Compensatória | Verde | 0% | 0% | Município |
| 830 | 3.1.3.10.18.1.2 | Documentação de licitação do Pleito COLESPJ07 - Elaboração do projeto executivo do SES da localidade Maria Ortiz apresentada ao banco | milestone | 0d | 2020-02-10 | 2020-02-10 | 829FS+5d | 2020-02-10 | 2020-02-10 | 0d | 2020-02-10 | 2020-02-10 | 346d | 0d | Verde | Verde | 0% | 0% | Compensatória | Verde | 0% | 0% | Município |
| 831 | 3.1.3.10.18.1.3 | Analisar e emitir resultado da licitação do projeto |  | 14d | 2020-02-11 | 2020-03-04 | 830 | 2020-02-11 | 2020-03-04 | 14d | 2020-02-11 | 2020-03-04 | 346d | 0d | Verde | Verde | 0% | 0% | Compensatória | Verde | 0% | 0% | Banco |
| 832 | 3.1.3.10.18.1.4 | Licitação do projeto do Pleito COLESPJ07 - Elaboração do projeto executivo do SES da localidade Maria Ortiz concluída | milestone | 0d | 2020-03-04 | 2020-03-04 | 831 | 2020-03-04 | 2020-03-04 | 0d | 2020-03-04 | 2020-03-04 | 346d | 0d | Verde | Verde | 0% | 0% | Compensatória | Verde | 0% | 0% | Município |
| 833 | 3.1.3.10.18.2 | **Elaboração do Projeto Básico** |  | 134d | 2020-03-05 | 2020-09-15 |  | 2020-03-05 | 2020-09-15 | 134d | 2020-03-05 | 2020-09-15 | 346d |  | Verde | Verde | 0% | 0% | Compensatória | Verde | 0% | 0% |  |
| 834 | 3.1.3.10.18.2.1 | Elaborar Projeto Básico |  | 62d | 2020-03-05 | 2020-06-03 | 832 | 2020-03-05 | 2020-06-03 | 62d | 2020-03-05 | 2020-06-03 | 346d | 0d | Verde | Verde | 0% | 0% | Compensatória | Verde | 0% | 0% | Município |
| 835 | 3.1.3.10.18.2.2 | Projeto básico do Pleito COLESPJ07 - Elaboração do projeto executivo do SES da localidade Maria Ortiz apresentado ao banco | milestone | 0d | 2020-06-03 | 2020-06-03 | 834 | 2020-06-03 | 2020-06-03 | 0d | 2020-06-03 | 2020-06-03 | 346d | 0d | Verde | Verde | 0% | 0% | Compensatória | Verde | 0% | 0% | Município |
| 836 | 3.1.3.10.18.2.3 | Analisar Projeto Básico |  | 67d | 2020-06-04 | 2020-09-08 | 835 | 2020-06-04 | 2020-09-08 | 67d | 2020-06-04 | 2020-07-06 | 428d | 0d | Verde | Verde | 0% | 0% | Compensatória | Verde | 0% | 0% | Banco |
| 837 | 3.1.3.10.18.2.4 | Projeto básico do Pleito COLESPJ07 - Elaboração do projeto executivo do SES da localidade Maria Ortiz concluído | milestone | 0d | 2020-09-08 | 2020-09-08 | 836 | 2020-09-08 | 2020-09-08 | 0d | 2020-09-08 | 2020-09-08 | 428d | 0d | Verde | Verde | 0% | 0% | Compensatória | Verde | 0% | 0% | Município |
| 838 | 3.1.3.10.18.2.5 | Recurso do projeto básico do Pleito COLESPJ07 - Elaboração do projeto executivo do SES da localidade Maria Ortiz repassado | milestone | 0d | 2020-09-15 | 2020-09-15 | 837FS+5d | 2020-09-15 | 2020-09-15 | 0d | 2020-09-15 | 2020-09-15 | 428d | 82d | Verde | Verde | 0% | 0% | Compensatória | Verde | 0% | 0% | Banco |
| 839 | 3.1.3.10.18.3 | Realizar Licenciamento Ambiental |  | 149d | 2020-06-04 | 2021-01-07 | 835 | 2020-06-04 | 2021-01-07 | 149d | 2020-06-04 | 2021-01-07 | 351d | 5d | Verde | Verde | 0% | 0% | Compensatória | Verde | 0% | 0% | Município |
| 840 | 3.1.3.10.18.4 | **Elaboração do Projeto Executivo** |  | 154d | 2020-06-04 | 2021-01-14 |  | 2020-06-04 | 2021-01-14 | 154d | 2020-06-04 | 2021-01-14 | 346d |  | Verde | Verde | 0% | 0% | Compensatória | Verde | 0% | 0% |  |
| 841 | 3.1.3.10.18.4.1 | Elaborar Projeto Executivo |  | 84d | 2020-06-04 | 2020-10-01 | 835 | 2020-06-04 | 2020-10-01 | 84d | 2020-06-04 | 2020-10-01 | 346d | 0d | Verde | Verde | 0% | 0% | Compensatória | Verde | 0% | 0% | Município |
| 842 | 3.1.3.10.18.4.2 | Projeto executivo do Pleito COLESPJ07 - Elaboração do projeto executivo do SES da localidade Maria Ortiz apresentado ao banco | milestone | 0d | 2020-10-01 | 2020-10-01 | 841 | 2020-10-01 | 2020-10-01 | 0d | 2020-10-01 | 2020-10-01 | 346d | 0d | Verde | Verde | 0% | 0% | Compensatória | Verde | 0% | 0% | Município |
| 843 | 3.1.3.10.18.4.3 | Analisar projeto executivo |  | 65d | 2020-10-02 | 2021-01-07 | 842 | 2020-10-02 | 2021-01-07 | 65d | 2020-10-02 | 2020-11-06 | 346d | 0d | Verde | Verde | 0% | 0% | Compensatória | Verde | 0% | 0% | Banco |
| 844 | 3.1.3.10.18.4.4 | Projeto executivo do Pleito COLESPJ07 - Elaboração do projeto executivo do SES da localidade Maria Ortiz concluído | milestone | 0d | 2021-01-07 | 2021-01-07 | 843 | 2021-01-07 | 2021-01-07 | 0d | 2021-01-07 | 2021-01-07 | 346d | 0d | Verde | Verde | 0% | 0% | Compensatória | Verde | 0% | 0% | Município |
| 845 | 3.1.3.10.18.4.5 | Recurso do projeto executivo do Pleito COLESPJ07 - Elaboração do projeto executivo do SES da localidade Maria Ortiz repassado | milestone | 0d | 2021-01-14 | 2021-01-14 | 844FS+5d | 2021-01-14 | 2021-01-14 | 0d | 2021-01-14 | 2021-01-14 | 346d | 0d | Verde | Verde | 0% | 0% | Compensatória | Verde | 0% | 0% | Banco |
| 846 | 3.1.3.10.18.5 | Pleito COLESPJ07 - Elaboração do projeto executivo do SES da localidade Maria Ortiz de Colatina concluído | milestone | 0d | 2021-01-14 | 2021-01-14 | 838, 839, 845 | 2021-01-14 | 2021-01-14 | 0d | 2021-01-14 | 2021-01-14 | 346d | 0d | Verde | Verde | 0% | 0% | Compensatória | Verde | 0% | 0% | Município |
| 847 | 3.1.3.10.19 | **Pleito COLESOB14 - Implantação do SES da localidade Maria Ortiz** |  | 348d | 2021-01-14 | 2022-06-08 |  | 2021-01-14 | 2022-06-08 | 348d | 2021-01-14 | 2022-07-05 | 346d |  | Verde | Verde | 0% | 0% | Compensatória | Verde | 0% | 0% |  |
| 848 | 3.1.3.10.19.1 | **Licitação da Obra** |  | 75d | 2021-01-14 | 2021-05-06 |  | 2021-01-14 | 2021-05-06 | 75d | 2021-01-14 | 2021-05-06 | 346d |  | Verde | Verde | 0% | 0% | Compensatória | Verde | 0% | 0% |  |
| 849 | 3.1.3.10.19.1.1 | Licitação da obra do Pleito COLESOB14 - Implantação do SES da localidade Maria Ortiz autorizada pelo banco | milestone | 0d | 2021-01-14 | 2021-01-14 | 846 | 2021-01-14 | 2021-01-14 | 0d | 2021-01-14 | 2021-01-14 | 346d | 0d | Verde | Verde | 0% | 0% | Compensatória | Verde | 0% | 0% | Banco |
| 850 | 3.1.3.10.19.1.2 | Licitar Obra |  | 61d | 2021-01-15 | 2021-04-15 | 849 | 2021-01-15 | 2021-04-15 | 61d | 2021-01-15 | 2021-04-15 | 346d | 0d | Verde | Verde | 0% | 0% | Compensatória | Verde | 0% | 0% | Município |
| 851 | 3.1.3.10.19.1.3 | Analisar e emitir resultado da licitação da obra |  | 14d | 2021-04-16 | 2021-05-06 | 850 | 2021-04-16 | 2021-05-06 | 14d | 2021-04-16 | 2021-05-06 | 346d | 0d | Verde | Verde | 0% | 0% | Compensatória | Verde | 0% | 0% | Banco |
| 852 | 3.1.3.10.19.1.4 | Licitação da obra do Pleito COLESOB14 - Implantação do SES da localidade Maria Ortiz concluída | milestone | 0d | 2021-05-06 | 2021-05-06 | 851 | 2021-05-06 | 2021-05-06 | 0d | 2021-05-06 | 2021-05-06 | 346d | 0d | Verde | Verde | 0% | 0% | Compensatória | Verde | 0% | 0% | Município |
| 853 | 3.1.3.10.19.2 | Executar obra |  | 128d | 2021-06-07 | 2021-12-07 | 852FS+20d | 2021-06-07 | 2021-12-07 | 128d | 2021-06-21 | 2021-12-21 | 346d | 0d | Verde | Verde | 0% | 0% | Compensatória | Verde | 0% | 0% | Município |
| 854 | 3.1.3.10.19.3 | Realizar processo de pré-operação |  | 120d | 2021-12-08 | 2022-06-01 | 853 | 2021-12-08 | 2022-06-01 | 120d | 2021-12-22 | 2022-06-28 | 346d | 0d | Verde | Verde | 0% | 0% | Compensatória | Verde | 0% | 0% | Município |
| 855 | 3.1.3.10.19.4 | Recurso da obra do Pleito COLESOB14 - Implantação do SES da localidade Maria Ortiz repassado | milestone | 0d | 2022-06-08 | 2022-06-08 | 854FS+5d | 2022-06-08 | 2022-06-08 | 0d | 2022-07-05 | 2022-07-05 | 346d | 0d | Verde | Verde | 0% | 0% | Compensatória | Verde | 0% | 0% | Banco |
| 856 | 3.1.3.10.19.5 | Pleito COLESOB14 - Implantação do SES da localidade Maria Ortiz de Colatina concluído | milestone | 0d | 2022-06-08 | 2022-06-08 | 855 | 2022-06-08 | 2022-06-08 | 0d | 2022-07-05 | 2022-07-05 | 346d | 188d | Verde | Verde | 0% | 0% | Compensatória | Verde | 0% | 0% | Município |

| ID | WBS | Task | Type | Duration | Start | Finish | Predecessors | Complete | Remaining | Baseline start | Baseline finish | Baseline duration | Baseline 1 start | Baseline 1 finish | Total slack | Free slack | Text1 | Text2 | Text3 | Text6 | Text8 | Text12 | Text14 | Text16 | Text9 |
| --- | --- | --- | --- | --- | --- | --- | --- | --- | --- | --- | --- | --- | --- | --- | --- | --- | --- | --- | --- | --- | --- | --- | --- | --- | --- |
| 857 | 3.1.3.10.20 | **Pleito COLESPJ09 - Elaboração de projeto executivo de redes coletoras do SES das micro bacias dos bairros Santa Helena e Mário Giurizatto** |  | 277d | 2019-12-02 | 2021-01-14 |  |  |  | 2019-12-02 | 2021-01-14 | 277d | 2019-12-02 | 2021-01-14 | 303d |  | Verde | Verde | 0% | 0% | Compensatória | Verde | 0% | 0% |  |
| 858 | 3.1.3.10.20.1 | **Licitação do Projeto** |  | 61d | 2019-12-02 | 2020-03-04 |  |  |  | 2019-12-02 | 2020-03-04 | 61d | 2019-12-02 | 2020-03-04 | 303d |  | Verde | Verde | 0% | 0% | Compensatória | Verde | 0% | 0% |  |
| 859 | 3.1.3.10.20.1.1 | Licitar projeto |  | 42d | 2019-12-02 | 2020-02-03 | 3021FS+242d |  |  | 2019-12-02 | 2020-02-03 | 42d | 2019-12-02 | 2020-02-03 | 303d | 0d | Verde | Verde | 0% | 0% | Compensatória | Verde | 0% | 0% | Município |
| 860 | 3.1.3.10.20.1.2 | Documentação de licitação do Pleito COLESPJ09 - Elaboração de projeto executivo de redes coletoras do SES das micro bacias dos bairros Santa Helena e Mário Giurizatto apresentada ao banco | milestone | 0d | 2020-02-10 | 2020-02-10 | 859FS+5d |  |  | 2020-02-10 | 2020-02-10 | 0d | 2020-02-10 | 2020-02-10 | 303d | 0d | Verde | Verde | 0% | 0% | Compensatória | Verde | 0% | 0% | Município |
| 861 | 3.1.3.10.20.1.3 | Analisar e emitir resultado da licitação do projeto |  | 14d | 2020-02-11 | 2020-03-04 | 860 |  |  | 2020-02-11 | 2020-03-04 | 14d | 2020-02-11 | 2020-03-04 | 303d | 0d | Verde | Verde | 0% | 0% | Compensatória | Verde | 0% | 0% | Banco |
| 862 | 3.1.3.10.20.1.4 | Licitação do projeto do Pleito COLESPJ09 - Elaboração de projeto executivo de redes coletoras do SES das micro bacias dos bairros Santa Helena e Mário Giurizatto concluída | milestone | 0d | 2020-03-04 | 2020-03-04 | 861 |  |  | 2020-03-04 | 2020-03-04 | 0d | 2020-03-04 | 2020-03-04 | 303d | 0d | Verde | Verde | 0% | 0% | Compensatória | Verde | 0% | 0% | Município |
| 863 | 3.1.3.10.20.2 | **Elaboração do Projeto Básico** |  | 134d | 2020-03-05 | 2020-09-15 |  |  |  | 2020-03-05 | 2020-09-15 | 134d | 2020-03-05 | 2020-09-15 | 303d |  | Verde | Verde | 0% | 0% | Compensatória | Verde | 0% | 0% |  |
| 864 | 3.1.3.10.20.2.1 | Elaborar Projeto Básico |  | 62d | 2020-03-05 | 2020-06-03 | 862 |  |  | 2020-03-05 | 2020-06-03 | 62d | 2020-03-05 | 2020-06-03 | 303d | 0d | Verde | Verde | 0% | 0% | Compensatória | Verde | 0% | 0% | Município |
| 865 | 3.1.3.10.20.2.2 | Projeto básico do Pleito COLESPJ09 - Elaboração de projeto executivo de redes coletoras do SES das micro bacias dos bairros Santa Helena e Mário Giurizatto apresentado ao banco | milestone | 0d | 2020-06-03 | 2020-06-03 | 864 |  |  | 2020-06-03 | 2020-06-03 | 0d | 2020-06-03 | 2020-06-03 | 303d | 0d | Verde | Verde | 0% | 0% | Compensatória | Verde | 0% | 0% | Município |
| 866 | 3.1.3.10.20.2.3 | Analisar Projeto Básico |  | 67d | 2020-06-04 | 2020-09-08 | 865 |  |  | 2020-06-04 | 2020-09-08 | 67d | 2020-06-04 | 2020-07-06 | 385d | 0d | Verde | Verde | 0% | 0% | Compensatória | Verde | 0% | 0% | Banco |
| 867 | 3.1.3.10.20.2.4 | Projeto básico do Pleito COLESPJ09 - Elaboração de projeto executivo de redes coletoras do SES das micro bacias dos bairros Santa Helena e Mário Giurizatto concluído | milestone | 0d | 2020-09-08 | 2020-09-08 | 866 |  |  | 2020-09-08 | 2020-09-08 | 0d | 2020-09-08 | 2020-09-08 | 385d | 0d | Verde | Verde | 0% | 0% | Compensatória | Verde | 0% | 0% | Município |
| 868 | 3.1.3.10.20.2.5 | Recurso do projeto básico do Pleito COLESPJ09 - Elaboração de projeto executivo de redes coletoras do SES das micro bacias dos bairros Santa Helena e Mário Giurizatto repassado | milestone | 0d | 2020-09-15 | 2020-09-15 | 867FS+5d |  |  | 2020-09-15 | 2020-09-15 | 0d | 2020-09-15 | 2020-09-15 | 385d | 82d | Verde | Verde | 0% | 0% | Compensatória | Verde | 0% | 0% | Banco |
| 869 | 3.1.3.10.20.3 | Realizar Licenciamento Ambiental |  | 149d | 2020-06-04 | 2021-01-07 | 865 |  |  | 2020-06-04 | 2021-01-07 | 149d | 2020-06-04 | 2021-01-07 | 308d | 5d | Verde | Verde | 0% | 0% | Compensatória | Verde | 0% | 0% | Município |
| 870 | 3.1.3.10.20.4 | **Elaboração do Projeto Executivo** |  | 154d | 2020-06-04 | 2021-01-14 |  |  |  | 2020-06-04 | 2021-01-14 | 154d | 2020-06-04 | 2021-01-14 | 303d |  | Verde | Verde | 0% | 0% | Compensatória | Verde | 0% | 0% |  |
| 871 | 3.1.3.10.20.4.1 | Elaborar Projeto Executivo |  | 84d | 2020-06-04 | 2020-10-01 | 865 |  |  | 2020-06-04 | 2020-10-01 | 84d | 2020-06-04 | 2020-10-01 | 303d | 0d | Verde | Verde | 0% | 0% | Compensatória | Verde | 0% | 0% | Município |
| 872 | 3.1.3.10.20.4.2 | Projeto executivo do Pleito COLESPJ09 - Elaboração de projeto executivo de redes coletoras do SES das micro bacias dos bairros Santa Helena e Mário Giurizatto apresentado ao banco | milestone | 0d | 2020-10-01 | 2020-10-01 | 871 |  |  | 2020-10-01 | 2020-10-01 | 0d | 2020-10-01 | 2020-10-01 | 303d | 0d | Verde | Verde | 0% | 0% | Compensatória | Verde | 0% | 0% | Município |
| 873 | 3.1.3.10.20.4.3 | Analisar projeto executivo |  | 65d | 2020-10-02 | 2021-01-07 | 872 |  |  | 2020-10-02 | 2021-01-07 | 65d | 2020-10-02 | 2020-11-06 | 303d | 0d | Verde | Verde | 0% | 0% | Compensatória | Verde | 0% | 0% | Banco |
| 874 | 3.1.3.10.20.4.4 | Projeto executivo do Pleito COLESPJ09 - Elaboração de projeto executivo de redes coletoras do SES das micro bacias dos bairros Santa Helena e Mário Giurizatto concluído | milestone | 0d | 2021-01-07 | 2021-01-07 | 873 |  |  | 2021-01-07 | 2021-01-07 | 0d | 2021-01-07 | 2021-01-07 | 303d | 0d | Verde | Verde | 0% | 0% | Compensatória | Verde | 0% | 0% | Município |
| 875 | 3.1.3.10.20.4.5 | Recurso do projeto executivo do Pleito COLESPJ09 - Elaboração de projeto executivo de redes coletoras do SES das micro bacias dos bairros Santa Helena e Mário Giurizatto repassado | milestone | 0d | 2021-01-14 | 2021-01-14 | 874FS+5d |  |  | 2021-01-14 | 2021-01-14 | 0d | 2021-01-14 | 2021-01-14 | 303d | 0d | Verde | Verde | 0% | 0% | Compensatória | Verde | 0% | 0% | Banco |
| 876 | 3.1.3.10.20.5 | Pleito COLESPJ09 - Elaboração de projeto executivo de redes coletoras do SES das micro bacias dos bairros Santa Helena e Mário Giurizatto de Colatina concluído | milestone | 0d | 2021-01-14 | 2021-01-14 | 868, 869, 875 |  |  | 2021-01-14 | 2021-01-14 | 0d | 2021-01-14 | 2021-01-14 | 303d | 0d | Verde | Verde | 0% | 0% | Compensatória | Verde | 0% | 0% | Município |
| 877 | 3.1.3.10.21 | **Pleito COLESOB28 - Implantação de redes coletoras nos bairros Santa Helena e Mário Giurizatto** |  | 789d | 2019-06-10 A | 2022-08-09 |  |  | 789d | 2019-06-14 | 2022-08-09 | 785d | 2021-01-14 | 2022-09-05 | 303d |  | Verde | Verde | 0% | 0% | Compensatória | Verde | 0% | 0% |  |
| 878 | 3.1.3.10.21.1 | Alteração do Pleito COLESOB28 - Implantação de redes coletoras nos bairros Santa Helena e Mário Giurizatto de Colatina aprovado pela Renova | milestone | 0d | 2019-06-10 A | 2019-06-10 A | 3052FS+121d | 100% |  | 2019-06-14 | 2019-06-14 | 0d |  |  |  |  | Verde | Verde | 0% | 0% | Compensatória | Verde | 0% | 0% |  |
| 879 | 3.1.3.10.21.2 | **Licitação da Obra** |  | 75d | 2021-01-14 | 2021-05-06 |  |  |  | 2021-01-14 | 2021-05-06 | 75d | 2021-01-14 | 2021-05-06 | 303d |  | Verde | Verde | 0% | 0% | Compensatória | Verde | 0% | 0% |  |
| 880 | 3.1.3.10.21.2.1 | Licitação da obra do Pleito COLESOB28 - Implantação de redes coletoras nos bairros Santa Helena e Mário Giurizatto autorizada pelo banco | milestone | 0d | 2021-01-14 | 2021-01-14 | 876, 878 |  |  | 2021-01-14 | 2021-01-14 | 0d | 2021-01-14 | 2021-01-14 | 303d | 0d | Verde | Verde | 0% | 0% | Compensatória | Verde | 0% | 0% | Banco |
| 881 | 3.1.3.10.21.2.2 | Licitar Obra |  | 61d | 2021-01-15 | 2021-04-15 | 880 |  |  | 2021-01-15 | 2021-04-15 | 61d | 2021-01-15 | 2021-04-15 | 303d | 0d | Verde | Verde | 0% | 0% | Compensatória | Verde | 0% | 0% | Município |
| 882 | 3.1.3.10.21.2.3 | Analisar e emitir resultado da licitação da obra |  | 14d | 2021-04-16 | 2021-05-06 | 881 |  |  | 2021-04-16 | 2021-05-06 | 14d | 2021-04-16 | 2021-05-06 | 303d | 0d | Verde | Verde | 0% | 0% | Compensatória | Verde | 0% | 0% | Banco |
| 883 | 3.1.3.10.21.2.4 | Licitação da obra do Pleito COLESOB28 - Implantação de redes coletoras nos bairros Santa Helena e Mário Giurizatto concluída | milestone | 0d | 2021-05-06 | 2021-05-06 | 882 |  |  | 2021-05-06 | 2021-05-06 | 0d | 2021-05-06 | 2021-05-06 | 303d | 0d | Verde | Verde | 0% | 0% | Compensatória | Verde | 0% | 0% | Município |
| 884 | 3.1.3.10.21.3 | Executar obra |  | 171d | 2021-06-07 | 2022-02-07 | 883FS+20d |  |  | 2021-06-07 | 2022-02-07 | 171d | 2021-06-21 | 2022-02-21 | 303d | 0d | Verde | Verde | 0% | 0% | Compensatória | Verde | 0% | 0% | Município |
| 885 | 3.1.3.10.21.4 | Realizar processo de pré-operação |  | 120d | 2022-02-08 | 2022-08-02 | 884 |  |  | 2022-02-08 | 2022-08-02 | 120d | 2022-02-22 | 2022-08-29 | 303d | 0d | Verde | Verde | 0% | 0% | Compensatória | Verde | 0% | 0% | Município |
| 886 | 3.1.3.10.21.5 | Recurso da obra do Pleito COLESOB28 - Implantação de redes coletoras nos bairros Santa Helena e Mário Giurizatto repassado | milestone | 0d | 2022-08-09 | 2022-08-09 | 885FS+5d |  |  | 2022-08-09 | 2022-08-09 | 0d | 2022-09-05 | 2022-09-05 | 303d | 0d | Verde | Verde | 0% | 0% | Compensatória | Verde | 0% | 0% | Banco |
| 887 | 3.1.3.10.21.6 | Pleito COLESOB28 - Implantação de redes coletoras nos bairros Santa Helena e Mário Giurizatto de Colatina concluído | milestone | 0d | 2022-08-09 | 2022-08-09 | 886 |  |  | 2022-08-09 | 2022-08-09 | 0d | 2022-09-05 | 2022-09-05 | 303d | 145d | Verde | Verde | 0% | 0% | Compensatória | Verde | 0% | 0% | Município |

Notes:
- 878: 07/06/2019: ofício de alteração do valor do pleito de R$ 2.100.000,00 para R$ 1.733.394,27 foi enviado a Fundação Renova e será aprovado até o dia 14/06/2019 / 13/06/2019: Renova aprovou a alteração do pleito dia 10/06 (ofício 052019.6752-01)

| ID | WBS | Task | Type | Duration | Start | Finish | Predecessors | Complete | Remaining | Baseline start | Baseline finish | Baseline duration | Baseline 1 start | Baseline 1 finish | Total slack | Free slack | Text1 | Text2 | Text3 | Text6 | Text8 | Text12 | Text14 | Text16 | Text9 | Text18 |
| --- | --- | --- | --- | --- | --- | --- | --- | --- | --- | --- | --- | --- | --- | --- | --- | --- | --- | --- | --- | --- | --- | --- | --- | --- | --- | --- |
| 888 | 3.1.3.10.22 | **Pleito COLESOB04 - Contratação de assessoria técnica para supervisão geral da implantação de todos os componentes do SES da sede municipal** |  | 859d | 2019-06-05 A | 2022-11-17 |  | 3% | 832.85d | 2019-06-05 | 2022-11-17 | 859d | 2019-06-03 | 2022-09-13 | 236d |  | Verde | Verde | 0% | 0% | Compensatória | Verde | 0% | 0% |  |  |
| 889 | 3.1.3.10.22.1 | **Licitação da Empresa Gerenciadora** |  | 118d | 2019-06-05 A | 2019-11-21 |  | 22% | 92d | 2019-06-05 | 2019-11-21 | 118d | 2019-06-03 | 2019-09-19 | 236d |  | Verde | Verde | 0% | 0% | Compensatória | Verde | 0% | 0% |  |  |
| 890 | 3.1.3.10.22.1.1 | Licitação da gerenciadora do Pleito COLESOB04 - Contratação de assessoria técnica para supervisão geral da implantação de todos os componentes do SES da sede municipal autorizada pelo banco | milestone | 0d | 2019-06-05 A | 2019-06-05 A | 3021FS+118d | 100% |  | 2019-06-05 | 2019-06-05 | 0d | 2019-06-03 | 2019-06-03 |  |  | Verde | Verde | 0% | 0% | Compensatória | Verde | 0% | 0% | Banco |  |
| 891 | 3.1.3.10.22.1.2 | Licitar gerenciadora |  | 104d | 2019-06-06 A | 2019-10-31 | 890 | 25% | 78d | 2019-06-06 | 2019-10-31 | 104d | 2019-06-04 | 2019-09-05 | 236d | 0d | Verde | Verde | 0% | 0% | Compensatória | Verde | 0% | 0% | Município | Critério FR |
| 892 | 3.1.3.10.22.1.3 | Analisar e emitir resultado da licitação da gerenciadora |  | 14d | 2019-11-01 | 2019-11-21 | 891 |  |  | 2019-11-01 | 2019-11-21 | 14d | 2019-09-06 | 2019-09-19 | 236d | 0d | Verde | Verde | 0% | 0% | Compensatória | Verde | 0% | 0% | Banco | Critério FR |
| 893 | 3.1.3.10.22.1.4 | Licitação da gerenciadora do Pleito COLESOB04 - Contratação de assessoria técnica para supervisão geral da implantação de todos os componentes do SES da sede municipal concluída | milestone | 0d | 2019-11-21 | 2019-11-21 | 892 |  |  | 2019-11-21 | 2019-11-21 | 0d | 2019-09-19 | 2019-09-19 | 236d | 0d | Verde | Verde | 0% | 0% | Compensatória | Verde | 0% | 0% | Município |  |
| 894 | 3.1.3.10.22.2 | Acompanhar obras |  | 736d | 2019-11-22 | 2022-11-09 | 893 |  |  | 2019-11-22 | 2022-11-09 | 736d | 2019-09-20 | 2022-09-05 | 236d | 0d | Verde | Verde | 0% | 0% | Compensatória | Verde | 0% | 0% | Município |  |
| 895 | 3.1.3.10.22.3 | Recurso do serviço do Pleito COLESOB04 - Contratação de assessoria técnica para supervisão geral da implantação de todos os componentes do SES da sede municipal repassado | milestone | 0d | 2022-11-17 | 2022-11-17 | 894FS+5d |  |  | 2022-11-17 | 2022-11-17 | 0d | 2022-09-13 | 2022-09-13 | 236d | 0d | Verde | Verde | 0% | 0% | Compensatória | Verde | 0% | 0% | Banco |  |
| 896 | 3.1.3.10.22.4 | Pleito COLESOB04 - Contratação de assessoria técnica para supervisão geral da implantação de todos os componentes do SES da sede municipal de Colatina concluído | milestone | 0d | 2022-11-17 | 2022-11-17 | 895 |  |  | 2022-11-17 | 2022-11-17 | 0d | 2022-09-13 | 2022-09-13 | 236d | 78d | Verde | Verde | 0% | 0% | Compensatória | Verde | 0% | 0% | Município |  |
| 897 | 3.1.3.10.23 | **Pleito COLESOB05 - Outras ações complementares - execução de ligações domiciliares de esgoto às redes coletoras existentes, e execução de interligações das redes coletoras existentes às redes novas e interceptores** |  | 393d | 2021-08-11 | 2023-03-13 |  |  |  | 2021-08-11 | 2023-03-13 | 393d | 2021-08-11 | 2022-09-14 | 158d |  | Verde | Verde | 0% | 0% | Compensatória | Verde | 0% | 0% |  |  |
| 898 | 3.1.3.10.23.1 | **Licitação da Obra** |  | 80d | 2021-08-11 | 2021-12-07 |  |  |  | 2021-08-11 | 2021-12-07 | 80d | 2021-08-11 | 2021-12-07 | 158d |  | Verde | Verde | 0% | 0% | Compensatória | Verde | 0% | 0% |  |  |
| 899 | 3.1.3.10.23.1.1 | Licitação da obra do Pleito COLESOB05 - Outras ações complementares - execução de ligações domiciliares de esgoto às redes coletoras existentes, e execução de interligações das redes coletoras existentes às redes novas e interceptoresautorizada pelo banco | milestone | 0d | 2021-08-11 | 2021-08-11 | 3052FS+662d |  |  | 2021-08-11 | 2021-08-11 | 0d | 2021-08-11 | 2021-08-11 | 158d | 0d | Verde | Verde | 0% | 0% | Compensatória | Verde | 0% | 0% | Banco |  |
| 900 | 3.1.3.10.23.1.2 | Licitar Obra |  | 66d | 2021-08-12 | 2021-11-17 | 899 |  |  | 2021-08-12 | 2021-11-17 | 66d | 2021-08-12 | 2021-11-17 | 158d | 0d | Verde | Verde | 0% | 0% | Compensatória | Verde | 0% | 0% | Município |  |
| 901 | 3.1.3.10.23.1.3 | Analisar e emitir resultado da licitação da obra |  | 14d | 2021-11-18 | 2021-12-07 | 900 |  |  | 2021-11-18 | 2021-12-07 | 14d | 2021-11-18 | 2021-12-07 | 158d | 0d | Verde | Verde | 0% | 0% | Compensatória | Verde | 0% | 0% | Banco |  |
| 902 | 3.1.3.10.23.1.4 | Licitação da obra do Pleito COLESOB05 - Outras ações complementares - execução de ligações domiciliares de esgoto às redes coletoras existentes, e execução de interligações das redes coletoras existentes às redes novas e interceptores concluída | milestone | 0d | 2021-12-07 | 2021-12-07 | 901 |  |  | 2021-12-07 | 2021-12-07 | 0d | 2021-12-07 | 2021-12-07 | 158d | 0d | Verde | Verde | 0% | 0% | Compensatória | Verde | 0% | 0% | Município |  |
| 903 | 3.1.3.10.23.2 | Executar obra |  | 167d | 2022-01-07 | 2022-09-08 | 902FS+21d |  |  | 2022-01-07 | 2022-09-08 | 167d | 2021-12-08 | 2022-09-06 | 158d | 0d | Verde | Verde | 0% | 0% | Compensatória | Verde | 0% | 0% | Município |  |
| 904 | 3.1.3.10.23.3 | Realizar processo de pré-operação |  | 120d | 2022-09-09 | 2023-03-06 | 903 |  |  | 2022-09-09 | 2023-03-06 | 120d | 2022-09-14 | 2022-09-14 | 158d | 0d | Verde | Verde | 0% | 0% | Compensatória | Verde | 0% | 0% | Banco |  |
| 905 | 3.1.3.10.23.4 | Recurso da obra do Pleito COLESOB05 - Outras ações complementares - execução de ligações domiciliares de esgoto às redes coletoras existentes, e execução de interligações das redes coletoras existentes às redes novas e interceptores repassado | milestone | 0d | 2023-03-13 | 2023-03-13 | 904FS+5d |  |  | 2023-03-13 | 2023-03-13 | 0d |  |  | 158d | 0d | Verde | Verde | 0% | 0% | Compensatória | Verde | 0% | 0% |  |  |
| 906 | 3.1.3.10.23.5 | Pleito COLESOB05 - Outras ações complementares - execução de ligações domiciliares de esgoto às redes coletoras existentes, e execução de interligações das redes coletoras existentes às redes novas e interceptores de Colatina concluído | milestone | 0d | 2023-03-13 | 2023-03-13 | 905 |  |  | 2023-03-13 | 2023-03-13 | 0d | 2022-09-14 | 2022-09-14 | 158d | 0d | Verde | Verde | 0% | 0% | Compensatória | Verde | 0% | 0% | Município |  |
| 907 | 3.1.3.10.24 | **Pleito COLESPJ08 - Elaboração de projeto executivo de redes interceptoras de sistemas de esgotamento sanitário das micro bacias da sede municipal (Centro – Lado Sul e São Silvano – Lado Norte) que despejam esgoto “in natura” nos córregos municipais** |  | 277d | 2019-12-02 | 2021-01-14 |  |  |  | 2019-12-02 | 2021-01-14 | 277d | 2019-12-02 | 2021-01-14 | 303d |  | Verde | Verde | 0% | 0% | Compensatória | Verde | 0% | 0% |  |  |
| 908 | 3.1.3.10.24.1 | **Licitação do Projeto** |  | 61d | 2019-12-02 | 2020-03-04 |  |  |  | 2019-12-02 | 2020-03-04 | 61d | 2019-12-02 | 2020-03-04 | 303d |  | Verde | Verde | 0% | 0% | Compensatória | Verde | 0% | 0% |  |  |
| 909 | 3.1.3.10.24.1.1 | Licitar projeto |  | 42d | 2019-12-02 | 2020-02-03 | 3021FS+242d |  |  | 2019-12-02 | 2020-02-03 | 42d | 2019-12-02 | 2020-02-03 | 303d | 0d | Verde | Verde | 0% | 0% | Compensatória | Verde | 0% | 0% | Município |  |
| 910 | 3.1.3.10.24.1.2 | Documentação de licitação do Pleito COLESPJ08 - Elaboração de projeto executivo de redes interceptoras de sistemas de esgotamento sanitário das micro bacias da sede municipal (Centro – Lado Sul e São Silvano – Lado Norte) apresentada ao banco | milestone | 0d | 2020-02-10 | 2020-02-10 | 909FS+5d |  |  | 2020-02-10 | 2020-02-10 | 0d | 2020-02-10 | 2020-02-10 | 303d | 0d | Verde | Verde | 0% | 0% | Compensatória | Verde | 0% | 0% | Município |  |
| 911 | 3.1.3.10.24.1.3 | Analisar e emitir resultado da licitação do projeto |  | 14d | 2020-02-11 | 2020-03-04 | 910 |  |  | 2020-02-11 | 2020-03-04 | 14d | 2020-02-11 | 2020-03-04 | 303d | 0d | Verde | Verde | 0% | 0% | Compensatória | Verde | 0% | 0% | Banco |  |
| 912 | 3.1.3.10.24.1.4 | Licitação do projeto do Pleito COLESPJ08 - Elaboração de projeto executivo de redes interceptoras de sistemas de esgotamento sanitário das micro bacias da sede municipal (Centro – Lado Sul e São Silvano – Lado Norte) concluída | milestone | 0d | 2020-03-04 | 2020-03-04 | 911 |  |  | 2020-03-04 | 2020-03-04 | 0d | 2020-03-04 | 2020-03-04 | 303d | 0d | Verde | Verde | 0% | 0% | Compensatória | Verde | 0% | 0% | Município |  |

Notes:
- 890: 05/06/2019: foi informado na reunião com o município da 2a rodada de reuniões que o banco enviou a autorização anteriormente
- 891: 05/06/2019: município terminará o TR e planilha até o dia 31/07. Considerado que o processo será concluído até o dia 31/10/2019
- 907: Nome do pleito completo: Elaboração de projeto executivo de redes interceptoras de sistemas de esgotamento sanitário das micro bacias da sede municipal (Centro Lado Sul e São Silvano Lado Norte) que despejam esgoto in natura nos córregos municipais. Projetos de rede coletora/interceptores nas micro bacias dos bairros Santa Terezinha, Maria Ismênia, Operário, São Vicente, Colatina Velha, Santa Mônica, Vila Verdi e São Miguel

| ID | WBS | Task | Type | Duration | Start | Finish | Predecessors | Baseline start | Baseline finish | Baseline duration | Baseline 1 start | Baseline 1 finish | Total slack | Free slack | Text1 | Text2 | Text3 | Text6 | Text8 | Text12 | Text14 | Text16 | Text9 |
| --- | --- | --- | --- | --- | --- | --- | --- | --- | --- | --- | --- | --- | --- | --- | --- | --- | --- | --- | --- | --- | --- | --- | --- |
| 913 | 3.1.3.10.24.2 | **Elaboração do Projeto Básico** |  | 134d | 2020-03-05 | 2020-09-15 |  | 2020-03-05 | 2020-09-15 | 134d | 2020-03-05 | 2020-09-15 | 303d |  | Verde | Verde | 0% | 0% | Compensatória | Verde | 0% | 0% |  |
| 914 | 3.1.3.10.24.2.1 | Elaborar Projeto Básico |  | 62d | 2020-03-05 | 2020-06-03 | 912 | 2020-03-05 | 2020-06-03 | 62d | 2020-03-05 | 2020-06-03 | 303d | 0d | Verde | Verde | 0% | 0% | Compensatória | Verde | 0% | 0% | Município |
| 915 | 3.1.3.10.24.2.2 | Projeto básico do Pleito COLESPJ08 - Elaboração de projeto executivo de redes interceptoras de sistemas de esgotamento sanitário das micro bacias da sede municipal (Centro – Lado Sul e São Silvano – Lado Norte) apresentado ao banco | milestone | 0d | 2020-06-03 | 2020-06-03 | 914 | 2020-06-03 | 2020-06-03 | 0d | 2020-06-03 | 2020-06-03 | 303d | 0d | Verde | Verde | 0% | 0% | Compensatória | Verde | 0% | 0% | Município |
| 916 | 3.1.3.10.24.2.3 | Analisar Projeto Básico |  | 67d | 2020-06-04 | 2020-09-08 | 915 | 2020-06-04 | 2020-09-08 | 67d | 2020-06-04 | 2020-07-06 | 385d | 0d | Verde | Verde | 0% | 0% | Compensatória | Verde | 0% | 0% | Banco |
| 917 | 3.1.3.10.24.2.4 | Projeto básico do Pleito COLESPJ08 - Elaboração de projeto executivo de redes interceptoras de sistemas de esgotamento sanitário das micro bacias da sede municipal (Centro – Lado Sul e São Silvano – Lado Norte) concluído | milestone | 0d | 2020-09-08 | 2020-09-08 | 916 | 2020-09-08 | 2020-09-08 | 0d | 2020-09-08 | 2020-09-08 | 385d | 0d | Verde | Verde | 0% | 0% | Compensatória | Verde | 0% | 0% | Município |
| 918 | 3.1.3.10.24.2.5 | Recurso do projeto básico do Pleito COLESPJ08 - Elaboração de projeto executivo de redes interceptoras de sistemas de esgotamento sanitário das micro bacias da sede municipal (Centro – Lado Sul e São Silvano – Lado Norte) repassado | milestone | 0d | 2020-09-15 | 2020-09-15 | 917FS+5d | 2020-09-15 | 2020-09-15 | 0d | 2020-09-15 | 2020-09-15 | 385d | 82d | Verde | Verde | 0% | 0% | Compensatória | Verde | 0% | 0% | Banco |
| 919 | 3.1.3.10.24.3 | Realizar Licenciamento Ambiental |  | 149d | 2020-06-04 | 2021-01-07 | 915 | 2020-06-04 | 2021-01-07 | 149d | 2020-06-04 | 2021-01-07 | 308d | 5d | Verde | Verde | 0% | 0% | Compensatória | Verde | 0% | 0% | Município |
| 920 | 3.1.3.10.24.4 | **Elaboração do Projeto Executivo** |  | 154d | 2020-06-04 | 2021-01-14 |  | 2020-06-04 | 2021-01-14 | 154d | 2020-06-04 | 2021-01-14 | 303d |  | Verde | Verde | 0% | 0% | Compensatória | Verde | 0% | 0% |  |
| 921 | 3.1.3.10.24.4.1 | Elaborar Projeto Executivo |  | 84d | 2020-06-04 | 2020-10-01 | 915 | 2020-06-04 | 2020-10-01 | 84d | 2020-06-04 | 2020-10-01 | 303d | 0d | Verde | Verde | 0% | 0% | Compensatória | Verde | 0% | 0% | Município |
| 922 | 3.1.3.10.24.4.2 | Projeto executivo do Pleito COLESPJ08 - Elaboração de projeto executivo de redes interceptoras de sistemas de esgotamento sanitário das micro bacias da sede municipal (Centro – Lado Sul e São Silvano – Lado Norte) apresentado ao banco | milestone | 0d | 2020-10-01 | 2020-10-01 | 921 | 2020-10-01 | 2020-10-01 | 0d | 2020-10-01 | 2020-10-01 | 303d | 0d | Verde | Verde | 0% | 0% | Compensatória | Verde | 0% | 0% | Município |
| 923 | 3.1.3.10.24.4.3 | Analisar projeto executivo |  | 65d | 2020-10-02 | 2021-01-07 | 922 | 2020-10-02 | 2021-01-07 | 65d | 2020-10-02 | 2020-11-06 | 303d | 0d | Verde | Verde | 0% | 0% | Compensatória | Verde | 0% | 0% | Banco |
| 924 | 3.1.3.10.24.4.4 | Projeto executivo do Pleito COLESPJ08 - Elaboração de projeto executivo de redes interceptoras de sistemas de esgotamento sanitário das micro bacias da sede municipal (Centro – Lado Sul e São Silvano – Lado Norte) concluído | milestone | 0d | 2021-01-07 | 2021-01-07 | 923 | 2021-01-07 | 2021-01-07 | 0d | 2021-01-07 | 2021-01-07 | 303d | 0d | Verde | Verde | 0% | 0% | Compensatória | Verde | 0% | 0% | Município |
| 925 | 3.1.3.10.24.4.5 | Recurso do projeto executivo do Pleito COLESPJ08 - Elaboração de projeto executivo de redes interceptoras de sistemas de esgotamento sanitário das micro bacias da sede municipal (Centro – Lado Sul e São Silvano – Lado Norte) repassado | milestone | 0d | 2021-01-14 | 2021-01-14 | 924FS+5d | 2021-01-14 | 2021-01-14 | 0d | 2021-01-14 | 2021-01-14 | 303d | 0d | Verde | Verde | 0% | 0% | Compensatória | Verde | 0% | 0% | Banco |
| 926 | 3.1.3.10.24.5 | Pleito COLESPJ08 - Elaboração de projeto executivo de redes interceptoras de sistemas de esgotamento sanitário das micro bacias da sede municipal (Centro – Lado Sul e São Silvano – Lado Norte) de Colatina concluído | milestone | 0d | 2021-01-14 | 2021-01-14 | 918, 919, 925 | 2021-01-14 | 2021-01-14 | 0d | 2021-01-14 | 2021-01-14 | 303d | 0d | Verde | Verde | 0% | 0% | Compensatória | Verde | 0% | 0% | Município |
| 927 | 3.1.3.10.25 | **Pleito COLESOB16 - Implantação de rede interceptora de esgoto sanitário na micro bacia do bairro Santa Terezinha** |  | 391d | 2021-01-14 | 2022-08-09 |  | 2021-01-14 | 2022-08-09 | 391d | 2021-01-14 | 2022-08-22 | 303d |  | Verde | Verde | 0% | 0% | Compensatória | Verde | 0% | 0% |  |
| 928 | 3.1.3.10.25.1 | **Licitação da Obra** |  | 75d | 2021-01-14 | 2021-05-06 |  | 2021-01-14 | 2021-05-06 | 75d | 2021-01-14 | 2021-05-06 | 303d |  | Verde | Verde | 0% | 0% | Compensatória | Verde | 0% | 0% |  |
| 929 | 3.1.3.10.25.1.1 | Licitação da obra do Pleito COLESOB16 - Implantação de rede interceptora de esgoto sanitário na micro bacia do bairro Santa Terezinha autorizada pelo banco | milestone | 0d | 2021-01-14 | 2021-01-14 | 926 | 2021-01-14 | 2021-01-14 | 0d | 2021-01-14 | 2021-01-14 | 303d | 0d | Verde | Verde | 0% | 0% | Compensatória | Verde | 0% | 0% | Banco |
| 930 | 3.1.3.10.25.1.2 | Licitar Obra |  | 61d | 2021-01-15 | 2021-04-15 | 929 | 2021-01-15 | 2021-04-15 | 61d | 2021-01-15 | 2021-04-15 | 303d | 0d | Verde | Verde | 0% | 0% | Compensatória | Verde | 0% | 0% | Município |
| 931 | 3.1.3.10.25.1.3 | Analisar e emitir resultado da licitação da obra |  | 14d | 2021-04-16 | 2021-05-06 | 930 | 2021-04-16 | 2021-05-06 | 14d | 2021-04-16 | 2021-05-06 | 303d | 0d | Verde | Verde | 0% | 0% | Compensatória | Verde | 0% | 0% | Banco |
| 932 | 3.1.3.10.25.1.4 | Licitação da obra do Pleito COLESOB16 - Implantação de rede interceptora de esgoto sanitário na micro bacia do bairro Santa Terezinha concluída | milestone | 0d | 2021-05-06 | 2021-05-06 | 931 | 2021-05-06 | 2021-05-06 | 0d | 2021-05-06 | 2021-05-06 | 303d | 0d | Verde | Verde | 0% | 0% | Compensatória | Verde | 0% | 0% | Município |
| 933 | 3.1.3.10.25.2 | Executar obra |  | 171d | 2021-06-07 | 2022-02-07 | 932FS+20d | 2021-06-07 | 2022-02-07 | 171d | 2021-06-07 | 2022-02-07 | 303d | 0d | Verde | Verde | 0% | 0% | Compensatória | Verde | 0% | 0% | Município |
| 934 | 3.1.3.10.25.3 | Realizar processo de pré-operação |  | 120d | 2022-02-08 | 2022-08-02 | 933 | 2022-02-08 | 2022-08-02 | 120d | 2022-02-08 | 2022-08-12 | 303d | 0d | Verde | Verde | 0% | 0% | Compensatória | Verde | 0% | 0% | Município |
| 935 | 3.1.3.10.25.4 | Recurso da obra do Pleito COLESOB16 - Implantação de rede interceptora de esgoto sanitário na micro bacia do bairro Santa Terezinha repassado | milestone | 0d | 2022-08-09 | 2022-08-09 | 934FS+5d | 2022-08-09 | 2022-08-09 | 0d | 2022-08-22 | 2022-08-22 | 303d | 0d | Verde | Verde | 0% | 0% | Compensatória | Verde | 0% | 0% | Banco |
| 936 | 3.1.3.10.25.5 | Pleito COLESOB16 - Implantação de rede interceptora de esgoto sanitário na micro bacia do bairro Santa Terezinha de Colatina concluído | milestone | 0d | 2022-08-09 | 2022-08-09 | 935 | 2022-08-09 | 2022-08-09 | 0d | 2022-08-22 | 2022-08-22 | 303d | 145d | Verde | Verde | 0% | 0% | Compensatória | Verde | 0% | 0% | Município |

| ID | WBS | Task | Type | Duration | Start | Finish | Predecessors | Baseline start | Baseline finish | Baseline duration | Baseline 1 start | Baseline 1 finish | Total slack | Free slack | Text1 | Text2 | Text3 | Text6 | Text8 | Text12 | Text14 | Text16 | Text9 |
| --- | --- | --- | --- | --- | --- | --- | --- | --- | --- | --- | --- | --- | --- | --- | --- | --- | --- | --- | --- | --- | --- | --- | --- |
| 937 | 3.1.3.10.26 | **Pleito COLESOB17 - Implantação de rede interceptora de esgoto sanitário na micro bacia do bairro Maria Ismênia** |  | 348d | 2021-01-14 | 2022-06-08 |  | 2021-01-14 | 2022-06-08 | 348d | 2021-01-14 | 2022-06-21 | 346d |  | Verde | Verde | 0% | 0% | Compensatória | Verde | 0% | 0% |  |
| 938 | 3.1.3.10.26.1 | **Licitação da Obra** |  | 75d | 2021-01-14 | 2021-05-06 |  | 2021-01-14 | 2021-05-06 | 75d | 2021-01-14 | 2021-05-06 | 346d |  | Verde | Verde | 0% | 0% | Compensatória | Verde | 0% | 0% |  |
| 939 | 3.1.3.10.26.1.1 | Licitação da obra do Pleito COLESOB17 - Implantação de rede interceptora de esgoto sanitário na micro bacia do bairro Maria Ismênia autorizada pelo banco | milestone | 0d | 2021-01-14 | 2021-01-14 | 926 | 2021-01-14 | 2021-01-14 | 0d | 2021-01-14 | 2021-01-14 | 346d | 0d | Verde | Verde | 0% | 0% | Compensatória | Verde | 0% | 0% | Banco |
| 940 | 3.1.3.10.26.1.2 | Licitar Obra |  | 61d | 2021-01-15 | 2021-04-15 | 939 | 2021-01-15 | 2021-04-15 | 61d | 2021-01-15 | 2021-04-15 | 346d | 0d | Verde | Verde | 0% | 0% | Compensatória | Verde | 0% | 0% | Município |
| 941 | 3.1.3.10.26.1.3 | Analisar e emitir resultado da licitação da obra |  | 14d | 2021-04-16 | 2021-05-06 | 940 | 2021-04-16 | 2021-05-06 | 14d | 2021-04-16 | 2021-05-06 | 346d | 0d | Verde | Verde | 0% | 0% | Compensatória | Verde | 0% | 0% | Banco |
| 942 | 3.1.3.10.26.1.4 | Licitação da obra do Pleito COLESOB17 - Implantação de rede interceptora de esgoto sanitário na micro bacia do bairro Maria Ismênia concluída | milestone | 0d | 2021-05-06 | 2021-05-06 | 941 | 2021-05-06 | 2021-05-06 | 0d | 2021-05-06 | 2021-05-06 | 346d | 0d | Verde | Verde | 0% | 0% | Compensatória | Verde | 0% | 0% | Município |
| 943 | 3.1.3.10.26.2 | Executar obra |  | 128d | 2021-06-07 | 2021-12-07 | 942FS+20d | 2021-06-07 | 2021-12-07 | 128d | 2021-06-07 | 2021-12-07 | 346d | 0d | Verde | Verde | 0% | 0% | Compensatória | Verde | 0% | 0% | Município |
| 944 | 3.1.3.10.26.3 | Realizar processo de pré-operação |  | 120d | 2021-12-08 | 2022-06-01 | 943 | 2021-12-08 | 2022-06-01 | 120d | 2021-12-08 | 2022-06-13 | 346d | 0d | Verde | Verde | 0% | 0% | Compensatória | Verde | 0% | 0% | Município |
| 945 | 3.1.3.10.26.4 | Recurso da obra do Pleito COLESOB17 - Implantação de rede interceptora de esgoto sanitário na micro bacia do bairro Maria Ismênia repassado | milestone | 0d | 2022-06-08 | 2022-06-08 | 944FS+5d | 2022-06-08 | 2022-06-08 | 0d | 2022-06-21 | 2022-06-21 | 346d | 0d | Verde | Verde | 0% | 0% | Compensatória | Verde | 0% | 0% | Banco |
| 946 | 3.1.3.10.26.5 | Pleito COLESOB17 - Implantação de rede interceptora de esgoto sanitário na micro bacia do bairro Maria Ismênia de Colatina concluído | milestone | 0d | 2022-06-08 | 2022-06-08 | 945 | 2022-06-08 | 2022-06-08 | 0d | 2022-06-21 | 2022-06-21 | 346d | 188d | Verde | Verde | 0% | 0% | Compensatória | Verde | 0% | 0% | Município |
| 947 | 3.1.3.10.27 | **Pleito COLESOB18 - Implantação de rede interceptora de esgoto sanitário na micro bacia do bairro Operário** |  | 391d | 2021-01-14 | 2022-08-09 |  | 2021-01-14 | 2022-08-09 | 391d | 2021-01-14 | 2022-08-22 | 303d |  | Verde | Verde | 0% | 0% | Compensatória | Verde | 0% | 0% |  |
| 948 | 3.1.3.10.27.1 | **Licitação da Obra** |  | 75d | 2021-01-14 | 2021-05-06 |  | 2021-01-14 | 2021-05-06 | 75d | 2021-01-14 | 2021-05-06 | 303d |  | Verde | Verde | 0% | 0% | Compensatória | Verde | 0% | 0% |  |
| 949 | 3.1.3.10.27.1.1 | Licitação da obra do Pleito COLESOB18 - Implantação de rede interceptora de esgoto sanitário na micro bacia do bairro Operário autorizada pelo banco | milestone | 0d | 2021-01-14 | 2021-01-14 | 926 | 2021-01-14 | 2021-01-14 | 0d | 2021-01-14 | 2021-01-14 | 303d | 0d | Verde | Verde | 0% | 0% | Compensatória | Verde | 0% | 0% | Banco |
| 950 | 3.1.3.10.27.1.2 | Licitar Obra |  | 61d | 2021-01-15 | 2021-04-15 | 949 | 2021-01-15 | 2021-04-15 | 61d | 2021-01-15 | 2021-04-15 | 303d | 0d | Verde | Verde | 0% | 0% | Compensatória | Verde | 0% | 0% | Município |
| 951 | 3.1.3.10.27.1.3 | Analisar e emitir resultado da licitação da obra |  | 14d | 2021-04-16 | 2021-05-06 | 950 | 2021-04-16 | 2021-05-06 | 14d | 2021-04-16 | 2021-05-06 | 303d | 0d | Verde | Verde | 0% | 0% | Compensatória | Verde | 0% | 0% | Banco |
| 952 | 3.1.3.10.27.1.4 | Licitação da obra do Pleito COLESOB18 - Implantação de rede interceptora de esgoto sanitário na micro bacia do bairro Operário concluída | milestone | 0d | 2021-05-06 | 2021-05-06 | 951 | 2021-05-06 | 2021-05-06 | 0d | 2021-05-06 | 2021-05-06 | 303d | 0d | Verde | Verde | 0% | 0% | Compensatória | Verde | 0% | 0% | Município |
| 953 | 3.1.3.10.27.2 | Executar obra |  | 171d | 2021-06-07 | 2022-02-07 | 952FS+20d | 2021-06-07 | 2022-02-07 | 171d | 2021-06-07 | 2022-02-07 | 303d | 0d | Verde | Verde | 0% | 0% | Compensatória | Verde | 0% | 0% | Município |
| 954 | 3.1.3.10.27.3 | Realizar processo de pré-operação |  | 120d | 2022-02-08 | 2022-08-02 | 953 | 2022-02-08 | 2022-08-02 | 120d | 2022-02-08 | 2022-08-12 | 303d | 0d | Verde | Verde | 0% | 0% | Compensatória | Verde | 0% | 0% | Município |
| 955 | 3.1.3.10.27.4 | Recurso da obra do Pleito COLESOB18 - Implantação de rede interceptora de esgoto sanitário na micro bacia do bairro Operário repassado | milestone | 0d | 2022-08-09 | 2022-08-09 | 954FS+5d | 2022-08-09 | 2022-08-09 | 0d | 2022-08-22 | 2022-08-22 | 303d | 0d | Verde | Verde | 0% | 0% | Compensatória | Verde | 0% | 0% | Banco |
| 956 | 3.1.3.10.27.5 | Pleito COLESOB18 - Implantação de rede interceptora de esgoto sanitário na micro bacia do bairro Operário de Colatina concluído | milestone | 0d | 2022-08-09 | 2022-08-09 | 955 | 2022-08-09 | 2022-08-09 | 0d | 2022-08-22 | 2022-08-22 | 303d | 145d | Verde | Verde | 0% | 0% | Compensatória | Verde | 0% | 0% | Município |
| 957 | 3.1.3.10.28 | **Pleito COLESOB19 - Implantação de rede interceptora de esgoto sanitário na micro bacia do bairro São Vicente** |  | 348d | 2021-01-14 | 2022-06-08 |  | 2021-01-14 | 2022-06-08 | 348d | 2021-01-14 | 2022-06-21 | 346d |  | Verde | Verde | 0% | 0% | Compensatória | Verde | 0% | 0% |  |
| 958 | 3.1.3.10.28.1 | **Licitação da Obra** |  | 75d | 2021-01-14 | 2021-05-06 |  | 2021-01-14 | 2021-05-06 | 75d | 2021-01-14 | 2021-05-06 | 346d |  | Verde | Verde | 0% | 0% | Compensatória | Verde | 0% | 0% |  |
| 959 | 3.1.3.10.28.1.1 | Licitação da obra do Pleito COLESOB19 - Implantação de rede interceptora de esgoto sanitário na micro bacia do bairro São Vicente autorizada pelo banco | milestone | 0d | 2021-01-14 | 2021-01-14 | 926 | 2021-01-14 | 2021-01-14 | 0d | 2021-01-14 | 2021-01-14 | 346d | 0d | Verde | Verde | 0% | 0% | Compensatória | Verde | 0% | 0% | Banco |
| 960 | 3.1.3.10.28.1.2 | Licitar Obra |  | 61d | 2021-01-15 | 2021-04-15 | 959 | 2021-01-15 | 2021-04-15 | 61d | 2021-01-15 | 2021-04-15 | 346d | 0d | Verde | Verde | 0% | 0% | Compensatória | Verde | 0% | 0% | Município |
| 961 | 3.1.3.10.28.1.3 | Analisar e emitir resultado da licitação da obra |  | 14d | 2021-04-16 | 2021-05-06 | 960 | 2021-04-16 | 2021-05-06 | 14d | 2021-04-16 | 2021-05-06 | 346d | 0d | Verde | Verde | 0% | 0% | Compensatória | Verde | 0% | 0% | Banco |
| 962 | 3.1.3.10.28.1.4 | Licitação da obra do Pleito COLESOB19 - Implantação de rede interceptora de esgoto sanitário na micro bacia do bairro São Vicente concluída | milestone | 0d | 2021-05-06 | 2021-05-06 | 961 | 2021-05-06 | 2021-05-06 | 0d | 2021-05-06 | 2021-05-06 | 346d | 0d | Verde | Verde | 0% | 0% | Compensatória | Verde | 0% | 0% | Município |
| 963 | 3.1.3.10.28.2 | Executar obra |  | 128d | 2021-06-07 | 2021-12-07 | 962FS+20d | 2021-06-07 | 2021-12-07 | 128d | 2021-06-07 | 2021-12-07 | 346d | 0d | Verde | Verde | 0% | 0% | Compensatória | Verde | 0% | 0% | Município |
| 964 | 3.1.3.10.28.3 | Realizar processo de pré-operação |  | 120d | 2021-12-08 | 2022-06-01 | 963 | 2021-12-08 | 2022-06-01 | 120d | 2021-12-08 | 2022-06-13 | 346d | 0d | Verde | Verde | 0% | 0% | Compensatória | Verde | 0% | 0% | Município |
| 965 | 3.1.3.10.28.4 | Recurso da obra do Pleito COLESOB19 - Implantação de rede interceptora de esgoto sanitário na micro bacia do bairro São Vicente repassado | milestone | 0d | 2022-06-08 | 2022-06-08 | 964FS+5d | 2022-06-08 | 2022-06-08 | 0d | 2022-06-21 | 2022-06-21 | 346d | 0d | Verde | Verde | 0% | 0% | Compensatória | Verde | 0% | 0% | Banco |
| 966 | 3.1.3.10.28.5 | Pleito COLESOB19 - Implantação de rede interceptora de esgoto sanitário na micro bacia do bairro São Vicente de Colatina concluído | milestone | 0d | 2022-06-08 | 2022-06-08 | 965 | 2022-06-08 | 2022-06-08 | 0d | 2022-06-21 | 2022-06-21 | 346d | 188d | Verde | Verde | 0% | 0% | Compensatória | Verde | 0% | 0% | Município |

| ID | WBS | Task | Type | Duration | Start | Finish | Predecessors | Baseline start | Baseline finish | Baseline duration | Baseline 1 start | Baseline 1 finish | Total slack | Free slack | Text1 | Text2 | Text3 | Text6 | Text8 | Text12 | Text14 | Text16 | Text9 |
| --- | --- | --- | --- | --- | --- | --- | --- | --- | --- | --- | --- | --- | --- | --- | --- | --- | --- | --- | --- | --- | --- | --- | --- |
| 967 | 3.1.3.10.29 | **Pleito COLESOB20 - Implantação de rede interceptora de esgoto sanitário na micro bacia do bairro Colatina Velha** |  | 348d | 2021-01-14 | 2022-06-08 |  | 2021-01-14 | 2022-06-08 | 348d | 2021-01-14 | 2022-06-21 | 346d |  | Verde | Verde | 0% | 0% | Compensatória | Verde | 0% | 0% |  |
| 968 | 3.1.3.10.29.1 | **Licitação da Obra** |  | 75d | 2021-01-14 | 2021-05-06 |  | 2021-01-14 | 2021-05-06 | 75d | 2021-01-14 | 2021-05-06 | 346d |  | Verde | Verde | 0% | 0% | Compensatória | Verde | 0% | 0% |  |
| 969 | 3.1.3.10.29.1.1 | Licitação da obra do Pleito COLESOB20 - Implantação de rede interceptora de esgoto sanitário na micro bacia do bairro Colatina Velha autorizada pelo banco | milestone | 0d | 2021-01-14 | 2021-01-14 | 926 | 2021-01-14 | 2021-01-14 | 0d | 2021-01-14 | 2021-01-14 | 346d | 0d | Verde | Verde | 0% | 0% | Compensatória | Verde | 0% | 0% | Banco |
| 970 | 3.1.3.10.29.1.2 | Licitar Obra |  | 61d | 2021-01-15 | 2021-04-15 | 969 | 2021-01-15 | 2021-04-15 | 61d | 2021-01-15 | 2021-04-15 | 346d | 0d | Verde | Verde | 0% | 0% | Compensatória | Verde | 0% | 0% | Município |
| 971 | 3.1.3.10.29.1.3 | Analisar e emitir resultado da licitação da obra |  | 14d | 2021-04-16 | 2021-05-06 | 970 | 2021-04-16 | 2021-05-06 | 14d | 2021-04-16 | 2021-05-06 | 346d | 0d | Verde | Verde | 0% | 0% | Compensatória | Verde | 0% | 0% | Banco |
| 972 | 3.1.3.10.29.1.4 | Licitação da obra do Pleito COLESOB20 - Implantação de rede interceptora de esgoto sanitário na micro bacia do bairro Colatina Velha concluída | milestone | 0d | 2021-05-06 | 2021-05-06 | 971 | 2021-05-06 | 2021-05-06 | 0d | 2021-05-06 | 2021-05-06 | 346d | 0d | Verde | Verde | 0% | 0% | Compensatória | Verde | 0% | 0% | Município |
| 973 | 3.1.3.10.29.2 | Executar obra |  | 128d | 2021-06-07 | 2021-12-07 | 972FS+20d | 2021-06-07 | 2021-12-07 | 128d | 2021-06-07 | 2021-12-07 | 346d | 0d | Verde | Verde | 0% | 0% | Compensatória | Verde | 0% | 0% | Município |
| 974 | 3.1.3.10.29.3 | Realizar processo de pré-operação |  | 120d | 2021-12-08 | 2022-06-01 | 973 | 2021-12-08 | 2022-06-01 | 120d | 2021-12-08 | 2022-06-13 | 346d | 0d | Verde | Verde | 0% | 0% | Compensatória | Verde | 0% | 0% | Município |
| 975 | 3.1.3.10.29.4 | Recurso da obra do Pleito COLESOB20 - Implantação de rede interceptora de esgoto sanitário na micro bacia do bairro Colatina Velha repassado | milestone | 0d | 2022-06-08 | 2022-06-08 | 974FS+5d | 2022-06-08 | 2022-06-08 | 0d | 2022-06-21 | 2022-06-21 | 346d | 0d | Verde | Verde | 0% | 0% | Compensatória | Verde | 0% | 0% | Banco |
| 976 | 3.1.3.10.29.5 | Pleito COLESOB20 - Implantação de rede interceptora de esgoto sanitário na micro bacia do bairro Colatina Velha de Colatina concluído | milestone | 0d | 2022-06-08 | 2022-06-08 | 975 | 2022-06-08 | 2022-06-08 | 0d | 2022-06-21 | 2022-06-21 | 346d | 188d | Verde | Verde | 0% | 0% | Compensatória | Verde | 0% | 0% | Município |
| 977 | 3.1.3.10.30 | **Pleito COLESOB21 - Implantação de rede interceptora de esgoto sanitário na micro bacia do bairro Santa Mônica** |  | 391d | 2021-01-14 | 2022-08-09 |  | 2021-01-14 | 2022-08-09 | 391d | 2021-01-14 | 2022-08-22 | 303d |  | Verde | Verde | 0% | 0% | Compensatória | Verde | 0% | 0% |  |
| 978 | 3.1.3.10.30.1 | **Licitação da Obra** |  | 75d | 2021-01-14 | 2021-05-06 |  | 2021-01-14 | 2021-05-06 | 75d | 2021-01-14 | 2021-05-06 | 303d |  | Verde | Verde | 0% | 0% | Compensatória | Verde | 0% | 0% |  |
| 979 | 3.1.3.10.30.1.1 | Licitação da obra do Pleito COLESOB21 - Implantação de rede interceptora de esgoto sanitário na micro bacia do bairro Santa Mônica autorizada pelo banco | milestone | 0d | 2021-01-14 | 2021-01-14 | 926 | 2021-01-14 | 2021-01-14 | 0d | 2021-01-14 | 2021-01-14 | 303d | 0d | Verde | Verde | 0% | 0% | Compensatória | Verde | 0% | 0% | Banco |
| 980 | 3.1.3.10.30.1.2 | Licitar Obra |  | 61d | 2021-01-15 | 2021-04-15 | 979 | 2021-01-15 | 2021-04-15 | 61d | 2021-01-15 | 2021-04-15 | 303d | 0d | Verde | Verde | 0% | 0% | Compensatória | Verde | 0% | 0% | Município |
| 981 | 3.1.3.10.30.1.3 | Analisar e emitir resultado da licitação da obra |  | 14d | 2021-04-16 | 2021-05-06 | 980 | 2021-04-16 | 2021-05-06 | 14d | 2021-04-16 | 2021-05-06 | 303d | 0d | Verde | Verde | 0% | 0% | Compensatória | Verde | 0% | 0% | Banco |
| 982 | 3.1.3.10.30.1.4 | Licitação da obra do Pleito COLESOB21 - Implantação de rede interceptora de esgoto sanitário na micro bacia do bairro Santa Mônica concluída | milestone | 0d | 2021-05-06 | 2021-05-06 | 981 | 2021-05-06 | 2021-05-06 | 0d | 2021-05-06 | 2021-05-06 | 303d | 0d | Verde | Verde | 0% | 0% | Compensatória | Verde | 0% | 0% | Município |
| 983 | 3.1.3.10.30.2 | Executar obra |  | 171d | 2021-06-07 | 2022-02-07 | 982FS+20d | 2021-06-07 | 2022-02-07 | 171d | 2021-06-07 | 2022-02-07 | 303d | 0d | Verde | Verde | 0% | 0% | Compensatória | Verde | 0% | 0% | Município |
| 984 | 3.1.3.10.30.3 | Realizar processo de pré-operação |  | 120d | 2022-02-08 | 2022-08-02 | 983 | 2022-02-08 | 2022-08-02 | 120d | 2022-02-08 | 2022-08-12 | 303d | 0d | Verde | Verde | 0% | 0% | Compensatória | Verde | 0% | 0% | Município |
| 985 | 3.1.3.10.30.4 | Recurso da obra do Pleito COLESOB21 - Implantação de rede interceptora de esgoto sanitário na micro bacia do bairro Santa Mônica repassado | milestone | 0d | 2022-08-09 | 2022-08-09 | 984FS+5d | 2022-08-09 | 2022-08-09 | 0d | 2022-08-22 | 2022-08-22 | 303d | 0d | Verde | Verde | 0% | 0% | Compensatória | Verde | 0% | 0% | Banco |
| 986 | 3.1.3.10.30.5 | Pleito COLESOB21 - Implantação de rede interceptora de esgoto sanitário na micro bacia do bairro Santa Mônica de Colatina concluído | milestone | 0d | 2022-08-09 | 2022-08-09 | 985 | 2022-08-09 | 2022-08-09 | 0d | 2022-08-22 | 2022-08-22 | 303d | 145d | Verde | Verde | 0% | 0% | Compensatória | Verde | 0% | 0% | Município |
| 987 | 3.1.3.10.31 | **Pleito COLESOB22 - Implantação de rede interceptora de esgoto sanitário na micro bacia do bairro Vila Verdi** |  | 343d | 2021-01-14 | 2022-06-01 |  | 2021-01-14 | 2022-06-01 | 343d | 2021-01-14 | 2022-06-13 | 351d |  | Verde | Verde | 0% | 0% | Compensatória | Verde | 0% | 0% |  |
| 988 | 3.1.3.10.31.1 | **Licitação da Obra** |  | 75d | 2021-01-14 | 2021-05-06 |  | 2021-01-14 | 2021-05-06 | 75d | 2021-01-14 | 2021-05-06 | 351d |  | Verde | Verde | 0% | 0% | Compensatória | Verde | 0% | 0% |  |
| 989 | 3.1.3.10.31.1.1 | Licitação da obra do Pleito COLESOB22 - Implantação de rede interceptora de esgoto sanitário na micro bacia do bairro Vila Verdi autorizada pelo banco | milestone | 0d | 2021-01-14 | 2021-01-14 | 926 | 2021-01-14 | 2021-01-14 | 0d | 2021-01-14 | 2021-01-14 | 351d | 0d | Verde | Verde | 0% | 0% | Compensatória | Verde | 0% | 0% | Banco |
| 990 | 3.1.3.10.31.1.2 | Licitar Obra |  | 61d | 2021-01-15 | 2021-04-15 | 989 | 2021-01-15 | 2021-04-15 | 61d | 2021-01-15 | 2021-04-15 | 351d | 0d | Verde | Verde | 0% | 0% | Compensatória | Verde | 0% | 0% | Município |
| 991 | 3.1.3.10.31.1.3 | Analisar e emitir resultado da licitação da obra |  | 14d | 2021-04-16 | 2021-05-06 | 990 | 2021-04-16 | 2021-05-06 | 14d | 2021-04-16 | 2021-05-06 | 351d | 0d | Verde | Verde | 0% | 0% | Compensatória | Verde | 0% | 0% | Banco |
| 992 | 3.1.3.10.31.1.4 | Licitação da obra do Pleito COLESOB22 - Implantação de rede interceptora de esgoto sanitário na micro bacia do bairro Vila Verdi concluída | milestone | 0d | 2021-05-06 | 2021-05-06 | 991 | 2021-05-06 | 2021-05-06 | 0d | 2021-05-06 | 2021-05-06 | 351d | 0d | Verde | Verde | 0% | 0% | Compensatória | Verde | 0% | 0% | Município |
| 993 | 3.1.3.10.31.2 | Executar obra |  | 128d | 2021-06-07 | 2021-12-07 | 992FS+20d | 2021-06-07 | 2021-12-07 | 128d | 2021-06-07 | 2021-12-07 | 351d | 0d | Verde | Verde | 0% | 0% | Compensatória | Verde | 0% | 0% | Município |
| 994 | 3.1.3.10.31.3 | Realizar processo de pré-operação |  | 120d | 2021-12-08 | 2022-06-01 | 993 | 2021-12-08 | 2022-06-01 | 120d | 2021-12-08 | 2022-06-13 | 351d | 0d | Verde | Verde | 0% | 0% | Compensatória | Verde | 0% | 0% | Município |
| 995 | 3.1.3.10.31.4 | Recurso da obra do Pleito COLESOB22 - Implantação de rede interceptora de esgoto sanitário na micro bacia do bairro Vila Verdi repassado | milestone | 0d | 2022-06-01 | 2022-06-01 | 994 | 2022-06-01 | 2022-06-01 | 0d | 2022-06-13 | 2022-06-13 | 351d | 0d | Verde | Verde | 0% | 0% | Compensatória | Verde | 0% | 0% | Banco |
| 996 | 3.1.3.10.31.5 | Pleito COLESOB22 - Implantação de rede interceptora de esgoto sanitário na micro bacia do bairro Vila Verdi de Colatina concluído | milestone | 0d | 2022-06-01 | 2022-06-01 | 995 | 2022-06-01 | 2022-06-01 | 0d | 2022-06-13 | 2022-06-13 | 351d | 193d | Verde | Verde | 0% | 0% | Compensatória | Verde | 0% | 0% | Município |

| ID | WBS | Task | Type | Duration | Start | Finish | Predecessors | Complete | Remaining | Baseline start | Baseline finish | Baseline duration | Baseline 1 start | Baseline 1 finish | Total slack | Free slack | Text1 | Text2 | Text3 | Text6 | Text8 | Text12 | Text14 | Text16 | Text9 | Text7 | Text4 | Text5 | Text15 | Text17 | Text18 |
| --- | --- | --- | --- | --- | --- | --- | --- | --- | --- | --- | --- | --- | --- | --- | --- | --- | --- | --- | --- | --- | --- | --- | --- | --- | --- | --- | --- | --- | --- | --- | --- |
| 997 | 3.1.3.10.32 | **Pleito COLESOB23 - Implantação de rede interceptora de esgoto sanitário na micro bacia do bairro São Miguel** |  | 348d | 2021-01-14 | 2022-06-08 |  |  |  | 2021-01-14 | 2022-06-08 | 348d | 2021-01-14 | 2022-06-21 | 346d |  | Verde | Verde | 0% | 0% | Compensatória | Verde | 0% | 0% |  |  |  |  |  |  |  |
| 998 | 3.1.3.10.32.1 | **Licitação da Obra** |  | 75d | 2021-01-14 | 2021-05-06 |  |  |  | 2021-01-14 | 2021-05-06 | 75d | 2021-01-14 | 2021-05-06 | 346d |  | Verde | Verde | 0% | 0% | Compensatória | Verde | 0% | 0% |  |  |  |  |  |  |  |
| 999 | 3.1.3.10.32.1.1 | Licitação da obra do Pleito COLESOB23 - Implantação de rede interceptora de esgoto sanitário na micro bacia do bairro São Miguel autorizada pelo banco | milestone | 0d | 2021-01-14 | 2021-01-14 | 926 |  |  | 2021-01-14 | 2021-01-14 | 0d | 2021-01-14 | 2021-01-14 | 346d | 0d | Verde | Verde | 0% | 0% | Compensatória | Verde | 0% | 0% | Banco |  |  |  |  |  |  |
| 1000 | 3.1.3.10.32.1.2 | Licitar Obra |  | 61d | 2021-01-15 | 2021-04-15 | 999 |  |  | 2021-01-15 | 2021-04-15 | 61d | 2021-01-15 | 2021-04-15 | 346d | 0d | Verde | Verde | 0% | 0% | Compensatória | Verde | 0% | 0% | Município |  |  |  |  |  |  |
| 1001 | 3.1.3.10.32.1.3 | Analisar e emitir resultado da licitação da obra |  | 14d | 2021-04-16 | 2021-05-06 | 1000 |  |  | 2021-04-16 | 2021-05-06 | 14d | 2021-04-16 | 2021-05-06 | 346d | 0d | Verde | Verde | 0% | 0% | Compensatória | Verde | 0% | 0% | Banco |  |  |  |  |  |  |
| 1002 | 3.1.3.10.32.1.4 | Licitação da obra do Pleito COLESOB23 - Implantação de rede interceptora de esgoto sanitário na micro bacia do bairro São Miguel concluída | milestone | 0d | 2021-05-06 | 2021-05-06 | 1001 |  |  | 2021-05-06 | 2021-05-06 | 0d | 2021-05-06 | 2021-05-06 | 346d | 0d | Verde | Verde | 0% | 0% | Compensatória | Verde | 0% | 0% | Município |  |  |  |  |  |  |
| 1003 | 3.1.3.10.32.2 | Executar obra |  | 128d | 2021-06-07 | 2021-12-07 | 1002FS+20d |  |  | 2021-06-07 | 2021-12-07 | 128d | 2021-06-07 | 2021-12-07 | 346d | 0d | Verde | Verde | 0% | 0% | Compensatória | Verde | 0% | 0% | Município |  |  |  |  |  |  |
| 1004 | 3.1.3.10.32.3 | Realizar processo de pré-operação |  | 120d | 2021-12-08 | 2022-06-01 | 1003 |  |  | 2021-12-08 | 2022-06-01 | 120d | 2021-12-08 | 2022-06-13 | 346d | 0d | Verde | Verde | 0% | 0% | Compensatória | Verde | 0% | 0% | Município |  |  |  |  |  |  |
| 1005 | 3.1.3.10.32.4 | Recurso da obra do Pleito COLESOB23 - Implantação de rede interceptora de esgoto sanitário na micro bacia do bairro São Miguel repassado | milestone | 0d | 2022-06-08 | 2022-06-08 | 1004FS+5d |  |  | 2022-06-08 | 2022-06-08 | 0d | 2022-06-21 | 2022-06-21 | 346d | 0d | Verde | Verde | 0% | 0% | Compensatória | Verde | 0% | 0% | Banco |  |  |  |  |  |  |
| 1006 | 3.1.3.10.32.5 | Pleito COLESOB23 - Implantação de rede interceptora de esgoto sanitário na micro bacia do bairro São Miguel de Colatina concluído | milestone | 0d | 2022-06-08 | 2022-06-08 | 1005 |  |  | 2022-06-08 | 2022-06-08 | 0d | 2022-06-21 | 2022-06-21 | 346d | 188d | Verde | Verde | 0% | 0% | Compensatória | Verde | 0% | 0% | Município |  |  |  |  |  |  |
| 1007 | 3.1.3.10.33 | **Pleito COLRSOB01 - Viabilizar a solução consorciada, com objetivo de executar as obras para a implantação da Central de Tratamento de Resíduos – CTR Colatina** |  | 638d | 2019-03-14 A | 2021-10-05 |  | 5% | 606.44d | 2019-03-14 | 2021-10-05 | 638d | 2019-03-14 | 2021-09-15 | 513d |  | Verde | Verde | 8% | 57% | Compensatória | Vermelho | 7% | 4% |  | 57 |  |  |  |  |  |
| 1008 | 3.1.3.10.33.1 | **Licitação da obra** |  | 114d | 2019-03-14 A | 2019-08-28 |  | 28% | 82.54d | 2019-03-14 | 2019-08-28 | 114d | 2019-03-14 | 2019-05-29 | 513d |  | Verde | Verde | 46% | 56% | Compensatória | Vermelho | 45% | 25% |  | 56 | 28 | 46 | 45 | 25 |  |
| 1009 | 3.1.3.10.33.1.1 | Licitação da obra do Pleito COLRSOB01 - Viabilizar a solução consorciada, com objetivo de executar as obras para a implantação da Central de Tratamento de Resíduos – CTR Colatina autorizada pelo banco | milestone | 0d | 2019-03-14 A | 2019-03-14 A | 3021FS+62d | 100% |  | 2019-03-14 | 2019-03-14 | 0d | 2019-03-14 | 2019-03-14 |  |  | Verde | Verde | 100% | 100% | Compensatória | Verde | 100% | 100% | Banco | 100 | 100 | 100 | 100 | 100 |  |
| 1010 | 3.1.3.10.33.1.2 | Licitar obra |  | 94d | 2019-03-15 A | 2019-07-30 | 1009 | 32% | 63.92d | 2019-03-15 | 2019-07-30 | 94d | 2019-03-14 | 2019-05-09 | 513d | 0d | Verde | Verde | 56% | 55% | Compensatória | Vermelho | 56% | 31% | Município | 55 | 32 | 56 | 56 | 31 | Conforme agendado |
| 1011 | 3.1.3.10.33.1.3 | Analisar e emitir resultado da licitação da obra |  | 15d | 2019-08-07 | 2019-08-28 | 1010FS+5d |  |  | 2019-08-07 | 2019-08-28 | 15d | 2019-05-20 | 2019-05-29 | 513d | 0d | Verde | Verde | 0% | 0% | Compensatória | Verde | 0% | 0% | Banco |  |  |  |  |  | Critério FR |
| 1012 | 3.1.3.10.33.1.4 | Licitação da obra do Pleito COLRSOB01 - Viabilizar a solução consorciada, com objetivo de executar as obras para a implantação da Central de Tratamento de Resíduos – CTR Colatina concluída | milestone | 0d | 2019-08-28 | 2019-08-28 | 1011 |  |  | 2019-08-28 | 2019-08-28 | 0d | 2019-05-29 | 2019-05-29 | 513d | 0d | Verde | Verde | 0% | 0% | Compensatória | Verde | 0% | 0% | Município |  |  |  |  |  |  |
| 1013 | 3.1.3.10.33.2 | Executar obra |  | 249d | 2019-09-26 | 2020-09-25 | 1012FS+20d |  |  | 2019-09-26 | 2020-09-25 | 249d | 2019-07-08 | 2021-03-08 | 513d | 0d | Verde | Verde | 0% | 0% | Compensatória | Verde | 0% | 0% | Município |  |  |  |  |  |  |
| 1014 | 3.1.3.10.33.3 | Realizar processo de pré-operação |  | 250d | 2020-09-28 | 2021-09-28 | 1013 |  |  | 2020-09-28 | 2021-09-28 | 250d | 2021-03-09 | 2021-09-08 | 513d | 0d | Verde | Verde | 0% | 0% | Compensatória | Verde | 0% | 0% | Município |  |  |  |  |  |  |
| 1015 | 3.1.3.10.33.4 | Recurso da obra do Pleito COLRSOB01 - Viabilizar a solução consorciada, com objetivo de executar as obras para a implantação da Central de Tratamento de Resíduos – CTR Colatina repassado | milestone | 0d | 2021-10-05 | 2021-10-05 | 1014FS+5d |  |  | 2021-10-05 | 2021-10-05 | 0d | 2021-09-15 | 2021-09-15 | 513d | 0d | Verde | Verde | 0% | 0% | Compensatória | Verde | 0% | 0% | Banco |  |  |  |  |  |  |
| 1016 | 3.1.3.10.33.5 | Pleito COLRSOB01 - Viabilizar a solução consorciada, com objetivo de executar as obras para a implantação da Central de Tratamento de Resíduos – CTR Colatina de Colatina concluído | milestone | 0d | 2021-10-05 | 2021-10-05 | 1015 |  |  | 2021-10-05 | 2021-10-05 | 0d | 2021-09-15 | 2021-09-15 | 513d | 355d | Verde | Verde | 0% | 0% | Compensatória | Verde | 0% | 0% | Município |  |  |  |  |  |  |
| 1017 | 3.1.3.10.34 | Recursos de Colatina repassados | milestone | 0d | 2023-03-13 | 2023-03-13 | 601, 608, 615, 631, 646, 666, 676, 696, 706, 726, 736, 756, 766, 786, 796, 816, 826, 846, 856, 876, 887, 896, 906, 926, 936, 946, 956, 966, 976, 986, 996, 1006, 1016 |  |  | 2023-03-13 | 2023-03-13 | 0d | 2022-09-14 | 2022-09-14 | 158d |  | Verde | Verde | 0% | 0% | Compensatória | Verde | 0% | 0% | Banco |  |  |  |  |  |  |
| 1018 | 3.1.3.11 | **Conselheiro Pena** |  | 779d | 2019-03-12 A | 2022-04-29 |  | 4% | 749.34d | 2019-03-12 | 2022-04-29 | 779d | 2019-03-28 | 2023-01-13 | 374d |  | Verde | Verde | 7% | 67% | Compensatória | Vermelho | 9% | 6% |  | 67 |  |  |  |  |  |
| 1019 | 3.1.3.11.1 | **Pleito COPESPJ01 - Contratação de empresa especializada para elaboração dos projetos executivos** |  | 753d | 2019-03-28 A | 2022-04-07 |  | 99% | 0d | 2019-03-28 | 2022-04-07 | 753d | 2019-03-28 | 2019-11-29 | 388d |  | Verde | Verde | 5% | 100% | Compensatória | Verde | 100% | 100% |  | 100 | 99 |  | 100 | 100 |  |
| 1020 | 3.1.3.11.1.1 | Pleito COPESPJ01 - Contratação de empresa especializada para elaboração dos projetos executivos aprovado | milestone | 0d | 2019-03-28 A | 2019-03-28 A | 3052FS+72d | 100% |  | 2019-03-28 | 2019-03-28 | 0d | 2019-03-28 | 2019-03-28 |  |  | Verde | Verde | 100% | 100% | Compensatória | Verde | 100% | 100% | CT/CIF | 100 | 100 | 100 | 100 | 100 |  |
| 1021 | 3.1.3.11.1.2 | Cancelar processo e realizar projeto com recurso próprio |  | 1d | 2019-05-30 A | 2019-05-30 A | 1020FS+41d | 100% |  | 2019-05-30 | 2019-05-30 | 1d |  |  |  |  | Verde | Verde | 100% | 100% | Compensatória | Verde | 100% | 100% |  | 100 | 100 | 100 | 100 | 100 |  |

Notes:
- 1009: Em 24/09/2019: mesma obra do pleito de baixo guandu para o consórcio CONDOESTE
- 1010: 31/05/2019: conforme e-mail da Mônica, algumas empresas entraram com recurso e por isso os envelopes de preço ainda não foram abertos. Considerado mais um mês de prazo. / 01/07/2019: e-mail Luiz - Os envelopes serão abertos no dia 03/07. Caso não haja imprevisto e nenhuma empresa entre com recurso, o prazo de término continuará dia 30/07.
- 1013: Em 24/09/2019: o valor da obra do CONDOESTE é de R$ 10,9 milhões - 20 meses
- 1017: Valor de recurso destinado ao munícipio: R$43.028.831,34
- 1018: Conselheiro Pena teve 100% dos pleitos de Esgotamento Sanitário aprovado (R$8.508.587,53), conforme Deliberação 75. / Conselheiro Pena solicitou mudança de pleito, mas ainda não foi autorizado pelo CIF. / ·Uso de 100% do teto em esgotamento sanitário para a sede (construção do SES e muros do tipo Gabião, para estabilização das margens do ribeirão João Pinto e proteção das redes) / Município está querendo mudar o pleito para solicitar recurso para projeto, o que mudaria as atividades do cronograma.
- 1020: Em 17/04/2019: pleito foi aprovado no dia 28/03 na deliberação 269.
- 1021: 30/05/2019: município informou que está usando recurso próprio para fazer o projeto, portanto o processo anterior com recurso renova foi cancelado.

| ID | WBS | Task | Type | Duration | Start | Finish | Predecessors | Complete | Remaining | Baseline start | Baseline finish | Baseline duration | Baseline 1 start | Baseline 1 finish | Total slack | Free slack | Text1 | Text2 | Text3 | Text4 | Text5 | Text6 | Text7 | Text8 | Text12 | Text14 | Text15 | Text16 | Text17 | Text9 | Text18 |
| --- | --- | --- | --- | --- | --- | --- | --- | --- | --- | --- | --- | --- | --- | --- | --- | --- | --- | --- | --- | --- | --- | --- | --- | --- | --- | --- | --- | --- | --- | --- | --- |
| 1022 | 3.1.3.11.1.3 | **Licitação do projeto (CANCELADO)** |  | 5d | 2019-04-16 A | 2019-04-25 A |  | 100% |  | 2019-04-16 | 2019-04-25 | 5d | 2019-04-16 | 2019-07-15 |  |  | Verde | Verde | 100% | 100 | 100 | 100% | 100 | Compensatória | Verde | 100% | 100 | 100% | 100 |  |  |
| 1023 | 3.1.3.11.1.3.1 | Licitação do projeto autorizada pelo banco (CANCELADO) | milestone | 0d | 2019-04-16 A | 2019-04-16 A |  | 100% |  | 2019-04-16 | 2019-04-16 | 0d | 2019-04-16 | 2019-04-16 |  |  | Verde | Verde | 100% | 100 | 100 | 100% | 100 | Compensatória | Verde | 100% | 100 | 100% | 100 | Banco |  |
| 1024 | 3.1.3.11.1.3.2 | Licitar projeto (CANCELADO) | milestone | 0d | 2019-04-16 A | 2019-04-16 A |  | 100% |  | 2019-04-16 | 2019-04-16 | 0d | 2019-04-17 | 2019-06-17 |  |  | Verde | Verde | 100% | 100 | 100 | 100% | 100 | Compensatória | Verde | 100% | 100 | 100% | 100 | Município |  |
| 1025 | 3.1.3.11.1.3.3 | Documentação de licitação apresentada ao banco (CANCELADO) | milestone | 0d | 2019-04-25 A | 2019-04-25 A |  | 100% |  | 2019-04-25 | 2019-04-25 | 0d | 2019-06-25 | 2019-06-25 |  |  | Verde | Verde | 100% | 100 | 100 | 100% | 100 | Compensatória | Verde | 100% | 100 | 100% | 100 | Município |  |
| 1026 | 3.1.3.11.1.3.4 | Analisar e emitir resultado da licitação do projeto (CANCELADO) | milestone | 0d | 2019-04-25 A | 2019-04-25 A |  | 100% |  | 2019-04-25 | 2019-04-25 | 0d | 2019-06-26 | 2019-07-15 |  |  | Verde | Verde | 100% | 100 | 100 | 100% | 100 | Compensatória | Verde | 100% | 100 | 100% | 100 | Banco |  |
| 1027 | 3.1.3.11.1.3.5 | Licitação do projeto concluída (CANCELADO) | milestone | 0d | 2019-04-25 A | 2019-04-25 A |  | 100% |  | 2019-04-25 | 2019-04-25 | 0d | 2019-07-15 | 2019-07-15 |  |  | Verde | Verde | 100% | 100 | 100 | 100% | 100 | Compensatória | Verde | 100% | 100 | 100% | 100 | Município |  |
| 1028 | 3.1.3.11.1.4 | **Elaboração do Projeto Executivo (CANCELADO)** |  | 5d | 2019-04-25 A | 2019-05-03 A |  | 100% |  | 2019-04-25 | 2019-05-03 | 5d | 2019-07-16 | 2019-11-29 |  |  | Verde | Verde | 100% | 100 | 100 | 100% | 100 | Compensatória | Verde | 100% | 100 | 100% | 100 |  |  |
| 1029 | 3.1.3.11.1.4.1 | Elaborar Projeto Executivo (CANCELADO) | milestone | 0d | 2019-04-25 A | 2019-04-25 A |  | 100% |  | 2019-04-25 | 2019-04-25 | 0d | 2019-07-16 | 2019-08-16 |  |  | Verde | Verde | 100% | 100 | 100 | 100% | 100 | Compensatória | Verde | 100% | 100 | 100% | 100 | Município |  |
| 1030 | 3.1.3.11.1.4.2 | Projeto executivo apresentado ao banco (CANCELADO) | milestone | 0d | 2019-04-25 A | 2019-04-25 A |  | 100% |  | 2019-04-25 | 2019-04-25 | 0d | 2019-08-16 | 2019-08-16 |  |  | Verde | Verde | 100% | 100 | 100 | 100% | 100 | Compensatória | Verde | 100% | 100 | 100% | 100 | Município |  |
| 1031 | 3.1.3.11.1.4.3 | Analisar projeto executivo (CANCELADO) | milestone | 0d | 2019-04-25 A | 2019-04-25 A |  | 100% |  | 2019-04-25 | 2019-04-25 | 0d | 2019-08-19 | 2019-09-19 |  |  | Verde | Verde | 100% | 100 | 100 | 100% | 100 | Compensatória | Verde | 100% | 100 | 100% | 100 | Banco |  |
| 1032 | 3.1.3.11.1.4.4 | Adequar/revisar projeto executivo (CANCELADO) | milestone | 0d | 2019-04-25 A | 2019-04-25 A |  | 100% |  | 2019-04-25 | 2019-04-25 | 0d | 2019-09-20 | 2019-10-21 |  |  | Verde | Verde | 100% | 100 | 100 | 100% | 100 | Compensatória | Verde | 100% | 100 | 100% | 100 | Município |  |
| 1033 | 3.1.3.11.1.4.5 | Analisar projeto executivo - final (CANCELADO) | milestone | 0d | 2019-04-25 A | 2019-04-25 A |  | 100% |  | 2019-04-25 | 2019-04-25 | 0d | 2019-10-22 | 2019-11-22 |  |  | Verde | Verde | 100% | 100 | 100 | 100% | 100 | Compensatória | Verde | 100% | 100 | 100% | 100 | Banco |  |
| 1034 | 3.1.3.11.1.4.6 | Projeto executivo concluído (CANCELADO) | milestone | 0d | 2019-04-25 A | 2019-04-25 A |  | 100% |  | 2019-04-25 | 2019-04-25 | 0d | 2019-11-22 | 2019-11-22 |  |  | Verde | Verde | 100% | 100 | 100 | 100% | 100 | Compensatória | Verde | 100% | 100 | 100% | 100 | Município |  |
| 1035 | 3.1.3.11.1.4.7 | Recurso do projeto do pleito COPESPJ01 repassado (CANCELADO) | milestone | 0d | 2019-05-03 A | 2019-05-03 A |  | 100% |  | 2019-05-03 | 2019-05-03 | 0d | 2019-11-29 | 2019-11-29 |  |  | Verde | Verde | 100% | 100 | 100 | 100% | 100 | Compensatória | Verde | 100% | 100 | 100% | 100 | Banco |  |
| 1036 | 3.1.3.11.1.5 | Pleito COPESPJ01 - Contratação de empresa especializada para elaboração dos projetos executivos de Conselheiro Pena concluído | milestone | 0d | 2022-04-07 | 2022-04-07 | 1021, 1054 |  |  | 2022-04-07 | 2022-04-07 | 0d | 2019-11-29 | 2019-11-29 | 388d | 14d | Verde | Verde | 0% |  |  | 0% |  | Compensatória | Verde | 0% |  | 0% |  | Município |  |
| 1037 | 3.1.3.11.2 | **Pleito COPESOB01 - Construção do sistema de esgotamento sanitário da sede do município** |  | 765d | 2019-03-12 A | 2022-04-07 |  | 4% | 736.83d | 2019-03-12 | 2022-04-07 | 765d | 2019-11-29 | 2022-08-04 | 388d |  | Verde | Verde | 7% |  |  | 20% | 20 | Compensatória | Vermelho | 5% |  | 1% |  |  |  |
| 1038 | 3.1.3.11.2.1 | **Aprovação do Projeto Básico** |  | 109d | 2019-03-12 A | 2019-08-19 |  | 25% | 81.75d | 2019-03-12 | 2019-08-19 | 109d |  |  | 388d |  | Verde | Verde | 50% | 16 | 50 | 28% | 28 | Compensatória | Vermelho | 32% | 32 | 9% |  |  |  |
| 1039 | 3.1.3.11.2.1.1 | Projeto básico do Pleito COPESOB01 - Construção do sistema de esgotamento sanitário da sede do município apresentado ao banco | milestone | 0d | 2019-03-12 A | 2019-03-12 A | 3052FS+60d | 100% |  | 2019-03-12 | 2019-03-12 | 0d |  |  |  |  | Verde | Verde | 100% | 100 | 100 | 100% | 100 | Compensatória | Verde | 100% | 100 | 100% | 100 |  |  |
| 1040 | 3.1.3.11.2.1.2 | Analisar projeto básico |  | 109d | 2019-03-13 A | 2019-08-19 | 1039 | 25% | 81.75d | 2019-03-13 | 2019-08-19 | 109d |  |  | 388d | 0d | Verde | Verde | 79% | 25 | 79 | 30% | 30 | Compensatória | Vermelho | 79% | 79 | 24% | 24 |  | Conforme agendado |
| 1041 | 3.1.3.11.2.1.3 | Projeto básico do Pleito COPESOB01 - Construção do sistema de esgotamento sanitário da sede do município aprovado | milestone | 0d | 2019-08-19 | 2019-08-19 | 1040 |  |  | 2019-08-19 | 2019-08-19 | 0d |  |  | 388d | 0d | Verde | Verde | 0% |  |  | 0% |  | Compensatória | Verde | 0% |  | 0% |  |  |  |
| 1042 | 3.1.3.11.2.2 | **Aprovação do Projeto Executivo** |  | 73d | 2019-07-30 | 2019-11-11 |  |  |  | 2019-07-30 | 2019-11-11 | 73d |  |  | 388d |  | Verde | Verde | 0% |  |  | 0% |  | Compensatória | Verde | 0% |  | 0% |  |  |  |
| 1043 | 3.1.3.11.2.2.1 | Projeto executivo do Pleito COPESOB01 - Construção do sistema de esgotamento sanitário da sede do município apresentado ao banco | milestone | 0d | 2019-07-30 | 2019-07-30 | 1039FS+96d |  |  | 2019-07-30 | 2019-07-30 | 0d |  |  | 401d | 13d | Verde | Verde | 0% |  |  | 0% |  | Compensatória | Verde | 0% |  | 0% |  |  |  |
| 1044 | 3.1.3.11.2.2.2 | Analisar projeto executivo |  | 60d | 2019-08-20 | 2019-11-11 | 1043, 1041 |  |  | 2019-08-20 | 2019-11-11 | 60d |  |  | 388d | 0d | Verde | Verde | 0% |  |  | 0% |  | Compensatória | Verde | 0% |  | 0% |  |  | Critério FR |
| 1045 | 3.1.3.11.2.2.3 | Projeto executivo do Pleito COPESOB01 - Construção do sistema de esgotamento sanitário da sede do município aprovado | milestone | 0d | 2019-11-11 | 2019-11-11 | 1044 |  |  | 2019-11-11 | 2019-11-11 | 0d |  |  | 388d | 0d | Verde | Verde | 0% |  |  | 0% |  | Compensatória | Verde | 0% |  | 0% |  |  |  |

Notes:
- 1023: 16/04/2019: licitação autorizada pelo BDMG conforme e-mail enviado pelo Gislaine. / 30/05/2019: município informou que está usando recurso próprio para fazer o projeto, portanto o processo anterior com recurso renova foi cancelado.
- 1024: Em 29/04/2019: atualizado como agendado / 21/05/2019: confirmar na reunião com o município se a licitação está em andamento / 30/05/2019: município informou que está usando recurso próprio para fazer o projeto, portanto o processo anterior com recurso renova foi cancelado.
- 1025: 30/05/2019: município informou que está usando recurso próprio para fazer o projeto, portanto o processo anterior com recurso renova foi cancelado.
- 1026: 30/05/2019: município informou que está usando recurso próprio para fazer o projeto, portanto o processo anterior com recurso renova foi cancelado.
- 1027: 30/05/2019: município informou que está usando recurso próprio para fazer o projeto, portanto o processo anterior com recurso renova foi cancelado.
- 1029: 24/05/2019: município pactuou com a Renova 1 mês para apresentar projeto executivo / 30/05/2019: município informou que está usando recurso próprio para fazer o projeto, portanto o processo anterior com recurso renova foi cancelado.
- 1030: 30/05/2019: município informou que está usando recurso próprio para fazer o projeto, portanto o processo anterior com recurso renova foi cancelado.
- 1031: 30/05/2019: município informou que está usando recurso próprio para fazer o projeto, portanto o processo anterior com recurso renova foi cancelado.
- 1032: 30/05/2019: município informou que está usando recurso próprio para fazer o projeto, portanto o processo anterior com recurso renova foi cancelado.
- 1033: 30/05/2019: município informou que está usando recurso próprio para fazer o projeto, portanto o processo anterior com recurso renova foi cancelado.
- 1034: 30/05/2019: município informou que está usando recurso próprio para fazer o projeto, portanto o processo anterior com recurso renova foi cancelado.
- 1035: 30/05/2019: município informou que está usando recurso próprio para fazer o projeto, portanto o processo anterior com recurso renova foi cancelado.
- 1036: 30/05/2019: considerado o término igual ao do pleito de obra, porque se a obra for concluída significa que o projeto foi concluído também.
- 1039: 30/05/2019: projeto protocolado no banco dia 25/07/2018; dia 12/03/2019 o prefeito protocolou o projeto com adequação para atender parte da cidade mediante os recursos disponíveis. O projeto se encontra em análise do Eng. Cláudio Soares.
- 1040: 30/05/2019: O projeto se encontra em análise do Eng. Cláudio Soares. Francisco solicitou mais 20 dias para a conclusão da análise. / 01/07/2019: Pendências encaminhadas por e-mail ao município no dia 13/06/2019 pelo Eng. Claudio (4 dias de atraso)

| ID | WBS | Task | Type | Duration | Start | Finish | Predecessors | Complete | Remaining | Baseline start | Baseline finish | Baseline duration | Baseline 1 start | Baseline 1 finish | Total slack | Free slack | Text1 | Text2 | Text3 | Text6 | Text8 | Text12 | Text14 | Text16 | Text9 | Text18 | Text4 | Text5 | Text7 | Text15 | Text17 |
| --- | --- | --- | --- | --- | --- | --- | --- | --- | --- | --- | --- | --- | --- | --- | --- | --- | --- | --- | --- | --- | --- | --- | --- | --- | --- | --- | --- | --- | --- | --- | --- |
| 1046 | 3.1.3.11.2.3 | **Licitação da obra** |  | 74d | 2019-11-11 | 2020-03-04 |  |  |  | 2019-11-11 | 2020-03-04 | 74d | 2019-11-29 | 2020-03-20 | 388d |  | Verde | Verde | 0% | 0% | Compensatória | Verde | 0% | 0% |  |  |  |  |  |  |  |
| 1047 | 3.1.3.11.2.3.1 | Licitação da obra do Pleito COPESOB01 - Construção do sistema de esgotamento sanitário da sede do município autorizada pelo banco | milestone | 0d | 2019-11-11 | 2019-11-11 | 1045 |  |  | 2019-11-11 | 2019-11-11 | 0d | 2019-11-29 | 2019-11-29 | 388d | 0d | Verde | Verde | 0% | 0% | Compensatória | Verde | 0% | 0% | Banco |  |  |  |  |  |  |
| 1048 | 3.1.3.11.2.3.2 | Licitar obra |  | 60d | 2019-11-12 | 2020-02-10 | 1047 |  |  | 2019-11-12 | 2020-02-10 | 60d | 2019-12-02 | 2020-03-02 | 388d | 0d | Verde | Verde | 0% | 0% | Compensatória | Verde | 0% | 0% | Município |  |  |  |  |  |  |
| 1049 | 3.1.3.11.2.3.3 | Analisar e emitir resultado da licitação da obra |  | 14d | 2020-02-11 | 2020-03-04 | 1048 |  |  | 2020-02-11 | 2020-03-04 | 14d | 2020-03-03 | 2020-03-20 | 388d | 0d | Verde | Verde | 0% | 0% | Compensatória | Verde | 0% | 0% | Banco |  |  |  |  |  |  |
| 1050 | 3.1.3.11.2.3.4 | Licitação da obra do Pleito COPESOB01 - Construção do sistema de esgotamento sanitário da sede do município concluída | milestone | 0d | 2020-03-04 | 2020-03-04 | 1049 |  |  | 2020-03-04 | 2020-03-04 | 0d | 2020-03-20 | 2020-03-20 | 388d | 0d | Verde | Verde | 0% | 0% | Compensatória | Verde | 0% | 0% | Município |  |  |  |  |  |  |
| 1051 | 3.1.3.11.2.4 | Executar obra |  | 377d | 2020-04-02 | 2021-10-05 | 1050FS+20d |  |  | 2020-04-02 | 2021-10-05 | 377d | 2020-04-22 | 2022-01-21 | 388d | 0d | Verde | Verde | 0% | 0% | Compensatória | Verde | 0% | 0% | Município |  |  |  |  |  |  |
| 1052 | 3.1.3.11.2.5 | Realizar processo de pré-operação |  | 120d | 2021-10-06 | 2022-03-31 | 1051 |  |  | 2021-10-06 | 2022-03-31 | 120d | 2022-01-24 | 2022-07-28 | 388d | 0d | Verde | Verde | 0% | 0% | Compensatória | Verde | 0% | 0% | Município |  |  |  |  |  |  |
| 1053 | 3.1.3.11.2.6 | Recurso da obra do Pleito COPESOB01 - Construção do sistema de esgotamento sanitário da sede do município repassado | milestone | 0d | 2022-04-07 | 2022-04-07 | 1052FS+5d |  |  | 2022-04-07 | 2022-04-07 | 0d | 2022-08-04 | 2022-08-04 | 388d | 0d | Verde | Verde | 0% | 0% | Compensatória | Verde | 0% | 0% | Banco |  |  |  |  |  |  |
| 1054 | 3.1.3.11.2.7 | Pleito COPESOB01 - Construção do sistema de esgotamento sanitário da sede do município de Conselheiro Pena concluído | milestone | 0d | 2022-04-07 | 2022-04-07 | 1053 |  |  | 2022-04-07 | 2022-04-07 | 0d | 2022-08-04 | 2022-08-04 | 388d | 0d | Verde | Verde | 0% | 0% | Compensatória | Verde | 0% | 0% | Município |  |  |  |  |  |  |
| 1055 | 3.1.3.11.3 | **Pleito de Conselheiro Pena de Resíduos Sólidos a definir** |  | 661d | 2019-08-30 | 2022-04-29 |  |  |  | 2019-08-30 | 2022-04-29 | 661d | 2019-08-30 | 2023-01-13 | 374d |  | Verde | Verde | 0% | 0% | Compensatória | Verde | 0% | 0% |  |  |  |  |  |  |  |
| 1056 | 3.1.3.11.3.1 | Pleito de Conselheiro Pena de Resíduos Sólidos a definir aprovado | milestone | 0d | 2019-08-30 | 2019-08-30 | 3052FS+178d |  |  | 2019-08-30 | 2019-08-30 | 0d | 2019-08-30 | 2019-08-30 | 374d | 0d | Verde | Verde | 0% | 0% | Compensatória | Verde | 0% | 0% | CT/CIF |  |  |  |  |  |  |
| 1057 | 3.1.3.11.3.2 | Iniciar serviço/projeto/obra do pleito de Conselheiro Pena de Resíduos Sólidos a definir |  | 1d | 2019-09-02 | 2019-09-02 | 1056 |  |  | 2019-09-02 | 2019-09-02 | 1d | 2019-09-02 | 2019-09-02 | 374d | 0d | Verde | Verde | 0% | 0% | Compensatória | Verde | 0% | 0% | Município | Critério FR |  |  |  |  |  |
| 1058 | 3.1.3.11.3.3 | Pleito de Conselheiro Pena de Resíduos Sólidos a definir concluído | milestone | 0d | 2022-04-29 | 2022-04-29 | 1057FS+660d |  |  | 2022-04-29 | 2022-04-29 | 0d | 2023-01-13 | 2023-01-13 | 374d | 0d | Verde | Verde | 0% | 0% | Compensatória | Verde | 0% | 0% | Município |  |  |  |  |  |  |
| 1059 | 3.1.3.11.4 | Recursos de Conselheiro Pena repassados | milestone | 0d | 2022-04-29 | 2022-04-29 | 1036, 1054, 1058 |  |  | 2022-04-29 | 2022-04-29 | 0d | 2023-01-13 | 2023-01-13 | 374d |  | Verde | Verde | 0% | 0% | Compensatória | Verde | 0% | 0% | Banco |  |  |  |  |  |  |
| 1060 | 3.1.3.12 | **Córrego Novo** |  | 994d | 2018-11-02 A | 2022-10-28 |  | 12% | 875.34d | 2018-11-02 | 2022-10-28 | 994d | 2018-11-01 | 2025-02-25 | 248d |  | Verde | Verde | 14% | 82% | Compensatória | Vermelho | 11% | 9% |  |  | 12 | 14 | 82 | 11 |  |
| 1061 | 3.1.3.12.1 | **Pleito CONESOB01 - Implantação de sistema de esgotamento sanitário da sede do município** |  | 594d | 2018-11-02 A | 2021-03-24 |  | 12% | 522.98d | 2018-11-02 | 2021-03-24 | 594d | 2018-11-01 | 2021-02-10 | 648d |  | Verde | Verde | 24% | 75% | Compensatória | Vermelho | 12% | 9% |  |  | 12 | 24 | 75 | 12 |  |
| 1062 | 3.1.3.12.1.1 | **Aprovação do Projeto** |  | 16d | 2019-04-08 A | 2019-05-02 A |  | 100% |  | 2019-04-08 | 2019-05-02 | 16d | 2019-04-08 | 2019-05-08 |  |  | Verde | Verde | 100% | 100% | Compensatória | Verde | 100% | 100% |  |  | 100 | 100 | 100 | 100 | 100 |
| 1063 | 3.1.3.12.1.1.1 | Analisar projeto |  | 16d | 2019-04-08 A | 2019-05-02 A | 3023FS+182d | 100% |  | 2019-04-08 | 2019-05-02 | 16d | 2019-04-08 | 2019-05-08 |  |  | Verde | Verde | 100% | 100% | Compensatória | Verde | 100% | 100% | Banco |  | 100 | 100 | 100 | 100 | 100 |
| 1064 | 3.1.3.12.1.1.2 | Projeto do Pleito CONESOB01 - Implantação de sistema de esgotamento sanitário da sede do município aprovado | milestone | 0d | 2019-05-02 A | 2019-05-02 A | 1063 | 100% |  | 2019-05-02 | 2019-05-02 | 0d | 2019-05-08 | 2019-05-08 |  |  | Verde | Verde | 100% | 100% | Compensatória | Verde | 100% | 100% | Município |  | 100 | 100 | 100 | 100 | 100 |
| 1065 | 3.1.3.12.1.2 | Realizar Licenciamento Ambiental |  | 183d | 2018-11-02 A | 2019-07-29 | 3023FS+105ed | 25% | 137.25d | 2018-11-02 | 2019-07-29 | 183d | 2018-11-01 | 2019-05-08 | 683d | 35d | Verde | Verde | 78% | 32% | Compensatória | Vermelho | 78% | 25% | Município | Conforme agendado | 25 | 78 | 32 | 78 | 25 |
| 1066 | 3.1.3.12.1.3 | **Licitação da obra** |  | 75d | 2019-05-02 A | 2019-08-19 |  | 20% | 59.75d | 2019-05-02 | 2019-08-19 | 75d | 2019-05-08 | 2019-07-29 | 648d |  | Verde | Verde | 28% | 74% | Compensatória | Vermelho | 27% | 20% |  |  | 20 | 28 | 74 | 27 | 20 |
| 1067 | 3.1.3.12.1.3.1 | Licitação da obra do Pleito CONESOB01 - Implantação de sistema de esgotamento sanitário da sede do município autorizada pelo banco | milestone | 0d | 2019-05-02 A | 2019-05-02 A | 1064 | 100% |  | 2019-05-02 | 2019-05-02 | 0d | 2019-05-08 | 2019-05-08 |  |  | Verde | Verde | 100% | 100% | Compensatória | Verde | 100% | 100% | Banco |  | 100 | 100 | 100 | 100 | 100 |
| 1068 | 3.1.3.12.1.3.2 | Licitar obra |  | 61d | 2019-05-03 A | 2019-07-29 | 1067 | 25% | 45.75d | 2019-05-03 | 2019-07-29 | 61d | 2019-05-09 | 2019-07-09 | 648d | 0d | Verde | Verde | 34% | 71% | Compensatória | Vermelho | 34% | 24% | Município | Conforme agendado | 25 | 34 | 71 | 34 | 24 |
| 1069 | 3.1.3.12.1.3.3 | Analisar e emitir resultado da licitação da obra |  | 14d | 2019-07-30 | 2019-08-19 | 1068 |  |  | 2019-07-30 | 2019-08-19 | 14d | 2019-07-10 | 2019-07-29 | 648d | 0d | Verde | Verde | 0% | 0% | Compensatória | Verde | 0% | 0% | Banco | Critério FR |  |  |  |  |  |
| 1070 | 3.1.3.12.1.3.4 | Licitação da obra do Pleito CONESOB01 - Implantação de sistema de esgotamento sanitário da sede do município concluída | milestone | 0d | 2019-08-19 | 2019-08-19 | 1069 |  |  | 2019-08-19 | 2019-08-19 | 0d | 2019-07-29 | 2019-07-29 | 648d | 0d | Verde | Verde | 0% | 0% | Compensatória | Verde | 0% | 0% | Município |  |  |  |  |  |  |
| 1071 | 3.1.3.12.1.4 | Executar obra |  | 250d | 2019-09-18 | 2020-09-18 | 1070FS+21d, 1065 |  |  | 2019-09-18 | 2020-09-18 | 250d | 2019-07-30 | 2020-07-30 | 648d | 0d | Verde | Verde | 0% | 0% | Compensatória | Verde | 0% | 0% | Município |  |  |  |  |  |  |
| 1072 | 3.1.3.12.1.5 | Realizar processo de pré-operação |  | 120d | 2020-09-21 | 2021-03-17 | 1071 |  |  | 2020-09-21 | 2021-03-17 | 120d | 2020-07-31 | 2021-02-03 | 648d | 0d | Verde | Verde | 0% | 0% | Compensatória | Verde | 0% | 0% | Município |  |  |  |  |  |  |
| 1073 | 3.1.3.12.1.6 | Recurso da obra do Pleito CONESOB01 - Implantação de sistema de esgotamento sanitário da sede do município repassado | milestone | 0d | 2021-03-24 | 2021-03-24 | 1072FS+5d |  |  | 2021-03-24 | 2021-03-24 | 0d | 2021-02-10 | 2021-02-10 | 648d | 0d | Verde | Verde | 0% | 0% | Compensatória | Verde | 0% | 0% | Banco |  |  |  |  |  |  |
| 1074 | 3.1.3.12.1.7 | Pleito CONESOB01 - Implantação de sistema de esgotamento sanitário da sede do município de Córrego Novo concluído | milestone | 0d | 2021-03-24 | 2021-03-24 | 1073 |  |  | 2021-03-24 | 2021-03-24 | 0d | 2021-02-10 | 2021-02-10 | 648d | 400d | Verde | Verde | 0% | 0% | Compensatória | Verde | 0% | 0% | Município |  |  |  |  |  |  |

Notes:
- 1051: 22/05/2019: valor da obra igual a 8.508.587,53 - 18 meses
- 1056: Em 24/04/2019: considerado que pleito será elaborado até julho e aprovado no CT/CIF de agosto/2019
- 1059: Valor de recurso destinado ao munícipio: R$9.453.986,14
- 1060: Córrego Novo solicitou 91,9% do total de recurso destinado ao munícipio para Esgotamento Sanitário, mas foi aprovado 90% (R$4.254.293,76) do valor teto para este fim, conforme Deliberação 75. / O município teve o pleito de resíduos sólidos negado (R$472.699,31), equivalente a 10% do total do recurso).
- 1063: 28/05/2019: foi informado na reunião que o projeto foi aprovado dia 02/05/2019.
- 1064: 28/05/2019: foi informado na reunião que o projeto foi aprovado dia 02/05/2019.
- 1065: O licenciamento ambiental somente poderá ser concluido após a certidão do cartório de posse do terreno. / Emissão do registro previsto para nov/18. / 28/05/2019: acordado com o município a conclusão do licenciamento na mesma data de conclusão da licitação da obra / 02/07/2019: foi protocolado a solicitação de vistoria da área da ETE pelo IEEF, mas até o dia 11/06/2019 o IEEF não tinha feito a vistoria. O processo está atrasado.
- 1067: 28/05/2019: foi informado na reunião que o projeto foi aprovado dia 02/05/2019. Assim, a licitação da obra também foi autorizada na mesma data.
- 1068: 24/05/2019: município pactuou com a Renova 2 meses para licitação da obra / 28/05/2019: o município pactuou com a Renova mais 2 meses para finalizar a licitação. / 02/07/2019: o apoio técnico está ajudando na elaboração do TR.

| ID | WBS | Task | Type | Duration | Start | Finish | Predecessors | Complete | Remaining | Baseline start | Baseline finish | Baseline duration | Baseline 1 start | Baseline 1 finish | Total slack | Free slack | Text1 | Text2 | Text3 | Text6 | Text8 | Text12 | Text14 | Text16 | Text9 | Text18 | Text4 | Text5 | Text7 | Text15 | Text17 |
| --- | --- | --- | --- | --- | --- | --- | --- | --- | --- | --- | --- | --- | --- | --- | --- | --- | --- | --- | --- | --- | --- | --- | --- | --- | --- | --- | --- | --- | --- | --- | --- |
| 1075 | 3.1.3.12.2 | **Pleito de Córrego Novo de Resíduos Sólidos a definir** |  | 787d | 2019-08-30 | 2022-10-28 |  |  |  | 2019-08-30 | 2022-10-28 | 787d | 2019-08-30 | 2025-02-25 | 248d |  | Verde | Verde | 0% | 0% | Compensatória | Verde | 0% | 0% |  |  |  |  |  |  |  |
| 1076 | 3.1.3.12.2.1 | Pleito de Córrego Novo de Resíduos Sólidos a definir aprovado | milestone | 0d | 2019-08-30 | 2019-08-30 | 418 |  |  | 2019-08-30 | 2019-08-30 | 0d | 2019-08-30 | 2019-08-30 | 248d | 0d | Verde | Verde | 0% | 0% | Compensatória | Verde | 0% | 0% | CT/CIF |  |  |  |  |  |  |
| 1077 | 3.1.3.12.2.2 | Iniciar serviço/projeto/obra do pleito de Córrego Novo de Resíduos Sólidos a definir |  | 1d | 2019-09-02 | 2019-09-02 | 1076 |  |  | 2019-09-02 | 2019-09-02 | 1d | 2019-09-02 | 2019-09-02 | 248d | 0d | Verde | Verde | 0% | 0% | Compensatória | Verde | 0% | 0% | Município | Critério FR |  |  |  |  |  |
| 1078 | 3.1.3.12.2.3 | Pleito de Córrego Novo de Resíduos Sólidos a definir concluído | milestone | 0d | 2022-10-28 | 2022-10-28 | 1077FS+786d |  |  | 2022-10-28 | 2022-10-28 | 0d | 2025-02-25 | 2025-02-25 | 248d | 0d | Verde | Verde | 0% | 0% | Compensatória | Verde | 0% | 0% | Município |  |  |  |  |  |  |
| 1079 | 3.1.3.12.3 | Recursos de Córrego Novo repassados | milestone | 0d | 2022-10-28 | 2022-10-28 | 1074, 1078 |  |  | 2022-10-28 | 2022-10-28 | 0d | 2025-02-25 | 2025-02-25 | 248d |  | Verde | Verde | 0% | 0% | Compensatória | Verde | 0% | 0% | Banco |  |  |  |  |  |  |
| 1080 | 3.1.3.13 | **Dionísio** |  | 684d | 2018-11-06 A | 2021-08-05 |  | 16% | 572.06d | 2018-11-06 | 2021-08-05 | 684d | 2018-11-06 | 2021-07-16 | 555d |  | Verde | Verde | 20% | 75% | Compensatória | Vermelho | 4% | 3% |  |  | 16 | 20 | 75 |  |  |
| 1081 | 3.1.3.13.1 | **Pleito DIORSPM02 - Elaboração de PRAD para lixão/aterro controlado** |  | 169d | 2019-02-01 A | 2019-10-07 |  | 35% | 109.23d | 2019-02-01 | 2019-10-07 | 169d | 2019-02-01 | 2019-08-08 | 1009d |  | Verde | Verde | 47% | 63% | Compensatória | Vermelho | 57% | 36% |  |  | 35 | 47 | 63 | 57 | 36 |
| 1082 | 3.1.3.13.1.1 | **Elaboração do Plano de Recuperação de Área Degradada** |  | 164d | 2019-02-01 A | 2019-09-30 |  | 35% | 106d | 2019-02-01 | 2019-09-30 | 164d | 2019-02-01 | 2019-08-01 | 1009d |  | Verde | Verde | 48% | 63% | Compensatória | Vermelho | 57% | 36% |  |  | 35 | 48 | 63 | 57 | 36 |
| 1083 | 3.1.3.13.1.1.1 | Elaborar PRAD |  | 100d | 2019-02-01 A | 2019-07-01 | 3052FS+35d | 58% | 42d | 2019-02-01 | 2019-07-01 | 100d | 2019-02-01 | 2019-05-02 | 1009d | 0d | Verde | Verde | 80% | 62% | Compensatória | Vermelho | 80% | 50% | Município | Conforme agendado | 58 | 80 | 62 | 80 | 50 |
| 1084 | 3.1.3.13.1.1.2 | PRAD do Pleito DIORSPM02 - Elaboração de PRAD para lixão/aterro controlado apresentado ao banco | milestone | 0d | 2019-07-01 | 2019-07-01 | 1083 |  |  | 2019-07-01 | 2019-07-01 | 0d | 2019-05-02 | 2019-05-02 | 1009d | 0d | Verde | Verde | 0% | 0% | Compensatória | Verde | 0% | 0% | Município |  |  |  |  |  |  |
| 1085 | 3.1.3.13.1.1.3 | Analisar PRAD |  | 64d | 2019-07-02 | 2019-09-30 | 1084 |  |  | 2019-07-02 | 2019-09-30 | 64d | 2019-05-03 | 2019-06-03 | 1009d | 0d | Verde | Verde | 0% | 0% | Compensatória | Verde | 0% | 0% | Banco | Critério FR |  |  |  |  |  |
| 1086 | 3.1.3.13.1.1.4 | PRAD do Pleito DIORSPM02 - Elaboração de PRAD para lixão/aterro controlado concluído | milestone | 0d | 2019-09-30 | 2019-09-30 | 1085 |  |  | 2019-09-30 | 2019-09-30 | 0d | 2019-08-01 | 2019-08-01 | 1009d | 0d | Verde | Verde | 0% | 0% | Compensatória | Verde | 0% | 0% | Município |  |  |  |  |  |  |
| 1087 | 3.1.3.13.1.2 | Recurso do PRAD do Pleito DIORSPM02 - Elaboração de PRAD para lixão/aterro controlado repassado | milestone | 0d | 2019-10-07 | 2019-10-07 | 1086FS+5d |  |  | 2019-10-07 | 2019-10-07 | 0d | 2019-08-08 | 2019-08-08 | 1009d | 0d | Verde | Verde | 0% | 0% | Compensatória | Verde | 0% | 0% | Banco |  |  |  |  |  |  |
| 1088 | 3.1.3.13.1.3 | Pleito DIORSPM02 - Elaboração de PRAD para lixão/aterro controlado de Dionísio concluído | milestone | 0d | 2019-10-07 | 2019-10-07 | 1087 |  |  | 2019-10-07 | 2019-10-07 | 0d | 2019-08-08 | 2019-08-08 | 1009d | 454d | Verde | Verde | 0% | 0% | Compensatória | Verde | 0% | 0% | Município |  |  |  |  |  |  |
| 1089 | 3.1.3.13.2 | **Pleito DIORSPM01 - Elaboração de estudo de viabilidade p/ implantação de aterro regional compartilhado junto ao COMDIN** |  | 217d | 2019-07-01 | 2020-05-15 |  |  |  | 2019-07-01 | 2020-05-15 | 217d | 2019-05-03 | 2020-03-17 | 861d |  | Verde | Verde | 0% | 0% | Compensatória | Verde | 0% | 0% |  |  |  |  |  |  |  |
| 1090 | 3.1.3.13.2.1 | **Licitação de Empresa para Estudo de Viabilidade** |  | 63d | 2019-07-01 | 2019-09-27 |  |  |  | 2019-07-01 | 2019-09-27 | 63d | 2019-05-03 | 2019-08-01 | 861d |  | Verde | Verde | 0% | 0% | Compensatória | Verde | 0% | 0% |  |  |  |  |  |  |  |
| 1091 | 3.1.3.13.2.1.1 | Licitação da empresa para Estudo de Viabilidade do Pleito DIORSPM01 - Elaboração de estudo de viabilidade p/ implantação de aterro regional compartilhado junto ao COMDIN autorizada pelo banco | milestone | 0d | 2019-07-01 | 2019-07-01 | 3052FS+135d |  |  | 2019-07-01 | 2019-07-01 | 0d | 2019-05-03 | 2019-05-03 | 861d | 0d | Verde | Verde | 0% | 0% | Compensatória | Verde | 0% | 0% | Banco |  |  |  |  |  |  |
| 1092 | 3.1.3.13.2.1.2 | Licitar empresa para Estudo de Viabilidade |  | 44d | 2019-07-02 | 2019-09-02 | 1091 |  |  | 2019-07-02 | 2019-09-02 | 44d | 2019-05-06 | 2019-07-05 | 861d | 0d | Verde | Verde | 0% | 0% | Compensatória | Verde | 0% | 0% | Município | Critério FR |  |  |  |  |  |
| 1093 | 3.1.3.13.2.1.3 | Documentação de licitação do Pleito DIORSPM01 - Elaboração de estudo de viabilidade p/ implantação de aterro regional compartilhado junto ao COMDIN apresentada ao banco | milestone | 0d | 2019-09-09 | 2019-09-09 | 1092FS+5d |  |  | 2019-09-09 | 2019-09-09 | 0d | 2019-07-12 | 2019-07-12 | 861d | 0d | Verde | Verde | 0% | 0% | Compensatória | Verde | 0% | 0% | Município |  |  |  |  |  |  |
| 1094 | 3.1.3.13.2.1.4 | Analisar e emitir resultado da licitação da empresa para Estudo de Viabilidade |  | 14d | 2019-09-10 | 2019-09-27 | 1093 |  |  | 2019-09-10 | 2019-09-27 | 14d | 2019-07-15 | 2019-08-01 | 861d | 0d | Verde | Verde | 0% | 0% | Compensatória | Verde | 0% | 0% | Banco | Critério FR |  |  |  |  |  |
| 1095 | 3.1.3.13.2.1.5 | Licitação da empresa do Pleito DIORSPM01 - Elaboração de estudo de viabilidade p/ implantação de aterro regional compartilhado junto ao COMDIN para Estudo de Viabilidade concluída | milestone | 0d | 2019-09-27 | 2019-09-27 | 1094 |  |  | 2019-09-27 | 2019-09-27 | 0d | 2019-08-01 | 2019-08-01 | 861d | 0d | Verde | Verde | 0% | 0% | Compensatória | Verde | 0% | 0% | Município |  |  |  |  |  |  |
| 1096 | 3.1.3.13.2.2 | **Elaboração do estudo de viabilidade** |  | 149d | 2019-09-30 | 2020-05-08 |  |  |  | 2019-09-30 | 2020-05-08 | 149d | 2019-08-02 | 2020-03-10 | 861d |  | Verde | Verde | 0% | 0% | Compensatória | Verde | 0% | 0% |  |  |  |  |  |  |  |
| 1097 | 3.1.3.13.2.2.1 | Elaborar estudo de viabilidade |  | 88d | 2019-09-30 | 2020-02-05 | 1095 |  |  | 2019-09-30 | 2020-02-05 | 88d | 2019-08-02 | 2019-12-05 | 861d | 0d | Verde | Verde | 0% | 0% | Compensatória | Verde | 0% | 0% | Município |  |  |  |  |  |  |
| 1098 | 3.1.3.13.2.2.2 | Analisar estudo |  | 61d | 2020-02-06 | 2020-05-08 | 1097 |  |  | 2020-02-06 | 2020-05-08 | 61d | 2019-12-06 | 2020-01-08 | 861d | 0d | Verde | Verde | 0% | 0% | Compensatória | Verde | 0% | 0% | Banco |  |  |  |  |  |  |
| 1099 | 3.1.3.13.2.2.3 | Estudo de viabilidade do Pleito DIORSPM01 - Elaboração de estudo de viabilidade p/ implantação de aterro regional compartilhado junto ao COMDIN concluído | milestone | 0d | 2020-05-08 | 2020-05-08 | 1098 |  |  | 2020-05-08 | 2020-05-08 | 0d | 2020-03-10 | 2020-03-10 | 861d | 0d | Verde | Verde | 0% | 0% | Compensatória | Verde | 0% | 0% | Município |  |  |  |  |  |  |
| 1100 | 3.1.3.13.2.3 | Recurso do serviço do Pleito DIORSPM01 - Elaboração de estudo de viabilidade p/ implantação de aterro regional compartilhado junto ao COMDIN repassado | milestone | 0d | 2020-05-15 | 2020-05-15 | 1099FS+5d |  |  | 2020-05-15 | 2020-05-15 | 0d | 2020-03-17 | 2020-03-17 | 861d | 0d | Verde | Verde | 0% | 0% | Compensatória | Verde | 0% | 0% | Banco |  |  |  |  |  |  |
| 1101 | 3.1.3.13.2.4 | Pleito DIORSPM01 - Elaboração de estudo de viabilidade p/ implantação de aterro regional compartilhado junto ao COMDIN de Dionísio concluído | milestone | 0d | 2020-05-15 | 2020-05-15 | 1100 |  |  | 2020-05-15 | 2020-05-15 | 0d | 2020-03-17 | 2020-03-17 | 861d | 306d | Verde | Verde | 0% | 0% | Compensatória | Verde | 0% | 0% | Município |  |  |  |  |  |  |

Notes:
- 1079: Valor de recurso destinado ao munícipio: R$4.726.993,07
- 1080: O pleito de Esgotamento Sanitário de Dionísio, contempla apenas a elaboração e adequação do projeto da sede do município e dos distritos de Baixa Verde e Conceição de Minas (5,3% - R$250.000,00 do valor de SES), conforme Deliberação 75. Somente após o projeto vai ser feito o pleito para as obras. Este pleito foi aprovado. / O município teve 1,7% dos 10% do valor teto destinado a Resíduos Sólidos aprovado (R$79.889,97). / Aderiu à ata de registro de preço.
- 1083: 24/04/2019: início da elaboração do PRAD no dia 01/02/2019 conforme planilha do plano de aceleração / 29/05/2019: município pediu mais um mês para entregar o PRAD ao banco / 01/07/2019: e-mail Lauro - Os prazos para término das atividades que foram informadas pelo município não foram atendidas. Por esta razão, entrei em contato com a prefeitura para saber de nova previsão. Por telefone foi informado que enviariam e-mail com nova previsão até o final da manhã de hoje.
- 1091: Em 24/04/2019: banco não autorizou início de licitação pois reportou que o município pretendia cancelar o pleito. Francisco vai confirmar informação até 25/04/2019. / 21/05/2019: pendente informações do consórcio CONDIM para início do processo

| ID | WBS | Task | Type | Duration | Start | Finish | Predecessors | Complete | Remaining | Baseline start | Baseline finish | Baseline duration | Baseline 1 start | Baseline 1 finish | Total slack | Free slack | Text1 | Text2 | Text3 | Text4 | Text5 | Text6 | Text7 | Text8 | Text12 | Text14 | Text15 | Text16 | Text17 | Text9 | Text18 |
| --- | --- | --- | --- | --- | --- | --- | --- | --- | --- | --- | --- | --- | --- | --- | --- | --- | --- | --- | --- | --- | --- | --- | --- | --- | --- | --- | --- | --- | --- | --- | --- |
| 1102 | 3.1.3.13.3 | **Pleito DIOESPJ01 - Elaboração e adequação de projetos de engenharia de sistema de esgotamento sanitário da sede do município e dos distritos de Baixa Verde e Conceição de Minas** |  | 253d | 2018-11-06 A | 2019-11-07 |  | 36% | 162.69d | 2018-11-06 | 2019-11-07 | 253d | 2018-11-06 | 2019-08-12 | 986d |  | Verde | Verde | 55% | 36 | 55 | 71% | 71 | Compensatória | Vermelho | 52% | 52 | 37% | 37 |  |  |
| 1103 | 3.1.3.13.3.1 | **Elaboração do Projeto** |  | 253d | 2018-11-06 A | 2019-11-07 |  | 36% | 161d | 2018-11-06 | 2019-11-07 | 253d | 2018-11-06 | 2019-08-12 | 986d |  | Verde | Verde | 55% | 36 | 55 | 79% | 79 | Compensatória | Vermelho | 48% | 48 | 38% | 38 |  |  |
| 1104 | 3.1.3.13.3.1.1 | Elaborar Projeto Básico/Executivo |  | 171d | 2018-11-06 A | 2019-07-30 | 3024FS+54ed | 63% | 63d | 2018-11-06 | 2019-07-30 | 171d | 2018-11-06 | 2019-05-02 | 986d | 0d | Verde | Verde | 77% | 63 | 77 | 78% | 78 | Compensatória | Vermelho | 77% | 77 | 60% | 60 | Município | Conforme agendado |
| 1105 | 3.1.3.13.3.1.2 | Projeto básico do Pleito DIOESPJ01 - Elaboração e adequação de projetos de engenharia de sistema de esgotamento sanitário da sede do município e dos distritos de Baixa Verde e Conceição de Minas apresentado ao banco | milestone | 0d | 2019-07-01 | 2019-07-01 | 1104SS+161d |  |  | 2019-07-01 | 2019-07-01 | 0d |  |  | 1008d | 0d | Verde | Verde | 0% |  |  | 0% |  | Compensatória | Verde | 0% |  | 0% |  |  |  |
| 1106 | 3.1.3.13.3.1.3 | Analisar projeto básico |  | 60d | 2019-07-02 | 2019-09-24 | 1105 |  |  | 2019-07-02 | 2019-09-24 | 60d |  |  | 1008d | 0d | Verde | Verde | 0% |  |  | 0% |  | Compensatória | Verde | 0% |  | 0% |  |  | Critério FR |
| 1107 | 3.1.3.13.3.1.4 | Projeto básico do Pleito DIOESPJ01 - Elaboração e adequação de projetos de engenharia de sistema de esgotamento sanitário da sede do município e dos distritos de Baixa Verde e Conceição de Minas concluído | milestone | 0d | 2019-09-24 | 2019-09-24 | 1106 |  |  | 2019-09-24 | 2019-09-24 | 0d |  |  | 1008d | 0d | Verde | Verde | 0% |  |  | 0% |  | Compensatória | Verde | 0% |  | 0% |  |  |  |
| 1108 | 3.1.3.13.3.1.5 | Recurso do estudo do Pleito DIOESPJ01 - Elaboração e adequação de projetos de engenharia de sistema de esgotamento sanitário da sede do município e dos distritos de Baixa Verde e Conceição de Minas repassado | milestone | 0d | 2019-10-01 | 2019-10-01 | 1107FS+5d |  |  | 2019-10-01 | 2019-10-01 | 0d |  |  | 1008d | 22d | Verde | Verde | 0% |  |  | 0% |  | Compensatória | Verde | 0% |  | 0% |  |  |  |
| 1109 | 3.1.3.13.3.1.6 | Recurso do projeto básico do Pleito DIOESPJ01 - Elaboração e adequação de projetos de engenharia de sistema de esgotamento sanitário da sede do município e dos distritos de Baixa Verde e Conceição de Minas repassado | milestone | 0d | 2019-10-01 | 2019-10-01 | 1107FS+5d |  |  | 2019-10-01 | 2019-10-01 | 0d |  |  | 1008d | 22d | Verde | Verde | 0% |  |  | 0% |  | Compensatória | Verde | 0% |  | 0% |  |  |  |
| 1110 | 3.1.3.13.3.1.7 | Projeto executivo do Pleito DIOESPJ01 - Elaboração e adequação de projetos de engenharia de sistema de esgotamento sanitário da sede do município e dos distritos de Baixa Verde e Conceição de Minas apresentado ao banco | milestone | 0d | 2019-07-30 | 2019-07-30 | 1104 |  |  | 2019-07-30 | 2019-07-30 | 0d | 2019-05-02 | 2019-05-02 | 986d | 0d | Verde | Verde | 0% |  |  | 0% |  | Compensatória | Verde | 0% |  | 0% |  | Município |  |
| 1111 | 3.1.3.13.3.1.8 | Analisar projeto executivo |  | 66d | 2019-07-31 | 2019-10-31 | 1110 |  |  | 2019-07-31 | 2019-10-31 | 66d | 2019-05-03 | 2019-06-03 | 986d | 0d | Verde | Verde | 0% |  |  | 0% |  | Compensatória | Verde | 0% |  | 0% |  | Banco | Critério FR |
| 1112 | 3.1.3.13.3.1.9 | Projeto executivo do Pleito DIOESPJ01 - Elaboração e adequação de projetos de engenharia de sistema de esgotamento sanitário da sede do município e dos distritos de Baixa Verde e Conceição de Minas concluído | milestone | 0d | 2019-10-31 | 2019-10-31 | 1114, 1108, 1109, 1111 |  |  | 2019-10-31 | 2019-10-31 | 0d | 2019-08-05 | 2019-08-05 | 986d | 0d | Verde | Verde | 0% |  |  | 0% |  | Compensatória | Verde | 0% |  | 0% |  | Município |  |
| 1113 | 3.1.3.13.3.1.10 | Recurso do projeto executivo do Pleito DIOESPJ01 - Elaboração e adequação de projetos de engenharia de sistema de esgotamento sanitário da sede do município e dos distritos de Baixa Verde e Conceição de Minas repassado | milestone | 0d | 2019-11-07 | 2019-11-07 | 1112FS+5d |  |  | 2019-11-07 | 2019-11-07 | 0d | 2019-08-12 | 2019-08-12 | 986d | 0d | Verde | Verde | 0% |  |  | 0% |  | Compensatória | Verde | 0% |  | 0% |  | Banco |  |
| 1114 | 3.1.3.13.3.2 | Realizar Licenciamento Ambiental |  | 98d | 2019-02-04 A | 2019-07-01 | 1104SS+63d | 34% | 65d | 2019-02-04 | 2019-07-01 | 98d | 2019-02-04 | 2019-07-01 | 1073d | 87d | Verde | Verde | 79% | 34 | 79 | 42% | 42 | Compensatória | Vermelho | 79% | 79 | 33% | 33 | Município | Conforme agendado |
| 1115 | 3.1.3.13.3.3 | Pleito DIOESPJ01 - Elaboração e adequação de projetos de engenharia de sistema de esgotamento sanitário da sede do município e dos distritos de Baixa Verde e Conceição de Minas de Dionísio concluído | milestone | 0d | 2019-11-07 | 2019-11-07 | 1113 |  |  | 2019-11-07 | 2019-11-07 | 0d | 2019-08-12 | 2019-08-12 | 986d | 431d | Verde | Verde | 0% |  |  | 0% |  | Compensatória | Verde | 0% |  | 0% |  | Município |  |
| 1116 | 3.1.3.13.4 | **Pleito de Dionísio a definir - Obra de sistema de esgotamento sanitário da sede do município** |  | 480d | 2019-08-30 | 2021-08-05 |  |  |  | 2019-08-30 | 2021-08-05 | 480d | 2019-08-30 | 2021-07-16 | 555d |  | Verde | Verde | 0% |  |  | 0% |  | Compensatória | Verde | 0% |  | 0% |  |  |  |
| 1117 | 3.1.3.13.4.1 | Pleito de Dionísio a definir - Obra de sistema de esgotamento sanitário da sede do município aprovado | milestone | 0d | 2019-08-30 | 2019-08-30 | 3052FS+178d |  |  | 2019-08-30 | 2019-08-30 | 0d | 2019-08-30 | 2019-08-30 | 555d | 0d | Verde | Verde | 0% |  |  | 0% |  | Compensatória | Verde | 0% |  | 0% |  | CT/CIF |  |
| 1118 | 3.1.3.13.4.2 | **Licitação da obra** |  | 80d | 2019-09-13 | 2020-01-10 |  |  |  | 2019-09-13 | 2020-01-10 | 80d | 2019-09-13 | 2020-01-10 | 555d |  | Verde | Verde | 0% |  |  | 0% |  | Compensatória | Verde | 0% |  | 0% |  |  |  |
| 1119 | 3.1.3.13.4.2.1 | Licitação da obra do Pleito de Dionísio a definir - Obra de sistema de esgotamento sanitário da sede do município autorizada pelo banco | milestone | 0d | 2019-09-13 | 2019-09-13 | 1117FS+10d |  |  | 2019-09-13 | 2019-09-13 | 0d | 2019-09-13 | 2019-09-13 | 555d | 0d | Verde | Verde | 0% |  |  | 0% |  | Compensatória | Verde | 0% |  | 0% |  | Banco |  |
| 1120 | 3.1.3.13.4.2.2 | Licitar obra |  | 66d | 2019-09-16 | 2019-12-18 | 1119 |  |  | 2019-09-16 | 2019-12-18 | 66d | 2019-09-16 | 2019-12-18 | 555d | 0d | Verde | Verde | 0% |  |  | 0% |  | Compensatória | Verde | 0% |  | 0% |  | Município | Critério FR |
| 1121 | 3.1.3.13.4.2.3 | Analisar e emitir resultado da licitação da obra |  | 14d | 2019-12-19 | 2020-01-10 | 1120 |  |  | 2019-12-19 | 2020-01-10 | 14d | 2019-12-19 | 2020-01-10 | 555d | 0d | Verde | Verde | 0% |  |  | 0% |  | Compensatória | Verde | 0% |  | 0% |  | Banco |  |
| 1122 | 3.1.3.13.4.2.4 | Licitação da obra do Pleito de Dionísio a definir - Obra de sistema de esgotamento sanitário da sede do município concluído | milestone | 0d | 2020-01-10 | 2020-01-10 | 1121 |  |  | 2020-01-10 | 2020-01-10 | 0d | 2020-01-10 | 2020-01-10 | 555d | 0d | Verde | Verde | 0% |  |  | 0% |  | Compensatória | Verde | 0% |  | 0% |  | Município |  |
| 1123 | 3.1.3.13.4.3 | Executar obra |  | 250d | 2020-02-10 | 2021-02-10 | 1122FS+20d |  |  | 2020-02-10 | 2021-02-10 | 250d | 2020-01-13 | 2021-01-11 | 555d | 0d | Verde | Verde | 0% |  |  | 0% |  | Compensatória | Verde | 0% |  | 0% |  | Município |  |
| 1124 | 3.1.3.13.4.4 | Realizar processo de pré-operação |  | 120d | 2021-02-11 | 2021-08-05 | 1123 |  |  | 2021-02-11 | 2021-08-05 | 120d | 2021-01-12 | 2021-07-16 | 555d | 0d | Verde | Verde | 0% |  |  | 0% |  | Compensatória | Verde | 0% |  | 0% |  | Município |  |
| 1125 | 3.1.3.13.4.5 | Recurso da obra do Pleito de Dionísio a definir - Obra de sistema de esgotamento sanitário da sede do município repassado | milestone | 0d | 2021-08-05 | 2021-08-05 | 1124 |  |  | 2021-08-05 | 2021-08-05 | 0d | 2021-07-16 | 2021-07-16 | 555d | 0d | Verde | Verde | 0% |  |  | 0% |  | Compensatória | Verde | 0% |  | 0% |  | Banco |  |
| 1126 | 3.1.3.13.4.6 | Pleito de Dionísio a definir - Obra de sistema de esgotamento sanitário da sede do município concluído | milestone | 0d | 2021-08-05 | 2021-08-05 | 1125 |  |  | 2021-08-05 | 2021-08-05 | 0d | 2021-07-16 | 2021-07-16 | 555d | 0d | Verde | Verde | 0% |  |  | 0% |  | Compensatória | Verde | 0% |  | 0% |  | Município |  |
| 1127 | 3.1.3.13.5 | Recursos de Dionísio repassados | milestone | 0d | 2021-08-05 | 2021-08-05 | 1101, 1115, 1126, 1088 |  |  | 2021-08-05 | 2021-08-05 | 0d | 2021-07-16 | 2021-07-16 | 555d |  | Verde | Verde | 0% |  |  | 0% |  | Compensatória | Verde | 0% |  | 0% |  | Banco |  |

Notes:
- 1104: 29/05/2019: empresa não entregou o projeto elétrico e as outras partes estão prontas. / 01/07/2019: e-mail Lauro - Os prazos para término das atividades que foram informadas pelo município não foram atendidas. Por esta razão, entrei em contato com a prefeitura para saber de nova previsão. Por telefone foi informado que enviariam e-mail com nova previsão até o final da manhã de hoje.
- 1114: 25/01/19 - Está aguardando confirmação do projetista para saber se será possível o aproveitamento das estruturas existentes. Caso afirmativo, esta área já está licenciada. Em relação aos distritos, estão aguardando a definição de localização da ETE / 01/07/2019: e-mail Lauro - Os prazos para término das atividades que foram informadas pelo município não foram atendidas. Por esta razão, entrei em contato com a prefeitura para saber de nova previsão. Por telefone foi informado que enviariam e-mail com nova previsão até o final da manhã de hoje.
- 1117: Em 17/04/2019: o pleito será enviado após apresentação do proj. executivo dia 02/05 e será aprovado pela CT/CIF até o dia 31/08 (NT33) / 29/05/2019: pleito foi feito e enviado novamente na semana passada
- 1123: 22/05/2019: valor da obra igual 90% do valor do teto menos o projeto de 250 mil R$ 4.004.293,76 - 12 meses
- 1127: Valor de recurso destinado ao munícipio: R$4.726.993,07

| ID | WBS | Task | Type | Duration | Start | Finish | Predecessors | Complete | Remaining | Baseline start | Baseline finish | Baseline duration | Baseline 1 start | Baseline 1 finish | Total slack | Free slack | Text1 | Text2 | Text3 | Text4 | Text5 | Text6 | Text8 | Text12 | Text14 | Text16 | Text15 | Text9 | Text18 |
| --- | --- | --- | --- | --- | --- | --- | --- | --- | --- | --- | --- | --- | --- | --- | --- | --- | --- | --- | --- | --- | --- | --- | --- | --- | --- | --- | --- | --- | --- |
| 1128 | 3.1.3.14 | **Fernandes Tourinho** |  | 887d | 2018-08-22 A | 2022-03-14 |  | 15% | 755.34d | 2018-08-22 | 2022-03-14 | 887d | 2018-06-15 | 2022-01-17 | 406d |  | Verde | Verde | 21% | 15 | 21 | 0% | Compensatória | Vermelho | 1% | 0% |  |  |  |
| 1129 | 3.1.3.14.1 | **Pleito FETESPJ01 - Elaboração de projeto depara implantação da ETE do distrito de Senhora da Penha** |  | 438d | 2018-11-05 A | 2020-08-06 |  | 14% | 374.91d | 2018-11-05 | 2020-08-06 | 438d | 2018-11-05 | 2020-07-23 | 803d |  | Verde | Verde | 32% | 14 | 32 | 0% | Compensatória | Vermelho | 4% | 0% |  |  |  |
| 1130 | 3.1.3.14.1.1 | **Licitação do Projeto** |  | 202d | 2018-11-05 A | 2019-08-26 |  | 61% | 77.93d | 2018-11-05 | 2019-08-26 | 202d | 2018-11-05 | 2019-06-11 | 483d |  | Verde | Verde | 70% | 61 | 70 | 0% | Compensatória | Vermelho | 39% | 0% | 39 |  |  |
| 1131 | 3.1.3.14.1.1.1 | Licitar Projeto |  | 183d | 2018-11-05 A | 2019-07-29 | 3025FS+77d | 66% | 62d | 2018-11-05 | 2019-07-29 | 183d | 2018-11-05 | 2019-05-15 | 483d | 0d | Verde | Verde | 78% | 66 | 78 | 0% | Compensatória | Vermelho | 78% | 0% | 78 | Município | Conforme agendado |
| 1132 | 3.1.3.14.1.1.2 | Documentação de licitação do Pleito FETESPJ01 - Elaboração de projeto depara implantação da ETE do distrito de Senhora da Penha apresentado ao banco | milestone | 0d | 2019-08-05 | 2019-08-05 | 1131FS+5d |  |  | 2019-08-05 | 2019-08-05 | 0d | 2019-05-22 | 2019-05-22 | 483d | 0d | Verde | Verde | 0% |  |  | 0% | Compensatória | Verde | 0% | 0% |  | Município |  |
| 1133 | 3.1.3.14.1.1.3 | Analisar e emitir resultado da licitação do projeto |  | 14d | 2019-08-06 | 2019-08-26 | 1132 |  |  | 2019-08-06 | 2019-08-26 | 14d | 2019-05-23 | 2019-06-11 | 483d | 0d | Verde | Verde | 0% |  |  | 0% | Compensatória | Verde | 0% | 0% |  | Banco | Critério FR |
| 1134 | 3.1.3.14.1.1.4 | Licitação do projeto do Pleito FETESPJ01 - Elaboração de projeto depara implantação da ETE do distrito de Senhora da Penha concluída | milestone | 0d | 2019-08-26 | 2019-08-26 | 1133 |  |  | 2019-08-26 | 2019-08-26 | 0d | 2019-06-11 | 2019-06-11 | 483d | 0d | Verde | Verde | 0% |  |  | 0% | Compensatória | Verde | 0% | 0% |  | Município |  |
| 1135 | 3.1.3.14.1.2 | **Elaboração do Estudo de Concepção** |  | 131d | 2019-08-27 | 2020-03-06 |  |  |  | 2019-08-27 | 2020-03-06 | 131d |  |  | 483d |  | Verde | Verde | 0% |  |  | 0% | Compensatória | Verde | 0% | 0% |  |  |  |
| 1136 | 3.1.3.14.1.2.1 | Elaborar estudo |  | 66d | 2019-08-27 | 2019-11-27 | 1134 |  |  | 2019-08-27 | 2019-11-27 | 66d |  |  | 483d | 0d | Verde | Verde | 0% |  |  | 0% | Compensatória | Verde | 0% | 0% |  |  | Critério FR |
| 1137 | 3.1.3.14.1.2.2 | Estudo de concepção do Pleito FETESPJ01 - Elaboração de projeto depara implantação da ETE do distrito de Senhora da Penha apresentado ao banco | milestone | 0d | 2019-11-27 | 2019-11-27 | 1136 |  |  | 2019-11-27 | 2019-11-27 | 0d |  |  | 488d | 0d | Verde | Verde | 0% |  |  | 0% | Compensatória | Verde | 0% | 0% |  |  |  |
| 1138 | 3.1.3.14.1.2.3 | Analisar estudo |  | 60d | 2019-11-28 | 2020-02-28 | 1137 |  |  | 2019-11-28 | 2020-02-28 | 60d |  |  | 488d | 0d | Verde | Verde | 0% |  |  | 0% | Compensatória | Verde | 0% | 0% |  |  | Critério FR |
| 1139 | 3.1.3.14.1.2.4 | Estudo de concepção do Pleito FETESPJ01 - Elaboração de projeto depara implantação da ETE do distrito de Senhora da Penha concluído | milestone | 0d | 2020-02-28 | 2020-02-28 | 1138 |  |  | 2020-02-28 | 2020-02-28 | 0d |  |  | 578d | 0d | Verde | Verde | 0% |  |  | 0% | Compensatória | Verde | 0% | 0% |  |  |  |
| 1140 | 3.1.3.14.1.2.5 | Recurso do estudo do Pleito FETESPJ01 - Elaboração de projeto depara implantação da ETE do distrito de Senhora da Penha repassado | milestone | 0d | 2020-03-06 | 2020-03-06 | 1139FS+5d |  |  | 2020-03-06 | 2020-03-06 | 0d |  |  | 578d | 62d | Verde | Verde | 0% |  |  | 0% | Compensatória | Verde | 0% | 0% |  |  |  |
| 1141 | 3.1.3.14.1.3 | **Elaboração do Projeto Básico** |  | 132d | 2019-11-28 | 2020-06-15 |  |  |  | 2019-11-28 | 2020-06-15 | 132d | 2019-06-12 | 2019-12-27 | 483d |  | Verde | Verde | 0% |  |  | 0% | Compensatória | Verde | 0% | 0% |  |  |  |
| 1142 | 3.1.3.14.1.3.1 | Elaborar Projeto Básico |  | 60d | 2019-11-28 | 2020-02-28 | 1136 |  |  | 2019-11-28 | 2020-02-28 | 60d | 2019-06-12 | 2019-09-12 | 483d | 0d | Verde | Verde | 0% |  |  | 0% | Compensatória | Verde | 0% | 0% |  | Município |  |
| 1143 | 3.1.3.14.1.3.2 | Projeto básico do Pleito FETESPJ01 - Elaboração de projeto depara implantação da ETE do distrito de Senhora da Penha apresentado ao banco | milestone | 0d | 2020-02-28 | 2020-02-28 | 1142 |  |  | 2020-02-28 | 2020-02-28 | 0d | 2019-09-12 | 2019-09-12 | 516d | 0d | Verde | Verde | 0% |  |  | 0% | Compensatória | Verde | 0% | 0% |  | Município |  |
| 1144 | 3.1.3.14.1.3.3 | Analisar projeto básico |  | 67d | 2020-03-02 | 2020-06-05 | 1143 |  |  | 2020-03-02 | 2020-06-05 | 67d | 2019-09-13 | 2019-10-14 | 516d | 0d | Verde | Verde | 0% |  |  | 0% | Compensatória | Verde | 0% | 0% |  | Banco |  |
| 1145 | 3.1.3.14.1.3.4 | Projeto básico do Pleito FETESPJ01 - Elaboração de projeto depara implantação da ETE do distrito de Senhora da Penha concluído | milestone | 0d | 2020-06-05 | 2020-06-05 | 1140, 1144 |  |  | 2020-06-05 | 2020-06-05 | 0d | 2019-12-18 | 2019-12-18 | 516d | 0d | Verde | Verde | 0% |  |  | 0% | Compensatória | Verde | 0% | 0% |  | Município |  |
| 1146 | 3.1.3.14.1.3.5 | Recurso do projeto básico do Pleito FETESPJ01 - Elaboração de projeto depara implantação da ETE do distrito de Senhora da Penha repassado | milestone | 0d | 2020-06-15 | 2020-06-15 | 1145FS+5d |  |  | 2020-06-15 | 2020-06-15 | 0d | 2019-12-27 | 2019-12-27 | 516d | 33d | Verde | Verde | 0% |  |  | 0% | Compensatória | Verde | 0% | 0% |  | Banco |  |
| 1147 | 3.1.3.14.1.4 | **Aquisição de Imóvel** |  | 135d | 2019-12-31 | 2020-07-16 |  |  |  | 2019-12-31 | 2020-07-16 | 135d | 2019-10-15 | 2020-05-12 | 493d |  | Verde | Verde | 0% |  |  | 0% | Compensatória | Verde | 0% | 0% |  |  |  |
| 1148 | 3.1.3.14.1.4.1 | Regularizar terreno e apresentar escritura ao banco |  | 85d | 2019-12-31 | 2020-05-06 | 1138FS-40d |  |  | 2019-12-31 | 2020-05-06 | 85d | 2019-10-15 | 2020-02-17 | 493d | 0d | Verde | Verde | 0% |  |  | 0% | Compensatória | Verde | 0% | 0% |  | Município |  |
| 1149 | 3.1.3.14.1.4.2 | Analisar documentação do terreno |  | 10d | 2020-05-07 | 2020-05-20 | 1148 |  |  | 2020-05-07 | 2020-05-20 | 10d | 2020-02-18 | 2020-03-05 | 533d | 40d | Verde | Verde | 0% |  |  | 0% | Compensatória | Verde | 0% | 0% |  | Banco |  |
| 1150 | 3.1.3.14.1.4.3 | Registrar imóvel e apresentar documentação ao banco |  | 40d | 2020-05-07 | 2020-07-02 | 1148 |  |  | 2020-05-07 | 2020-07-02 | 40d | 2020-02-18 | 2020-04-17 | 493d | 0d | Verde | Verde | 0% |  |  | 0% | Compensatória | Verde | 0% | 0% |  | Município |  |
| 1151 | 3.1.3.14.1.4.4 | Analisar documentação do terreno |  | 10d | 2020-07-03 | 2020-07-16 | 1150 |  |  | 2020-07-03 | 2020-07-16 | 10d | 2020-04-20 | 2020-05-05 | 493d | 0d | Verde | Verde | 0% |  |  | 0% | Compensatória | Verde | 0% | 0% |  | Banco |  |
| 1152 | 3.1.3.14.1.4.5 | Aquisição de imóvel do Pleito FETESPJ01 - Elaboração de projeto depara implantação da ETE do distrito de Senhora da Penha concluída | milestone | 0d | 2020-07-16 | 2020-07-16 | 1149, 1151 |  |  | 2020-07-16 | 2020-07-16 | 0d | 2020-05-12 | 2020-05-12 | 493d | 10d | Verde | Verde | 0% |  |  | 0% | Compensatória | Verde | 0% | 0% |  | Município |  |
| 1153 | 3.1.3.14.1.5 | Realizar Licenciamento Ambiental |  | 140d | 2019-12-31 | 2020-07-23 | 1138FS-40d |  |  | 2019-12-31 | 2020-07-23 | 140d | 2019-09-13 | 2020-02-12 | 488d | 5d | Verde | Verde | 0% |  |  | 0% | Compensatória | Verde | 0% | 0% |  | Município |  |

Notes:
- 1128: Fernandes Tourinhos solicitou 78,2% (R$2.081.606,95) dos 90% de recursos destinado para Esgotamento Sanitário e teve todo o pleito aprovado, conforme Deliberação 75. / O município teve 0,8%, dos 10% do valor teto destinado a Resíduos Sólidos aprovado (R$20.903,52). / Munícipio vai solicitar mudança de pleito, solicitando projeto e obra de ampliação e melhoria da ETE da sede.
- 1131: 22/01/19 - O TR para projeto da sede foi concluído e estava aguardando a mudança de pleito para publicação do edital. no entanto o município decidiu prosseguir com a licitação do projeto da sede separadamente do distrito Ns Penha (aguardando mudança de pleito) / 29/05/2019: envelopes serão abertos dia 25/06/2019, se não tiver recurso o processo licitatório finalizará dia 28/06/2019. Por isso consideramos mais 1 mês para o término do processo.
- 1153: 29/05/2019: município informou que pretende fazer um pleito para o licenciamento

| ID | WBS | Task | Type | Duration | Start | Finish | Predecessors | Complete | Remaining | Baseline start | Baseline finish | Baseline duration | Baseline 1 start | Baseline 1 finish | Total slack | Free slack | Text1 | Text2 | Text3 | Text6 | Text8 | Text12 | Text14 | Text16 | Text9 | Text4 | Text5 | Text15 | Text18 |
| --- | --- | --- | --- | --- | --- | --- | --- | --- | --- | --- | --- | --- | --- | --- | --- | --- | --- | --- | --- | --- | --- | --- | --- | --- | --- | --- | --- | --- | --- |
| 1154 | 3.1.3.14.1.6 | **Elaboração do Projeto Executivo** |  | 110d | 2020-03-02 | 2020-08-06 |  |  |  | 2020-03-02 | 2020-08-06 | 110d | 2019-12-19 | 2020-07-23 | 483d |  | Verde | Verde | 0% | 0% | Compensatória | Verde | 0% | 0% |  |  |  |  |  |
| 1155 | 3.1.3.14.1.6.1 | Elaborar Projeto Executivo |  | 40d | 2020-03-02 | 2020-04-28 | 1142 |  |  | 2020-03-02 | 2020-04-28 | 40d | 2019-12-19 | 2020-04-13 | 483d | 0d | Verde | Verde | 0% | 0% | Compensatória | Verde | 0% | 0% | Município |  |  |  |  |
| 1156 | 3.1.3.14.1.6.2 | Projeto executivo do Pleito FETESPJ01 - Elaboração de projeto depara implantação da ETE do distrito de Senhora da Penha apresentado ao banco | milestone | 0d | 2020-04-28 | 2020-04-28 | 1155 |  |  | 2020-04-28 | 2020-04-28 | 0d | 2020-04-13 | 2020-04-13 | 483d | 0d | Verde | Verde | 0% | 0% | Compensatória | Verde | 0% | 0% | Município |  |  |  |  |
| 1157 | 3.1.3.14.1.6.3 | Analisar projeto executivo |  | 65d | 2020-04-29 | 2020-07-30 | 1156 |  |  | 2020-04-29 | 2020-07-30 | 65d | 2020-04-14 | 2020-05-14 | 483d | 0d | Verde | Verde | 0% | 0% | Compensatória | Verde | 0% | 0% | Banco |  |  |  |  |
| 1158 | 3.1.3.14.1.6.4 | Projeto executivo do Pleito FETESPJ01 - Elaboração de projeto depara implantação da ETE do distrito de Senhora da Penha concluído | milestone | 0d | 2020-07-30 | 2020-07-30 | 1152, 1153, 1146, 1157 |  |  | 2020-07-30 | 2020-07-30 | 0d | 2020-07-16 | 2020-07-16 | 483d | 0d | Verde | Verde | 0% | 0% | Compensatória | Verde | 0% | 0% | Município |  |  |  |  |
| 1159 | 3.1.3.14.1.6.5 | Recurso do projeto executivo do Pleito FETESPJ01 - Elaboração de projeto depara implantação da ETE do distrito de Senhora da Penha repassado | milestone | 0d | 2020-08-06 | 2020-08-06 | 1158FS+5d |  |  | 2020-08-06 | 2020-08-06 | 0d | 2020-07-23 | 2020-07-23 | 803d | 0d | Verde | Verde | 0% | 0% | Compensatória | Verde | 0% | 0% | Banco |  |  |  |  |
| 1160 | 3.1.3.14.1.7 | Pleito FETESPJ01 - Elaboração de projeto depara implantação da ETE do distrito de Senhora da Penha de Fernandes Tourinho concluído | milestone | 0d | 2020-08-06 | 2020-08-06 | 1159 |  |  | 2020-08-06 | 2020-08-06 | 0d | 2020-07-23 | 2020-07-23 | 803d | 397d | Verde | Verde | 0% | 0% | Compensatória | Verde | 0% | 0% | Município |  |  |  |  |
| 1161 | 3.1.3.14.2 | **Pleito FETESOB02 - Contratação de empresa para obra de construção de ETE e revitalização na rede coletora de esgotos existente e construção de ramais secundários no distrito de Senhora da Penha** |  | 325d | 2020-07-30 | 2021-11-19 |  |  |  | 2020-07-30 | 2021-11-19 | 325d | 2020-07-16 | 2022-01-17 | 483d |  | Verde | Verde | 0% | 0% | Compensatória | Verde | 0% | 0% |  |  |  |  |  |
| 1162 | 3.1.3.14.2.1 | **Licitação da obra** |  | 58d | 2020-07-30 | 2020-10-22 |  |  |  | 2020-07-30 | 2020-10-22 | 58d | 2020-07-16 | 2020-10-07 | 483d |  | Verde | Verde | 0% | 0% | Compensatória | Verde | 0% | 0% |  |  |  |  |  |
| 1163 | 3.1.3.14.2.1.1 | Licitação da obra do Pleito FETESOB02 - Contratação de empresa para obra de construção de ETE e revitalização na rede coletora de esgotos existente e construção de ramais secundários no distrito de Senhora da Penha autorizada pelo banco | milestone | 0d | 2020-07-30 | 2020-07-30 | 1158 |  |  | 2020-07-30 | 2020-07-30 | 0d | 2020-07-16 | 2020-07-16 | 483d | 0d | Verde | Verde | 0% | 0% | Compensatória | Verde | 0% | 0% | Banco |  |  |  |  |
| 1164 | 3.1.3.14.2.1.2 | Licitar obra |  | 44d | 2020-07-31 | 2020-10-01 | 1163 |  |  | 2020-07-31 | 2020-10-01 | 44d | 2020-07-17 | 2020-09-17 | 483d | 0d | Verde | Verde | 0% | 0% | Compensatória | Verde | 0% | 0% | Município |  |  |  |  |
| 1165 | 3.1.3.14.2.1.3 | Analisar e emitir resultado da licitação da obra |  | 14d | 2020-10-02 | 2020-10-22 | 1164 |  |  | 2020-10-02 | 2020-10-22 | 14d | 2020-09-18 | 2020-10-07 | 483d | 0d | Verde | Verde | 0% | 0% | Compensatória | Verde | 0% | 0% | Banco |  |  |  |  |
| 1166 | 3.1.3.14.2.1.4 | Licitação da obra do Pleito FETESOB02 - Contratação de empresa para obra de construção de ETE e revitalização na rede coletora de esgotos existente e construção de ramais secundários no distrito de Senhora da Penha concluída | milestone | 0d | 2020-10-22 | 2020-10-22 | 1165 |  |  | 2020-10-22 | 2020-10-22 | 0d | 2020-10-07 | 2020-10-07 | 483d | 0d | Verde | Verde | 0% | 0% | Compensatória | Verde | 0% | 0% | Município |  |  |  |  |
| 1167 | 3.1.3.14.2.2 | Executar obra |  | 122d | 2020-11-23 | 2021-05-21 | 1166FS+20d |  |  | 2020-11-23 | 2021-05-21 | 122d | 2020-11-09 | 2021-07-07 | 483d | 0d | Verde | Verde | 0% | 0% | Compensatória | Verde | 0% | 0% | Município |  |  |  |  |
| 1168 | 3.1.3.14.2.3 | Realizar processo de pré-operação |  | 120d | 2021-05-24 | 2021-11-11 | 1167 |  |  | 2021-05-24 | 2021-11-11 | 120d | 2021-07-08 | 2022-01-10 | 483d | 0d | Verde | Verde | 0% | 0% | Compensatória | Verde | 0% | 0% | Município |  |  |  |  |
| 1169 | 3.1.3.14.2.4 | Recurso da obra do Pleito FETESOB02 - Contratação de empresa para obra de construção de ETE e revitalização na rede coletora de esgotos existente e construção de ramais secundários no distrito de Senhora da Penha repassado | milestone | 0d | 2021-11-19 | 2021-11-19 | 1168FS+5d |  |  | 2021-11-19 | 2021-11-19 | 0d | 2022-01-17 | 2022-01-17 | 483d | 0d | Verde | Verde | 0% | 0% | Compensatória | Verde | 0% | 0% | Banco |  |  |  |  |
| 1170 | 3.1.3.14.2.5 | Pleito FETESOB02 - Contratação de empresa para obra de construção de ETE e revitalização na rede coletora de esgotos existente e construção de ramais secundários no distrito de Senhora da Penha de Fernandes Tourinho concluído | milestone | 0d | 2021-11-19 | 2021-11-19 | 1169 |  |  | 2021-11-19 | 2021-11-19 | 0d | 2022-01-17 | 2022-01-17 | 483d | 77d | Verde | Verde | 0% | 0% | Compensatória | Verde | 0% | 0% | Município |  |  |  |  |
| 1171 | 3.1.3.14.3 | **Pleito FETESPJ02 - Adequação de projeto de sistema de esgotamento sanitário da sede do município** |  | 473d | 2018-11-05 A | 2020-09-25 |  | 17% | 391.36d | 2018-11-05 | 2020-09-25 | 473d | 2018-11-05 | 2020-07-23 | 768d |  | Verde | Verde | 30% | 0% | Compensatória | Vermelho | 5% | 0% |  | 17 | 30 |  |  |
| 1172 | 3.1.3.14.3.1 | **Licitação do Projeto** |  | 202d | 2018-11-05 A | 2019-08-26 |  | 61% | 77.93d | 2018-11-05 | 2019-08-26 | 202d | 2018-11-05 | 2019-06-11 | 406d |  | Verde | Verde | 70% | 0% | Compensatória | Vermelho | 39% | 0% |  | 61 | 70 | 39 |  |
| 1173 | 3.1.3.14.3.1.1 | Licitar projeto |  | 183d | 2018-11-05 A | 2019-07-29 | 3025FS+77d | 66% | 62d | 2018-11-05 | 2019-07-29 | 183d | 2018-11-05 | 2019-05-15 | 406d | 0d | Verde | Verde | 78% | 0% | Compensatória | Vermelho | 78% | 0% | Município | 66 | 78 | 78 | Conforme agendado |
| 1174 | 3.1.3.14.3.1.2 | Documentação de licitação do Pleito FETESPJ02 - Adequação de projeto de sistema de esgotamento sanitário da sede do município apresentado ao banco | milestone | 0d | 2019-08-05 | 2019-08-05 | 1173FS+5d |  |  | 2019-08-05 | 2019-08-05 | 0d | 2019-05-22 | 2019-05-22 | 406d | 0d | Verde | Verde | 0% | 0% | Compensatória | Verde | 0% | 0% | Município |  |  |  |  |
| 1175 | 3.1.3.14.3.1.3 | Analisar e emitir resultado da licitação do projeto |  | 14d | 2019-08-06 | 2019-08-26 | 1174 |  |  | 2019-08-06 | 2019-08-26 | 14d | 2019-05-23 | 2019-06-11 | 406d | 0d | Verde | Verde | 0% | 0% | Compensatória | Verde | 0% | 0% | Banco |  |  |  | Critério FR |
| 1176 | 3.1.3.14.3.1.4 | Licitação do projeto do Pleito FETESPJ02 - Adequação de projeto de sistema de esgotamento sanitário da sede do município concluída | milestone | 0d | 2019-08-26 | 2019-08-26 | 1175 |  |  | 2019-08-26 | 2019-08-26 | 0d | 2019-06-11 | 2019-06-11 | 406d | 0d | Verde | Verde | 0% | 0% | Compensatória | Verde | 0% | 0% | Município |  |  |  |  |
| 1177 | 3.1.3.14.3.2 | **Elaboração do Estudo de Concepção** |  | 132d | 2019-08-27 | 2020-03-09 |  |  |  | 2019-08-27 | 2020-03-09 | 132d |  |  | 406d |  | Verde | Verde | 0% | 0% | Compensatória | Verde | 0% | 0% |  |  |  |  |  |
| 1178 | 3.1.3.14.3.2.1 | Elaborar estudo |  | 60d | 2019-08-27 | 2019-11-19 | 1176 |  |  | 2019-08-27 | 2019-11-19 | 60d |  |  | 406d | 0d | Verde | Verde | 0% | 0% | Compensatória | Verde | 0% | 0% |  |  |  |  | Critério FR |
| 1179 | 3.1.3.14.3.2.2 | Estudo de concepção do Pleito FETESPJ02 - Adequação de projeto de sistema de esgotamento sanitário da sede do município apresentado ao banco | milestone | 0d | 2019-11-19 | 2019-11-19 | 1178 |  |  | 2019-11-19 | 2019-11-19 | 0d |  |  | 535d | 0d | Verde | Verde | 0% | 0% | Compensatória | Verde | 0% | 0% |  |  |  |  |  |
| 1180 | 3.1.3.14.3.2.3 | Analisar estudo |  | 67d | 2019-11-20 | 2020-03-02 | 1179 |  |  | 2019-11-20 | 2020-03-02 | 67d |  |  | 535d | 0d | Verde | Verde | 0% | 0% | Compensatória | Verde | 0% | 0% |  |  |  |  | Critério FR |
| 1181 | 3.1.3.14.3.2.4 | Estudo de concepção do Pleito FETESPJ02 - Adequação de projeto de sistema de esgotamento sanitário da sede do município concluído | milestone | 0d | 2020-03-02 | 2020-03-02 | 1180 |  |  | 2020-03-02 | 2020-03-02 | 0d |  |  | 535d | 0d | Verde | Verde | 0% | 0% | Compensatória | Verde | 0% | 0% |  |  |  |  |  |
| 1182 | 3.1.3.14.3.2.5 | Recurso do estudo de concepção do Pleito FETESPJ02 - Adequação de projeto de sistema de esgotamento sanitário da sede do município repassado | milestone | 0d | 2020-03-09 | 2020-03-09 | 1181FS+5d |  |  | 2020-03-09 | 2020-03-09 | 0d |  |  | 535d | 60d | Verde | Verde | 0% | 0% | Compensatória | Verde | 0% | 0% |  |  |  |  |  |

Notes:
- 1164: 24/05/2019: município pactuou com a Renova 2 meses para licitação da obra
- 1173: 29/05/2019: envelopes serão abertos dia 25/06/2019, se não tiver recurso o processo licitatório finalizará dia 28/06/2019. Por isso consideramos mais 1 mês para o término do processo.

| ID | WBS | Task | Type | Duration | Start | Finish | Predecessors | Baseline start | Baseline finish | Baseline duration | Baseline 1 start | Baseline 1 finish | Total slack | Free slack | Text1 | Text2 | Text3 | Text6 | Text8 | Text12 | Text14 | Text16 | Text9 |
| --- | --- | --- | --- | --- | --- | --- | --- | --- | --- | --- | --- | --- | --- | --- | --- | --- | --- | --- | --- | --- | --- | --- | --- |
| 1183 | 3.1.3.14.3.3 | **Elaboração do Projeto Básico** |  | 137d | 2019-11-20 | 2020-06-12 |  | 2019-11-20 | 2020-06-12 | 137d | 2019-06-12 | 2019-12-27 | 406d |  | Verde | Verde | 0% | 0% | Compensatória | Verde | 0% | 0% |  |
| 1184 | 3.1.3.14.3.3.1 | Elaborar Projeto Básico |  | 65d | 2019-11-20 | 2020-02-27 | 1178 | 2019-11-20 | 2020-02-27 | 65d | 2019-06-12 | 2019-09-12 | 406d | 0d | Verde | Verde | 0% | 0% | Compensatória | Verde | 0% | 0% | Município |
| 1185 | 3.1.3.14.3.3.2 | Projeto básico do Pleito FETESPJ02 - Adequação de projeto de sistema de esgotamento sanitário da sede do município apresentado ao banco | milestone | 0d | 2020-02-27 | 2020-02-27 | 1184 | 2020-02-27 | 2020-02-27 | 0d | 2019-09-12 | 2019-09-12 | 443d | 0d | Verde | Verde | 0% | 0% | Compensatória | Verde | 0% | 0% | Município |
| 1186 | 3.1.3.14.3.3.3 | Analisar projeto básico |  | 67d | 2020-02-28 | 2020-06-04 | 1185 | 2020-02-28 | 2020-06-04 | 67d | 2019-09-13 | 2019-10-14 | 475d | 0d | Verde | Verde | 0% | 0% | Compensatória | Verde | 0% | 0% | Banco |
| 1187 | 3.1.3.14.3.3.4 | Projeto básico do Pleito FETESPJ02 - Adequação de projeto de sistema de esgotamento sanitário da sede do município concluído | milestone | 0d | 2020-06-04 | 2020-06-04 | 1182, 1186 | 2020-06-04 | 2020-06-04 | 0d | 2019-12-18 | 2019-12-18 | 475d | 0d | Verde | Verde | 0% | 0% | Compensatória | Verde | 0% | 0% | Município |
| 1188 | 3.1.3.14.3.3.5 | Recurso do projeto básico do Pleito FETESPJ02 - Adequação de projeto de sistema de esgotamento sanitário da sede do município repassado | milestone | 0d | 2020-06-12 | 2020-06-12 | 1187FS+5d | 2020-06-12 | 2020-06-12 | 0d | 2019-12-27 | 2019-12-27 | 475d | 69d | Verde | Verde | 0% | 0% | Compensatória | Verde | 0% | 0% | Banco |
| 1189 | 3.1.3.14.3.4 | Realizar Licenciamento Ambiental |  | 104d | 2020-02-28 | 2020-07-28 | 1185 | 2020-02-28 | 2020-07-28 | 104d | 2019-09-13 | 2020-02-12 | 443d | 37d | Verde | Verde | 0% | 0% | Compensatória | Verde | 0% | 0% | Município |
| 1190 | 3.1.3.14.3.5 | **Elaboração do Projeto Executivo** |  | 146d | 2020-02-28 | 2020-09-25 |  | 2020-02-28 | 2020-09-25 | 146d | 2019-12-19 | 2020-07-23 | 406d |  | Verde | Verde | 0% | 0% | Compensatória | Verde | 0% | 0% |  |
| 1191 | 3.1.3.14.3.5.1 | Elaborar Projeto Executivo |  | 76d | 2020-02-28 | 2020-06-18 | 1184 | 2020-02-28 | 2020-06-18 | 76d | 2019-12-19 | 2020-04-13 | 406d | 0d | Verde | Verde | 0% | 0% | Compensatória | Verde | 0% | 0% | Município |
| 1192 | 3.1.3.14.3.5.2 | Projeto executivo do Pleito FETESPJ02 - Adequação de projeto de sistema de esgotamento sanitário da sede do município apresentado ao banco | milestone | 0d | 2020-06-18 | 2020-06-18 | 1191 | 2020-06-18 | 2020-06-18 | 0d | 2020-04-13 | 2020-04-13 | 406d | 0d | Verde | Verde | 0% | 0% | Compensatória | Verde | 0% | 0% | Município |
| 1193 | 3.1.3.14.3.5.3 | Analisar projeto executivo |  | 65d | 2020-06-19 | 2020-09-18 | 1192 | 2020-06-19 | 2020-09-18 | 65d | 2020-04-14 | 2020-05-14 | 406d | 0d | Verde | Verde | 0% | 0% | Compensatória | Verde | 0% | 0% | Banco |
| 1194 | 3.1.3.14.3.5.4 | Projeto executivo do Pleito FETESPJ02 - Adequação de projeto de sistema de esgotamento sanitário da sede do município concluído | milestone | 0d | 2020-09-18 | 2020-09-18 | 1189, 1188, 1193 | 2020-09-18 | 2020-09-18 | 0d | 2020-07-16 | 2020-07-16 | 406d | 0d | Verde | Verde | 0% | 0% | Compensatória | Verde | 0% | 0% | Município |
| 1195 | 3.1.3.14.3.5.5 | Recurso do projeto executivo do Pleito FETESPJ02 - Adequação de projeto de sistema de esgotamento sanitário da sede do município repassado | milestone | 0d | 2020-09-25 | 2020-09-25 | 1194FS+5d | 2020-09-25 | 2020-09-25 | 0d | 2020-07-23 | 2020-07-23 | 768d | 0d | Verde | Verde | 0% | 0% | Compensatória | Verde | 0% | 0% | Banco |
| 1196 | 3.1.3.14.3.6 | Pleito FETESPJ02 - Adequação de projeto de sistema de esgotamento sanitário da sede do município de Fernandes Tourinho concluído | milestone | 0d | 2020-09-25 | 2020-09-25 | 1195 | 2020-09-25 | 2020-09-25 | 0d | 2020-07-23 | 2020-07-23 | 768d | 362d | Verde | Verde | 0% | 0% | Compensatória | Verde | 0% | 0% | Município |
| 1197 | 3.1.3.14.4 | **Pleito FETESOB01 - Obras de adequação e complementação da rede coletora da sede** |  | 367d | 2020-09-18 | 2022-03-14 |  | 2020-09-18 | 2022-03-14 | 367d | 2020-07-16 | 2022-01-17 | 406d |  | Verde | Verde | 0% | 0% | Compensatória | Verde | 0% | 0% |  |
| 1198 | 3.1.3.14.4.1 | **Licitação da obra** |  | 58d | 2020-09-18 | 2020-12-11 |  | 2020-09-18 | 2020-12-11 | 58d | 2020-07-16 | 2020-10-07 | 406d |  | Verde | Verde | 0% | 0% | Compensatória | Verde | 0% | 0% |  |
| 1199 | 3.1.3.14.4.1.1 | Licitação da obra do Pleito FETESOB01 - Obras de adequação e complementação da rede coletora da sede autorizada pelo banco | milestone | 0d | 2020-09-18 | 2020-09-18 | 1194 | 2020-09-18 | 2020-09-18 | 0d | 2020-07-16 | 2020-07-16 | 406d | 0d | Verde | Verde | 0% | 0% | Compensatória | Verde | 0% | 0% | Banco |
| 1200 | 3.1.3.14.4.1.2 | Licitar obra |  | 44d | 2020-09-21 | 2020-11-23 | 1199 | 2020-09-21 | 2020-11-23 | 44d | 2020-07-17 | 2020-09-17 | 406d | 0d | Verde | Verde | 0% | 0% | Compensatória | Verde | 0% | 0% | Município |
| 1201 | 3.1.3.14.4.1.3 | Analisar e emitir resultado da licitação da obra |  | 14d | 2020-11-24 | 2020-12-11 | 1200 | 2020-11-24 | 2020-12-11 | 14d | 2020-09-18 | 2020-10-07 | 406d | 0d | Verde | Verde | 0% | 0% | Compensatória | Verde | 0% | 0% | Banco |
| 1202 | 3.1.3.14.4.1.4 | Licitação da obra do Pleito FETESOB01 - Obras de adequação e complementação da rede coletora da sede concluída | milestone | 0d | 2020-12-11 | 2020-12-11 | 1201 | 2020-12-11 | 2020-12-11 | 0d | 2020-10-07 | 2020-10-07 | 406d | 0d | Verde | Verde | 0% | 0% | Compensatória | Verde | 0% | 0% | Município |
| 1203 | 3.1.3.14.4.2 | Executar obra |  | 164d | 2021-01-14 | 2021-09-09 | 1202FS+20d | 2021-01-14 | 2021-09-09 | 164d | 2020-11-09 | 2021-07-07 | 406d | 0d | Verde | Verde | 0% | 0% | Compensatória | Verde | 0% | 0% | Município |
| 1204 | 3.1.3.14.4.3 | Realizar processo de pré-operação |  | 120d | 2021-09-10 | 2022-03-07 | 1203 | 2021-09-10 | 2022-03-07 | 120d | 2021-07-08 | 2022-01-10 | 406d | 0d | Verde | Verde | 0% | 0% | Compensatória | Verde | 0% | 0% | Município |
| 1205 | 3.1.3.14.4.4 | Recurso da obra do Pleito FETESOB01 - Obras de adequação e complementação da rede coletora da sede repassado | milestone | 0d | 2022-03-14 | 2022-03-14 | 1204FS+5d | 2022-03-14 | 2022-03-14 | 0d | 2022-01-17 | 2022-01-17 | 406d | 0d | Verde | Verde | 0% | 0% | Compensatória | Verde | 0% | 0% | Banco |
| 1206 | 3.1.3.14.4.5 | Pleito FETESOB01 - Obras de adequação e complementação da rede coletora da sede de Fernandes Tourinho concluído | milestone | 0d | 2022-03-14 | 2022-03-14 | 1205 | 2022-03-14 | 2022-03-14 | 0d | 2022-01-17 | 2022-01-17 | 406d | 0d | Verde | Verde | 0% | 0% | Compensatória | Verde | 0% | 0% | Município |

Notes:
- 1200: 24/05/2019: município pactuou com a Renova 2 meses para licitação da obra

| ID | WBS | Task | Type | Duration | Start | Finish | Predecessors | Complete | Remaining | Baseline start | Baseline finish | Baseline duration | Baseline 1 start | Baseline 1 finish | Total slack | Free slack | Text1 | Text2 | Text3 | Text6 | Text8 | Text12 | Text14 | Text16 | Text4 | Text5 | Text7 | Text9 | Text15 | Text17 | Text18 |
| --- | --- | --- | --- | --- | --- | --- | --- | --- | --- | --- | --- | --- | --- | --- | --- | --- | --- | --- | --- | --- | --- | --- | --- | --- | --- | --- | --- | --- | --- | --- | --- |
| 1207 | 3.1.3.14.5 | **Pleito FETESOB05 - Complementação de recursos para a aplicação e obras na Estação de Tratamento de Esgoto - ETE implantada na sede do município** |  | 372d | 2019-05-28 A | 2020-11-23 |  |  | 372d | 2019-05-28 | 2020-11-25 | 374d | 2019-05-31 | 2020-11-12 | 729d |  | Verde | Verde | 0% | 0% | Compensatória | Verde | 0% | 0% |  |  |  |  |  |  |  |
| 1208 | 3.1.3.14.5.1 | Pleito FETESOB05 - Complementação de recursos para a aplicação e obras na Estação de Tratamento de Esgoto - ETE implantada na sede do município aprovado | milestone | 0d | 2019-05-28 A | 2019-05-28 A | 3052FS+112d | 100% |  | 2019-05-28 | 2019-05-28 | 0d | 2019-05-31 | 2019-05-31 |  |  | Verde | Verde | 100% | 100% | Compensatória | Verde | 100% | 100% | 100 | 100 | 100 | CT/CIF | 100 | 100 |  |
| 1209 | 3.1.3.14.5.2 | **Aprovação da documentação da obra** |  | 102d | 2019-06-12 A | 2019-11-05 |  |  | 102d | 2019-06-14 | 2019-11-07 | 102d |  |  | 729d |  | Verde | Verde | 0% | 0% | Compensatória | Verde | 0% | 0% |  |  |  |  |  |  |  |
| 1210 | 3.1.3.14.5.2.1 | Documentos da obra do Pleito FETESOB05 - Complementação de recursos para a aplicação e obras na Estação de Tratamento de Esgoto - ETE implantada na sede do município solicitados pelo banco | milestone | 0d | 2019-06-12 A | 2019-06-12 A | 1208FS+11d | 100% |  | 2019-06-14 | 2019-06-14 | 0d |  |  |  |  | Verde | Verde | 0% | 0% | Compensatória | Verde | 0% | 0% |  |  |  |  |  |  |  |
| 1211 | 3.1.3.14.5.2.2 | Documentos da obra do Pleito FETESOB05 - Complementação de recursos para a aplicação e obras na Estação de Tratamento de Esgoto - ETE implantada na sede do município apresentados ao banco | milestone | 0d | 2019-08-12 | 2019-08-12 | 1210FS+42d |  |  | 2019-08-14 | 2019-08-14 | 0d |  |  | 729d | 0d | Verde | Verde | 0% | 0% | Compensatória | Verde | 0% | 0% |  |  |  |  |  |  |  |
| 1212 | 3.1.3.14.5.2.3 | Analisar documentos |  | 60d | 2019-08-13 | 2019-11-05 | 1211 |  |  | 2019-08-16 | 2019-11-07 | 60d |  |  | 729d | 0d | Verde | Verde | 0% | 0% | Compensatória | Verde | 0% | 0% |  |  |  |  |  |  | Critério FR |
| 1213 | 3.1.3.14.5.2.4 | Documentos da obra do Pleito FETESOB05 - Complementação de recursos para a aplicação e obras na Estação de Tratamento de Esgoto - ETE implantada na sede do município aprovados | milestone | 0d | 2019-11-05 | 2019-11-05 | 1212 |  |  | 2019-11-07 | 2019-11-07 | 0d |  |  | 729d | 0d | Verde | Verde | 0% | 0% | Compensatória | Verde | 0% | 0% |  |  |  |  |  |  |  |
| 1214 | 3.1.3.14.5.3 | **Licitação da obra** |  | 54d | 2019-11-05 | 2020-01-27 |  |  |  | 2019-11-07 | 2020-01-29 | 54d | 2019-06-14 | 2019-10-07 | 729d |  | Verde | Verde | 0% | 0% | Compensatória | Verde | 0% | 0% |  |  |  |  |  |  |  |
| 1215 | 3.1.3.14.5.3.1 | Licitação da obra do Pleito FETESOB05 - Complementação de recursos para a aplicação e obras na Estação de Tratamento de Esgoto - ETE implantada na sede do município autorizada pelo banco | milestone | 0d | 2019-11-05 | 2019-11-05 | 1213SS |  |  | 2019-11-07 | 2019-11-07 | 0d | 2019-06-14 | 2019-06-14 | 729d | 0d | Verde | Verde | 0% | 0% | Compensatória | Verde | 0% | 0% |  |  |  | Banco |  |  |  |
| 1216 | 3.1.3.14.5.3.2 | Licitar obra |  | 40d | 2019-11-06 | 2020-01-07 | 1215 |  |  | 2019-11-08 | 2020-01-09 | 40d | 2019-06-17 | 2019-09-17 | 729d | 0d | Verde | Verde | 0% | 0% | Compensatória | Verde | 0% | 0% |  |  |  | Município |  |  |  |
| 1217 | 3.1.3.14.5.3.3 | Analisar e emitir resultado da licitação da obra |  | 14d | 2020-01-08 | 2020-01-27 | 1216 |  |  | 2020-01-10 | 2020-01-29 | 14d | 2019-09-18 | 2019-10-07 | 729d | 0d | Verde | Verde | 0% | 0% | Compensatória | Verde | 0% | 0% |  |  |  | Banco |  |  |  |
| 1218 | 3.1.3.14.5.3.4 | Licitação da obra do Pleito FETESOB05 - Complementação de recursos para a aplicação e obras na Estação de Tratamento de Esgoto - ETE implantada na sede do município concluída | milestone | 0d | 2020-01-27 | 2020-01-27 | 1217 |  |  | 2020-01-29 | 2020-01-29 | 0d | 2019-10-07 | 2019-10-07 | 729d | 0d | Verde | Verde | 0% | 0% | Compensatória | Verde | 0% | 0% |  |  |  | Município |  |  |  |
| 1219 | 3.1.3.14.5.4 | Executar obra |  | 60d | 2020-02-28 | 2020-05-26 | 1218FS+20d |  |  | 2020-03-03 | 2020-05-28 | 60d | 2019-11-05 | 2020-05-05 | 729d | 0d | Verde | Verde | 0% | 0% | Compensatória | Verde | 0% | 0% |  |  |  | Município |  |  |  |
| 1220 | 3.1.3.14.5.5 | Realizar processo de pré-operação |  | 120d | 2020-05-27 | 2020-11-16 | 1219 |  |  | 2020-05-29 | 2020-11-18 | 120d | 2020-05-06 | 2020-11-05 | 729d | 0d | Verde | Verde | 0% | 0% | Compensatória | Verde | 0% | 0% |  |  |  | Município |  |  |  |
| 1221 | 3.1.3.14.5.6 | Recurso da obra do Pleito FETESOB05 - Complementação de recursos para a aplicação e obras na Estação de Tratamento de Esgoto - ETE implantada na sede do município repassado | milestone | 0d | 2020-11-23 | 2020-11-23 | 1220FS+5d |  |  | 2020-11-25 | 2020-11-25 | 0d | 2020-11-12 | 2020-11-12 | 729d | 0d | Verde | Verde | 0% | 0% | Compensatória | Verde | 0% | 0% |  |  |  | Banco |  |  |  |
| 1222 | 3.1.3.14.5.7 | Pleito FETESOB05 - Complementação de recursos para a aplicação e obras na Estação de Tratamento de Esgoto - ETE implantada na sede do município de Fernandes Tourinho concluído | milestone | 0d | 2020-11-23 | 2020-11-23 | 1221 |  |  | 2020-11-25 | 2020-11-25 | 0d | 2020-11-12 | 2020-11-12 | 729d | 323d | Verde | Verde | 0% | 0% | Compensatória | Verde | 0% | 0% |  |  |  | Município |  |  |  |
| 1223 | 3.1.3.14.6 | **Pleito FETRSPM01 - Elaboração de estudos de viabilidade para concepção dos serviços de infraestrutura de sistemas integrados de destinação final de resíduos sólidos urbanos, assim como educação ambiental e programas de coleta seletiva** |  | 437d | 2018-08-22 A | 2020-05-22 |  | 45% | 241.39d | 2018-08-22 | 2020-05-22 | 437d | 2018-06-15 | 2020-03-11 | 856d |  | Verde | Verde | 44% | 80% | Compensatória | Vermelho | 5% | 4% | 45 | 44 | 80 |  |  |  |  |
| 1224 | 3.1.3.14.6.1 | **Licitação de Empresa para Estudo de Viabilidade** |  | 283d | 2018-08-22 A | 2019-10-04 |  | 69% | 86.68d | 2018-08-22 | 2019-10-04 | 283d | 2018-06-15 | 2019-07-26 | 856d |  | Verde | Verde | 68% | 67% | Compensatória | Vermelho | 49% | 33% | 69 | 68 | 67 |  | 49 | 33 |  |
| 1225 | 3.1.3.14.6.1.1 | Licitação da empresa para Estudo de Viabilidade do Pleito FETRSPM01 - Elaboração de estudos de viabilidade para concepção dos serviços de infraestrutura de sistemas integrados de destinação final de resíduos sólidos urbanos autorizada pelo banco | milestone | 0d | 2018-08-22 A | 2018-08-22 A | 3025FS+25d | 100% |  | 2018-08-22 | 2018-08-22 | 0d | 2018-06-15 | 2018-06-15 |  |  | Verde | Verde | 100% | 100% | Compensatória | Verde | 100% | 100% | 100 | 100 | 100 | Banco | 100 | 100 |  |
| 1226 | 3.1.3.14.6.1.2 | Licitar empresa para Estudo de Viabilidade |  | 257d | 2018-09-03 A | 2019-09-09 | 1225FS+7d | 73% | 69d | 2018-09-03 | 2019-09-09 | 257d | 2018-09-03 | 2019-07-01 | 856d | 0d | Verde | Verde | 73% | 68% | Compensatória | Vermelho | 73% | 50% | 73 | 73 | 68 | Município | 73 | 50 | Conforme agendado |
| 1227 | 3.1.3.14.6.1.3 | Documentação de licitação do Pleito FETRSPM01 - Elaboração de estudos de viabilidade para concepção dos serviços de infraestrutura de sistemas integrados de destinação final de resíduos sólidos urbanos apresentada ao banco | milestone | 0d | 2019-09-16 | 2019-09-16 | 1226FS+5d |  |  | 2019-09-16 | 2019-09-16 | 0d | 2019-07-08 | 2019-07-08 | 856d | 0d | Verde | Verde | 0% | 0% | Compensatória | Verde | 0% | 0% |  |  |  | Município |  |  |  |
| 1228 | 3.1.3.14.6.1.4 | Analisar e emitir resultado da licitação da empresa para Estudo de Viabilidade |  | 14d | 2019-09-17 | 2019-10-04 | 1227 |  |  | 2019-09-17 | 2019-10-04 | 14d | 2019-07-09 | 2019-07-26 | 856d | 0d | Verde | Verde | 0% | 0% | Compensatória | Verde | 0% | 0% |  |  |  | Banco |  |  | Critério FR |
| 1229 | 3.1.3.14.6.1.5 | Licitação da empresa para Estudo de Viabilidade do Pleito FETRSPM01 - Elaboração de estudos de viabilidade para concepção dos serviços de infraestrutura de sistemas integrados de destinação final de resíduos sólidos urbanos concluída | milestone | 0d | 2019-10-04 | 2019-10-04 | 1228 |  |  | 2019-10-04 | 2019-10-04 | 0d | 2019-07-26 | 2019-07-26 | 856d | 0d | Verde | Verde | 0% | 0% | Compensatória | Verde | 0% | 0% |  |  |  | Município |  |  |  |
| 1230 | 3.1.3.14.6.2 | **Elaboração do estudo de viabilidade** |  | 149d | 2019-10-07 | 2020-05-15 |  |  |  | 2019-10-07 | 2020-05-15 | 149d | 2019-07-29 | 2020-03-04 | 856d |  | Verde | Verde | 0% | 0% | Compensatória | Verde | 0% | 0% |  |  |  |  |  |  |  |
| 1231 | 3.1.3.14.6.2.1 | Elaborar estudo de viabilidade |  | 88d | 2019-10-07 | 2020-02-12 | 1229 |  |  | 2019-10-07 | 2020-02-12 | 88d | 2019-07-29 | 2019-11-29 | 856d | 0d | Verde | Verde | 0% | 0% | Compensatória | Verde | 0% | 0% |  |  |  | Município |  |  |  |
| 1232 | 3.1.3.14.6.2.2 | Analisar estudo |  | 61d | 2020-02-13 | 2020-05-15 | 1231 |  |  | 2020-02-13 | 2020-05-15 | 61d | 2019-12-02 | 2020-01-02 | 856d | 0d | Verde | Verde | 0% | 0% | Compensatória | Verde | 0% | 0% |  |  |  | Banco |  |  |  |
| 1233 | 3.1.3.14.6.2.3 | Estudo de viabilidade do Pleito FETRSPM01 - Elaboração de estudos de viabilidade para concepção dos serviços de infraestrutura de sistemas integrados de destinação final de resíduos sólidos urbanos coconcluído | milestone | 0d | 2020-05-15 | 2020-05-15 | 1232 |  |  | 2020-05-15 | 2020-05-15 | 0d | 2020-03-04 | 2020-03-04 | 856d | 0d | Verde | Verde | 0% | 0% | Compensatória | Verde | 0% | 0% |  |  |  | Município |  |  |  |
| 1234 | 3.1.3.14.6.3 | Recurso do serviço do Pleito FETRSPM01 - Elaboração de estudos de viabilidade para concepção dos serviços de infraestrutura de sistemas integrados de destinação final de resíduos sólidos urbanos repassado | milestone | 0d | 2020-05-22 | 2020-05-22 | 1233FS+5d |  |  | 2020-05-22 | 2020-05-22 | 0d | 2020-03-11 | 2020-03-11 | 856d | 0d | Verde | Verde | 0% | 0% | Compensatória | Verde | 0% | 0% |  |  |  | Banco |  |  |  |
| 1235 | 3.1.3.14.6.4 | Pleito FETRSPM01 - Elaboração de estudos de viabilidade para concepção dos serviços de infraestrutura de sistemas integrados de destinação final de resíduos sólidos urbanos de Fernandes Tourinho concluído | milestone | 0d | 2020-05-22 | 2020-05-22 | 1234 |  |  | 2020-05-22 | 2020-05-22 | 0d | 2020-03-11 | 2020-03-11 | 856d | 450d | Verde | Verde | 0% | 0% | Compensatória | Verde | 0% | 0% |  |  |  | Município |  |  |  |
| 1236 | 3.1.3.14.7 | Recursos de Fernandes Tourinho repassados | milestone | 0d | 2022-03-14 | 2022-03-14 | 1235, 1222, 1206, 1196, 1170, 1160 |  |  | 2022-03-14 | 2022-03-14 | 0d | 2022-01-17 | 2022-01-17 | 406d |  | Verde | Verde | 0% | 0% | Compensatória | Verde | 0% | 0% |  |  |  | Banco |  |  |  |

Notes:
- 1208: 02/06/2019: pleito aprovado na deliberação 290 dia 28/05/2019
- 1210: 01/07/2019: e-mail Gislaine - 12/06/2019 foi encaminhado solicitando o projeto pra verificação e posteriormente encaminhar autorização de licitação de obra
- 1216: 29/05/2019: município pactuou 2 meses para licitação da obra
- 1219: 22/05/2019: valor da obra R$ 98.791,41 - 6 meses
- 1225: 02/06/2019: banco autorizou a licitação do estudo no dia 22/08/2018 conforme planilha Controle Gerencial Renova
- 1226: 21/05/2019: atualizada a data de término conforme cronograma do consórcio
- 1236: Valor de recurso destinado ao munícipio: R$2.661.115,58

| ID | WBS | Task | Type | Duration | Start | Finish | Predecessors | Complete | Remaining | Baseline start | Baseline finish | Baseline duration | Baseline 1 start | Baseline 1 finish | Total slack | Free slack | Text1 | Text2 | Text3 | Text4 | Text5 | Text6 | Text8 | Text12 | Text14 | Text16 | Text15 | Text9 | Text18 |
| --- | --- | --- | --- | --- | --- | --- | --- | --- | --- | --- | --- | --- | --- | --- | --- | --- | --- | --- | --- | --- | --- | --- | --- | --- | --- | --- | --- | --- | --- |
| 1237 | 3.1.3.15 | **Galiléia** |  | 884d | 2018-08-22 A | 2022-03-08 |  | 21% | 697.37d | 2018-08-22 | 2022-03-08 | 884d | 2018-06-15 | 2022-02-22 | 410d |  | Verde | Verde | 22% | 19 | 22 | 0% | Compensatória | Vermelho | 1% | 0% |  |  |  |
| 1238 | 3.1.3.15.1 | **Pleito GALESPJ01 - Elaboração de projetos de sistema de esgotamento sanitário da sede do município** |  | 359d | 2018-12-04 A | 2020-05-15 |  | 24% | 271.99d | 2018-12-04 | 2020-05-15 | 359d | 2018-12-04 | 2020-03-18 | 410d |  | Verde | Verde | 33% | 17 | 33 | 0% | Compensatória | Vermelho | 2% | 0% |  |  |  |
| 1239 | 3.1.3.15.1.1 | **Licitação do Projeto** |  | 171d | 2018-12-04 A | 2019-08-09 |  | 84% | 26.95d | 2018-12-04 | 2019-08-09 | 171d | 2018-12-04 | 2019-05-30 | 410d |  | Verde | Verde | 71% | 60 | 71 | 0% | Compensatória | Vermelho | 40% | 0% | 40 |  |  |
| 1240 | 3.1.3.15.1.1.1 | Licitar Projeto |  | 152d | 2018-12-04 A | 2019-07-15 | 3052FS-7d | 92% | 12.16d | 2018-12-04 | 2019-07-15 | 152d | 2018-12-04 | 2019-05-03 | 410d | 0d | Verde | Verde | 80% | 66 | 80 | 0% | Compensatória | Vermelho | 80% | 0% | 80 | Município | Conforme agendado |
| 1241 | 3.1.3.15.1.1.2 | Documentação de licitação do Pleito GALESPJ01 - Elaboração de projetos de sistema de esgotamento sanitário da sede do município apresentada ao banco | milestone | 0d | 2019-07-22 | 2019-07-22 | 1240FS+5d |  |  | 2019-07-22 | 2019-07-22 | 0d | 2019-05-10 | 2019-05-10 | 410d | 0d | Verde | Verde | 0% |  |  | 0% | Compensatória | Verde | 0% | 0% |  | Município |  |
| 1242 | 3.1.3.15.1.1.3 | Analisar e emitir resultado da licitação do projeto |  | 14d | 2019-07-23 | 2019-08-09 | 1241 |  |  | 2019-07-23 | 2019-08-09 | 14d | 2019-05-13 | 2019-05-30 | 410d | 0d | Verde | Verde | 0% |  |  | 0% | Compensatória | Verde | 0% | 0% |  | Banco | Critério FR |
| 1243 | 3.1.3.15.1.1.4 | Licitação do projeto do Pleito GALESPJ01 - Elaboração de projetos de sistema de esgotamento sanitário da sede do município concluída | milestone | 0d | 2019-08-09 | 2019-08-09 | 1242 |  |  | 2019-08-09 | 2019-08-09 | 0d | 2019-05-30 | 2019-05-30 | 410d | 0d | Verde | Verde | 0% |  |  | 0% | Compensatória | Verde | 0% | 0% |  | Município |  |
| 1244 | 3.1.3.15.1.2 | **Elaboração do Estudo de Concepção** |  | 105d | 2019-08-12 | 2020-01-13 |  |  |  | 2019-08-12 | 2020-01-13 | 105d |  |  | 410d |  | Verde | Verde | 0% |  |  | 0% | Compensatória | Verde | 0% | 0% |  |  |  |
| 1245 | 3.1.3.15.1.2.1 | Elaborar estudo |  | 40d | 2019-08-12 | 2019-10-07 | 1243 |  |  | 2019-08-12 | 2019-10-07 | 40d |  |  | 410d | 0d | Verde | Verde | 0% |  |  | 0% | Compensatória | Verde | 0% | 0% |  |  | Critério FR |
| 1246 | 3.1.3.15.1.2.2 | Estudo de concepção do Pleito GALESPJ01 - Elaboração de projetos de sistema de esgotamento sanitário da sede do município apresentado ao banco | milestone | 0d | 2019-10-07 | 2019-10-07 | 1245 |  |  | 2019-10-07 | 2019-10-07 | 0d |  |  | 416d | 0d | Verde | Verde | 0% |  |  | 0% | Compensatória | Verde | 0% | 0% |  |  |  |
| 1247 | 3.1.3.15.1.2.3 | Analisar estudo |  | 60d | 2019-10-08 | 2020-01-06 | 1246 |  |  | 2019-10-08 | 2020-01-06 | 60d |  |  | 416d | 0d | Verde | Verde | 0% |  |  | 0% | Compensatória | Verde | 0% | 0% |  |  | Critério FR |
| 1248 | 3.1.3.15.1.2.4 | Estudo de concepção do Pleito GALESPJ01 - Elaboração de projetos de sistema de esgotamento sanitário da sede do município concluído | milestone | 0d | 2020-01-06 | 2020-01-06 | 1247 |  |  | 2020-01-06 | 2020-01-06 | 0d |  |  | 483d | 0d | Verde | Verde | 0% |  |  | 0% | Compensatória | Verde | 0% | 0% |  |  |  |
| 1249 | 3.1.3.15.1.2.5 | Recurso do estudo do Pleito GALESPJ01 - Elaboração de projetos de sistema de esgotamento sanitário da sede do município repassado | milestone | 0d | 2020-01-13 | 2020-01-13 | 1248FS+5d |  |  | 2020-01-13 | 2020-01-13 | 0d |  |  | 483d | 43d | Verde | Verde | 0% |  |  | 0% | Compensatória | Verde | 0% | 0% |  |  |  |
| 1250 | 3.1.3.15.1.3 | **Elaboração do Projeto Básico** |  | 113d | 2019-10-08 | 2020-03-24 |  |  |  | 2019-10-08 | 2020-03-24 | 113d | 2019-05-31 | 2019-12-16 | 410d |  | Verde | Verde | 0% |  |  | 0% | Compensatória | Verde | 0% | 0% |  |  |  |
| 1251 | 3.1.3.15.1.3.1 | Elaborar Projeto Básico |  | 40d | 2019-10-08 | 2019-12-03 | 1245 |  |  | 2019-10-08 | 2019-12-03 | 40d | 2019-05-31 | 2019-09-02 | 410d | 0d | Verde | Verde | 0% |  |  | 0% | Compensatória | Verde | 0% | 0% |  | Município | Critério FR |
| 1252 | 3.1.3.15.1.3.2 | Projeto básico do Pleito GALESPJ01 - Elaboração de projetos de sistema de esgotamento sanitário da sede do município apresentado ao banco | milestone | 0d | 2019-12-03 | 2019-12-03 | 1251 |  |  | 2019-12-03 | 2019-12-03 | 0d | 2019-09-02 | 2019-09-02 | 413d | 0d | Verde | Verde | 0% |  |  | 0% | Compensatória | Verde | 0% | 0% |  | Município |  |
| 1253 | 3.1.3.15.1.3.3 | Analisar projeto básico |  | 68d | 2019-12-04 | 2020-03-17 | 1252 |  |  | 2019-12-04 | 2020-03-17 | 68d | 2019-09-03 | 2019-10-02 | 440d | 0d | Verde | Verde | 0% |  |  | 0% | Compensatória | Verde | 0% | 0% |  | Banco |  |
| 1254 | 3.1.3.15.1.3.4 | Projeto básico do Pleito GALESPJ01 - Elaboração de projetos de sistema de esgotamento sanitário da sede do município concluído | milestone | 0d | 2020-03-17 | 2020-03-17 | 1249, 1253 |  |  | 2020-03-17 | 2020-03-17 | 0d | 2019-12-06 | 2019-12-06 | 440d | 0d | Verde | Verde | 0% |  |  | 0% | Compensatória | Verde | 0% | 0% |  | Município |  |
| 1255 | 3.1.3.15.1.3.5 | Recurso do projeto básico do Pleito GALESPJ01 - Elaboração de projetos de sistema de esgotamento sanitário da sede do município repassado | milestone | 0d | 2020-03-24 | 2020-03-24 | 1254FS+5d |  |  | 2020-03-24 | 2020-03-24 | 0d | 2019-12-16 | 2019-12-16 | 440d | 30d | Verde | Verde | 0% |  |  | 0% | Compensatória | Verde | 0% | 0% |  | Banco |  |
| 1256 | 3.1.3.15.1.4 | Realizar Licenciamento Ambiental |  | 100d | 2019-12-04 | 2020-05-05 | 1252 |  |  | 2019-12-04 | 2020-05-05 | 100d | 2019-09-03 | 2020-03-11 | 413d | 0d | Verde | Verde | 0% |  |  | 0% | Compensatória | Verde | 0% | 0% |  | Município |  |
| 1257 | 3.1.3.15.1.5 | **Elaboração do Projeto Executivo** |  | 108d | 2019-12-04 | 2020-05-15 |  |  |  | 2019-12-04 | 2020-05-15 | 108d | 2019-09-03 | 2020-03-18 | 410d |  | Verde | Verde | 0% |  |  | 0% | Compensatória | Verde | 0% | 0% |  |  |  |
| 1258 | 3.1.3.15.1.5.1 | Elaborar Projeto Executivo |  | 40d | 2019-12-04 | 2020-02-03 | 1251 |  |  | 2019-12-04 | 2020-02-03 | 40d | 2019-09-03 | 2019-12-04 | 410d | 0d | Verde | Verde | 0% |  |  | 0% | Compensatória | Verde | 0% | 0% |  | Município |  |
| 1259 | 3.1.3.15.1.5.2 | Projeto executivo do Pleito GALESPJ01 - Elaboração de projetos de sistema de esgotamento sanitário da sede do município apresentado ao banco | milestone | 0d | 2020-02-03 | 2020-02-03 | 1258 |  |  | 2020-02-03 | 2020-02-03 | 0d | 2019-12-04 | 2019-12-04 | 410d | 0d | Verde | Verde | 0% |  |  | 0% | Compensatória | Verde | 0% | 0% |  | Município |  |
| 1260 | 3.1.3.15.1.5.3 | Analisar projeto executivo |  | 63d | 2020-02-04 | 2020-05-08 | 1259 |  |  | 2020-02-04 | 2020-05-08 | 63d | 2019-12-05 | 2020-01-07 | 410d | 0d | Verde | Verde | 0% |  |  | 0% | Compensatória | Verde | 0% | 0% |  | Banco |  |
| 1261 | 3.1.3.15.1.5.4 | Projeto executivo do Pleito GALESPJ01 - Elaboração de projetos de sistema de esgotamento sanitário da sede do município concluído | milestone | 0d | 2020-05-08 | 2020-05-08 | 1256, 1255, 1260 |  |  | 2020-05-08 | 2020-05-08 | 0d | 2020-03-11 | 2020-03-11 | 410d | 0d | Verde | Verde | 0% |  |  | 0% | Compensatória | Verde | 0% | 0% |  | Município |  |
| 1262 | 3.1.3.15.1.5.5 | Recurso do projeto executivo do Pleito GALESPJ01 - Elaboração de projetos de sistema de esgotamento sanitário da sede do município repassado | milestone | 0d | 2020-05-15 | 2020-05-15 | 1261FS+5d |  |  | 2020-05-15 | 2020-05-15 | 0d | 2020-03-18 | 2020-03-18 | 410d | 0d | Verde | Verde | 0% |  |  | 0% | Compensatória | Verde | 0% | 0% |  | Banco |  |
| 1263 | 3.1.3.15.1.6 | Pleito GALESPJ01 - Elaboração de projetos de sistema de esgotamento sanitário da sede do município de Galiléia concluído | milestone | 0d | 2020-05-15 | 2020-05-15 | 1262 |  |  | 2020-05-15 | 2020-05-15 | 0d | 2020-03-18 | 2020-03-18 | 410d | 0d | Verde | Verde | 0% |  |  | 0% | Compensatória | Verde | 0% | 0% |  | Município |  |

Notes:
- 1237: Galileia pediu 89,4% (R$4.226.993,07) dos 90% de recursos destinado para Esgotamento Sanitário e teve todo o pleito aprovado, conforme Deliberação 75. / O município teve 0,8%, dos 10% do valor teto destinado a Resíduos Sólidos aprovado (R$37.131,34).
- 1240: 21/05/2019: 17/05/2019 recebida informação de que o edital foi publicado e que a previsão de abertura é dia 31/05/2019, confirmar com município se a data de término estimada está de acordo. / 30/05/2019: amanhã será a abertura dos envelopes. previsão de conclusão em 45 dias. / 01/07/2019: e-mail Fernanda - Em contato telefônico na data de hoje, Sr. Adelânio R. Souza - ponto focal, foi informado que os envelopes com as propostas serão abertos no dia 03/07/19, caso não tenha nenhum recurso, os documentos serão encaminhados para contratação.
- 1258: 24/05/2019: município pactuou com a Renova 3 meses para elaborar projeto executivo

| ID | WBS | Task | Type | Duration | Start | Finish | Predecessors | Complete | Remaining | Baseline start | Baseline finish | Baseline duration | Baseline 1 start | Baseline 1 finish | Total slack | Free slack | Text1 | Text2 | Text3 | Text6 | Text8 | Text12 | Text14 | Text16 | Text9 | Text18 | Text4 | Text5 | Text7 | Text15 | Text17 |
| --- | --- | --- | --- | --- | --- | --- | --- | --- | --- | --- | --- | --- | --- | --- | --- | --- | --- | --- | --- | --- | --- | --- | --- | --- | --- | --- | --- | --- | --- | --- | --- |
| 1264 | 3.1.3.15.2 | **Pleito GALESCT01 - Aquisição de terrenos para implantação do sistema de esgotamento sanitário da sede do município** |  | 122d | 2019-11-05 | 2020-05-07 |  |  |  | 2019-11-05 | 2020-05-07 | 122d | 2019-10-23 | 2020-04-23 | 416d |  | Verde | Verde | 0% | 0% | Compensatória | Verde | 0% | 0% |  |  |  |  |  |  |  |
| 1265 | 3.1.3.15.2.1 | **Aquisição de Terreno** |  | 122d | 2019-11-05 | 2020-05-07 |  |  |  | 2019-11-05 | 2020-05-07 | 122d | 2019-10-23 | 2020-04-23 | 416d |  | Verde | Verde | 0% | 0% | Compensatória | Verde | 0% | 0% |  |  |  |  |  |  |  |
| 1266 | 3.1.3.15.2.1.1 | Regularizar terreno e apresentar escritura ao banco |  | 76d | 2019-11-05 | 2020-02-28 | 1247FS-40d |  |  | 2019-11-05 | 2020-02-28 | 76d | 2019-10-23 | 2020-02-12 | 416d | 0d | Verde | Verde | 0% | 0% | Compensatória | Verde | 0% | 0% | Município |  |  |  |  |  |  |
| 1267 | 3.1.3.15.2.1.2 | Analisar documentação do terreno |  | 10d | 2020-03-02 | 2020-03-13 | 1266 |  |  | 2020-03-02 | 2020-03-13 | 10d | 2020-02-13 | 2020-03-02 | 447d | 0d | Verde | Verde | 0% | 0% | Compensatória | Verde | 0% | 0% | Banco |  |  |  |  |  |  |
| 1268 | 3.1.3.15.2.1.3 | 50% do valor do imóvel do Pleito GALESCT01 - Aquisição de terrenos para implantação do sistema de esgotamento sanitário da sede do município repassado | milestone | 0d | 2020-03-20 | 2020-03-20 | 1267FS+5d |  |  | 2020-03-20 | 2020-03-20 | 0d | 2020-03-09 | 2020-03-09 | 447d | 31d | Verde | Verde | 0% | 0% | Compensatória | Verde | 0% | 0% | Banco |  |  |  |  |  |  |
| 1269 | 3.1.3.15.2.1.4 | Registrar imóvel e apresentar documentação ao banco |  | 31d | 2020-03-02 | 2020-04-14 | 1266 |  |  | 2020-03-02 | 2020-04-14 | 31d | 2020-02-13 | 2020-03-31 | 416d | 0d | Verde | Verde | 0% | 0% | Compensatória | Verde | 0% | 0% | Município |  |  |  |  |  |  |
| 1270 | 3.1.3.15.2.1.5 | Analisar documentação do terreno |  | 10d | 2020-04-15 | 2020-04-29 | 1269 |  |  | 2020-04-15 | 2020-04-29 | 10d | 2020-04-01 | 2020-04-15 | 416d | 0d | Verde | Verde | 0% | 0% | Compensatória | Verde | 0% | 0% | Banco |  |  |  |  |  |  |
| 1271 | 3.1.3.15.2.1.6 | 50% do valor do imóvel do Pleito GALESCT01 - Aquisição de terrenos para implantação do sistema de esgotamento sanitário da sede do município repassado | milestone | 0d | 2020-05-07 | 2020-05-07 | 1270FS+5d |  |  | 2020-05-07 | 2020-05-07 | 0d | 2020-04-23 | 2020-04-23 | 416d | 0d | Verde | Verde | 0% | 0% | Compensatória | Verde | 0% | 0% | Banco |  |  |  |  |  |  |
| 1272 | 3.1.3.15.2.1.7 | Aquisição de terreno do Pleito GALESCT01 - Aquisição de terrenos para implantação do sistema de esgotamento sanitário da sede do município concluída | milestone | 0d | 2020-05-07 | 2020-05-07 | 1271, 1268 |  |  | 2020-05-07 | 2020-05-07 | 0d | 2020-04-23 | 2020-04-23 | 416d | 0d | Verde | Verde | 0% | 0% | Compensatória | Verde | 0% | 0% | Município |  |  |  |  |  |  |
| 1273 | 3.1.3.15.2.2 | Pleito GALESCT01 - Aquisição de terrenos para implantação do sistema de esgotamento sanitário da sede do município de Galiléia concluído | milestone | 0d | 2020-05-07 | 2020-05-07 | 1272 |  |  | 2020-05-07 | 2020-05-07 | 0d | 2020-04-23 | 2020-04-23 | 416d | 6d | Verde | Verde | 0% | 0% | Compensatória | Verde | 0% | 0% | Município |  |  |  |  |  |  |
| 1274 | 3.1.3.15.3 | **Pleito GALESOB01 - Implantação do sistema de esgotamento sanitário da sede do município** |  | 451d | 2020-05-15 | 2022-03-08 |  |  |  | 2020-05-15 | 2022-03-08 | 451d | 2020-04-23 | 2022-02-22 | 410d |  | Verde | Verde | 0% | 0% | Compensatória | Verde | 0% | 0% |  |  |  |  |  |  |  |
| 1275 | 3.1.3.15.3.1 | **Licitação da Obra** |  | 56d | 2020-05-15 | 2020-08-04 |  |  |  | 2020-05-15 | 2020-08-04 | 56d | 2020-04-23 | 2020-07-14 | 410d |  | Verde | Verde | 0% | 0% | Compensatória | Verde | 0% | 0% |  |  |  |  |  |  |  |
| 1276 | 3.1.3.15.3.1.1 | Licitação da obra do Pleito GALESOB01 - Implantação do sistema de esgotamento sanitário da sede do município autorizada pelo banco | milestone | 0d | 2020-05-15 | 2020-05-15 | 1263, 1273 |  |  | 2020-05-15 | 2020-05-15 | 0d | 2020-04-23 | 2020-04-23 | 410d | 0d | Verde | Verde | 0% | 0% | Compensatória | Verde | 0% | 0% | Banco |  |  |  |  |  |  |
| 1277 | 3.1.3.15.3.1.2 | Licitar Obra |  | 42d | 2020-05-18 | 2020-07-15 | 1276 |  |  | 2020-05-18 | 2020-07-15 | 42d | 2020-04-24 | 2020-06-24 | 410d | 0d | Verde | Verde | 0% | 0% | Compensatória | Verde | 0% | 0% | Município |  |  |  |  |  |  |
| 1278 | 3.1.3.15.3.1.3 | Analisar e emitir resultado da licitação da obra |  | 14d | 2020-07-16 | 2020-08-04 | 1277 |  |  | 2020-07-16 | 2020-08-04 | 14d | 2020-06-25 | 2020-07-14 | 410d | 0d | Verde | Verde | 0% | 0% | Compensatória | Verde | 0% | 0% | Banco |  |  |  |  |  |  |
| 1279 | 3.1.3.15.3.1.4 | Licitação da obra do Pleito GALESOB01 - Implantação do sistema de esgotamento sanitário da sede do município concluída | milestone | 0d | 2020-08-04 | 2020-08-04 | 1278 |  |  | 2020-08-04 | 2020-08-04 | 0d | 2020-07-14 | 2020-07-14 | 410d | 0d | Verde | Verde | 0% | 0% | Compensatória | Verde | 0% | 0% | Município |  |  |  |  |  |  |
| 1280 | 3.1.3.15.3.2 | Executar obra |  | 250d | 2020-09-02 | 2021-09-02 | 1279FS+20d |  |  | 2020-09-02 | 2021-09-02 | 250d | 2020-08-12 | 2021-08-12 | 410d | 0d | Verde | Verde | 0% | 0% | Compensatória | Verde | 0% | 0% | Município |  |  |  |  |  |  |
| 1281 | 3.1.3.15.3.3 | Realizar processo de pré-operação |  | 120d | 2021-09-03 | 2022-02-24 | 1280 |  |  | 2021-09-03 | 2022-02-24 | 120d | 2021-08-13 | 2022-02-15 | 410d | 0d | Verde | Verde | 0% | 0% | Compensatória | Verde | 0% | 0% | Município |  |  |  |  |  |  |
| 1282 | 3.1.3.15.3.4 | Recurso da obra do Pleito GALESOB01 - Implantação do sistema de esgotamento sanitário da sede do município repassado | milestone | 0d | 2022-03-08 | 2022-03-08 | 1281FS+5d |  |  | 2022-03-08 | 2022-03-08 | 0d | 2022-02-22 | 2022-02-22 | 410d | 0d | Verde | Verde | 0% | 0% | Compensatória | Verde | 0% | 0% | Banco |  |  |  |  |  |  |
| 1283 | 3.1.3.15.3.5 | Pleito GALESOB01 - Implantação do sistema de esgotamento sanitário da sede do município de Galiléia concluído | milestone | 0d | 2022-03-08 | 2022-03-08 | 1282 |  |  | 2022-03-08 | 2022-03-08 | 0d | 2022-02-22 | 2022-02-22 | 410d | 0d | Verde | Verde | 0% | 0% | Compensatória | Verde | 0% | 0% | Município |  |  |  |  |  |  |
| 1284 | 3.1.3.15.4 | **Pleito GALESPJ02 - Contratação de empresa para adequação de projeto relacionado à regularização ambiental da obra do SES da sede municipal** |  | 143d | 2019-10-03 | 2020-05-05 |  |  |  | 2019-10-03 | 2020-05-05 | 143d | 2019-07-03 | 2020-03-11 | 869d |  | Verde | Verde | 0% | 0% | Compensatória | Verde | 0% | 0% |  |  |  |  |  |  |  |
| 1285 | 3.1.3.15.4.1 | Analisar necessidade do pleito GALESPJ02 |  | 1d | 2019-10-03 | 2019-10-03 | 1256SS-43d |  |  | 2019-10-03 | 2019-10-03 | 1d | 2019-07-03 | 2019-07-03 | 1011d | 142d | Verde | Verde | 0% | 0% | Compensatória | Verde | 0% | 0% | Banco | Critério FR |  |  |  |  |  |
| 1286 | 3.1.3.15.4.2 | Pleito GALESPJ02 - Contratação de empresa para adequação de projeto relacionado à regularização ambiental da obra do SES da sede municipal de Galiléia concluído | milestone | 0d | 2020-05-05 | 2020-05-05 | 1256, 1285 |  |  | 2020-05-05 | 2020-05-05 | 0d | 2020-03-11 | 2020-03-11 | 869d | 459d | Verde | Verde | 0% | 0% | Compensatória | Verde | 0% | 0% | Município |  |  |  |  |  |  |
| 1287 | 3.1.3.15.5 | **Pleito GALRSPM01 - Elaboração de estudos de viabiliadade para concepção dos serviços de infraestrutura de sistemas integrados de destinação final de resíduos sólidos urbanos, bem como educação ambiental e programas de coleta seletiva** |  | 438d | 2018-08-22 A | 2020-05-22 |  | 45% | 242.35d | 2018-08-22 | 2020-05-22 | 438d | 2018-06-15 | 2020-03-11 | 856d |  | Verde | Verde | 44% | 100% | Compensatória | Verde | 4% | 4% |  |  | 45 | 44 | 100 |  |  |
| 1288 | 3.1.3.15.5.1 | **Licitação de Empresa para Estudo de Viabilidade** |  | 284d | 2018-08-22 A | 2019-10-04 |  | 69% | 87.39d | 2018-08-22 | 2019-10-04 | 284d | 2018-06-15 | 2019-07-26 | 856d |  | Verde | Verde | 69% | 91% | Compensatória | Vermelho | 55% | 50% |  |  | 69 | 69 | 91 | 55 | 50 |
| 1289 | 3.1.3.15.5.1.1 | Licitação da empresa para Estudo de Viabilidade do Pleito GALRSPM01 - Elaboração de estudos de viabiliadade para concepção dos serviços de infraestrutura de sistemas integrados de destinação final de resíduos sólidos urbanos autorizada pelo banco | milestone | 0d | 2018-08-22 A | 2018-08-22 A | 3052FS-81d | 100% |  | 2018-08-22 | 2018-08-22 | 0d | 2018-06-15 | 2018-06-15 |  |  | Verde | Verde | 100% | 100% | Compensatória | Verde | 100% | 100% | Banco |  | 100 | 100 | 100 | 100 | 100 |
| 1290 | 3.1.3.15.5.1.2 | Licitar empresa para Estudo de Viabilidade |  | 257d | 2018-09-03 A | 2019-09-09 | 1289FS+8d | 73% | 69.39d | 2018-09-03 | 2019-09-09 | 257d | 2018-09-03 | 2019-07-01 | 856d | 0d | Verde | Verde | 73% | 92% | Compensatória | Vermelho | 73% | 67% | Município | Conforme agendado | 73 | 73 | 92 | 73 | 67 |
| 1291 | 3.1.3.15.5.1.3 | Documentação de licitação do Pleito GALRSPM01 - Elaboração de estudos de viabiliadade para concepção dos serviços de infraestrutura de sistemas integrados de destinação final de resíduos sólidos urbanos apresentada ao banco | milestone | 0d | 2019-09-16 | 2019-09-16 | 1290FS+5d |  |  | 2019-09-16 | 2019-09-16 | 0d | 2019-07-08 | 2019-07-08 | 856d | 0d | Verde | Verde | 0% | 0% | Compensatória | Verde | 0% | 0% | Município |  |  |  |  |  |  |
| 1292 | 3.1.3.15.5.1.4 | Analisar e emitir resultado da licitação da empresa para Estudo de Viabilidade |  | 14d | 2019-09-17 | 2019-10-04 | 1291 |  |  | 2019-09-17 | 2019-10-04 | 14d | 2019-07-09 | 2019-07-26 | 856d | 0d | Verde | Verde | 0% | 0% | Compensatória | Verde | 0% | 0% | Banco | Critério FR |  |  |  |  |  |
| 1293 | 3.1.3.15.5.1.5 | Licitação da empresa para Estudo de Viabilidade Pleito GALRSPM01 - Elaboração de estudos de viabiliadade para concepção dos serviços de infraestrutura de sistemas integrados de destinação final de resíduos sólidos urbanos concluída | milestone | 0d | 2019-10-04 | 2019-10-04 | 1292 |  |  | 2019-10-04 | 2019-10-04 | 0d | 2019-07-26 | 2019-07-26 | 856d | 0d | Verde | Verde | 0% | 0% | Compensatória | Verde | 0% | 0% | Município |  |  |  |  |  |  |

Notes:
- 1277: 24/05/2019: município pactuou com a Renova 2 meses para licitação da obra
- 1289: 02/06/2019: banco autorizou a licitação do estudo no dia 22/08/2018 conforme planilha Controle Gerencial Renova
- 1290: 21/05/2019: atualizada a data de término conforme cronograma do consórcio

| ID | WBS | Task | Type | Duration | Start | Finish | Predecessors | Complete | Remaining | Baseline start | Baseline finish | Baseline duration | Baseline 1 start | Baseline 1 finish | Total slack | Free slack | Text1 | Text2 | Text3 | Text6 | Text8 | Text12 | Text14 | Text16 | Text9 | Text5 | Text18 |
| --- | --- | --- | --- | --- | --- | --- | --- | --- | --- | --- | --- | --- | --- | --- | --- | --- | --- | --- | --- | --- | --- | --- | --- | --- | --- | --- | --- |
| 1294 | 3.1.3.15.5.2 | **Elaboração do estudo de viabilidade** |  | 149d | 2019-10-07 | 2020-05-15 |  |  |  | 2019-10-07 | 2020-05-15 | 149d | 2019-07-29 | 2020-03-04 | 856d |  | Verde | Verde | 0% | 0% | Compensatória | Verde | 0% | 0% |  |  |  |
| 1295 | 3.1.3.15.5.2.1 | Elaborar estudo de viabilidade |  | 88d | 2019-10-07 | 2020-02-12 | 1293 |  |  | 2019-10-07 | 2020-02-12 | 88d | 2019-07-29 | 2019-11-29 | 856d | 0d | Verde | Verde | 0% | 0% | Compensatória | Verde | 0% | 0% | Município |  |  |
| 1296 | 3.1.3.15.5.2.2 | Analisar estudo |  | 61d | 2020-02-13 | 2020-05-15 | 1295 |  |  | 2020-02-13 | 2020-05-15 | 61d | 2019-12-02 | 2020-01-02 | 856d | 0d | Verde | Verde | 0% | 0% | Compensatória | Verde | 0% | 0% | Banco |  |  |
| 1297 | 3.1.3.15.5.2.3 | Estudo de viabilidade do Pleito GALRSPM01 - Elaboração de estudos de viabiliadade para concepção dos serviços de infraestrutura de sistemas integrados de destinação final de resíduos sólidos urbanos concluído | milestone | 0d | 2020-05-15 | 2020-05-15 | 1296 |  |  | 2020-05-15 | 2020-05-15 | 0d | 2020-03-04 | 2020-03-04 | 856d | 0d | Verde | Verde | 0% | 0% | Compensatória | Verde | 0% | 0% | Município |  |  |
| 1298 | 3.1.3.15.5.3 | Recurso do serviço do Pleito GALRSPM01 - Elaboração de estudos de viabiliadade para concepção dos serviços de infraestrutura de sistemas integrados de destinação final de resíduos sólidos urbanos repassado | milestone | 0d | 2020-05-22 | 2020-05-22 | 1297FS+5d |  |  | 2020-05-22 | 2020-05-22 | 0d | 2020-03-11 | 2020-03-11 | 856d | 0d | Verde | Verde | 0% | 0% | Compensatória | Verde | 0% | 0% | Banco |  |  |
| 1299 | 3.1.3.15.5.4 | Pleito GALRSPM01 - Elaboração de estudos de viabiliadade para concepção dos serviços de infraestrutura de sistemas integrados de destinação final de resíduos sólidos urbanos de Galiléia concluído | milestone | 0d | 2020-05-22 | 2020-05-22 | 1298 |  |  | 2020-05-22 | 2020-05-22 | 0d | 2020-03-11 | 2020-03-11 | 856d | 446d | Verde | Verde | 0% | 0% | Compensatória | Verde | 0% | 0% | Município |  |  |
| 1300 | 3.1.3.15.6 | Recursos de Galileia repassados | milestone | 0d | 2022-03-08 | 2022-03-08 | 1263, 1273, 1283, 1286, 1299 |  |  | 2022-03-08 | 2022-03-08 | 0d | 2022-02-22 | 2022-02-22 | 410d |  | Verde | Verde | 0% | 0% | Compensatória | Verde | 0% | 0% | Banco |  |  |
| 1301 | 3.1.3.16 | **Governador Valadares** |  | 1256d | 2018-08-22 A | 2023-09-04 |  | 6% | 1180.31d | 2018-08-22 | 2023-09-04 | 1256d | 2018-06-15 | 2024-01-19 | 38d |  | Verde | Verde | 15% | 0% | Compensatória | Vermelho | 0% | 0% |  | 15 |  |
| 1302 | 3.1.3.16.1 | **Pleito de Governador Valadares a definir - Obra ETE Santos Dumont** |  | 928d | 2019-07-31 | 2023-04-26 |  |  |  | 2019-07-31 | 2023-04-26 | 928d | 2019-05-31 | 2023-03-07 | 128d |  | Verde | Verde | 0% | 0% | Compensatória | Verde | 0% | 0% |  |  |  |
| 1303 | 3.1.3.16.1.1 | Pleito de Governador Valadares a definir - Obra ETE Santos Dumont aprovado | milestone | 0d | 2019-07-31 | 2019-07-31 | 3052FS+157d |  |  | 2019-07-31 | 2019-07-31 | 0d | 2019-05-31 | 2019-05-31 | 128d | 0d | Verde | Verde | 0% | 0% | Compensatória | Verde | 0% | 0% | CT/CIF |  |  |
| 1304 | 3.1.3.16.1.2 | **Apresentação do Projeto Executivo** |  | 68d | 2019-07-31 | 2019-11-05 |  |  |  | 2019-07-31 | 2019-11-05 | 68d | 2019-05-31 | 2019-09-06 | 128d |  | Verde | Verde | 0% | 0% | Compensatória | Verde | 0% | 0% |  |  |  |
| 1305 | 3.1.3.16.1.2.1 | Projeto executivo do Pleito de Governador Valadares a definir - Obra ETE Santos Dumont apresentado ao banco | milestone | 0d | 2019-07-31 | 2019-07-31 | 1303 |  |  | 2019-07-31 | 2019-07-31 | 0d | 2019-05-31 | 2019-05-31 | 128d | 0d | Verde | Verde | 0% | 0% | Compensatória | Verde | 0% | 0% | Município |  |  |
| 1306 | 3.1.3.16.1.2.2 | Analisar projeto executivo |  | 68d | 2019-08-01 | 2019-11-05 | 1305 |  |  | 2019-08-01 | 2019-11-05 | 68d | 2019-06-03 | 2019-07-02 | 128d | 0d | Verde | Verde | 0% | 0% | Compensatória | Verde | 0% | 0% | Banco |  | Critério FR |
| 1307 | 3.1.3.16.1.2.3 | Projeto executivo do Pleito de Governador Valadares a definir - Obra ETE Santos Dumont concluído | milestone | 0d | 2019-11-05 | 2019-11-05 | 1306 |  |  | 2019-11-05 | 2019-11-05 | 0d | 2019-09-06 | 2019-09-06 | 128d | 0d | Verde | Verde | 0% | 0% | Compensatória | Verde | 0% | 0% | Município |  |  |
| 1308 | 3.1.3.16.1.3 | **Licitação da Obra** |  | 96d | 2019-11-05 | 2020-03-30 |  |  |  | 2019-11-05 | 2020-03-30 | 96d | 2019-09-06 | 2020-01-27 | 128d |  | Verde | Verde | 0% | 0% | Compensatória | Verde | 0% | 0% |  |  |  |
| 1309 | 3.1.3.16.1.3.1 | Licitação da obra do Pleito de Governador Valadares a definir - Obra ETE Santos Dumont autorizada pelo banco | milestone | 0d | 2019-11-05 | 2019-11-05 | 1307 |  |  | 2019-11-05 | 2019-11-05 | 0d | 2019-09-06 | 2019-09-06 | 128d | 0d | Verde | Verde | 0% | 0% | Compensatória | Verde | 0% | 0% | Banco |  |  |
| 1310 | 3.1.3.16.1.3.2 | Licitar Obra |  | 82d | 2019-11-06 | 2020-03-10 | 1309 |  |  | 2019-11-06 | 2020-03-10 | 82d | 2019-09-09 | 2020-01-07 | 128d | 0d | Verde | Verde | 0% | 0% | Compensatória | Verde | 0% | 0% | Município |  |  |
| 1311 | 3.1.3.16.1.3.3 | Analisar e emitir resultado da licitação da obra |  | 14d | 2020-03-11 | 2020-03-30 | 1310 |  |  | 2020-03-11 | 2020-03-30 | 14d | 2020-01-08 | 2020-01-27 | 128d | 0d | Verde | Verde | 0% | 0% | Compensatória | Verde | 0% | 0% | Banco |  |  |
| 1312 | 3.1.3.16.1.3.4 | Licitação da obra do Pleito de Governador Valadares a definir - Obra ETE Santos Dumont concluída | milestone | 0d | 2020-03-30 | 2020-03-30 | 1311 |  |  | 2020-03-30 | 2020-03-30 | 0d | 2020-01-27 | 2020-01-27 | 128d | 0d | Verde | Verde | 0% | 0% | Compensatória | Verde | 0% | 0% | Município |  |  |
| 1313 | 3.1.3.16.1.4 | Executar Obra |  | 622d | 2020-04-27 | 2022-10-21 | 1312FS+17d |  |  | 2020-04-27 | 2022-10-21 | 622d | 2020-02-20 | 2022-08-22 | 128d | 0d | Verde | Verde | 0% | 0% | Compensatória | Verde | 0% | 0% | Município |  |  |
| 1314 | 3.1.3.16.1.5 | Realizar processo de pré-operação |  | 120d | 2022-10-24 | 2023-04-18 | 1313 |  |  | 2022-10-24 | 2023-04-18 | 120d | 2022-08-23 | 2023-02-28 | 128d | 0d | Verde | Verde | 0% | 0% | Compensatória | Verde | 0% | 0% | Município |  |  |
| 1315 | 3.1.3.16.1.6 | Recurso da obra do Pleito de Governador Valadares a definir - Obra ETE Santos Dumont repassado | milestone | 0d | 2023-04-26 | 2023-04-26 | 1314FS+5d |  |  | 2023-04-26 | 2023-04-26 | 0d | 2023-03-07 | 2023-03-07 | 128d | 0d | Verde | Verde | 0% | 0% | Compensatória | Verde | 0% | 0% | Banco |  |  |
| 1316 | 3.1.3.16.1.7 | Pleito de Governador Valadares a definir - Obra ETE Santos Dumont concluído | milestone | 0d | 2023-04-26 | 2023-04-26 | 1315 |  |  | 2023-04-26 | 2023-04-26 | 0d | 2023-03-07 | 2023-03-07 | 128d | 90d | Verde | Verde | 0% | 0% | Compensatória | Verde | 0% | 0% | Município |  |  |
| 1317 | 3.1.3.16.2 | **Pleito de Governador Valadares a definir - Projeto de Interligação de Coletores aos Interceptores e laboratório ETE Santos Dumont** |  | 291d | 2019-07-31 | 2020-09-30 |  |  |  | 2019-07-31 | 2020-09-30 | 291d | 2019-05-31 | 2020-07-07 | 765d |  | Verde | Verde | 0% | 0% | Compensatória | Verde | 0% | 0% |  |  |  |
| 1318 | 3.1.3.16.2.1 | Pleito de Governador Valadares a definir - Projeto de Interligação de Coletores aos Interceptores e laboratório ETE Santos Dumont aprovado | milestone | 0d | 2019-07-31 | 2019-07-31 | 3052FS+157d |  |  | 2019-07-31 | 2019-07-31 | 0d | 2019-05-31 | 2019-05-31 | 765d | 0d | Verde | Verde | 0% | 0% | Compensatória | Verde | 0% | 0% | CT/CIF |  |  |

Notes:
- 1300: Valor de recurso destinado ao munícipio: R$4.726.993,07
- 1301: Governador Valadares teve todo o pleito de Esgotamento Sanitário negado. / Está em tratativas visando a definição do escopo dos projetos e obras que poderão ser financiadas com estes recursos. Assim que forem concluídas tais tratativas, será elaborada NT para apresentar a análise do pleito ajustado pelo munícipio. / O município teve 0,8%, dos 10% do valor teto destinado a Resíduos Sólidos aprovado (R$502.718,13). / Como ainda não está definido quantas obras serão realizadas, foi considerado o valor total de obras, dividido por 4 para o critério de prazo, de forma a não impactar no prazo final do programa.
- 1302: Em 23/04/2019: / - obra ETE Santos Dumont + comissionamento/operação assistida - 1a etapa ETE Santos Dumont. / - valor: 21.125.771,30 + 308.928,66
- 1303: 30/05/2019: pleito não foi analisado antes da reunião do CIF de maio e da reunião da CT de junho, por isso o pleito só será aprovado em julho.
- 1317: Em 23/04/2019: Interligações dos coletores aos interceptores / - bacia ETE Santos Dumond 1a etapa BDMG / - bacia ETE Elvamar / - Gran Duquesa, Centro, Vale Verde (Bacia de Santos Dumond) / - bacia ETE Santos Dumond - complementação da 1a etapa Renova / - bacia Santos Dumond 2a etapa CEF
- 1318: 30/05/2019: pleito não foi analisado antes da reunião do CIF de maio e da reunião da CT de junho, por isso o pleito só será aprovado em julho.

| ID | WBS | Task | Type | Duration | Start | Finish | Predecessors | Baseline start | Baseline finish | Baseline duration | Baseline 1 start | Baseline 1 finish | Total slack | Free slack | Text1 | Text2 | Text3 | Text6 | Text8 | Text12 | Text14 | Text16 | Text9 | Text18 |
| --- | --- | --- | --- | --- | --- | --- | --- | --- | --- | --- | --- | --- | --- | --- | --- | --- | --- | --- | --- | --- | --- | --- | --- | --- |
| 1319 | 3.1.3.16.2.2 | **Licitação do Projeto** |  | 63d | 2019-08-14 | 2019-11-12 |  | 2019-08-14 | 2019-11-12 | 63d | 2019-06-14 | 2019-09-13 | 765d |  | Verde | Verde | 0% | 0% | Compensatória | Verde | 0% | 0% |  |  |
| 1320 | 3.1.3.16.2.2.1 | Licitação do projeto do Pleito de Governador Valadares a definir - Projeto de Interligação de Coletores aos Interceptores e laboratório ETE Santos Dumont autorizada pelo banco | milestone | 0d | 2019-08-14 | 2019-08-14 | 1318FS+10d | 2019-08-14 | 2019-08-14 | 0d | 2019-06-14 | 2019-06-14 | 765d | 0d | Verde | Verde | 0% | 0% | Compensatória | Verde | 0% | 0% | Banco |  |
| 1321 | 3.1.3.16.2.2.2 | Licitar projeto |  | 44d | 2019-08-16 | 2019-10-16 | 1320 | 2019-08-16 | 2019-10-16 | 44d | 2019-06-17 | 2019-08-19 | 765d | 0d | Verde | Verde | 0% | 0% | Compensatória | Verde | 0% | 0% | Município | Critério FR |
| 1322 | 3.1.3.16.2.2.3 | Documentação de licitação do Pleito de Governador Valadares a definir - Projeto de Interligação de Coletores aos Interceptores e laboratório ETE Santos Dumont apresentada ao banco | milestone | 0d | 2019-10-23 | 2019-10-23 | 1321FS+5d | 2019-10-23 | 2019-10-23 | 0d | 2019-08-26 | 2019-08-26 | 765d | 0d | Verde | Verde | 0% | 0% | Compensatória | Verde | 0% | 0% | Município |  |
| 1323 | 3.1.3.16.2.2.4 | Analisar e emitir resultado da licitação do projeto |  | 14d | 2019-10-24 | 2019-11-12 | 1322 | 2019-10-24 | 2019-11-12 | 14d | 2019-08-27 | 2019-09-13 | 765d | 0d | Verde | Verde | 0% | 0% | Compensatória | Verde | 0% | 0% | Banco | Critério FR |
| 1324 | 3.1.3.16.2.2.5 | Licitação do projeto do Pleito de Governador Valadares a definir - Projeto de Interligação de Coletores aos Interceptores e laboratório ETE Santos Dumont concluída | milestone | 0d | 2019-11-12 | 2019-11-12 | 1323 | 2019-11-12 | 2019-11-12 | 0d | 2019-09-13 | 2019-09-13 | 765d | 0d | Verde | Verde | 0% | 0% | Compensatória | Verde | 0% | 0% | Município |  |
| 1325 | 3.1.3.16.2.3 | **Elaboração do Projeto Básico** |  | 137d | 2019-11-13 | 2020-06-05 |  | 2019-11-13 | 2020-06-05 | 137d | 2019-09-16 | 2020-04-03 | 765d |  | Verde | Verde | 0% | 0% | Compensatória | Verde | 0% | 0% |  |  |
| 1326 | 3.1.3.16.2.3.1 | Elaborar Projeto Básico |  | 66d | 2019-11-13 | 2020-02-19 | 1324 | 2019-11-13 | 2020-02-19 | 66d | 2019-09-16 | 2019-12-18 | 765d | 0d | Verde | Verde | 0% | 0% | Compensatória | Verde | 0% | 0% | Município |  |
| 1327 | 3.1.3.16.2.3.2 | Projeto básico do Pleito de Governador Valadares a definir - Projeto de Interligação de Coletores aos Interceptores e laboratório ETE Santos Dumont apresentado ao banco | milestone | 0d | 2020-02-19 | 2020-02-19 | 1326 | 2020-02-19 | 2020-02-19 | 0d | 2019-12-18 | 2019-12-18 | 765d | 0d | Verde | Verde | 0% | 0% | Compensatória | Verde | 0% | 0% | Município |  |
| 1328 | 3.1.3.16.2.3.3 | Analisar projeto básico |  | 66d | 2020-02-20 | 2020-05-29 | 1327 | 2020-02-20 | 2020-05-29 | 66d | 2019-12-19 | 2020-01-22 | 841d | 0d | Verde | Verde | 0% | 0% | Compensatória | Verde | 0% | 0% | Banco |  |
| 1329 | 3.1.3.16.2.3.4 | Projeto básico do Pleito de Governador Valadares a definir - Projeto de Interligação de Coletores aos Interceptores e laboratório ETE Santos Dumont concluído | milestone | 0d | 2020-05-29 | 2020-05-29 | 1328 | 2020-05-29 | 2020-05-29 | 0d | 2020-03-27 | 2020-03-27 | 841d | 0d | Verde | Verde | 0% | 0% | Compensatória | Verde | 0% | 0% | Município |  |
| 1330 | 3.1.3.16.2.3.5 | Recurso do projeto básico do Pleito de Governador Valadares a definir - Projeto de Interligação de Coletores aos Interceptores e laboratório ETE Santos Dumont repassado | milestone | 0d | 2020-06-05 | 2020-06-05 | 1329FS+5d | 2020-06-05 | 2020-06-05 | 0d | 2020-04-03 | 2020-04-03 | 841d | 76d | Verde | Verde | 0% | 0% | Compensatória | Verde | 0% | 0% | Banco |  |
| 1331 | 3.1.3.16.2.4 | **Elaboração do Projeto Executivo** |  | 152d | 2020-02-20 | 2020-09-30 |  | 2020-02-20 | 2020-09-30 | 152d | 2019-12-19 | 2020-07-07 | 765d |  | Verde | Verde | 0% | 0% | Compensatória | Verde | 0% | 0% |  |  |
| 1332 | 3.1.3.16.2.4.1 | Elaborar Projeto Executivo |  | 80d | 2020-02-20 | 2020-06-19 | 1327 | 2020-02-20 | 2020-06-19 | 80d | 2019-12-19 | 2020-03-23 | 765d | 0d | Verde | Verde | 0% | 0% | Compensatória | Verde | 0% | 0% | Município |  |
| 1333 | 3.1.3.16.2.4.2 | Projeto apresentado do Pleito de Governador Valadares a definir - Projeto de Interligação de Coletores aos Interceptores e laboratório ETE Santos Dumont ao banco | milestone | 0d | 2020-06-19 | 2020-06-19 | 1332 | 2020-06-19 | 2020-06-19 | 0d | 2020-03-23 | 2020-03-23 | 765d | 0d | Verde | Verde | 0% | 0% | Compensatória | Verde | 0% | 0% | Município |  |
| 1334 | 3.1.3.16.2.4.3 | Analisar projeto executivo |  | 67d | 2020-06-22 | 2020-09-23 | 1333 | 2020-06-22 | 2020-09-23 | 67d | 2020-03-24 | 2020-04-27 | 765d | 0d | Verde | Verde | 0% | 0% | Compensatória | Verde | 0% | 0% | Banco |  |
| 1335 | 3.1.3.16.2.4.4 | Projeto executivo do Pleito de Governador Valadares a definir - Projeto de Interligação de Coletores aos Interceptores e laboratório ETE Santos Dumont concluído | milestone | 0d | 2020-09-23 | 2020-09-23 | 1330, 1334 | 2020-09-23 | 2020-09-23 | 0d | 2020-06-30 | 2020-06-30 | 765d | 0d | Verde | Verde | 0% | 0% | Compensatória | Verde | 0% | 0% | Município |  |
| 1336 | 3.1.3.16.2.4.5 | Recurso do projeto executivo do Pleito de Governador Valadares a definir - Projeto de Interligação de Coletores aos Interceptores e laboratório ETE Santos Dumont repassado | milestone | 0d | 2020-09-30 | 2020-09-30 | 1335FS+5d | 2020-09-30 | 2020-09-30 | 0d | 2020-07-07 | 2020-07-07 | 765d | 0d | Verde | Verde | 0% | 0% | Compensatória | Verde | 0% | 0% | Banco |  |
| 1337 | 3.1.3.16.2.5 | Pleito de Governador Valadares a definir - Projeto de Interligação de Coletores aos Interceptores e laboratório ETE Santos Dumont concluído | milestone | 0d | 2020-09-30 | 2020-09-30 | 1336 | 2020-09-30 | 2020-09-30 | 0d | 2020-07-07 | 2020-07-07 | 765d | 727d | Verde | Verde | 0% | 0% | Compensatória | Verde | 0% | 0% | Município |  |
| 1338 | 3.1.3.16.3 | **Pleito de Governador Valadares a definir - Obra Interligação de Coletores aos Interceptores e laboratório ETE Santos Dumont** |  | 813d | 2020-05-29 | 2023-09-04 |  | 2020-05-29 | 2023-09-04 | 813d | 2020-05-29 | 2024-01-19 | 38d |  | Verde | Verde | 0% | 0% | Compensatória | Verde | 0% | 0% |  |  |
| 1339 | 3.1.3.16.3.1 | Pleito de Governador Valadares a definir - Obra Interligação de Coletores aos Interceptores e laboratório ETE Santos Dumont aprovado | milestone | 0d | 2020-05-29 | 2020-05-29 | 3052FS+362d | 2020-05-29 | 2020-05-29 | 0d | 2020-05-29 | 2020-05-29 | 38d | 0d | Verde | Verde | 0% | 0% | Compensatória | Verde | 0% | 0% | CT/CIF |  |
| 1340 | 3.1.3.16.3.2 | **Licitação da obra** |  | 80d | 2020-06-15 | 2020-10-06 |  | 2020-06-15 | 2020-10-06 | 80d | 2020-06-15 | 2020-10-06 | 38d |  | Verde | Verde | 0% | 0% | Compensatória | Verde | 0% | 0% |  |  |
| 1341 | 3.1.3.16.3.2.1 | Licitação da obra do Pleito de Governador Valadares a definir - Obra Interligação de Coletores aos Interceptores e laboratório ETE Santos Dumont autorizada pelo banco | milestone | 0d | 2020-06-15 | 2020-06-15 | 1339FS+10d | 2020-06-15 | 2020-06-15 | 0d | 2020-06-15 | 2020-06-15 | 38d | 0d | Verde | Verde | 0% | 0% | Compensatória | Verde | 0% | 0% | Banco |  |
| 1342 | 3.1.3.16.3.2.2 | Licitar obra |  | 66d | 2020-06-16 | 2020-09-16 | 1341 | 2020-06-16 | 2020-09-16 | 66d | 2020-06-16 | 2020-09-16 | 38d | 0d | Verde | Verde | 0% | 0% | Compensatória | Verde | 0% | 0% | Município |  |
| 1343 | 3.1.3.16.3.2.3 | Analisar e emitir resultado da licitação da obra |  | 14d | 2020-09-17 | 2020-10-06 | 1342 | 2020-09-17 | 2020-10-06 | 14d | 2020-09-17 | 2020-10-06 | 38d | 0d | Verde | Verde | 0% | 0% | Compensatória | Verde | 0% | 0% | Banco |  |
| 1344 | 3.1.3.16.3.2.4 | Licitação da obra do Pleito de Governador Valadares a definir - Obra Interligação de Coletores aos Interceptores e laboratório ETE Santos Dumont concluída | milestone | 0d | 2020-10-06 | 2020-10-06 | 1343 | 2020-10-06 | 2020-10-06 | 0d | 2020-10-06 | 2020-10-06 | 38d | 0d | Verde | Verde | 0% | 0% | Compensatória | Verde | 0% | 0% | Município |  |
| 1345 | 3.1.3.16.3.3 | Executar obra |  | 578d | 2020-11-06 | 2023-03-06 | 1344FS+20d | 2020-11-06 | 2023-03-06 | 578d | 2020-11-06 | 2023-07-06 | 38d | 0d | Verde | Verde | 0% | 0% | Compensatória | Verde | 0% | 0% | Município |  |
| 1346 | 3.1.3.16.3.4 | Realizar processo de pré-operação |  | 120d | 2023-03-07 | 2023-08-28 | 1345 | 2023-03-07 | 2023-08-28 | 120d | 2023-07-07 | 2024-01-12 | 38d | 0d | Verde | Verde | 0% | 0% | Compensatória | Verde | 0% | 0% | Município |  |
| 1347 | 3.1.3.16.3.5 | Recurso da obra do Pleito de Governador Valadares a definir - Obra Interligação de Coletores aos Interceptores e laboratório ETE Santos Dumont repassado | milestone | 0d | 2023-09-04 | 2023-09-04 | 1346FS+5d | 2023-09-04 | 2023-09-04 | 0d | 2024-01-19 | 2024-01-19 | 38d | 0d | Verde | Verde | 0% | 0% | Compensatória | Verde | 0% | 0% | Banco |  |
| 1348 | 3.1.3.16.3.6 | Pleito de Governador Valadares a definir - Obra Interligação de Coletores aos Interceptores e laboratório ETE Santos Dumont concluído | milestone | 0d | 2023-09-04 | 2023-09-04 | 1347 | 2023-09-04 | 2023-09-04 | 0d | 2024-01-19 | 2024-01-19 | 38d | 0d | Verde | Verde | 0% | 0% | Compensatória | Verde | 0% | 0% | Município |  |

Notes:
- 1338: Em 23/04/2019: Obra de interligações dos coletores aos interceptores / - Santos Dumond, SIR, Universitário (Bacia ETE Santos Dumont) - 1a etapa BDMG / - Santos Dumond, SIR, Universitário (Bacia ETE Santos Dumont) - complementação 1a etapa Renova / - Santos Dumond, SIR, Universitário (Bacia ETE Santos Dumont) - 2a etapa CEF / - Gran Duquesa, Centro, Vale Verde (Bacia ETE Santos Dumont) / E: / - Complementação sistema santa rita (bacia ETE Santos Dumont) - interceptores, estações elevatórias de esgoto, linhas de recalque. / - Equipamentos/Materiais para laboratório da ETE Santos Dumont e execução da ETE Laboratório Santos Dumont
- 1345: 21/05/2019: premissa de duração da obra foi alterada

| ID | WBS | Task | Type | Duration | Start | Finish | Predecessors | Complete | Remaining | Baseline start | Baseline finish | Baseline duration | Baseline 1 start | Baseline 1 finish | Total slack | Free slack | Text1 | Text2 | Text3 | Text6 | Text8 | Text12 | Text14 | Text16 | Text9 | Text18 | Text4 | Text5 | Text7 | Text15 | Text17 |
| --- | --- | --- | --- | --- | --- | --- | --- | --- | --- | --- | --- | --- | --- | --- | --- | --- | --- | --- | --- | --- | --- | --- | --- | --- | --- | --- | --- | --- | --- | --- | --- |
| 1349 | 3.1.3.16.4 | **Pleito de Governador Valadares a definir - Obra Interligação de Coletores aos Interceptores da ETE Elvamar** |  | 399d | 2020-05-29 | 2022-01-04 |  |  |  | 2020-05-29 | 2022-01-04 | 399d | 2020-05-29 | 2022-01-14 | 452d |  | Verde | Verde | 0% | 0% | Compensatória | Verde | 0% | 0% |  |  |  |  |  |  |  |
| 1350 | 3.1.3.16.4.1 | Pleito de Governador Valadares a definir - Obra Interligação de Coletores aos Interceptores da ETE Elvamar aprovado | milestone | 0d | 2020-05-29 | 2020-05-29 | 3052FS+362d |  |  | 2020-05-29 | 2020-05-29 | 0d | 2020-05-29 | 2020-05-29 | 452d | 0d | Verde | Verde | 0% | 0% | Compensatória | Verde | 0% | 0% | CT/CIF |  |  |  |  |  |  |
| 1351 | 3.1.3.16.4.2 | **Licitação da obra** |  | 80d | 2020-06-15 | 2020-10-06 |  |  |  | 2020-06-15 | 2020-10-06 | 80d | 2020-06-15 | 2020-10-06 | 452d |  | Verde | Verde | 0% | 0% | Compensatória | Verde | 0% | 0% |  |  |  |  |  |  |  |
| 1352 | 3.1.3.16.4.2.1 | Licitação da obra do Pleito de Governador Valadares a definir - Obra Interligação de Coletores aos Interceptores da ETE Elvamar autorizada pelo banco | milestone | 0d | 2020-06-15 | 2020-06-15 | 1350FS+10d |  |  | 2020-06-15 | 2020-06-15 | 0d | 2020-06-15 | 2020-06-15 | 452d | 0d | Verde | Verde | 0% | 0% | Compensatória | Verde | 0% | 0% | Banco |  |  |  |  |  |  |
| 1353 | 3.1.3.16.4.2.2 | Licitar obra |  | 66d | 2020-06-16 | 2020-09-16 | 1352 |  |  | 2020-06-16 | 2020-09-16 | 66d | 2020-06-16 | 2020-09-16 | 452d | 0d | Verde | Verde | 0% | 0% | Compensatória | Verde | 0% | 0% | Município |  |  |  |  |  |  |
| 1354 | 3.1.3.16.4.2.3 | Analisar e emitir resultado da licitação da obra |  | 14d | 2020-09-17 | 2020-10-06 | 1353 |  |  | 2020-09-17 | 2020-10-06 | 14d | 2020-09-17 | 2020-10-06 | 452d | 0d | Verde | Verde | 0% | 0% | Compensatória | Verde | 0% | 0% | Banco |  |  |  |  |  |  |
| 1355 | 3.1.3.16.4.2.4 | Licitação da obra do Pleito de Governador Valadares a definir - Obra Interligação de Coletores aos Interceptores da ETE Elvamar concluída | milestone | 0d | 2020-10-06 | 2020-10-06 | 1354 |  |  | 2020-10-06 | 2020-10-06 | 0d | 2020-10-06 | 2020-10-06 | 452d | 0d | Verde | Verde | 0% | 0% | Compensatória | Verde | 0% | 0% | Município |  |  |  |  |  |  |
| 1356 | 3.1.3.16.4.3 | Executar obra |  | 164d | 2020-11-06 | 2021-07-06 | 1355FS+20d |  |  | 2020-11-06 | 2021-07-06 | 164d | 2020-11-06 | 2021-07-06 | 452d | 0d | Verde | Verde | 0% | 0% | Compensatória | Verde | 0% | 0% | Município |  |  |  |  |  |  |
| 1357 | 3.1.3.16.4.4 | Realizar processo de pré-operação |  | 120d | 2021-07-07 | 2021-12-28 | 1356 |  |  | 2021-07-07 | 2021-12-28 | 120d | 2021-07-07 | 2022-01-07 | 452d | 0d | Verde | Verde | 0% | 0% | Compensatória | Verde | 0% | 0% | Município |  |  |  |  |  |  |
| 1358 | 3.1.3.16.4.5 | Recurso da obra de Governador Valadares do Pleito de Governador Valadares a definir - Obra Interligação de Coletores aos Interceptores da ETE Elvamar repassado | milestone | 0d | 2022-01-04 | 2022-01-04 | 1357FS+5d |  |  | 2022-01-04 | 2022-01-04 | 0d | 2022-01-14 | 2022-01-14 | 452d | 0d | Verde | Verde | 0% | 0% | Compensatória | Verde | 0% | 0% | Banco |  |  |  |  |  |  |
| 1359 | 3.1.3.16.4.6 | Pleito de Governador Valadares a definir - Obra Interligação de Coletores aos Interceptores da ETE Elvamar concluído | milestone | 0d | 2022-01-04 | 2022-01-04 | 1358 |  |  | 2022-01-04 | 2022-01-04 | 0d | 2022-01-14 | 2022-01-14 | 452d | 414d | Verde | Verde | 0% | 0% | Compensatória | Verde | 0% | 0% | Município |  |  |  |  |  |  |
| 1360 | 3.1.3.16.5 | **Pleito de Governador Valadares a definir - Assessoria Licenciamento Ambiental ETE Elvamar** |  | 335d | 2019-07-31 | 2020-12-03 |  |  |  | 2019-07-31 | 2020-12-03 | 335d | 2019-05-31 | 2020-10-02 | 721d |  | Verde | Verde | 0% | 0% | Compensatória | Verde | 0% | 0% |  |  |  |  |  |  |  |
| 1361 | 3.1.3.16.5.1 | Pleito de Governador Valadares a definir - Assessoria Licenciamento Ambiental ETE Elvamar aprovado | milestone | 0d | 2019-07-31 | 2019-07-31 | 3052FS+157d |  |  | 2019-07-31 | 2019-07-31 | 0d | 2019-05-31 | 2019-05-31 | 721d | 0d | Verde | Verde | 0% | 0% | Compensatória | Verde | 0% | 0% | CT/CIF |  |  |  |  |  |  |
| 1362 | 3.1.3.16.5.2 | **Licitação do Serviço de Assessoria** |  | 63d | 2019-08-14 | 2019-11-12 |  |  |  | 2019-08-14 | 2019-11-12 | 63d | 2019-06-14 | 2019-09-13 | 721d |  | Verde | Verde | 0% | 0% | Compensatória | Verde | 0% | 0% |  |  |  |  |  |  |  |
| 1363 | 3.1.3.16.5.2.1 | Licitação do serviço do Pleito de Governador Valadares a definir - Assessoria Licenciamento Ambiental ETE Elvamar autorizada pelo banco | milestone | 0d | 2019-08-14 | 2019-08-14 | 1361FS+10d |  |  | 2019-08-14 | 2019-08-14 | 0d | 2019-06-14 | 2019-06-14 | 721d | 0d | Verde | Verde | 0% | 0% | Compensatória | Verde | 0% | 0% | Banco |  |  |  |  |  |  |
| 1364 | 3.1.3.16.5.2.2 | Licitar serviço |  | 44d | 2019-08-16 | 2019-10-16 | 1363 |  |  | 2019-08-16 | 2019-10-16 | 44d | 2019-06-17 | 2019-08-19 | 721d | 0d | Verde | Verde | 0% | 0% | Compensatória | Verde | 0% | 0% | Município | Critério FR |  |  |  |  |  |
| 1365 | 3.1.3.16.5.2.3 | Documentação de licitação do Pleito de Governador Valadares a definir - Assessoria Licenciamento Ambiental ETE Elvamar apresentada ao banco | milestone | 0d | 2019-10-23 | 2019-10-23 | 1364FS+5d |  |  | 2019-10-23 | 2019-10-23 | 0d | 2019-08-26 | 2019-08-26 | 721d | 0d | Verde | Verde | 0% | 0% | Compensatória | Verde | 0% | 0% | Município |  |  |  |  |  |  |
| 1366 | 3.1.3.16.5.2.4 | Analisar e emitir resultado da licitação do serviço |  | 14d | 2019-10-24 | 2019-11-12 | 1365 |  |  | 2019-10-24 | 2019-11-12 | 14d | 2019-08-27 | 2019-09-13 | 721d | 0d | Verde | Verde | 0% | 0% | Compensatória | Verde | 0% | 0% | Banco | Critério FR |  |  |  |  |  |
| 1367 | 3.1.3.16.5.2.5 | Licitação do serviço do Pleito de Governador Valadares a definir - Assessoria Licenciamento Ambiental ETE Elvamar concluída | milestone | 0d | 2019-11-12 | 2019-11-12 | 1366 |  |  | 2019-11-12 | 2019-11-12 | 0d | 2019-09-13 | 2019-09-13 | 721d | 0d | Verde | Verde | 0% | 0% | Compensatória | Verde | 0% | 0% | Município |  |  |  |  |  |  |
| 1368 | 3.1.3.16.5.3 | Executar serviço |  | 250d | 2019-11-25 | 2020-11-26 | 1367FS+7d |  |  | 2019-11-25 | 2020-11-26 | 250d | 2019-09-25 | 2020-09-25 | 721d | 0d | Verde | Verde | 0% | 0% | Compensatória | Verde | 0% | 0% | Município |  |  |  |  |  |  |
| 1369 | 3.1.3.16.5.4 | Recurso do serviço do Pleito de Governador Valadares a definir - Assessoria Licenciamento Ambiental ETE Elvamar repassado | milestone | 0d | 2020-12-03 | 2020-12-03 | 1368FS+5d |  |  | 2020-12-03 | 2020-12-03 | 0d | 2020-10-02 | 2020-10-02 | 721d | 0d | Verde | Verde | 0% | 0% | Compensatória | Verde | 0% | 0% | Banco |  |  |  |  |  |  |
| 1370 | 3.1.3.16.5.5 | Pleito de Governador Valadares a definir - Assessoria Licenciamento Ambiental ETE Elvamar concluído | milestone | 0d | 2020-12-03 | 2020-12-03 | 1369 |  |  | 2020-12-03 | 2020-12-03 | 0d | 2020-10-02 | 2020-10-02 | 721d | 683d | Verde | Verde | 0% | 0% | Compensatória | Verde | 0% | 0% | Município |  |  |  |  |  |  |
| 1371 | 3.1.3.16.6 | **Pleito GOVRSPM01 - Elaboração de estudos de viabilidade para concepção dos serviços de infraestrutura de sistemas integrados de destinação final de resíduos sólidos urbanos, assim como educação ambiental e programas de coleta seletiva** |  | 438d | 2018-08-22 A | 2020-05-22 |  | 45% | 242.35d | 2018-08-22 | 2020-05-22 | 438d | 2018-06-15 | 2020-03-11 | 856d |  | Verde | Verde | 44% | 100% | Compensatória | Verde | 3% | 3% |  |  | 45 | 44 | 100 |  |  |
| 1372 | 3.1.3.16.6.1 | **Licitação de Empresa para Estudo de Viabilidade** |  | 284d | 2018-08-22 A | 2019-10-04 |  | 69% | 87.39d | 2018-08-22 | 2019-10-04 | 284d | 2018-06-15 | 2019-07-26 | 856d |  | Verde | Verde | 69% | 98% | Compensatória | Vermelho | 58% | 57% |  |  | 69 | 69 | 98 | 58 | 57 |
| 1373 | 3.1.3.16.6.1.1 | Licitação da empresa para Estudo de Viabilidade de Governador Valadares do Pleito GOVRSPM01 - Elaboração de estudos de viabilidade para concepção dos serviços de infraestrutura de sistemas integrados de destinação final de resíduos autorizada pelo banco | milestone | 0d | 2018-08-22 A | 2018-08-22 A | 3052FS-81d | 100% |  | 2018-08-22 | 2018-08-22 | 0d | 2018-06-15 | 2018-06-15 |  |  | Verde | Verde | 100% | 100% | Compensatória | Verde | 100% | 100% | Banco |  | 100 | 100 | 100 | 100 | 100 |
| 1374 | 3.1.3.16.6.1.2 | Licitar empresa para Estudo de Viabilidade |  | 257d | 2018-09-03 A | 2019-09-09 | 1373FS+8d | 73% | 69.39d | 2018-09-03 | 2019-09-09 | 257d | 2018-09-03 | 2019-07-01 | 856d | 0d | Verde | Verde | 73% | 99% | Compensatória | Vermelho | 73% | 72% | Município | Conforme agendado | 73 | 73 | 99 | 73 | 72 |
| 1375 | 3.1.3.16.6.1.3 | Documentação de licitação de Governador Valadares do Pleito GOVRSPM01 - Elaboração de estudos de viabilidade para concepção dos serviços de infraestrutura de sistemas integrados de destinação final de resíduos apresentada ao banco | milestone | 0d | 2019-09-16 | 2019-09-16 | 1374FS+5d |  |  | 2019-09-16 | 2019-09-16 | 0d | 2019-07-08 | 2019-07-08 | 856d | 0d | Verde | Verde | 0% | 0% | Compensatória | Verde | 0% | 0% | Município |  |  |  |  |  |  |
| 1376 | 3.1.3.16.6.1.4 | Analisar e emitir resultado da licitação da empresa para Estudo de Viabilidade |  | 14d | 2019-09-17 | 2019-10-04 | 1375 |  |  | 2019-09-17 | 2019-10-04 | 14d | 2019-07-09 | 2019-07-26 | 856d | 0d | Verde | Verde | 0% | 0% | Compensatória | Verde | 0% | 0% | Banco | Critério FR |  |  |  |  |  |
| 1377 | 3.1.3.16.6.1.5 | Licitação da empresa para Estudo de Viabilidade de Governador Valadares do Pleito GOVRSPM01 - Elaboração de estudos de viabilidade para concepção dos serviços de infraestrutura de sistemas integrados de destinação final de resíduos concluída | milestone | 0d | 2019-10-04 | 2019-10-04 | 1376 |  |  | 2019-10-04 | 2019-10-04 | 0d | 2019-07-26 | 2019-07-26 | 856d | 0d | Verde | Verde | 0% | 0% | Compensatória | Verde | 0% | 0% | Município |  |  |  |  |  |  |

Notes:
- 1361: 30/05/2019: pleito não foi analisado antes da reunião do CIF de maio e da reunião da CT de junho, por isso o pleito só será aprovado em julho.
- 1373: 02/06/2019: banco autorizou a licitação do estudo no dia 22/08/2018 conforme planilha Controle Gerencial Renova
- 1374: 21/05/2019: atualizada a data de término conforme cronograma do consórcio / 02/07/2019: e-mail Claudia - Encaminhado o e-mail ao secretário executivo CIMDOCE na data do dia 27/06/2019 solicitando atualizações do status do ~processo licitatório. Aguardando retorno.

| ID | WBS | Task | Type | Duration | Start | Finish | Predecessors | Complete | Remaining | Baseline start | Baseline finish | Baseline duration | Baseline 1 start | Baseline 1 finish | Total slack | Free slack | Text1 | Text2 | Text3 | Text6 | Text8 | Text12 | Text14 | Text16 | Text9 | Text5 | Text4 | Text15 | Text7 | Text17 | Text18 |
| --- | --- | --- | --- | --- | --- | --- | --- | --- | --- | --- | --- | --- | --- | --- | --- | --- | --- | --- | --- | --- | --- | --- | --- | --- | --- | --- | --- | --- | --- | --- | --- |
| 1378 | 3.1.3.16.6.2 | **Elaboração do estudo de viabilidade** |  | 149d | 2019-10-07 | 2020-05-15 |  |  |  | 2019-10-07 | 2020-05-15 | 149d | 2019-07-29 | 2020-03-04 | 856d |  | Verde | Verde | 0% | 0% | Compensatória | Verde | 0% | 0% |  |  |  |  |  |  |  |
| 1379 | 3.1.3.16.6.2.1 | Elaborar estudo de viabilidade |  | 88d | 2019-10-07 | 2020-02-12 | 1377 |  |  | 2019-10-07 | 2020-02-12 | 88d | 2019-07-29 | 2019-11-29 | 856d | 0d | Verde | Verde | 0% | 0% | Compensatória | Verde | 0% | 0% | Município |  |  |  |  |  |  |
| 1380 | 3.1.3.16.6.2.2 | Analisar estudo |  | 61d | 2020-02-13 | 2020-05-15 | 1379 |  |  | 2020-02-13 | 2020-05-15 | 61d | 2019-12-02 | 2020-01-02 | 856d | 0d | Verde | Verde | 0% | 0% | Compensatória | Verde | 0% | 0% | Banco |  |  |  |  |  |  |
| 1381 | 3.1.3.16.6.2.3 | Estudo de viabilidade de Governador Valadares do Pleito GOVRSPM01 - Elaboração de estudos de viabilidade para concepção dos serviços de infraestrutura de sistemas integrados de destinação final de resíduos concluído | milestone | 0d | 2020-05-15 | 2020-05-15 | 1380 |  |  | 2020-05-15 | 2020-05-15 | 0d | 2020-03-04 | 2020-03-04 | 856d | 0d | Verde | Verde | 0% | 0% | Compensatória | Verde | 0% | 0% | Município |  |  |  |  |  |  |
| 1382 | 3.1.3.16.6.3 | Recurso do serviço de Governador Valadares do Pleito GOVRSPM01 - Elaboração de estudos de viabilidade para concepção dos serviços de infraestrutura de sistemas integrados de destinação final de resíduos repassado | milestone | 0d | 2020-05-22 | 2020-05-22 | 1381FS+5d |  |  | 2020-05-22 | 2020-05-22 | 0d | 2020-03-11 | 2020-03-11 | 856d | 0d | Verde | Verde | 0% | 0% | Compensatória | Verde | 0% | 0% | Banco |  |  |  |  |  |  |
| 1383 | 3.1.3.16.6.4 | Pleito GOVRSPM01 - Elaboração de estudos de viabilidade para concepção dos serviços de infraestrutura de sistemas integrados de destinação final de resíduos de Governador Valadares concluído | milestone | 0d | 2020-05-22 | 2020-05-22 | 1382 |  |  | 2020-05-22 | 2020-05-22 | 0d | 2020-03-11 | 2020-03-11 | 856d | 818d | Verde | Verde | 0% | 0% | Compensatória | Verde | 0% | 0% | Município |  |  |  |  |  |  |
| 1384 | 3.1.3.16.7 | Recursos de Governador Valadares repassados | milestone | 0d | 2023-09-04 | 2023-09-04 | 1316, 1337, 1348, 1359, 1370, 1383 |  |  | 2023-09-04 | 2023-09-04 | 0d | 2024-01-19 | 2024-01-19 | 38d |  | Verde | Verde | 0% | 0% | Compensatória | Verde | 0% | 0% | Banco |  |  |  |  |  |  |
| 1385 | 3.1.3.17 | **Iapu** |  | 841d | 2018-08-22 A | 2022-01-03 |  | 10% | 756.34d | 2018-08-22 | 2022-01-03 | 841d | 2018-12-03 | 2021-09-20 | 453d |  | Verde | Verde | 23% | 0% | Compensatória | Vermelho | 4% | 0% |  | 23 |  |  |  |  |  |
| 1386 | 3.1.3.17.1 | **Pleito IAPRSPM01 - Elaboração de estudos ambientais** |  | 455d | 2018-08-22 A | 2020-06-17 |  | 28% | 329.88d | 2018-08-22 | 2020-06-17 | 455d | 2018-12-03 | 2019-10-09 | 839d |  | Verde | Verde | 43% | 0% | Compensatória | Vermelho | 8% | 0% |  | 43 | 28 |  |  |  |  |
| 1387 | 3.1.3.17.1.1 | **Licitação de Empresa para Licenciamento Ambiental** |  | 402d | 2018-08-22 A | 2020-03-30 |  | 32% | 275.07d | 2018-08-22 | 2020-03-30 | 402d | 2018-12-03 | 2019-07-25 | 453d |  | Verde | Verde | 48% | 0% | Compensatória | Vermelho | 20% | 0% |  | 48 | 32 | 20 |  |  |  |
| 1388 | 3.1.3.17.1.1.1 | Licitação da empresa para Licenciamento Ambiental de Iapu do Pleito IAPRSPM01 - Elaboração de estudos ambientais autorizada pelo banco | milestone | 0d | 2018-08-22 A | 2018-08-22 A | 3052FS-81d | 100% |  | 2018-08-22 | 2018-08-22 | 0d | 2018-12-03 | 2018-12-03 |  |  | Verde | Verde | 100% | 100% | Compensatória | Verde | 100% | 100% | Banco | 100 | 100 | 100 | 100 | 100 |  |
| 1389 | 3.1.3.17.1.1.2 | Licitar empresa para Licenciamento Ambiental |  | 310d | 2018-12-03 A | 2020-03-03 | 1388FS+73d | 33% | 207.7d | 2018-12-03 | 2020-03-03 | 310d | 2018-12-03 | 2019-06-28 | 453d | 0d | Verde | Verde | 39% | 0% | Compensatória | Vermelho | 39% | 0% | Município | 39 | 33 | 39 |  |  |  |
| 1390 | 3.1.3.17.1.1.3 | Documentação de licitação de Iapu do Pleito IAPRSPM01 - Elaboração de estudos ambientais apresentada ao banco | milestone | 0d | 2020-03-10 | 2020-03-10 | 1389FS+5d |  |  | 2020-03-10 | 2020-03-10 | 0d | 2019-07-05 | 2019-07-05 | 453d | 0d | Verde | Verde | 0% | 0% | Compensatória | Verde | 0% | 0% | Município |  |  |  |  |  |  |
| 1391 | 3.1.3.17.1.1.4 | Analisar e emitir resultado da licitação do empresa para Licenciamento Ambiental |  | 14d | 2020-03-11 | 2020-03-30 | 1390 |  |  | 2020-03-11 | 2020-03-30 | 14d | 2019-07-08 | 2019-07-25 | 453d | 0d | Verde | Verde | 0% | 0% | Compensatória | Verde | 0% | 0% | Banco |  |  |  |  |  |  |
| 1392 | 3.1.3.17.1.1.5 | Licitação da empresa para Licenciamento Ambiental de Iapu do Pleito IAPRSPM01 - Elaboração de estudos ambientais concluída | milestone | 0d | 2020-03-30 | 2020-03-30 | 1391 |  |  | 2020-03-30 | 2020-03-30 | 0d | 2019-07-25 | 2019-07-25 | 453d | 0d | Verde | Verde | 0% | 0% | Compensatória | Verde | 0% | 0% | Município |  |  |  |  |  |  |
| 1393 | 3.1.3.17.1.2 | Executar o Licenciamento Ambiental |  | 48d | 2020-03-31 | 2020-06-09 | 1392 |  |  | 2020-03-31 | 2020-06-09 | 48d | 2019-07-26 | 2019-10-02 | 453d | 0d | Verde | Verde | 0% | 0% | Compensatória | Verde | 0% | 0% | Município |  |  |  |  |  |  |
| 1394 | 3.1.3.17.1.3 | Recurso do serviço de Iapu do Pleito IAPRSPM01 - Elaboração de estudos ambientais repassado | milestone | 0d | 2020-06-17 | 2020-06-17 | 1393FS+5d |  |  | 2020-06-17 | 2020-06-17 | 0d | 2019-10-09 | 2019-10-09 | 839d | 0d | Verde | Verde | 0% | 0% | Compensatória | Verde | 0% | 0% | Banco |  |  |  |  |  |  |
| 1395 | 3.1.3.17.1.4 | Pleito IAPRSPM01 - Elaboração de estudos ambientais de Iapu concluído | milestone | 0d | 2020-06-17 | 2020-06-17 | 1394 |  |  | 2020-06-17 | 2020-06-17 | 0d | 2019-10-09 | 2019-10-09 | 839d | 386d | Verde | Verde | 0% | 0% | Compensatória | Verde | 0% | 0% | Município |  |  |  |  |  |  |
| 1396 | 3.1.3.17.2 | **Pleito IAPRSOB02 - Implantação de aterro sanitário** |  | 625d | 2019-07-01 | 2022-01-03 |  |  |  | 2019-06-28 | 2022-01-03 | 626d | 2019-06-28 | 2021-05-17 | 453d |  | Verde | Verde | 0% | 0% | Compensatória | Verde | 0% | 0% |  |  |  |  |  |  |  |
| 1397 | 3.1.3.17.2.1 | **Aprovação do Projeto Executivo** |  | 234d | 2019-07-01 | 2020-06-09 |  |  |  | 2019-06-28 | 2020-06-09 | 235d | 2019-06-28 | 2019-10-03 | 453d |  | Verde | Verde | 0% | 0% | Compensatória | Verde | 0% | 0% |  |  |  |  |  |  |  |
| 1398 | 3.1.3.17.2.1.1 | Projeto de Iapu do Pleito IAPRSOB02 - Implantação de aterro sanitário apresentado ao banco | milestone | 0d | 2019-07-01 | 2019-07-01 | 3052FS+135d |  |  | 2019-06-28 | 2019-06-28 | 0d | 2019-06-28 | 2019-06-28 | 619d | 0d | Verde | Verde | 0% | 0% | Compensatória | Verde | 0% | 0% | Município |  |  |  |  |  |  |
| 1399 | 3.1.3.17.2.1.2 | Analisar projeto |  | 68d | 2019-07-02 | 2019-10-04 | 1398 |  |  | 2019-07-01 | 2019-10-03 | 68d | 2019-07-01 | 2019-07-30 | 619d | 166d | Verde | Verde | 0% | 0% | Compensatória | Verde | 0% | 0% | Banco |  |  |  |  |  | Critério FR |
| 1400 | 3.1.3.17.2.1.3 | Projeto de Iapu do Pleito IAPRSOB02 - Implantação de aterro sanitário concluído | milestone | 0d | 2020-06-09 | 2020-06-09 | 1393, 1399 |  |  | 2020-06-09 | 2020-06-09 | 0d | 2019-10-03 | 2019-10-03 | 453d | 0d | Verde | Verde | 0% | 0% | Compensatória | Verde | 0% | 0% | Município |  |  |  |  |  |  |
| 1401 | 3.1.3.17.2.2 | **Licitação da obra** |  | 80d | 2020-06-09 | 2020-10-01 |  |  |  | 2020-06-09 | 2020-10-01 | 80d | 2019-10-03 | 2020-01-30 | 453d |  | Verde | Verde | 0% | 0% | Compensatória | Verde | 0% | 0% |  |  |  |  |  |  |  |
| 1402 | 3.1.3.17.2.2.1 | Licitação da obra de Iapu do Pleito IAPRSOB02 - Implantação de aterro sanitário autorizada pelo banco | milestone | 0d | 2020-06-09 | 2020-06-09 | 1400 |  |  | 2020-06-09 | 2020-06-09 | 0d | 2019-10-03 | 2019-10-03 | 453d | 0d | Verde | Verde | 0% | 0% | Compensatória | Verde | 0% | 0% | Banco |  |  |  |  |  |  |
| 1403 | 3.1.3.17.2.2.2 | Licitar obra |  | 66d | 2020-06-10 | 2020-09-11 | 1402 |  |  | 2020-06-10 | 2020-09-11 | 66d | 2019-10-04 | 2020-01-10 | 453d | 0d | Verde | Verde | 0% | 0% | Compensatória | Verde | 0% | 0% | Município |  |  |  |  |  |  |
| 1404 | 3.1.3.17.2.2.3 | Analisar e emitir resultado da licitação da obra |  | 14d | 2020-09-14 | 2020-10-01 | 1403 |  |  | 2020-09-14 | 2020-10-01 | 14d | 2020-01-13 | 2020-01-30 | 453d | 0d | Verde | Verde | 0% | 0% | Compensatória | Verde | 0% | 0% | Banco |  |  |  |  |  |  |
| 1405 | 3.1.3.17.2.2.4 | Licitação da obra de Iapu do Pleito IAPRSOB02 - Implantação de aterro sanitário concluída | milestone | 0d | 2020-10-01 | 2020-10-01 | 1404 |  |  | 2020-10-01 | 2020-10-01 | 0d | 2020-01-30 | 2020-01-30 | 453d | 0d | Verde | Verde | 0% | 0% | Compensatória | Verde | 0% | 0% | Município |  |  |  |  |  |  |
| 1406 | 3.1.3.17.2.3 | Executar obra |  | 168d | 2020-10-29 | 2021-07-05 | 1405FS+18d |  |  | 2020-10-29 | 2021-07-05 | 168d | 2020-03-02 | 2020-10-29 | 453d | 0d | Verde | Verde | 0% | 0% | Compensatória | Verde | 0% | 0% | Município |  |  |  |  |  |  |
| 1407 | 3.1.3.17.2.4 | Realizar processo de pré-operação |  | 120d | 2021-07-06 | 2021-12-27 | 1406 |  |  | 2021-07-06 | 2021-12-27 | 120d | 2020-10-30 | 2021-05-10 | 453d | 0d | Verde | Verde | 0% | 0% | Compensatória | Verde | 0% | 0% | Município |  |  |  |  |  |  |
| 1408 | 3.1.3.17.2.5 | Recurso da obra de Iapu do Pleito IAPRSOB02 - Implantação de aterro sanitário repassado | milestone | 0d | 2022-01-03 | 2022-01-03 | 1407FS+5d |  |  | 2022-01-03 | 2022-01-03 | 0d | 2021-05-17 | 2021-05-17 | 453d | 0d | Verde | Verde | 0% | 0% | Compensatória | Verde | 0% | 0% | Banco |  |  |  |  |  |  |
| 1409 | 3.1.3.17.2.6 | Pleito IAPRSOB02 - Implantação de aterro sanitário de Iapu concluído | milestone | 0d | 2022-01-03 | 2022-01-03 | 1408 |  |  | 2022-01-03 | 2022-01-03 | 0d | 2021-05-17 | 2021-05-17 | 453d | 0d | Verde | Verde | 0% | 0% | Compensatória | Verde | 0% | 0% | Município |  |  |  |  |  |  |

Notes:
- 1384: Valor de recurso destinado ao munícipio: R$68.532.492,00 / Em 19/03/19: por solicitação da A&M foi modificada a duração da atividade Governador Valadares de 1170 dias para 1161 dias para atendimento à demanda do MP e igualar as datas de término tendência às da definição do programa.
- 1385: Iapu solicitou mudança de pleito e foi autorizado pelo CIF na NT21. / Iapu teve 87,3% (R$5.502.219,94) dos recursos destinado para Esgotamento Sanitário aprovado, conforme Deliberação 75. / O pleito de resíduos sólido (10% do total do recurso destinado ao munícipio, R$630.265,74), foi aprovado na NT20.
- 1388: 02/06/2019: banco autorizou a licitação do estudo no dia 22/08/2018 conforme planilha Controle Gerencial Renova
- 1389: 21/05/2019: na reunião do consórcio o representante do CIMVA2 informou que terminou TR; / 29/05/2019: município Iapu mostrou interesse em alterar pleito para fazer aquisição de equipamentos, Ipaba e Bugre não compareceram na reunião e consórcio CIMVA1 não foi citado na reunião dos consórcios. Portanto, a duração dessa tarefa foi alterada até que se tenha algum encaminhamento.
- 1398: 29/05/2019: município mostrou interesse em alterar o pleito / 01/07/2019: projeto não foi entregue ao banco dia 28/09/2019 conforme planilha Controle Gerencial Renova. Atividade reprogramada para próximo ciclo.

| ID | WBS | Task | Type | Duration | Start | Finish | Predecessors | Complete | Remaining | Baseline start | Baseline finish | Baseline duration | Baseline 1 start | Baseline 1 finish | Total slack | Free slack | Constraint | Text1 | Text2 | Text3 | Text6 | Text7 | Text8 | Text12 | Text14 | Text16 | Text4 | Text5 | Text9 | Text15 | Text17 | Text18 |
| --- | --- | --- | --- | --- | --- | --- | --- | --- | --- | --- | --- | --- | --- | --- | --- | --- | --- | --- | --- | --- | --- | --- | --- | --- | --- | --- | --- | --- | --- | --- | --- | --- |
| 1410 | 3.1.3.17.3 | **Pleito IAPESOB03 - Implantação de sistema de coleta e tratamento de esgoto sanitário** |  | 656d | 2019-03-28 A | 2021-11-16 |  | 6% | 617.6d | 2019-03-28 | 2021-11-16 | 656d | 2019-03-28 | 2021-09-20 | 486d |  |  | Verde | Verde | 6% | 25% | 25 | Compensatória | Vermelho | 4% | 1% |  |  |  |  |  |  |
| 1411 | 3.1.3.17.3.1 | Alteração Pleito IAPESOB03 - Implantação de sistema de coleta e tratamento de esgoto sanitário de Iapu aprovada | milestone | 0d | 2019-03-28 A | 2019-03-28 A |  | 100% |  | 2019-03-28 | 2019-03-28 | 0d | 2019-03-28 | 2019-03-28 |  |  | must start on 2019-03-28 | Verde | Verde | 100% | 100% | 100 | Compensatória | Verde | 100% | 100% | 100 | 100 | CT/CIF | 100 | 100 |  |
| 1412 | 3.1.3.17.3.2 | **Aprovação do Projeto Executivo** |  | 111d | 2019-04-15 A | 2019-09-24 |  | 25% | 83.25d | 2019-04-15 | 2019-09-24 | 111d | 2019-04-15 | 2019-07-19 | 486d |  |  | Verde | Verde | 27% | 25% | 25 | Compensatória | Vermelho | 16% | 4% |  | 27 |  | 16 |  |  |
| 1413 | 3.1.3.17.3.2.1 | Projeto de Iapu do Pleito IAPESOB03 - Implantação de sistema de coleta e tratamento de esgoto sanitário apresentado ao banco | milestone | 0d | 2019-04-15 A | 2019-04-15 A | 1411FS+13d | 100% |  | 2019-04-15 | 2019-04-15 | 0d | 2019-04-15 | 2019-04-15 |  |  |  | Verde | Verde | 100% | 100% | 100 | Compensatória | Verde | 100% | 100% | 100 | 100 | Município | 100 | 100 |  |
| 1414 | 3.1.3.17.3.2.2 | Analisar projeto |  | 111d | 2019-04-16 A | 2019-09-24 | 1413 | 25% | 83.25d | 2019-04-16 | 2019-09-24 | 111d | 2019-04-16 | 2019-05-15 | 486d | 0d |  | Verde | Verde | 47% | 28% | 28 | Compensatória | Vermelho | 47% | 13% | 14 | 47 | Banco | 47 | 13 | Conforme agendado |
| 1415 | 3.1.3.17.3.2.3 | Projeto de Iapu do Pleito IAPESOB03 - Implantação de sistema de coleta e tratamento de esgoto sanitário aprovado | milestone | 0d | 2019-09-24 | 2019-09-24 | 1414 |  |  | 2019-09-24 | 2019-09-24 | 0d | 2019-07-19 | 2019-07-19 | 486d | 0d |  | Verde | Verde | 0% | 0% |  | Compensatória | Verde | 0% | 0% |  |  | Município |  |  |  |
| 1416 | 3.1.3.17.3.3 | Realizar Licenciamento Ambiental |  | 44d | 2019-04-29 A | 2019-07-01 | 1413FS+7d | 25% | 33d | 2019-04-29 | 2019-06-07 | 29d | 2019-04-29 | 2019-06-07 | 546d | 60d |  | Verde | Verde | 82% | 6% |  | Compensatória | Vermelho | 82% | 5% |  | 82 | Município | 82 |  | Conforme agendado |
| 1417 | 3.1.3.17.3.4 | **Licitação da obra** |  | 80d | 2019-09-24 | 2020-01-21 |  |  |  | 2019-09-24 | 2020-01-21 | 80d | 2019-07-19 | 2019-11-11 | 486d |  |  | Verde | Verde | 0% | 0% |  | Compensatória | Verde | 0% | 0% |  |  |  |  |  |  |
| 1418 | 3.1.3.17.3.4.1 | Licitação da obra de Iapu do Pleito IAPESOB03 - Implantação de sistema de coleta e tratamento de esgoto sanitário autorizada pelo banco | milestone | 0d | 2019-09-24 | 2019-09-24 | 1415, 1416, 1435 |  |  | 2019-09-24 | 2019-09-24 | 0d | 2019-07-19 | 2019-07-19 | 486d | 0d |  | Verde | Verde | 0% | 0% |  | Compensatória | Verde | 0% | 0% |  |  | Banco |  |  |  |
| 1419 | 3.1.3.17.3.4.2 | Licitar obra |  | 66d | 2019-09-25 | 2019-12-31 | 1418 |  |  | 2019-09-25 | 2019-12-31 | 66d | 2019-07-22 | 2019-10-22 | 486d | 0d |  | Verde | Verde | 0% | 0% |  | Compensatória | Verde | 0% | 0% |  |  | Município |  |  | Critério FR |
| 1420 | 3.1.3.17.3.4.3 | Analisar e emitir resultado da licitação da obra |  | 14d | 2020-01-02 | 2020-01-21 | 1419 |  |  | 2020-01-02 | 2020-01-21 | 14d | 2019-10-23 | 2019-11-11 | 486d | 0d |  | Verde | Verde | 0% | 0% |  | Compensatória | Verde | 0% | 0% |  |  | Banco |  |  |  |
| 1421 | 3.1.3.17.3.4.4 | Licitação da obra de Iapu do Pleito IAPESOB03 - Implantação de sistema de coleta e tratamento de esgoto sanitário concluída | milestone | 0d | 2020-01-21 | 2020-01-21 | 1420 |  |  | 2020-01-21 | 2020-01-21 | 0d | 2019-11-11 | 2019-11-11 | 486d | 0d |  | Verde | Verde | 0% | 0% |  | Compensatória | Verde | 0% | 0% |  |  | Município |  |  |  |
| 1422 | 3.1.3.17.3.5 | Executar obra |  | 307d | 2020-02-19 | 2021-05-18 | 1421FS+20d |  |  | 2020-02-19 | 2021-05-18 | 307d | 2019-12-11 | 2021-03-11 | 486d | 0d |  | Verde | Verde | 0% | 0% |  | Compensatória | Verde | 0% | 0% |  |  | Município |  |  |  |
| 1423 | 3.1.3.17.3.6 | Realizar processo de pré-operação |  | 120d | 2021-05-19 | 2021-11-08 | 1422 |  |  | 2021-05-19 | 2021-11-08 | 120d | 2021-03-12 | 2021-09-13 | 486d | 0d |  | Verde | Verde | 0% | 0% |  | Compensatória | Verde | 0% | 0% |  |  | Município |  |  |  |
| 1424 | 3.1.3.17.3.7 | Recurso da obra de Iapu do Pleito IAPESOB03 - Implantação de sistema de coleta e tratamento de esgoto sanitário repassado | milestone | 0d | 2021-11-16 | 2021-11-16 | 1423FS+5d |  |  | 2021-11-16 | 2021-11-16 | 0d | 2021-09-20 | 2021-09-20 | 486d | 0d |  | Verde | Verde | 0% | 0% |  | Compensatória | Verde | 0% | 0% |  |  | Banco |  |  |  |
| 1425 | 3.1.3.17.3.8 | Pleito IAPESOB03 - Implantação de sistema de coleta e tratamento de esgoto sanitário de Iapu concluído | milestone | 0d | 2021-11-16 | 2021-11-16 | 1424 |  |  | 2021-11-16 | 2021-11-16 | 0d | 2021-09-20 | 2021-09-20 | 486d | 33d |  | Verde | Verde | 0% | 0% |  | Compensatória | Verde | 0% | 0% |  |  | Município |  |  |  |
| 1426 | 3.1.3.17.4 | **Pleito IAPESCT01 - Aquisição de terreno para implantação de estação de tratamento de esgoto** |  | 105d | 2019-03-28 A | 2019-08-28 |  | 17% | 87.15d | 2019-03-28 | 2019-08-28 | 105d | 2019-03-28 | 2019-06-27 | 1037d |  |  | Verde | Verde | 41% | 0% |  | Compensatória | Vermelho | 23% | 0% | 12 | 41 |  | 23 |  |  |
| 1427 | 3.1.3.17.4.1 | Pleito IAPESCT01 - Aquisição de terreno para implantação de estação de tratamento de esgoto de Iapu aprovado | milestone | 0d | 2019-03-28 A | 2019-03-28 A |  | 100% |  | 2019-03-28 | 2019-03-28 | 0d | 2019-03-28 | 2019-03-28 |  |  | must start on 2019-03-28 | Verde | Verde | 100% | 100% | 100 | Compensatória | Verde | 100% | 100% | 100 | 100 | CT/CIF | 100 | 100 |  |
| 1428 | 3.1.3.17.4.2 | **Aquisição de Terreno** |  | 95d | 2019-04-11 A | 2019-08-28 |  | 17% | 78.85d | 2019-04-11 | 2019-08-28 | 95d | 2019-04-11 | 2019-06-27 | 505d |  |  | Verde | Verde | 35% | 0% |  | Compensatória | Vermelho | 23% | 0% | 12 | 35 |  | 23 |  |  |
| 1429 | 3.1.3.17.4.2.1 | Regularizar terreno e apresentar escritura ao banco |  | 68d | 2019-04-11 A | 2019-07-19 | 1427FS+10d | 25% | 51d | 2019-04-11 | 2019-07-19 | 68d | 2019-04-11 | 2019-05-20 | 505d | 0d |  | Verde | Verde | 50% | 0% |  | Compensatória | Vermelho | 50% | 0% | 18 | 50 | Município | 50 |  | Conforme agendado |
| 1430 | 3.1.3.17.4.2.2 | Analisar documentação do terreno |  | 10d | 2019-07-22 | 2019-08-02 | 1429 |  |  | 2019-07-22 | 2019-08-02 | 10d | 2019-05-21 | 2019-06-03 | 517d | 0d |  | Verde | Verde | 0% | 0% |  | Compensatória | Verde | 0% | 0% |  |  | Banco |  |  | Critério FR |
| 1431 | 3.1.3.17.4.2.3 | 50% do valor do imóvel de Iapu do Pleito IAPESCT01 - Aquisição de terreno para implantação de estação de tratamento de esgoto repassado | milestone | 0d | 2019-08-09 | 2019-08-09 | 1430FS+5d |  |  | 2019-08-09 | 2019-08-09 | 0d | 2019-06-10 | 2019-06-10 | 517d | 12d |  | Verde | Verde | 0% | 0% |  | Compensatória | Verde | 0% | 0% |  |  | Banco |  |  |  |
| 1432 | 3.1.3.17.4.2.4 | Registrar imóvel e apresentar documentação ao banco |  | 12d | 2019-07-22 | 2019-08-06 | 1429 |  |  | 2019-07-22 | 2019-08-06 | 12d | 2019-05-21 | 2019-06-05 | 505d | 0d |  | Verde | Verde | 0% | 0% |  | Compensatória | Verde | 0% | 0% |  |  | Município |  |  | Critério FR |
| 1433 | 3.1.3.17.4.2.5 | Analisar documentação do terreno |  | 10d | 2019-08-07 | 2019-08-21 | 1432 |  |  | 2019-08-07 | 2019-08-21 | 10d | 2019-06-06 | 2019-06-19 | 505d | 0d |  | Verde | Verde | 0% | 0% |  | Compensatória | Verde | 0% | 0% |  |  | Banco |  |  | Critério FR |
| 1434 | 3.1.3.17.4.2.6 | 50% do valor do imóvel de Iapu do Pleito IAPESCT01 - Aquisição de terreno para implantação de estação de tratamento de esgoto repassado | milestone | 0d | 2019-08-28 | 2019-08-28 | 1433FS+5d |  |  | 2019-08-28 | 2019-08-28 | 0d | 2019-06-27 | 2019-06-27 | 505d | 0d |  | Verde | Verde | 0% | 0% |  | Compensatória | Verde | 0% | 0% |  |  | Banco |  |  |  |
| 1435 | 3.1.3.17.4.2.7 | Aquisição de terreno de Iapu do Pleito IAPESCT01 - Aquisição de terreno para implantação de estação de tratamento de esgoto concluída | milestone | 0d | 2019-08-28 | 2019-08-28 | 1434, 1431 |  |  | 2019-08-28 | 2019-08-28 | 0d | 2019-06-27 | 2019-06-27 | 505d | 0d |  | Verde | Verde | 0% | 0% |  | Compensatória | Verde | 0% | 0% |  |  | Município |  |  |  |
| 1436 | 3.1.3.17.4.3 | Pleito IAPESCT01 - Aquisição de terreno para implantação de estação de tratamento de esgoto de Iapu concluído | milestone | 0d | 2019-08-28 | 2019-08-28 | 1435 |  |  | 2019-08-28 | 2019-08-28 | 0d | 2019-06-27 | 2019-06-27 | 1037d | 584d |  | Verde | Verde | 0% | 0% |  | Compensatória | Verde | 0% | 0% |  |  | Município |  |  |  |
| 1437 | 3.1.3.17.5 | Recursos de Iapu repassados | milestone | 0d | 2022-01-03 | 2022-01-03 | 1436, 1425, 1409, 1395 |  |  | 2022-01-03 | 2022-01-03 | 0d | 2021-09-20 | 2021-09-20 | 453d |  |  | Verde | Verde | 0% | 0% |  | Compensatória | Verde | 0% | 0% |  |  | Banco |  |  |  |

Notes:
- 1411: 02/06/2019: aprovado pelo CIF na deliberação 269.
- 1413: 02/06/2019: projeto protocolado no banco dia 15/04/2019 conforme planilha Controle Gerencial Renova
- 1414: 23/05/2019: confirmar com o município semana que vem a situação (Deiwid informou que foi encaminhado e-mail com pendências em 03/05/19, município ainda não respondeu.) (fonte: e-mail Gislaine) / 29/05/2019: município concordou em entregar a planilha orçamentária ao banco dia 21/06. O banco terá 1 mês após a entrega para fazer a análise. / 01/07/2019: município não entregou as pendências no dia 21/06/2019 conforme planilha controle gerencial Renova
- 1416: 02/05/2019: atividade reprogramada para o próximo mês, pois faltam informações sobre o andamento do processo.
- 1427: 02/06/2019: aprovado pelo CIF na deliberação 269.
- 1429: 29/05/2019: aguardando a vistoria do banco em junho durante a análise do projeto para poder finalizar a regularização do terreno.
- 1437: Valor de recurso destinado ao munícipio: R$6.302.657,43

| ID | WBS | Task | Type | Duration | Start | Finish | Predecessors | Complete | Remaining | Baseline start | Baseline finish | Baseline duration | Baseline 1 start | Baseline 1 finish | Total slack | Free slack | Text1 | Text2 | Text3 | Text5 | Text6 | Text8 | Text12 | Text14 | Text16 | Text9 | Text18 | Text4 | Text15 |
| --- | --- | --- | --- | --- | --- | --- | --- | --- | --- | --- | --- | --- | --- | --- | --- | --- | --- | --- | --- | --- | --- | --- | --- | --- | --- | --- | --- | --- | --- |
| 1438 | 3.1.3.18 | **Ipaba** |  | 1120d | 2018-08-22 A | 2023-02-14 |  | 9% | 1019.36d | 2018-08-22 | 2023-02-14 | 1120d | 2018-12-03 | 2022-10-26 | 174d |  | Verde | Verde | 17% | 17 | 0% | Compensatória | Vermelho | 0% | 0% |  |  |  |  |
| 1439 | 3.1.3.18.1 | **Pleito IPBESPJ01 - Elaboração de projeto de sistema de esgotamento sanitário da sede do município e povoado de Boachá** |  | 402d | 2019-03-11 A | 2020-10-19 |  | 12% | 353.45d | 2019-03-11 | 2020-10-19 | 402d | 2019-03-11 | 2020-06-22 | 174d |  | Verde | Verde | 14% | 14 | 0% | Compensatória | Vermelho | 1% | 0% |  |  |  |  |
| 1440 | 3.1.3.18.1.1 | **Licitação do Projeto** |  | 64d | 2019-09-02 | 2019-11-29 |  |  |  | 2019-09-02 | 2019-11-29 | 64d | 2019-05-06 | 2019-08-02 | 174d |  | Verde | Verde | 0% |  | 0% | Compensatória | Verde | 0% | 0% |  |  |  |  |
| 1441 | 3.1.3.18.1.1.1 | Licitar projeto |  | 45d | 2019-09-02 | 2019-11-01 | 3052FS+178d |  |  | 2019-09-02 | 2019-11-01 | 45d | 2019-05-06 | 2019-07-08 | 174d | 0d | Verde | Verde | 0% |  | 0% | Compensatória | Verde | 0% | 0% | Município | Critério FR |  |  |
| 1442 | 3.1.3.18.1.1.2 | Documentação de licitação de Ipaba do Pleito IPBESPJ01 - Elaboração de projeto de sistema de esgotamento sanitário da sede do município e povoado de Boachá apresentada ao banco | milestone | 0d | 2019-11-08 | 2019-11-08 | 1441FS+5d |  |  | 2019-11-08 | 2019-11-08 | 0d | 2019-07-15 | 2019-07-15 | 174d | 0d | Verde | Verde | 0% |  | 0% | Compensatória | Verde | 0% | 0% | Município |  |  |  |
| 1443 | 3.1.3.18.1.1.3 | Analisar e emitir resultado da licitação do projeto |  | 14d | 2019-11-11 | 2019-11-29 | 1442 |  |  | 2019-11-11 | 2019-11-29 | 14d | 2019-07-16 | 2019-08-02 | 174d | 0d | Verde | Verde | 0% |  | 0% | Compensatória | Verde | 0% | 0% | Banco | Critério FR |  |  |
| 1444 | 3.1.3.18.1.1.4 | Licitação do projeto de Ipaba do Pleito IPBESPJ01 - Elaboração de projeto de sistema de esgotamento sanitário da sede do município e povoado de Boachá concluída | milestone | 0d | 2019-11-29 | 2019-11-29 | 1443 |  |  | 2019-11-29 | 2019-11-29 | 0d | 2019-08-02 | 2019-08-02 | 174d | 0d | Verde | Verde | 0% |  | 0% | Compensatória | Verde | 0% | 0% | Município |  |  |  |
| 1445 | 3.1.3.18.1.2 | **Elaboração do Projeto Básico** |  | 135d | 2019-12-02 | 2020-06-22 |  |  |  | 2019-12-02 | 2020-06-22 | 135d | 2019-08-05 | 2020-02-17 | 174d |  | Verde | Verde | 0% |  | 0% | Compensatória | Verde | 0% | 0% |  |  |  |  |
| 1446 | 3.1.3.18.1.2.1 | Elaborar Projeto Básico |  | 66d | 2019-12-02 | 2020-03-11 | 1444 |  |  | 2019-12-02 | 2020-03-11 | 66d | 2019-08-05 | 2019-11-05 | 174d | 0d | Verde | Verde | 0% |  | 0% | Compensatória | Verde | 0% | 0% | Município |  |  |  |
| 1447 | 3.1.3.18.1.2.2 | Projeto básico de Ipaba do Pleito IPBESPJ01 - Elaboração de projeto de sistema de esgotamento sanitário da sede do município e povoado de Boachá apresentado ao banco | milestone | 0d | 2020-03-11 | 2020-03-11 | 1446 |  |  | 2020-03-11 | 2020-03-11 | 0d | 2019-11-05 | 2019-11-05 | 252d | 0d | Verde | Verde | 0% |  | 0% | Compensatória | Verde | 0% | 0% | Município |  |  |  |
| 1448 | 3.1.3.18.1.2.3 | Analisar projeto básico |  | 64d | 2020-03-12 | 2020-06-15 | 1447 |  |  | 2020-03-12 | 2020-06-15 | 64d | 2019-11-06 | 2019-12-06 | 252d | 0d | Verde | Verde | 0% |  | 0% | Compensatória | Verde | 0% | 0% | Banco |  |  |  |
| 1449 | 3.1.3.18.1.2.4 | Projeto básico de Ipaba do Pleito IPBESPJ01 - Elaboração de projeto de sistema de esgotamento sanitário da sede do município e povoado de Boachá concluído | milestone | 0d | 2020-06-15 | 2020-06-15 | 1448 |  |  | 2020-06-15 | 2020-06-15 | 0d | 2020-02-10 | 2020-02-10 | 252d | 0d | Verde | Verde | 0% |  | 0% | Compensatória | Verde | 0% | 0% | Município |  |  |  |
| 1450 | 3.1.3.18.1.2.5 | Recurso do projeto básico de Ipaba do Pleito IPBESPJ01 - Elaboração de projeto de sistema de esgotamento sanitário da sede do município e povoado de Boachá repassado | milestone | 0d | 2020-06-22 | 2020-06-22 | 1449FS+5d |  |  | 2020-06-22 | 2020-06-22 | 0d | 2020-02-17 | 2020-02-17 | 252d | 78d | Verde | Verde | 0% |  | 0% | Compensatória | Verde | 0% | 0% | Banco |  |  |  |
| 1451 | 3.1.3.18.1.3 | Realizar Licenciamento Ambiental |  | 314d | 2019-03-11 A | 2020-06-15 | 3052FS+58d | 25% | 235.5d | 2019-03-11 | 2020-06-15 | 314d | 2019-03-11 | 2020-06-15 | 257d | 83d | Verde | Verde | 18% | 18 | 0% | Compensatória | Vermelho | 18% | 0% | Município |  | 11 | 18 |
| 1452 | 3.1.3.18.1.4 | **Elaboração do Projeto Executivo** |  | 152d | 2020-03-12 | 2020-10-19 |  |  |  | 2020-03-12 | 2020-10-19 | 152d | 2019-11-06 | 2020-06-22 | 174d |  | Verde | Verde | 0% |  | 0% | Compensatória | Verde | 0% | 0% |  |  |  |  |
| 1453 | 3.1.3.18.1.4.1 | Elaborar Projeto Executivo |  | 80d | 2020-03-12 | 2020-07-07 | 1446 |  |  | 2020-03-12 | 2020-07-07 | 80d | 2019-11-06 | 2020-03-06 | 174d | 0d | Verde | Verde | 0% |  | 0% | Compensatória | Verde | 0% | 0% | Município |  |  |  |
| 1454 | 3.1.3.18.1.4.2 | Projeto executivo de Ipaba do Pleito IPBESPJ01 - Elaboração de projeto de sistema de esgotamento sanitário da sede do município e povoado de Boachá apresentado ao banco | milestone | 0d | 2020-07-07 | 2020-07-07 | 1453 |  |  | 2020-07-07 | 2020-07-07 | 0d | 2020-03-06 | 2020-03-06 | 174d | 0d | Verde | Verde | 0% |  | 0% | Compensatória | Verde | 0% | 0% | Município |  |  |  |
| 1455 | 3.1.3.18.1.4.3 | Analisar projeto executivo |  | 67d | 2020-07-08 | 2020-10-09 | 1454 |  |  | 2020-07-08 | 2020-10-09 | 67d | 2020-03-09 | 2020-04-09 | 174d | 0d | Verde | Verde | 0% |  | 0% | Compensatória | Verde | 0% | 0% | Banco |  |  |  |
| 1456 | 3.1.3.18.1.4.4 | Projeto executivo de Ipaba do Pleito IPBESPJ01 - Elaboração de projeto de sistema de esgotamento sanitário da sede do município e povoado de Boachá concluído | milestone | 0d | 2020-10-09 | 2020-10-09 | 1450, 1451, 1455 |  |  | 2020-10-09 | 2020-10-09 | 0d | 2020-06-15 | 2020-06-15 | 174d | 0d | Verde | Verde | 0% |  | 0% | Compensatória | Verde | 0% | 0% | Município |  |  |  |
| 1457 | 3.1.3.18.1.4.5 | Recurso do projeto executivo de Ipaba do Pleito IPBESPJ01 - Elaboração de projeto de sistema de esgotamento sanitário da sede do município e povoado de Boachá repassado | milestone | 0d | 2020-10-19 | 2020-10-19 | 1456FS+5d |  |  | 2020-10-19 | 2020-10-19 | 0d | 2020-06-22 | 2020-06-22 | 174d | 0d | Verde | Verde | 0% |  | 0% | Compensatória | Verde | 0% | 0% | Banco |  |  |  |
| 1458 | 3.1.3.18.1.5 | Pleito IPBESPJ01 - Elaboração de projeto de sistema de esgotamento sanitário da sede do município e povoado de Boachá de Ipaba concluído | milestone | 0d | 2020-10-19 | 2020-10-19 | 1457 |  |  | 2020-10-19 | 2020-10-19 | 0d | 2020-06-22 | 2020-06-22 | 174d | 0d | Verde | Verde | 0% |  | 0% | Compensatória | Verde | 0% | 0% | Município |  |  |  |
| 1459 | 3.1.3.18.2 | **Pleito IPBESOB01 - Implantação de sistema de esgotamento sanitário da sede do município e povoado de Boachá** |  | 579d | 2020-10-19 | 2023-02-14 |  |  |  | 2020-10-19 | 2023-02-14 | 579d | 2020-06-22 | 2022-10-26 | 174d |  | Verde | Verde | 0% |  | 0% | Compensatória | Verde | 0% | 0% |  |  |  |  |
| 1460 | 3.1.3.18.2.1 | **Licitação da Obra** |  | 60d | 2020-10-19 | 2021-01-15 |  |  |  | 2020-10-19 | 2021-01-15 | 60d | 2020-06-22 | 2020-09-15 | 174d |  | Verde | Verde | 0% |  | 0% | Compensatória | Verde | 0% | 0% |  |  |  |  |
| 1461 | 3.1.3.18.2.1.1 | Licitação da obra de Ipaba do Pleito IPBESOB01 - Implantação de sistema de esgotamento sanitário da sede do município e povoado de Boachá autorizada pelo banco | milestone | 0d | 2020-10-19 | 2020-10-19 | 1458 |  |  | 2020-10-19 | 2020-10-19 | 0d | 2020-06-22 | 2020-06-22 | 174d | 0d | Verde | Verde | 0% |  | 0% | Compensatória | Verde | 0% | 0% | Banco |  |  |  |
| 1462 | 3.1.3.18.2.1.2 | Licitar Obra |  | 46d | 2020-10-20 | 2020-12-23 | 1461 |  |  | 2020-10-20 | 2020-12-23 | 46d | 2020-06-23 | 2020-08-25 | 174d | 0d | Verde | Verde | 0% |  | 0% | Compensatória | Verde | 0% | 0% | Município |  |  |  |
| 1463 | 3.1.3.18.2.1.3 | Analisar e emitir resultado da licitação da obra |  | 14d | 2020-12-28 | 2021-01-15 | 1462 |  |  | 2020-12-28 | 2021-01-15 | 14d | 2020-08-26 | 2020-09-15 | 174d | 0d | Verde | Verde | 0% |  | 0% | Compensatória | Verde | 0% | 0% | Banco |  |  |  |
| 1464 | 3.1.3.18.2.1.4 | Licitação da obra de Ipaba do Pleito IPBESOB01 - Implantação de sistema de esgotamento sanitário da sede do município e povoado de Boachá concluída | milestone | 0d | 2021-01-15 | 2021-01-15 | 1463 |  |  | 2021-01-15 | 2021-01-15 | 0d | 2020-09-15 | 2020-09-15 | 174d | 0d | Verde | Verde | 0% |  | 0% | Compensatória | Verde | 0% | 0% | Município |  |  |  |
| 1465 | 3.1.3.18.2.2 | Executar obra |  | 374d | 2021-02-18 | 2022-08-16 | 1464FS+20d |  |  | 2021-02-18 | 2022-08-16 | 374d | 2020-10-15 | 2022-04-18 | 174d | 0d | Verde | Verde | 0% |  | 0% | Compensatória | Verde | 0% | 0% | Município |  |  |  |
| 1466 | 3.1.3.18.2.3 | Realizar processo de pré-operação |  | 120d | 2022-08-17 | 2023-02-07 | 1465 |  |  | 2022-08-17 | 2023-02-07 | 120d | 2022-04-19 | 2022-10-19 | 174d | 0d | Verde | Verde | 0% |  | 0% | Compensatória | Verde | 0% | 0% | Município |  |  |  |
| 1467 | 3.1.3.18.2.4 | Recurso da obra de Ipaba do Pleito IPBESOB01 - Implantação de sistema de esgotamento sanitário da sede do município e povoado de Boachá repassado | milestone | 0d | 2023-02-14 | 2023-02-14 | 1466FS+5d |  |  | 2023-02-14 | 2023-02-14 | 0d | 2022-10-26 | 2022-10-26 | 174d | 0d | Verde | Verde | 0% |  | 0% | Compensatória | Verde | 0% | 0% | Banco |  |  |  |
| 1468 | 3.1.3.18.2.5 | Pleito IPBESOB01 - Implantação de sistema de esgotamento sanitário da sede do município e povoado de Boachá de Ipaba concluído | milestone | 0d | 2023-02-14 | 2023-02-14 | 1467 |  |  | 2023-02-14 | 2023-02-14 | 0d | 2022-10-26 | 2022-10-26 | 174d | 0d | Verde | Verde | 0% |  | 0% | Compensatória | Verde | 0% | 0% | Município |  |  |  |

Notes:
- 1438: Ipaba teve 100% dos pleitos de Esgotamento Sanitário Aprovado, conforme Deliberação 75. / O pleito de resíduos sólido (10% do total do recurso destinado ao munícipio, R$945.398,61) foi aprovado na NT20. / Aderiu à ata de registro de preço.
- 1441: 30/04/2019: prazo redefinido para município refazer a licitação do projeto. Dia 21/03/2019 foi enviado e-mail por Francisco informando ao município que processo licitatório está em desconformidade ao check list do BDMG. / 29/05/2019: município não apareceu na reunião, por isso foi premissado que município começará o licitação em setembro (conforme Cynthia)
- 1462: 24/05/2019: município pactuou com a Renova 1 mês e meio para licitação da obra

| ID | WBS | Task | Type | Duration | Start | Finish | Predecessors | Complete | Remaining | Baseline start | Baseline finish | Baseline duration | Baseline 1 start | Baseline 1 finish | Total slack | Free slack | Text1 | Text2 | Text3 | Text4 | Text5 | Text6 | Text8 | Text12 | Text14 | Text16 | Text15 | Text7 | Text9 | Text17 | Text18 |
| --- | --- | --- | --- | --- | --- | --- | --- | --- | --- | --- | --- | --- | --- | --- | --- | --- | --- | --- | --- | --- | --- | --- | --- | --- | --- | --- | --- | --- | --- | --- | --- |
| 1469 | 3.1.3.18.3 | **Pleito IPBRSPM01 - Elaboração de estudos ambientais** |  | 455d | 2018-08-22 A | 2020-06-17 |  | 28% | 329.88d | 2018-08-22 | 2020-06-17 | 455d | 2018-12-03 | 2019-10-09 | 839d |  | Verde | Verde | 43% | 28 | 43 | 0% | Compensatória | Vermelho | 8% | 0% |  |  |  |  |  |
| 1470 | 3.1.3.18.3.1 | **Licitação de Empresa para Licenciamento Ambiental** |  | 402d | 2018-08-22 A | 2020-03-30 |  | 32% | 275.07d | 2018-08-22 | 2020-03-30 | 402d | 2018-12-03 | 2019-07-25 | 453d |  | Verde | Verde | 48% | 32 | 48 | 0% | Compensatória | Vermelho | 20% | 0% | 20 |  |  |  |  |
| 1471 | 3.1.3.18.3.1.1 | Licitação da empresa para Licenciamento Ambiental de Ipaba do Pleito IPBRSPM01 - Elaboração de estudos ambientais autorizada pelo banco | milestone | 0d | 2018-08-22 A | 2018-08-22 A | 3052FS-81d | 100% |  | 2018-08-22 | 2018-08-22 | 0d | 2018-12-03 | 2018-12-03 |  |  | Verde | Verde | 100% | 100 | 100 | 100% | Compensatória | Verde | 100% | 100% | 100 | 100 | Banco | 100 |  |
| 1472 | 3.1.3.18.3.1.2 | Licitar empresa para Licenciamento Ambiental |  | 310d | 2018-12-03 A | 2020-03-03 | 1471FS+73d | 33% | 207.7d | 2018-12-03 | 2020-03-03 | 310d | 2018-12-03 | 2019-06-28 | 453d | 0d | Verde | Verde | 39% | 33 | 39 | 0% | Compensatória | Vermelho | 39% | 0% | 39 |  | Município |  |  |
| 1473 | 3.1.3.18.3.1.3 | Documentação de licitação de Ipaba do Pleito IPBRSPM01 - Elaboração de estudos ambientais apresentada ao banco | milestone | 0d | 2020-03-10 | 2020-03-10 | 1472FS+5d |  |  | 2020-03-10 | 2020-03-10 | 0d | 2019-07-05 | 2019-07-05 | 453d | 0d | Verde | Verde | 0% |  |  | 0% | Compensatória | Verde | 0% | 0% |  |  | Município |  |  |
| 1474 | 3.1.3.18.3.1.4 | Analisar e emitir resultado da licitação do empresa para Licenciamento Ambiental |  | 14d | 2020-03-11 | 2020-03-30 | 1473 |  |  | 2020-03-11 | 2020-03-30 | 14d | 2019-07-08 | 2019-07-25 | 453d | 0d | Verde | Verde | 0% |  |  | 0% | Compensatória | Verde | 0% | 0% |  |  | Banco |  |  |
| 1475 | 3.1.3.18.3.1.5 | Licitação da empresa para Licenciamento Ambiental de Ipaba do Pleito IPBRSPM01 - Elaboração de estudos ambientais concluída | milestone | 0d | 2020-03-30 | 2020-03-30 | 1474 |  |  | 2020-03-30 | 2020-03-30 | 0d | 2019-07-25 | 2019-07-25 | 453d | 0d | Verde | Verde | 0% |  |  | 0% | Compensatória | Verde | 0% | 0% |  |  | Município |  |  |
| 1476 | 3.1.3.18.3.2 | Executar o Licenciamento Ambiental |  | 48d | 2020-03-31 | 2020-06-09 | 1475 |  |  | 2020-03-31 | 2020-06-09 | 48d | 2019-07-26 | 2019-10-02 | 453d | 0d | Verde | Verde | 0% |  |  | 0% | Compensatória | Verde | 0% | 0% |  |  | Município |  |  |
| 1477 | 3.1.3.18.3.3 | Recurso do serviço de Ipaba do Pleito IPBRSPM01 - Elaboração de estudos ambientais repassado | milestone | 0d | 2020-06-17 | 2020-06-17 | 1476FS+5d |  |  | 2020-06-17 | 2020-06-17 | 0d | 2019-10-09 | 2019-10-09 | 839d | 0d | Verde | Verde | 0% |  |  | 0% | Compensatória | Verde | 0% | 0% |  |  | Banco |  |  |
| 1478 | 3.1.3.18.3.4 | Pleito IPBRSPM01 - Elaboração de estudos ambientais de Ipaba concluído | milestone | 0d | 2020-06-17 | 2020-06-17 | 1477 |  |  | 2020-06-17 | 2020-06-17 | 0d | 2019-10-09 | 2019-10-09 | 839d | 665d | Verde | Verde | 0% |  |  | 0% | Compensatória | Verde | 0% | 0% |  |  | Município |  |  |
| 1479 | 3.1.3.18.4 | **Pleito IPBRSOB02 - Implantação de aterro sanitário** |  | 625d | 2019-07-01 | 2022-01-03 |  |  |  | 2019-06-28 | 2022-01-03 | 626d | 2019-06-28 | 2021-05-17 | 453d |  | Verde | Verde | 0% |  |  | 0% | Compensatória | Verde | 0% | 0% |  |  |  |  |  |
| 1480 | 3.1.3.18.4.1 | **Aprovação do Projeto Executivo** |  | 234d | 2019-07-01 | 2020-06-09 |  |  |  | 2019-06-28 | 2020-06-09 | 235d | 2019-06-28 | 2019-10-03 | 453d |  | Verde | Verde | 0% |  |  | 0% | Compensatória | Verde | 0% | 0% |  |  |  |  |  |
| 1481 | 3.1.3.18.4.1.1 | Projeto de Ipaba do Pleito IPBRSOB02 - Implantação de aterro sanitário apresentado ao banco | milestone | 0d | 2019-07-01 | 2019-07-01 | 3052FS+135d |  |  | 2019-06-28 | 2019-06-28 | 0d | 2019-06-28 | 2019-06-28 | 619d | 0d | Verde | Verde | 0% |  |  | 0% | Compensatória | Verde | 0% | 0% |  |  | Município |  |  |
| 1482 | 3.1.3.18.4.1.2 | Analisar projeto |  | 68d | 2019-07-02 | 2019-10-04 | 1481 |  |  | 2019-07-01 | 2019-10-03 | 68d | 2019-07-01 | 2019-07-30 | 619d | 166d | Verde | Verde | 0% |  |  | 0% | Compensatória | Verde | 0% | 0% |  |  | Banco |  | Critério FR |
| 1483 | 3.1.3.18.4.1.3 | Projeto de Ipaba do Pleito IPBRSOB02 - Implantação de aterro sanitário aprovado | milestone | 0d | 2020-06-09 | 2020-06-09 | 1476, 1482 |  |  | 2020-06-09 | 2020-06-09 | 0d | 2019-10-03 | 2019-10-03 | 453d | 0d | Verde | Verde | 0% |  |  | 0% | Compensatória | Verde | 0% | 0% |  |  | Município |  |  |
| 1484 | 3.1.3.18.4.2 | **Licitação da obra** |  | 80d | 2020-06-09 | 2020-10-01 |  |  |  | 2020-06-09 | 2020-10-01 | 80d | 2019-10-03 | 2020-01-30 | 453d |  | Verde | Verde | 0% |  |  | 0% | Compensatória | Verde | 0% | 0% |  |  |  |  |  |
| 1485 | 3.1.3.18.4.2.1 | Licitação da obra de Ipaba do Pleito IPBRSOB02 - Implantação de aterro sanitário autorizada pelo banco | milestone | 0d | 2020-06-09 | 2020-06-09 | 1483 |  |  | 2020-06-09 | 2020-06-09 | 0d | 2019-10-03 | 2019-10-03 | 453d | 0d | Verde | Verde | 0% |  |  | 0% | Compensatória | Verde | 0% | 0% |  |  | Banco |  |  |
| 1486 | 3.1.3.18.4.2.2 | Licitar obra |  | 66d | 2020-06-10 | 2020-09-11 | 1485 |  |  | 2020-06-10 | 2020-09-11 | 66d | 2019-10-04 | 2020-01-10 | 453d | 0d | Verde | Verde | 0% |  |  | 0% | Compensatória | Verde | 0% | 0% |  |  | Município |  |  |
| 1487 | 3.1.3.18.4.2.3 | Analisar e emitir resultado da licitação da obra |  | 14d | 2020-09-14 | 2020-10-01 | 1486 |  |  | 2020-09-14 | 2020-10-01 | 14d | 2020-01-13 | 2020-01-30 | 453d | 0d | Verde | Verde | 0% |  |  | 0% | Compensatória | Verde | 0% | 0% |  |  | Banco |  |  |
| 1488 | 3.1.3.18.4.2.4 | Licitação da obra de Ipaba do Pleito IPBRSOB02 - Implantação de aterro sanitário concluída | milestone | 0d | 2020-10-01 | 2020-10-01 | 1487 |  |  | 2020-10-01 | 2020-10-01 | 0d | 2020-01-30 | 2020-01-30 | 453d | 0d | Verde | Verde | 0% |  |  | 0% | Compensatória | Verde | 0% | 0% |  |  | Município |  |  |
| 1489 | 3.1.3.18.4.3 | Executar obra |  | 168d | 2020-10-29 | 2021-07-05 | 1488FS+18d |  |  | 2020-10-29 | 2021-07-05 | 168d | 2020-03-02 | 2020-10-29 | 453d | 0d | Verde | Verde | 0% |  |  | 0% | Compensatória | Verde | 0% | 0% |  |  | Município |  |  |
| 1490 | 3.1.3.18.4.4 | Realizar processo de pré-operação |  | 120d | 2021-07-06 | 2021-12-27 | 1489 |  |  | 2021-07-06 | 2021-12-27 | 120d | 2020-10-30 | 2021-05-10 | 453d | 0d | Verde | Verde | 0% |  |  | 0% | Compensatória | Verde | 0% | 0% |  |  | Município |  |  |
| 1491 | 3.1.3.18.4.5 | Recurso da obra de Ipaba do Pleito IPBRSOB02 - Implantação de aterro sanitário repassado | milestone | 0d | 2022-01-03 | 2022-01-03 | 1490FS+5d |  |  | 2022-01-03 | 2022-01-03 | 0d | 2021-05-17 | 2021-05-17 | 453d | 0d | Verde | Verde | 0% |  |  | 0% | Compensatória | Verde | 0% | 0% |  |  | Banco |  |  |
| 1492 | 3.1.3.18.4.6 | Pleito IPBRSOB02 - Implantação de aterro sanitário de Ipaba concluído | milestone | 0d | 2022-01-03 | 2022-01-03 | 1491 |  |  | 2022-01-03 | 2022-01-03 | 0d | 2021-05-17 | 2021-05-17 | 453d | 279d | Verde | Verde | 0% |  |  | 0% | Compensatória | Verde | 0% | 0% |  |  | Município |  |  |
| 1493 | 3.1.3.18.5 | Recursos de Ipaba repassados | milestone | 0d | 2023-02-14 | 2023-02-14 | 1492, 1478, 1468, 1458 |  |  | 2023-02-14 | 2023-02-14 | 0d | 2022-10-26 | 2022-10-26 | 174d |  | Verde | Verde | 0% |  |  | 0% | Compensatória | Verde | 0% | 0% |  |  | Banco |  |  |

Notes:
- 1472: 21/05/2019: na reunião do consórcio município informou que terminou TR; / 29/05/2019: município Iapu mostrou interesse em alterar pleito para fazer aquisição de equipamentos, Ipaba e Bugre não compareceram na reunião e consórcio CIMVA1 não foi citado na reunião dos consórcios. Portanto, a duração dessa tarefa foi alterada até que se tenha algum encaminhamento.
- 1481: 02/07/2019: projeto não foi apresentado ao banco conforme planilha Controle Gerencial Renova. Atividade reprogramada para o próximo ciclo.
- 1493: Valor de recurso destinado ao munícipio: R$9.453.986,14

| ID | WBS | Task | Type | Duration | Start | Finish | Predecessors | Complete | Remaining | Baseline start | Baseline finish | Baseline duration | Baseline 1 start | Baseline 1 finish | Total slack | Free slack | Text1 | Text2 | Text3 | Text4 | Text5 | Text6 | Text8 | Text12 | Text14 | Text16 | Text7 | Text15 | Text17 | Text9 | Text18 |
| --- | --- | --- | --- | --- | --- | --- | --- | --- | --- | --- | --- | --- | --- | --- | --- | --- | --- | --- | --- | --- | --- | --- | --- | --- | --- | --- | --- | --- | --- | --- | --- |
| 1494 | 3.1.3.19 | **Ipatinga** |  | 1250d | 2018-08-22 A | 2023-08-25 |  | 10% | 1123.52d | 2018-08-22 | 2023-08-25 | 1250d | 2018-08-22 | 2023-07-27 | 44d |  | Verde | Verde | 15% | 10 | 15 | 0% | Compensatória | Vermelho | 0% | 0% |  |  |  |  |  |
| 1495 | 3.1.3.19.1 | **Pleito IPAESPJ02 - Elaboração de projeto para a sede do município de Ipatinga** |  | 266d | 2019-03-13 A | 2020-04-07 |  | 12% | 233.22d | 2019-03-13 | 2020-04-07 | 266d |  |  | 886d |  | Verde | Verde | 20% | 12 | 20 | 80% | Compensatória | Vermelho | 5% | 4% | 80 |  |  |  |  |
| 1496 | 3.1.3.19.1.1 | **Licitação do Projeto - Avenida Furquilha (rua Salmão e Marli), R 14 com R Anis até Cimbidio (Nova Esperança), R Vitória Regia (Beco 20), Beco Maria Arruda (Barra Alegre), R Geraldo Arino Barra Alegre, Com. José Pedrinho (Bom Jardim), R Olinda (Caravelas),** |  | 113d | 2019-03-13 A | 2019-08-26 |  | 49% | 57.57d | 2019-03-13 | 2019-08-26 | 113d | 2019-03-01 | 2019-07-09 | 44d |  | Verde | Verde | 47% | 49 | 47 | 89% | Compensatória | Vermelho | 45% | 40% | 89 | 45 | 40 |  |  |
| 1497 | 3.1.3.19.1.1.1 | Licitação do projeto de Ipatinga do Pleito IPAESPJ02 - Elaboração de projeto para a sede do município de Ipatinga autorizada pelo banco | milestone | 0d | 2019-03-13 A | 2019-03-13 A | 3052FS+61d | 100% |  | 2019-03-13 | 2019-03-13 | 0d | 2019-03-01 | 2019-03-01 |  |  | Verde | Verde | 100% | 100 | 100 | 100% | Compensatória | Verde | 100% | 100% | 100 | 100 | 100 | Banco |  |
| 1498 | 3.1.3.19.1.1.2 | Licitar projeto |  | 92d | 2019-03-18 A | 2019-07-29 | 1497FS+2d | 57% | 40d | 2019-03-18 | 2019-07-29 | 92d | 2019-03-11 | 2019-06-11 | 44d | 0d | Verde | Verde | 56% | 57 | 56 | 89% | Compensatória | Vermelho | 56% | 50% | 89 | 56 | 50 | Município | Conforme agendado |
| 1499 | 3.1.3.19.1.1.3 | Documentação de licitação de Ipatinga do Pleito IPAESPJ02 - Elaboração de projeto para a sede do município de Ipatinga apresentada ao banco | milestone | 0d | 2019-08-05 | 2019-08-05 | 1498FS+5d |  |  | 2019-08-05 | 2019-08-05 | 0d | 2019-06-18 | 2019-06-18 | 44d | 0d | Verde | Verde | 0% |  |  | 0% | Compensatória | Verde | 0% | 0% |  |  |  | Município |  |
| 1500 | 3.1.3.19.1.1.4 | Analisar e emitir resultado da licitação do projeto |  | 14d | 2019-08-06 | 2019-08-26 | 1499 |  |  | 2019-08-06 | 2019-08-26 | 14d | 2019-06-19 | 2019-07-09 | 44d | 0d | Verde | Verde | 0% |  |  | 0% | Compensatória | Verde | 0% | 0% |  |  |  | Banco | Critério FR |
| 1501 | 3.1.3.19.1.1.5 | Licitação do projeto de Ipaba do Pleito IPAESPJ02 - Elaboração de projeto para a sede do município de Ipatinga concluída | milestone | 0d | 2019-08-26 | 2019-08-26 | 1500 |  |  | 2019-08-26 | 2019-08-26 | 0d | 2019-07-09 | 2019-07-09 | 44d | 0d | Verde | Verde | 0% |  |  | 0% | Compensatória | Verde | 0% | 0% |  |  |  | Município |  |
| 1502 | 3.1.3.19.1.2 | **Elaboração do Projeto Básico** |  | 113d | 2019-08-27 | 2020-02-06 |  |  |  | 2019-08-27 | 2020-02-06 | 113d | 2019-07-10 | 2019-12-18 | 44d |  | Verde | Verde | 0% |  |  | 0% | Compensatória | Verde | 0% | 0% |  |  |  |  |  |
| 1503 | 3.1.3.19.1.2.1 | Elaborar Projeto Básico |  | 44d | 2019-08-27 | 2019-10-25 | 1501 |  |  | 2019-08-27 | 2019-10-25 | 44d | 2019-07-10 | 2019-09-10 | 44d | 0d | Verde | Verde | 0% |  |  | 0% | Compensatória | Verde | 0% | 0% |  |  |  | Município | Critério FR |
| 1504 | 3.1.3.19.1.2.2 | Projeto básico de Ipatinga do Pleito IPAESPJ02 - Elaboração de projeto para a sede do município de Ipatinga apresentado ao banco | milestone | 0d | 2019-10-25 | 2019-10-25 | 1503 |  |  | 2019-10-25 | 2019-10-25 | 0d | 2019-09-10 | 2019-09-10 | 79d | 0d | Verde | Verde | 0% |  |  | 0% | Compensatória | Verde | 0% | 0% |  |  |  | Município |  |
| 1505 | 3.1.3.19.1.2.3 | Analisar projeto básico |  | 64d | 2019-10-28 | 2020-01-30 | 1504 |  |  | 2019-10-28 | 2020-01-30 | 64d | 2019-09-11 | 2019-10-10 | 79d | 0d | Verde | Verde | 0% |  |  | 0% | Compensatória | Verde | 0% | 0% |  |  |  | Banco | Critério FR |
| 1506 | 3.1.3.19.1.2.4 | Projeto básico de Ipatinga do Pleito IPAESPJ02 - Elaboração de projeto para a sede do município de Ipatinga concluído | milestone | 0d | 2020-01-30 | 2020-01-30 | 1505 |  |  | 2020-01-30 | 2020-01-30 | 0d | 2019-12-10 | 2019-12-10 | 79d | 0d | Verde | Verde | 0% |  |  | 0% | Compensatória | Verde | 0% | 0% |  |  |  | Município |  |
| 1507 | 3.1.3.19.1.2.5 | Recurso do projeto básico de Ipatinga do Pleito IPAESPJ02 - Elaboração de projeto para a sede do município de Ipatinga repassado | milestone | 0d | 2020-02-06 | 2020-02-06 | 1506FS+5d |  |  | 2020-02-06 | 2020-02-06 | 0d | 2019-12-18 | 2019-12-18 | 79d | 35d | Verde | Verde | 0% |  |  | 0% | Compensatória | Verde | 0% | 0% |  |  |  | Banco |  |
| 1508 | 3.1.3.19.1.3 | Realizar Licenciamento Ambiental |  | 104d | 2019-10-28 | 2020-03-31 | 1503 |  |  | 2019-10-28 | 2020-03-31 | 104d | 2019-09-11 | 2020-02-10 | 44d | 0d | Verde | Verde | 0% |  |  | 0% | Compensatória | Verde | 0% | 0% |  |  |  | Município |  |
| 1509 | 3.1.3.19.1.4 | **Elaboração do Projeto Executivo** |  | 109d | 2019-10-28 | 2020-04-07 |  |  |  | 2019-10-28 | 2020-04-07 | 109d | 2019-09-11 | 2020-02-17 | 44d |  | Verde | Verde | 0% |  |  | 0% | Compensatória | Verde | 0% | 0% |  |  |  |  |  |
| 1510 | 3.1.3.19.1.4.1 | Elaborar Projeto Executivo |  | 44d | 2019-10-28 | 2020-01-02 | 1503 |  |  | 2019-10-28 | 2020-01-02 | 44d | 2019-09-11 | 2019-11-11 | 44d | 0d | Verde | Verde | 0% |  |  | 0% | Compensatória | Verde | 0% | 0% |  |  |  | Município |  |
| 1511 | 3.1.3.19.1.4.2 | Projeto executivo de Ipatinga do Pleito IPAESPJ02 - Elaboração de projeto para a sede do município de Ipatinga apresentado ao banco | milestone | 0d | 2020-01-02 | 2020-01-02 | 1510 |  |  | 2020-01-02 | 2020-01-02 | 0d | 2019-11-11 | 2019-11-11 | 44d | 0d | Verde | Verde | 0% |  |  | 0% | Compensatória | Verde | 0% | 0% |  |  |  | Município |  |
| 1512 | 3.1.3.19.1.4.3 | Analisar projeto executivo |  | 60d | 2020-01-03 | 2020-03-31 | 1511 |  |  | 2020-01-03 | 2020-03-31 | 60d | 2019-11-12 | 2019-12-10 | 44d | 0d | Verde | Verde | 0% |  |  | 0% | Compensatória | Verde | 0% | 0% |  |  |  | Banco |  |
| 1513 | 3.1.3.19.1.4.4 | Projeto executivo de Ipatinga do Pleito IPAESPJ02 - Elaboração de projeto para a sede do município de Ipatinga concluído | milestone | 0d | 2020-03-31 | 2020-03-31 | 1508, 1507, 1512 |  |  | 2020-03-31 | 2020-03-31 | 0d | 2020-02-10 | 2020-02-10 | 44d | 0d | Verde | Verde | 0% |  |  | 0% | Compensatória | Verde | 0% | 0% |  |  |  | Município |  |
| 1514 | 3.1.3.19.1.4.5 | Recurso do projeto executivo de Ipatinga do Pleito IPAESPJ02 - Elaboração de projeto para a sede do município de Ipatinga repassado | milestone | 0d | 2020-04-07 | 2020-04-07 | 1513FS+5d |  |  | 2020-04-07 | 2020-04-07 | 0d | 2020-02-17 | 2020-02-17 | 44d | 0d | Verde | Verde | 0% |  |  | 0% | Compensatória | Verde | 0% | 0% |  |  |  | Banco |  |
| 1515 | 3.1.3.19.1.5 | Pleito IPAESPJ02 - Elaboração de projeto para a sede do município de Ipatinga concluído | milestone | 0d | 2020-04-07 | 2020-04-07 | 1514 |  |  | 2020-04-07 | 2020-04-07 | 0d |  |  | 886d | 842d | Verde | Verde | 0% |  |  | 0% | Compensatória | Verde | 0% | 0% |  |  |  |  |  |
| 1516 | 3.1.3.19.2 | **Pleito IPAESOB01 - Ampliação do sistema de coleta e tratamento de esgoto da sede do município - Bairros Vila Celeste, Barra Alegre, Horto, Vila Militar e Forquilha** |  | 1036d | 2019-06-27 A | 2023-08-25 |  |  | 1036d | 2019-06-04 | 2023-08-25 | 1052d | 2019-03-01 | 2023-07-20 | 44d |  | Verde | Verde | 0% |  |  | 0% | Compensatória | Verde | 0% | 0% |  |  |  |  |  |
| 1517 | 3.1.3.19.2.1 | Alteração do Pleito IPAESOB01 - Ampliação do sistema de coleta e tratamento de esgoto da sede do município - Bairros Vila Celeste, Barra Alegre, Horto, Vila Militar e Forquilha de Ipatinga aprovada | milestone | 0d | 2019-06-27 A | 2019-06-27 A | 3052FS+133d | 100% |  | 2019-06-10 | 2019-06-10 | 0d |  |  |  |  | Verde | Verde | 0% |  |  | 0% | Compensatória | Verde | 0% | 0% |  |  |  |  |  |

Notes:
- 1494: Ipatinga solicitou pediu 82,5% (R%14.640.770,57) dos 90% de recursos destinado para Esgotamento Sanitário e teve todo o pleito aprovado, conforme Deliberação 75. / O município teve 2,5%, dos 10% do valor teto destinado a Resíduos Sólidos aprovado (R$450.000,00). / Como ainda não está definido quantas obras seram realizadas, foi considerado o valor total de obras, dividido por 3 / para o critério de prazo, de forma a não impactar no prazo final do programa.
- 1497: 21/05/2019: atualizada a data de autorização conforme data do status do pleito da planilha Controle Gerencial Renova (aba Pleitos)
- 1498: 19/12/18 - Apoio Técnico está dando suporte na elaboração da planilha orçamentária (data prevista para 31/01/19) / 25/01/19 - Oficio 006 17/01/19 - Solicitou alteração de pleito de projeto de rede coletora da sede. (2 meses para a aprovação da mudança de pleito + 1 mês para a adesão a ATA de registro de preço e aprovação do banco) / 29/05/2019: município informou que o processo licitatório está em andamento e pediu mais 2 meses para conclusão
- 1503: 23/05/2019: município pactuou com a Renova 2 meses para elaboração do projeto básico
- 1510: 24/05/2019: município pactuou com a Renova 2 meses para elaborar projeto executivo
- 1517: 03/07/2019: dia 27/06/2019 a Bruna Buldrini enviou e-mail ao município informando que a Fundação Renova considera apta a solicitação de inclusão de novas localidades ao pleito.

| ID | WBS | Task | Type | Duration | Start | Finish | Predecessors | Baseline start | Baseline finish | Baseline duration | Total slack | Free slack | Text1 | Text2 | Text3 | Text6 | Text8 | Text12 | Text14 | Text16 | Text18 |
| --- | --- | --- | --- | --- | --- | --- | --- | --- | --- | --- | --- | --- | --- | --- | --- | --- | --- | --- | --- | --- | --- |
| 1518 | 3.1.3.19.2.2 | **Aprovação dos projetos dos bairros Limoeiro (córrego do Barro Branco), Avenida Manain e Beco Marobá (Bairro Granjas Vagalume)** |  | 60d | 2019-07-01 | 2019-09-24 |  | 2019-06-04 | 2019-08-29 | 60d | 699d |  | Verde | Verde | 0% | 0% | Compensatória | Verde | 0% | 0% |  |
| 1519 | 3.1.3.19.2.2.1 | Projetos dos bairros Limoeiro, Avenida Manain e Beco Marobá de Ipatinga do Pleito IPAESOB01 - Ampliação do sistema de coleta e tratamento de esgoto da sede do município apresentados ao banco | milestone | 0d | 2019-07-01 | 2019-07-01 | 3052FS+135d | 2019-06-04 | 2019-06-04 | 0d | 699d | 0d | Verde | Verde | 0% | 0% | Compensatória | Verde | 0% | 0% |  |
| 1520 | 3.1.3.19.2.2.2 | Analisar projetos |  | 60d | 2019-07-02 | 2019-09-24 | 1519 | 2019-06-05 | 2019-08-29 | 60d | 699d | 0d | Verde | Verde | 0% | 0% | Compensatória | Verde | 0% | 0% | Critério FR |
| 1521 | 3.1.3.19.2.2.3 | Projetos dos bairros Limoeiro, Avenida Manain e Beco Marobá de Ipatinga do Pleito IPAESOB01 - Ampliação do sistema de coleta e tratamento de esgoto da sede do município aprovados | milestone | 0d | 2019-09-24 | 2019-09-24 | 1520 | 2019-08-29 | 2019-08-29 | 0d | 699d | 0d | Verde | Verde | 0% | 0% | Compensatória | Verde | 0% | 0% |  |
| 1522 | 3.1.3.19.2.3 | **Licitação da obra dos bairros Limoeiro (córrego do Barro Branco), Avenida Manain e Beco Marobá (Bairro Granjas Vagalume)** |  | 54d | 2019-09-24 | 2019-12-10 |  | 2019-08-29 | 2019-11-13 | 54d | 699d |  | Verde | Verde | 0% | 0% | Compensatória | Verde | 0% | 0% |  |
| 1523 | 3.1.3.19.2.3.1 | Licitação da obra dos bairros Limoeiro, Avenida Manain e Beco Marobá de Ipatinga do Pleito IPAESOB01 - Ampliação do sistema de coleta e tratamento de esgoto da sede do município autorizada pelo banco | milestone | 0d | 2019-09-24 | 2019-09-24 | 1521, 1517 | 2019-08-29 | 2019-08-29 | 0d | 699d | 0d | Verde | Verde | 0% | 0% | Compensatória | Verde | 0% | 0% |  |
| 1524 | 3.1.3.19.2.3.2 | Licitar Obra |  | 40d | 2019-09-25 | 2019-11-20 | 1523 | 2019-08-30 | 2019-10-24 | 40d | 699d | 0d | Verde | Verde | 0% | 0% | Compensatória | Verde | 0% | 0% | Critério FR |
| 1525 | 3.1.3.19.2.3.3 | Analisar e emitir resultado da licitação da obra |  | 14d | 2019-11-21 | 2019-12-10 | 1524 | 2019-10-25 | 2019-11-13 | 14d | 699d | 0d | Verde | Verde | 0% | 0% | Compensatória | Verde | 0% | 0% | Critério FR |
| 1526 | 3.1.3.19.2.3.4 | Licitação da obra dos bairros Limoeiro, Avenida Manain e Beco Marobá de Ipatinga do Pleito IPAESOB01 - Ampliação do sistema de coleta e tratamento de esgoto da sede do município concluída | milestone | 0d | 2019-12-10 | 2019-12-10 | 1525 | 2019-11-13 | 2019-11-13 | 0d | 699d | 0d | Verde | Verde | 0% | 0% | Compensatória | Verde | 0% | 0% |  |
| 1527 | 3.1.3.19.2.4 | Executar obra dos bairros Limoeiro (córrego do Barro Branco), Avenida Manain e Beco Marobá (Bairro Granjas Vagalume) |  | 120d | 2020-01-14 | 2020-07-08 | 1526FS+20d | 2019-12-16 | 2020-06-12 | 120d | 699d | 0d | Verde | Verde | 0% | 0% | Compensatória | Verde | 0% | 0% |  |
| 1528 | 3.1.3.19.2.5 | Realizar processo de pré-operação |  | 120d | 2020-07-09 | 2020-12-30 | 1527 | 2020-06-15 | 2020-12-02 | 120d | 699d | 0d | Verde | Verde | 0% | 0% | Compensatória | Verde | 0% | 0% |  |
| 1529 | 3.1.3.19.2.6 | Recurso da obra dos dos bairros Limoeiro, Avenida Manain e Beco Marobá de Ipatinga do Pleito IPAESOB01 - Ampliação do sistema de coleta e tratamento de esgoto da sede do município repassado | milestone | 0d | 2021-01-07 | 2021-01-07 | 1528FS+5d | 2020-12-09 | 2020-12-09 | 0d | 699d | 655d | Verde | Verde | 0% | 0% | Compensatória | Verde | 0% | 0% |  |
| 1530 | 3.1.3.19.2.7 | **Aprovação do projeto do Horto** |  | 60d | 2019-07-09 | 2019-10-02 |  | 2019-07-09 | 2019-10-02 | 60d | 693d |  | Verde | Verde | 0% | 0% | Compensatória | Verde | 0% | 0% |  |
| 1531 | 3.1.3.19.2.7.1 | Projeto do Horto de Ipatinga do Pleito IPAESOB01 - Ampliação do sistema de coleta e tratamento de esgoto da sede do município apresentado ao banco | milestone | 0d | 2019-07-09 | 2019-07-09 | 3052FS+141d | 2019-07-09 | 2019-07-09 | 0d | 693d | 0d | Verde | Verde | 0% | 0% | Compensatória | Verde | 0% | 0% |  |
| 1532 | 3.1.3.19.2.7.2 | Analisar projeto |  | 60d | 2019-07-10 | 2019-10-02 | 1531 | 2019-07-10 | 2019-10-02 | 60d | 693d | 0d | Verde | Verde | 0% | 0% | Compensatória | Verde | 0% | 0% | Critério FR |
| 1533 | 3.1.3.19.2.7.3 | Projeto do Horto de Ipatinga do Pleito IPAESOB01 - Ampliação do sistema de coleta e tratamento de esgoto da sede do município aprovado | milestone | 0d | 2019-10-02 | 2019-10-02 | 1532 | 2019-10-02 | 2019-10-02 | 0d | 693d | 0d | Verde | Verde | 0% | 0% | Compensatória | Verde | 0% | 0% |  |
| 1534 | 3.1.3.19.2.8 | **Licitação da obra do Horto** |  | 54d | 2019-10-02 | 2019-12-19 |  | 2019-10-02 | 2019-12-19 | 54d | 693d |  | Verde | Verde | 0% | 0% | Compensatória | Verde | 0% | 0% |  |
| 1535 | 3.1.3.19.2.8.1 | Licitação da obra do Horto de Ipatinga do Pleito IPAESOB01 - Ampliação do sistema de coleta e tratamento de esgoto da sede do município autorizada pelo banco | milestone | 0d | 2019-10-02 | 2019-10-02 | 1533 | 2019-10-02 | 2019-10-02 | 0d | 693d | 0d | Verde | Verde | 0% | 0% | Compensatória | Verde | 0% | 0% |  |
| 1536 | 3.1.3.19.2.8.2 | Licitar Obra |  | 40d | 2019-10-03 | 2019-11-28 | 1535 | 2019-10-03 | 2019-11-28 | 40d | 693d | 0d | Verde | Verde | 0% | 0% | Compensatória | Verde | 0% | 0% | Critério FR |
| 1537 | 3.1.3.19.2.8.3 | Analisar e emitir resultado da licitação da obra |  | 14d | 2019-11-29 | 2019-12-19 | 1536 | 2019-11-29 | 2019-12-19 | 14d | 693d | 0d | Verde | Verde | 0% | 0% | Compensatória | Verde | 0% | 0% | Critério FR |
| 1538 | 3.1.3.19.2.8.4 | Licitação da obra do Horto de Ipatinga do Pleito IPAESOB01 - Ampliação do sistema de coleta e tratamento de esgoto da sede do município concluída | milestone | 0d | 2019-12-19 | 2019-12-19 | 1537 | 2019-12-19 | 2019-12-19 | 0d | 693d | 0d | Verde | Verde | 0% | 0% | Compensatória | Verde | 0% | 0% |  |
| 1539 | 3.1.3.19.2.9 | Executar obra do Horto |  | 120d | 2020-01-22 | 2020-07-16 | 1538FS+20d | 2020-01-22 | 2020-07-16 | 120d | 693d | 0d | Verde | Verde | 0% | 0% | Compensatória | Verde | 0% | 0% |  |
| 1540 | 3.1.3.19.2.10 | Realizar processo de pré-operação |  | 120d | 2020-07-17 | 2021-01-08 | 1539 | 2020-07-17 | 2021-01-08 | 120d | 693d | 0d | Verde | Verde | 0% | 0% | Compensatória | Verde | 0% | 0% |  |
| 1541 | 3.1.3.19.2.11 | Recurso da obra de Horto de Ipatinga do Pleito IPAESOB01 - Ampliação do sistema de coleta e tratamento de esgoto da sede do município repassado | milestone | 0d | 2021-01-15 | 2021-01-15 | 1540FS+5d | 2021-01-15 | 2021-01-15 | 0d | 693d | 649d | Verde | Verde | 0% | 0% | Compensatória | Verde | 0% | 0% |  |

Notes:
- 1519: 01/07/2019: projetos não foram a apresentados ao banco conforme planilha controle gerencial renova. Atividade reprogramada para o próximo ciclo.

| ID | WBS | Task | Type | Duration | Start | Finish | Predecessors | Complete | Remaining | Baseline start | Baseline finish | Baseline duration | Baseline 1 start | Baseline 1 finish | Total slack | Free slack | Text1 | Text2 | Text3 | Text6 | Text8 | Text12 | Text14 | Text16 | Text9 | Text4 | Text5 | Text7 | Text15 | Text17 | Text18 |
| --- | --- | --- | --- | --- | --- | --- | --- | --- | --- | --- | --- | --- | --- | --- | --- | --- | --- | --- | --- | --- | --- | --- | --- | --- | --- | --- | --- | --- | --- | --- | --- |
| 1542 | 3.1.3.19.2.12 | **Licitação da obra** |  | 73d | 2020-04-07 | 2020-07-23 |  |  |  | 2020-04-07 | 2020-07-23 | 73d | 2020-02-17 | 2020-06-05 | 44d |  | Verde | Verde | 0% | 0% | Compensatória | Verde | 0% | 0% |  |  |  |  |  |  |  |
| 1543 | 3.1.3.19.2.12.1 | Licitação da obra dos bairros restantes de Ipatinga do Pleito IPAESOB01 - Ampliação do sistema de coleta e tratamento de esgoto da sede do município autorizada pelo banco | milestone | 0d | 2020-04-07 | 2020-04-07 | 1514 |  |  | 2020-04-07 | 2020-04-07 | 0d | 2020-02-17 | 2020-02-17 | 44d | 0d | Verde | Verde | 0% | 0% | Compensatória | Verde | 0% | 0% | Banco |  |  |  |  |  |  |
| 1544 | 3.1.3.19.2.12.2 | Licitar Obra |  | 59d | 2020-04-08 | 2020-07-03 | 1543 |  |  | 2020-04-08 | 2020-07-03 | 59d | 2020-02-18 | 2020-05-18 | 44d | 0d | Verde | Verde | 0% | 0% | Compensatória | Verde | 0% | 0% | Município |  |  |  |  |  |  |
| 1545 | 3.1.3.19.2.12.3 | Analisar e emitir resultado da licitação da obra |  | 14d | 2020-07-06 | 2020-07-23 | 1544 |  |  | 2020-07-06 | 2020-07-23 | 14d | 2020-05-19 | 2020-06-05 | 44d | 0d | Verde | Verde | 0% | 0% | Compensatória | Verde | 0% | 0% | Banco |  |  |  |  |  |  |
| 1546 | 3.1.3.19.2.12.4 | Licitação da obra dos bairros restantes de Ipatinga do Pleito IPAESOB01 - Ampliação do sistema de coleta e tratamento de esgoto da sede do município concluída | milestone | 0d | 2020-07-23 | 2020-07-23 | 1545 |  |  | 2020-07-23 | 2020-07-23 | 0d | 2020-06-05 | 2020-06-05 | 44d | 0d | Verde | Verde | 0% | 0% | Compensatória | Verde | 0% | 0% | Município |  |  |  |  |  |  |
| 1547 | 3.1.3.19.2.13 | Executar obra |  | 625d | 2020-08-20 | 2023-02-24 | 1546FS+19d |  |  | 2020-08-20 | 2023-02-24 | 625d | 2020-07-06 | 2023-01-05 | 44d | 0d | Verde | Verde | 0% | 0% | Compensatória | Verde | 0% | 0% | Município |  |  |  |  |  |  |
| 1548 | 3.1.3.19.2.14 | Realizar processo de pré-operação |  | 120d | 2023-02-27 | 2023-08-18 | 1547 |  |  | 2023-02-27 | 2023-08-18 | 120d | 2023-01-06 | 2023-07-13 | 44d | 0d | Verde | Verde | 0% | 0% | Compensatória | Verde | 0% | 0% | Município |  |  |  |  |  |  |
| 1549 | 3.1.3.19.2.15 | Recurso da obra dos bairros restantes de Ipatinga do Pleito IPAESOB01 - Ampliação do sistema de coleta e tratamento de esgoto da sede do município repassado | milestone | 0d | 2023-08-25 | 2023-08-25 | 1548FS+5d |  |  | 2023-08-25 | 2023-08-25 | 0d | 2023-07-20 | 2023-07-20 | 44d | 0d | Verde | Verde | 0% | 0% | Compensatória | Verde | 0% | 0% | Banco |  |  |  |  |  |  |
| 1550 | 3.1.3.19.2.16 | Pleito IPAESOB01 - Ampliação do sistema de coleta e tratamento de esgoto da sede do município de Ipatinga concluído | milestone | 0d | 2023-08-25 | 2023-08-25 | 1549, 1529, 1541 |  |  | 2023-08-25 | 2023-08-25 | 0d | 2023-07-20 | 2023-07-20 | 44d | 0d | Verde | Verde | 0% | 0% | Compensatória | Verde | 0% | 0% | Município |  |  |  |  |  |  |
| 1551 | 3.1.3.19.3 | **Pleito IPARSPM01 - Elaboração do estudo de viabilidade e indicação de área para implantação de aterro sanitário** |  | 423d | 2018-08-22 A | 2020-04-30 |  | 45% | 231.47d | 2018-08-22 | 2020-04-30 | 423d | 2018-08-22 | 2020-03-17 | 871d |  | Verde | Verde | 46% | 67% | Compensatória | Vermelho | 3% | 2% |  | 45 | 46 | 67 |  |  |  |
| 1552 | 3.1.3.19.3.1 | **Licitação de Empresa para Estudo de Viabilidade** |  | 418d | 2018-08-22 A | 2020-04-23 |  | 45% | 228.74d | 2018-08-22 | 2020-04-23 | 418d | 2018-08-22 | 2020-03-10 | 871d |  | Verde | Verde | 46% | 67% | Compensatória | Vermelho | 3% | 2% |  | 45 | 46 | 67 |  |  |  |
| 1553 | 3.1.3.19.3.1.1 | Licitação da empresa para Estudo de Viabilidade de Ipatinga do Pleito IPARSPM01 - Elaboração do estudo de viabilidade e indicação de área para implantação de aterro sanitário autorizada pelo banco | milestone | 0d | 2018-08-22 A | 2018-08-22 A | 3052FS-81d | 100% |  | 2018-08-22 | 2018-08-22 | 0d | 2018-08-22 | 2018-08-22 |  |  | Verde | Verde | 100% | 100% | Compensatória | Verde | 100% | 100% | Banco | 100 | 100 | 100 | 100 | 100 |  |
| 1554 | 3.1.3.19.3.1.2 | Licitar empresa para Estudo de Viabilidade |  | 245d | 2018-08-22 A | 2019-08-09 | 1553 | 76% | 58d | 2018-08-22 | 2019-08-09 | 245d | 2018-08-22 | 2019-06-28 | 871d | 0d | Verde | Verde | 80% | 62% | Compensatória | Vermelho | 80% | 50% | Município | 76 | 80 | 62 | 80 | 50 | Conforme agendado |
| 1555 | 3.1.3.19.3.1.3 | Documentação de licitação de Ipatinga do Pleito IPARSPM01 - Elaboração do estudo de viabilidade e indicação de área para implantação de aterro sanitário apresentada ao banco | milestone | 0d | 2019-08-19 | 2019-08-19 | 1554FS+5d |  |  | 2019-08-19 | 2019-08-19 | 0d | 2019-07-05 | 2019-07-05 | 871d | 0d | Verde | Verde | 0% | 0% | Compensatória | Verde | 0% | 0% | Município |  |  |  |  |  |  |
| 1556 | 3.1.3.19.3.1.4 | Analisar e emitir resultado da licitação da empresa para Estudo de Viabilidade |  | 14d | 2019-08-20 | 2019-09-06 | 1555 |  |  | 2019-08-20 | 2019-09-06 | 14d | 2019-07-08 | 2019-07-25 | 871d | 0d | Verde | Verde | 0% | 0% | Compensatória | Verde | 0% | 0% | Banco |  |  |  |  |  | Critério FR |
| 1557 | 3.1.3.19.3.1.5 | Licitação da empresa para Estudo de Viabilidade de Ipatinga do Pleito IPARSPM01 - Elaboração do estudo de viabilidade e indicação de área para implantação de aterro sanitárioconcluída | milestone | 0d | 2019-09-06 | 2019-09-06 | 1556 |  |  | 2019-09-06 | 2019-09-06 | 0d | 2019-07-25 | 2019-07-25 | 871d | 0d | Verde | Verde | 0% | 0% | Compensatória | Verde | 0% | 0% | Município |  |  |  |  |  |  |
| 1558 | 3.1.3.19.3.1.6 | **Elaboração do estudo de viabilidade** |  | 154d | 2019-09-09 | 2020-04-23 |  |  |  | 2019-09-09 | 2020-04-23 | 154d | 2019-07-26 | 2020-03-10 | 871d |  | Verde | Verde | 0% | 0% | Compensatória | Verde | 0% | 0% |  |  |  |  |  |  |  |
| 1559 | 3.1.3.19.3.1.6.1 | Elaborar estudo de viabilidade |  | 88d | 2019-09-09 | 2020-01-15 | 1557 |  |  | 2019-09-09 | 2020-01-15 | 88d | 2019-07-26 | 2019-11-28 | 871d | 0d | Verde | Verde | 0% | 0% | Compensatória | Verde | 0% | 0% | Município |  |  |  |  |  |  |
| 1560 | 3.1.3.19.3.1.6.2 | Analisar estudo |  | 66d | 2020-01-16 | 2020-04-23 | 1559 |  |  | 2020-01-16 | 2020-04-23 | 66d | 2019-11-29 | 2020-01-03 | 871d | 0d | Verde | Verde | 0% | 0% | Compensatória | Verde | 0% | 0% | Banco |  |  |  |  |  |  |
| 1561 | 3.1.3.19.3.1.6.3 | Estudo de viabilidade de Ipatinga do Pleito IPARSPM01 - Elaboração do estudo de viabilidade e indicação de área para implantação de aterro sanitário concluído | milestone | 0d | 2020-04-23 | 2020-04-23 | 1560 |  |  | 2020-04-23 | 2020-04-23 | 0d | 2020-03-10 | 2020-03-10 | 871d | 0d | Verde | Verde | 0% | 0% | Compensatória | Verde | 0% | 0% | Município |  |  |  |  |  |  |
| 1562 | 3.1.3.19.3.2 | Recurso do serviço de Ipatinga do Pleito IPARSPM01 - Elaboração do estudo de viabilidade e indicação de área para implantação de aterro sanitário repassado | milestone | 0d | 2020-04-30 | 2020-04-30 | 1561FS+5d |  |  | 2020-04-30 | 2020-04-30 | 0d | 2020-03-17 | 2020-03-17 | 871d | 0d | Verde | Verde | 0% | 0% | Compensatória | Verde | 0% | 0% | Banco |  |  |  |  |  |  |
| 1563 | 3.1.3.19.3.3 | Pleito IPARSPM01 - Elaboração do estudo de viabilidade e indicação de área para implantação de aterro sanitário de Ipatinga concluído | milestone | 0d | 2020-04-30 | 2020-04-30 | 1562 |  |  | 2020-04-30 | 2020-04-30 | 0d | 2020-03-17 | 2020-03-17 | 871d | 827d | Verde | Verde | 0% | 0% | Compensatória | Verde | 0% | 0% | Município |  |  |  |  |  |  |
| 1564 | 3.1.3.19.4 | **Pleito de Ipatinga de Resíduos Sólidos a definir - Projeto e Obra** |  | 787d | 2019-08-30 | 2022-10-28 |  |  |  | 2019-08-30 | 2022-10-28 | 787d | 2019-08-30 | 2023-07-27 | 248d |  | Verde | Verde | 0% | 0% | Compensatória | Verde | 0% | 0% |  |  |  |  |  |  |  |
| 1565 | 3.1.3.19.4.1 | Pleito de Ipatinga de Resíduos Sólidos a definir aprovado | milestone | 0d | 2019-08-30 | 2019-08-30 | 3052FS+178d |  |  | 2019-08-30 | 2019-08-30 | 0d | 2019-08-30 | 2019-08-30 | 248d | 0d | Verde | Verde | 0% | 0% | Compensatória | Verde | 0% | 0% | CT/CIF |  |  |  |  |  |  |
| 1566 | 3.1.3.19.4.2 | Iniciar serviço/projeto/obra do pleito de Ipatinga de Resíduos Sólidos a definir |  | 1d | 2019-09-02 | 2019-09-02 | 1565 |  |  | 2019-09-02 | 2019-09-02 | 1d | 2019-09-02 | 2019-09-02 | 248d | 0d | Verde | Verde | 0% | 0% | Compensatória | Verde | 0% | 0% | Município |  |  |  |  |  | Critério FR |
| 1567 | 3.1.3.19.4.3 | Pleito de Ipatinga de Resíduos Sólidos a definir concluído | milestone | 0d | 2022-10-28 | 2022-10-28 | 1566FS+786d |  |  | 2022-10-28 | 2022-10-28 | 0d | 2023-07-27 | 2023-07-27 | 248d | 204d | Verde | Verde | 0% | 0% | Compensatória | Verde | 0% | 0% | Município |  |  |  |  |  |  |
| 1568 | 3.1.3.19.5 | Recursos de Ipatinga repassados | milestone | 0d | 2023-08-25 | 2023-08-25 | 1550, 1563, 1567, 1515 |  |  | 2023-08-25 | 2023-08-25 | 0d | 2023-07-27 | 2023-07-27 | 44d |  | Verde | Verde | 0% | 0% | Compensatória | Verde | 0% | 0% | Banco |  |  |  |  |  |  |

Notes:
- 1547: 22/05/2019: valor da obra - 14.190.747,45 - 30 meses
- 1553: Em 24/04/2019: a licitação foi autorizada pelo banco no dia 22/08/2018 conforme planilha de controle gerencial renova
- 1554: 21/05/2019: atualizada a data de término conforme cronograma dos consórcios
- 1565: Em 24/09/2019: pleito aprovado no dia 30/08/2019 conforme NT 33 e premissa de que o município enviará pleito entre junho e julho para ser avaliado.
- 1567: Em 24/09/2019: considerado a soma dos valores para resíduos sólidos de cada município parcipante do consórcio CIMVA 2 menos o valor do pleito de Ipatinga de estudo de viabilidade para definição da duração do pleito.
- 1568: Valor de recurso destinado ao munícipio: R$17.740.770,56

| ID | WBS | Task | Type | Duration | Start | Finish | Predecessors | Complete | Remaining | Baseline start | Baseline finish | Baseline duration | Baseline 1 start | Baseline 1 finish | Total slack | Free slack | Constraint | Text1 | Text2 | Text3 | Text6 | Text8 | Text12 | Text14 | Text16 | Text5 | Text4 | Text7 | Text9 | Text15 | Text17 | Text18 |
| --- | --- | --- | --- | --- | --- | --- | --- | --- | --- | --- | --- | --- | --- | --- | --- | --- | --- | --- | --- | --- | --- | --- | --- | --- | --- | --- | --- | --- | --- | --- | --- | --- |
| 1569 | 3.1.3.20 | **Itueta** |  | 690d | 2019-03-28 A | 2022-01-04 |  | 1% | 680.48d | 2019-03-28 | 2022-01-04 | 690d | 2019-03-28 | 2022-01-14 | 452d |  |  | Verde | Verde | 6% | 0% | Compensatória | Vermelho | 0% | 0% |  |  |  |  |  |  |  |
| 1570 | 3.1.3.20.1 | **Pleito ITUESPJ02 - Contratação de empresa especializada de engenharia para elaboração de projetos básicos e executivos para ampliação do sistema de esgotamento sanitário nos distritos de Vila Nietzel e Quatituba** |  | 315d | 2019-03-28 A | 2020-07-03 |  | 5% | 299.04d | 2019-03-28 | 2020-07-03 | 315d | 2019-03-28 | 2020-04-15 | 827d |  |  | Verde | Verde | 13% | 0% | Compensatória | Vermelho | 1% | 0% | 13 |  |  |  |  |  |  |
| 1571 | 3.1.3.20.1.1 | Alteração do Pleito ITUESPJ02 - Contratação de empresa especializada de engenharia para elaboração de projetos básicos e executivos para ampliação do sistema de esgotamento sanitário nos distritos de Vila Nietzel e Quatituba de Itueta aprovada | milestone | 0d | 2019-03-28 A | 2019-03-28 A |  | 100% |  | 2019-03-28 | 2019-03-28 | 0d | 2019-03-28 | 2019-03-28 |  |  | must start on 2019-03-28 | Verde | Verde | 100% | 100% | Compensatória | Verde | 100% | 100% | 100 | 100 | 100 | CT/CIF | 100 | 100 |  |
| 1572 | 3.1.3.20.1.2 | **Licitação do Projeto** |  | 120d | 2019-04-08 A | 2019-09-30 |  | 24% | 91.33d | 2019-04-08 | 2019-09-30 | 120d | 2019-04-08 | 2019-07-04 | 827d |  |  | Verde | Verde | 30% | 0% | Compensatória | Vermelho | 18% | 0% | 30 | 24 |  |  | 18 |  |  |
| 1573 | 3.1.3.20.1.2.1 | Licitação do projeto de Itueta do Pleito ITUESPJ02 - Contratação de empresa especializada de engenharia para elaboração de projetos básicos e executivos para ampliação do sistema de esgotamento sanitário nos distritos de Vila Nietzeautorizada pelo banco | milestone | 0d | 2019-04-08 A | 2019-04-08 A | 1571FS+8d | 100% |  | 2019-04-08 | 2019-04-08 | 0d | 2019-04-08 | 2019-04-08 |  |  |  | Verde | Verde | 100% | 100% | Compensatória | Verde | 100% | 100% | 100 | 100 | 100 | Banco | 100 | 100 |  |
| 1574 | 3.1.3.20.1.2.2 | Licitar projeto |  | 99d | 2019-04-09 A | 2019-08-30 | 1573 | 27% | 72d | 2019-04-09 | 2019-08-30 | 99d | 2019-04-09 | 2019-06-06 | 827d | 0d |  | Verde | Verde | 36% | 0% | Compensatória | Vermelho | 36% | 0% | 36 | 27 |  | Município | 36 |  | Conforme agendado |
| 1575 | 3.1.3.20.1.2.3 | Documentação de licitação de Itueta do Pleito ITUESPJ02 - Contratação de empresa especializada de engenharia para elaboração de projetos básicos e executivos para ampliação do sistema de esgotamento sanitário nos distritos de Vila Nietapresentada ao banco | milestone | 0d | 2019-09-10 | 2019-09-10 | 1574FS+7d |  |  | 2019-09-10 | 2019-09-10 | 0d | 2019-06-13 | 2019-06-13 | 827d | 0d |  | Verde | Verde | 0% | 0% | Compensatória | Verde | 0% | 0% |  |  |  | Município |  |  |  |
| 1576 | 3.1.3.20.1.2.4 | Analisar e emitir resultado da licitação do projeto |  | 14d | 2019-09-11 | 2019-09-30 | 1575 |  |  | 2019-09-11 | 2019-09-30 | 14d | 2019-06-14 | 2019-07-04 | 827d | 0d |  | Verde | Verde | 0% | 0% | Compensatória | Verde | 0% | 0% |  |  |  | Banco |  |  | Critério FR |
| 1577 | 3.1.3.20.1.2.5 | Licitação do projeto de Itueta do Pleito ITUESPJ02 - Contratação de empresa especializada de engenharia para elaboração de projetos básicos e executivos para ampliação do sistema de esgotamento sanitário nos distritos de Vila Nietzel e Quatituba concluída | milestone | 0d | 2019-09-30 | 2019-09-30 | 1576 |  |  | 2019-09-30 | 2019-09-30 | 0d | 2019-07-04 | 2019-07-04 | 827d | 0d |  | Verde | Verde | 0% | 0% | Compensatória | Verde | 0% | 0% |  |  |  | Município |  |  |  |
| 1578 | 3.1.3.20.1.3 | **Elaboração do Estudo de Concepção** |  | 105d | 2019-10-01 | 2020-03-05 |  |  |  | 2019-10-01 | 2020-03-05 | 105d |  |  | 827d |  |  | Verde | Verde | 0% | 0% | Compensatória | Verde | 0% | 0% |  |  |  |  |  |  |  |
| 1579 | 3.1.3.20.1.3.1 | Elaborar estudo |  | 40d | 2019-10-01 | 2019-11-26 | 1577 |  |  | 2019-10-01 | 2019-11-26 | 40d |  |  | 827d | 0d |  | Verde | Verde | 0% | 0% | Compensatória | Verde | 0% | 0% |  |  |  |  |  |  | Critério FR |
| 1580 | 3.1.3.20.1.3.2 | Estudo de concepção de Itueta do Pleito ITUESPJ02 - Contratação de empresa especializada de engenharia para elaboração de projetos básicos e executivos para ampliação do sistema de esgotamento sanitário nos distritos de Vila Nietzel e apresentado ao banco | milestone | 0d | 2019-11-26 | 2019-11-26 | 1579 |  |  | 2019-11-26 | 2019-11-26 | 0d |  |  | 829d | 0d |  | Verde | Verde | 0% | 0% | Compensatória | Verde | 0% | 0% |  |  |  |  |  |  |  |
| 1581 | 3.1.3.20.1.3.3 | Analisar estudo |  | 60d | 2019-11-27 | 2020-02-27 | 1580 |  |  | 2019-11-27 | 2020-02-27 | 60d |  |  | 829d | 0d |  | Verde | Verde | 0% | 0% | Compensatória | Verde | 0% | 0% |  |  |  |  |  |  | Critério FR |
| 1582 | 3.1.3.20.1.3.4 | Estudo de concepção de Itueta do Pleito ITUESPJ02 - Contratação de empresa especializada de engenharia para elaboração de projetos básicos e executivos para ampliação do sistema de esgotamento sanitário nos distritos de Vila Nietzel e Quatituba concluído | milestone | 0d | 2020-02-27 | 2020-02-27 | 1581 |  |  | 2020-02-27 | 2020-02-27 | 0d |  |  | 899d | 0d |  | Verde | Verde | 0% | 0% | Compensatória | Verde | 0% | 0% |  |  |  |  |  |  |  |
| 1583 | 3.1.3.20.1.3.5 | Recurso do estudo de concepção de Itueta do Pleito ITUESPJ02 - Contratação de empresa especializada de engenharia para elaboração de projetos básicos e executivos para ampliação do sistema de esgotamento sanitário nos distritos repassado | milestone | 0d | 2020-03-05 | 2020-03-05 | 1582FS+5d |  |  | 2020-03-05 | 2020-03-05 | 0d |  |  | 899d | 35d |  | Verde | Verde | 0% | 0% | Compensatória | Verde | 0% | 0% |  |  |  |  |  |  |  |
| 1584 | 3.1.3.20.1.4 | **Elaboração do Projeto Básico** |  | 105d | 2019-11-27 | 2020-05-05 |  |  |  | 2019-11-27 | 2020-05-05 | 105d | 2019-07-05 | 2020-01-14 | 827d |  |  | Verde | Verde | 0% | 0% | Compensatória | Verde | 0% | 0% |  |  |  |  |  |  |  |
| 1585 | 3.1.3.20.1.4.1 | Elaborar Projeto Básico |  | 40d | 2019-11-27 | 2020-01-27 | 1579 |  |  | 2019-11-27 | 2020-01-27 | 40d | 2019-07-05 | 2019-10-04 | 827d | 0d |  | Verde | Verde | 0% | 0% | Compensatória | Verde | 0% | 0% |  |  |  | Município |  |  |  |
| 1586 | 3.1.3.20.1.4.2 | Projeto básico de Itueta do Pleito ITUESPJ02 - Contratação de empresa especializada de engenharia para elaboração de projetos básicos e executivos para ampliação do sistema de esgotamento sanitário nos distritos apresentado ao banco | milestone | 0d | 2020-01-27 | 2020-01-27 | 1585 |  |  | 2020-01-27 | 2020-01-27 | 0d | 2019-10-04 | 2019-10-04 | 864d | 0d |  | Verde | Verde | 0% | 0% | Compensatória | Verde | 0% | 0% |  |  |  | Município |  |  |  |
| 1587 | 3.1.3.20.1.4.3 | Analisar projeto básico |  | 60d | 2020-01-28 | 2020-04-27 | 1586 |  |  | 2020-01-28 | 2020-04-27 | 60d | 2019-10-07 | 2019-11-06 | 864d | 0d |  | Verde | Verde | 0% | 0% | Compensatória | Verde | 0% | 0% |  |  |  | Banco |  |  |  |
| 1588 | 3.1.3.20.1.4.4 | Projeto básico de Itueta do Pleito ITUESPJ02 - Contratação de empresa especializada de engenharia para elaboração de projetos básicos e executivos para ampliação do sistema de esgotamento sanitário nos distritos de Vila Nietzel e Quatituba concluído | milestone | 0d | 2020-04-27 | 2020-04-27 | 1583, 1587 |  |  | 2020-04-27 | 2020-04-27 | 0d | 2020-01-07 | 2020-01-07 | 864d | 0d |  | Verde | Verde | 0% | 0% | Compensatória | Verde | 0% | 0% |  |  |  | Município |  |  |  |
| 1589 | 3.1.3.20.1.4.5 | Recurso do projeto básico de Itueta do Pleito ITUESPJ02 - Contratação de empresa especializada de engenharia para elaboração de projetos básicos e executivos para ampliação do sistema de esgotamento sanitário nos distritos repassado | milestone | 0d | 2020-05-05 | 2020-05-05 | 1588FS+5d |  |  | 2020-05-05 | 2020-05-05 | 0d | 2020-01-14 | 2020-01-14 | 864d | 37d |  | Verde | Verde | 0% | 0% | Compensatória | Verde | 0% | 0% |  |  |  | Banco |  |  |  |
| 1590 | 3.1.3.20.1.5 | Realizar Licenciamento Ambiental |  | 120d | 2019-12-30 | 2020-06-24 | 1581FS-40d |  |  | 2019-12-30 | 2020-06-24 | 120d | 2019-10-07 | 2020-04-07 | 829d | 2d |  | Verde | Verde | 0% | 0% | Compensatória | Verde | 0% | 0% |  |  |  | Município |  |  |  |
| 1591 | 3.1.3.20.1.6 | **Elaboração do Projeto Executivo** |  | 105d | 2020-01-30 | 2020-07-03 |  |  |  | 2020-01-30 | 2020-07-03 | 105d | 2019-10-09 | 2020-04-15 | 827d |  |  | Verde | Verde | 0% | 0% | Compensatória | Verde | 0% | 0% |  |  |  |  |  |  |  |
| 1592 | 3.1.3.20.1.6.1 | Elaborar Projeto Executivo |  | 40d | 2020-01-30 | 2020-03-30 | 1585FS+2d |  |  | 2020-01-30 | 2020-03-30 | 40d | 2019-10-09 | 2020-01-07 | 827d | 0d |  | Verde | Verde | 0% | 0% | Compensatória | Verde | 0% | 0% |  |  |  | Município |  |  |  |
| 1593 | 3.1.3.20.1.6.2 | Projeto executivo de Itueta do Pleito ITUESPJ02 - Contratação de empresa especializada de engenharia para elaboração de projetos básicos e executivos para ampliação do sistema de esgotamento sanitário nos distritos apresentado ao banco | milestone | 0d | 2020-03-30 | 2020-03-30 | 1592 |  |  | 2020-03-30 | 2020-03-30 | 0d | 2020-01-07 | 2020-01-07 | 827d | 0d |  | Verde | Verde | 0% | 0% | Compensatória | Verde | 0% | 0% |  |  |  | Município |  |  |  |
| 1594 | 3.1.3.20.1.6.3 | Analisar projeto executivo |  | 60d | 2020-03-31 | 2020-06-26 | 1593 |  |  | 2020-03-31 | 2020-06-26 | 60d | 2020-01-08 | 2020-02-06 | 827d | 0d |  | Verde | Verde | 0% | 0% | Compensatória | Verde | 0% | 0% |  |  |  | Banco |  |  |  |
| 1595 | 3.1.3.20.1.6.4 | Projeto executivo de Itueta do Pleito ITUESPJ02 - Contratação de empresa especializada de engenharia para elaboração de projetos básicos e executivos para ampliação do sistema de esgotamento sanitário nos distritos de Vila Nietzel e Quatituba concluído | milestone | 0d | 2020-06-26 | 2020-06-26 | 1590, 1589, 1594 |  |  | 2020-06-26 | 2020-06-26 | 0d | 2020-04-07 | 2020-04-07 | 827d | 0d |  | Verde | Verde | 0% | 0% | Compensatória | Verde | 0% | 0% |  |  |  | Município |  |  |  |
| 1596 | 3.1.3.20.1.6.5 | Recurso do projeto executivo de Itueta do Pleito ITUESPJ02 - Contratação de empresa especializada de engenharia para elaboração de projetos básicos e executivos para ampliação do sistema de esgotamento sanitário nos distritos repassado | milestone | 0d | 2020-07-03 | 2020-07-03 | 1595FS+5d |  |  | 2020-07-03 | 2020-07-03 | 0d | 2020-04-15 | 2020-04-15 | 827d | 0d |  | Verde | Verde | 0% | 0% | Compensatória | Verde | 0% | 0% |  |  |  | Banco |  |  |  |
| 1597 | 3.1.3.20.1.7 | Pleito ITUESPJ02 - Contratação de empresa especializada de engenharia para elaboração de projetos básicos e executivos para ampliação do sistema de esgotamento sanitário nos distritos de Vila Nietzel e Quatituba de Itueta concluído | milestone | 0d | 2020-07-03 | 2020-07-03 | 1596 |  |  | 2020-07-03 | 2020-07-03 | 0d | 2020-04-15 | 2020-04-15 | 827d | 375d |  | Verde | Verde | 0% | 0% | Compensatória | Verde | 0% | 0% |  |  |  | Município |  |  |  |

Notes:
- 1569: Itueta teve 58,2% dos pleitos de Esgotamento Sanitário aprovado (R$1.550.000,00), conforme Deliberação 75. / O município teve o pleito de resíduos sólidos negado (R$266.111,56), equivalente a 10% do total do recurso,). / Itueta solicitou mudança de pleito, mas ainda não foi autorizado pelo CIF. / ·Alteração do pleito que beneficiava o distrito de Vila Neitzel com SES, uma vez que o mesmo não possui sistema de abastecimento de água. Desta forma o SES seria ineficiente. / ·Solicitaram alteração da obrigatoriedade de direcionamento de 10% da recurso em Resíduos Sólidos para utilizar 100% dos recursos na área de Esgotamento Sanítário no distrito de Quatituba.
- 1571: Em 21/04/2019: pleito foi aprovado na deliberação 269 pelo CIF no dia 28/03/2019
- 1573: 21/05/2019: BDMG enviou a autorização para início do processo licitatório dia 08/04/2019 (planilha de pleitos e situação PG 31)
- 1574: 22/01/19 - Fazendo adequação de projeto com recurso próprio e fazendo alteração de pleito / 31/05/2019: município está elaborando TR e prevê a conclusão do processo licitatório em 3 meses
- 1579: 31/05/2019: município solicitou 2 meses para cada etapa do projeto
- 1585: 31/05/2019: município solicitou 2 meses para cada etapa do projeto
- 1592: 24/05/2019: município pactuou com a Renova 3 meses para elaborar projeto executivo / 31/05/2019: município solicitou 2 meses para cada etapa do projeto

| ID | WBS | Task | Type | Duration | Start | Finish | Predecessors | Complete | Remaining | Baseline start | Baseline finish | Baseline duration | Baseline 1 start | Baseline 1 finish | Total slack | Free slack | Constraint | Text1 | Text2 | Text3 | Text6 | Text8 | Text12 | Text14 | Text16 | Text18 | Text9 | Text5 | Text4 | Text7 | Text15 | Text17 |
| --- | --- | --- | --- | --- | --- | --- | --- | --- | --- | --- | --- | --- | --- | --- | --- | --- | --- | --- | --- | --- | --- | --- | --- | --- | --- | --- | --- | --- | --- | --- | --- | --- |
| 1598 | 3.1.3.20.2 | **Pleito ITUESOB03 - Contratação de empresa para execução de obras de reformas e melhorias na área da estação de tratamento de esgotos e nas estações elevatórias de esgoto da Sede e distrito de Quatituba** |  | 360d | 2019-07-01 | 2020-12-08 |  |  |  | 2019-06-28 | 2020-12-07 | 360d | 2020-04-07 | 2021-09-03 | 718d |  |  | Verde | Verde | 0% | 0% | Compensatória | Verde | 0% | 0% |  |  |  |  |  |  |  |
| 1599 | 3.1.3.20.2.1 | **Aprovação do Projeto Executivo** |  | 60d | 2019-07-01 | 2019-09-24 |  |  |  | 2019-06-28 | 2019-09-23 | 60d |  |  | 718d |  |  | Verde | Verde | 0% | 0% | Compensatória | Verde | 0% | 0% |  |  |  |  |  |  |  |
| 1600 | 3.1.3.20.2.1.1 | Projeto executivo de Itueta do Pleito ITUESOB03 - Contratação de empresa para execução de obras de reformas e melhorias na área da estação de tratamento de esgotos e nas estações elevatórias de esgoto da Sede e distrito de Quatituba apresentado ao banco | milestone | 0d | 2019-07-01 | 2019-07-01 | 3052FS+135d |  |  | 2019-06-28 | 2019-06-28 | 0d |  |  | 718d | 0d |  | Verde | Verde | 0% | 0% | Compensatória | Verde | 0% | 0% |  |  |  |  |  |  |  |
| 1601 | 3.1.3.20.2.1.2 | Analisar projeto executivo |  | 60d | 2019-07-02 | 2019-09-24 | 1600 |  |  | 2019-07-01 | 2019-09-23 | 60d |  |  | 718d | 0d |  | Verde | Verde | 0% | 0% | Compensatória | Verde | 0% | 0% | Critério FR |  |  |  |  |  |  |
| 1602 | 3.1.3.20.2.1.3 | Projeto executivo de Itueta do Pleito ITUESOB03 - Contratação de empresa para execução de obras de reformas e melhorias na área da estação de tratamento de esgotos e nas estações elevatórias de esgoto da Sede e distrito de Quatituba aprovado | milestone | 0d | 2019-09-24 | 2019-09-24 | 1601 |  |  | 2019-09-23 | 2019-09-23 | 0d |  |  | 718d | 0d |  | Verde | Verde | 0% | 0% | Compensatória | Verde | 0% | 0% |  |  |  |  |  |  |  |
| 1603 | 3.1.3.20.2.2 | **Licitação da Obra** |  | 74d | 2019-09-24 | 2020-01-13 |  |  |  | 2019-09-23 | 2020-01-10 | 74d | 2020-04-07 | 2020-07-27 | 718d |  |  | Verde | Verde | 0% | 0% | Compensatória | Verde | 0% | 0% |  |  |  |  |  |  |  |
| 1604 | 3.1.3.20.2.2.1 | Licitação da obra de Itueta do Pleito ITUESOB03 - Contratação de empresa para execução de obras de reformas e melhorias na área da estação de tratamento de esgotos e nas estações elevatórias de esgoto da Sede e distrito de Quatituba autorizada pelo banco | milestone | 0d | 2019-09-24 | 2019-09-24 | 1602 |  |  | 2019-09-23 | 2019-09-23 | 0d | 2020-04-07 | 2020-04-07 | 718d | 0d |  | Verde | Verde | 0% | 0% | Compensatória | Verde | 0% | 0% |  | Banco |  |  |  |  |  |
| 1605 | 3.1.3.20.2.2.2 | Licitar Obra |  | 60d | 2019-09-25 | 2019-12-19 | 1604 |  |  | 2019-09-24 | 2019-12-18 | 60d | 2020-04-08 | 2020-07-07 | 718d | 0d |  | Verde | Verde | 0% | 0% | Compensatória | Verde | 0% | 0% | Critério FR | Município |  |  |  |  |  |
| 1606 | 3.1.3.20.2.2.3 | Analisar e emitir resultado da licitação da obra |  | 14d | 2019-12-20 | 2020-01-13 | 1605 |  |  | 2019-12-19 | 2020-01-10 | 14d | 2020-07-08 | 2020-07-27 | 718d | 0d |  | Verde | Verde | 0% | 0% | Compensatória | Verde | 0% | 0% |  | Banco |  |  |  |  |  |
| 1607 | 3.1.3.20.2.2.4 | Licitação da obra de Itueta do Pleito ITUESOB03 - Contratação de empresa para execução de obras de reformas e melhorias na área da estação de tratamento de esgotos e nas estações elevatórias de esgoto da Sede e distrito de Quatituba concluída | milestone | 0d | 2020-01-13 | 2020-01-13 | 1606 |  |  | 2020-01-10 | 2020-01-10 | 0d | 2020-07-27 | 2020-07-27 | 718d | 0d |  | Verde | Verde | 0% | 0% | Compensatória | Verde | 0% | 0% |  | Município |  |  |  |  |  |
| 1608 | 3.1.3.20.2.3 | Executar obra |  | 80d | 2020-02-12 | 2020-06-10 | 1607FS+21d |  |  | 2020-02-11 | 2020-06-09 | 80d | 2020-08-26 | 2021-02-25 | 718d | 0d |  | Verde | Verde | 0% | 0% | Compensatória | Verde | 0% | 0% |  | Município |  |  |  |  |  |
| 1609 | 3.1.3.20.2.4 | Realizar processo de pré-operação |  | 120d | 2020-06-12 | 2020-12-01 | 1608 |  |  | 2020-06-10 | 2020-11-30 | 120d | 2021-02-26 | 2021-08-27 | 718d | 0d |  | Verde | Verde | 0% | 0% | Compensatória | Verde | 0% | 0% |  | Município |  |  |  |  |  |
| 1610 | 3.1.3.20.2.5 | Recurso da obra de Itueta do Pleito ITUESOB03 - Contratação de empresa para execução de obras de reformas e melhorias na área da estação de tratamento de esgotos e nas estações elevatórias de esgoto da Sede e distrito de Quatituba repassado | milestone | 0d | 2020-12-08 | 2020-12-08 | 1609FS+5d |  |  | 2020-12-07 | 2020-12-07 | 0d | 2021-09-03 | 2021-09-03 | 718d | 0d |  | Verde | Verde | 0% | 0% | Compensatória | Verde | 0% | 0% |  | Banco |  |  |  |  |  |
| 1611 | 3.1.3.20.2.6 | Pleito ITUESOB03 - Contratação de empresa para execução de obras de reformas e melhorias na área da estação de tratamento de esgotos e nas estações elevatórias de esgoto da Sede e distrito de Quatituba de Itueta concluído | milestone | 0d | 2020-12-08 | 2020-12-08 | 1610 |  |  | 2020-12-07 | 2020-12-07 | 0d | 2021-09-03 | 2021-09-03 | 718d | 266d |  | Verde | Verde | 0% | 0% | Compensatória | Verde | 0% | 0% |  | Município |  |  |  |  |  |
| 1612 | 3.1.3.20.3 | **Pleito ITUESOB04 - Contratação de empresa para execução de obras para ampliação da rede coletora de esgoto na sede do município** |  | 425d | 2019-03-28 A | 2020-12-09 |  |  | 425d | 2019-03-28 | 2020-12-08 | 424d | 2019-03-28 | 2020-09-08 | 717d |  |  | Verde | Verde | 10% | 0% | Compensatória | Vermelho | 0% | 0% |  |  | 10 |  |  |  |  |
| 1613 | 3.1.3.20.3.1 | Alteração do Pleito ITUESOB04 - Contratação de empresa para execução de obras para ampliação da rede coletora de esgoto na sede do município de Itueta aprovada | milestone | 0d | 2019-03-28 A | 2019-03-28 A |  | 100% |  | 2019-03-28 | 2019-03-28 | 0d | 2019-03-28 | 2019-03-28 |  |  | must start on 2019-03-28 | Verde | Verde | 100% | 100% | Compensatória | Verde | 100% | 100% |  | CT/CIF | 100 | 100 | 100 | 100 | 100 |
| 1614 | 3.1.3.20.3.2 | **Aprovação do Projeto Executivo** |  | 60d | 2019-07-01 | 2019-09-24 |  |  |  | 2019-06-28 | 2019-09-23 | 60d | 2019-04-05 | 2019-07-05 | 717d |  |  | Verde | Verde | 0% | 0% | Compensatória | Verde | 0% | 0% |  |  |  |  |  |  |  |
| 1615 | 3.1.3.20.3.2.1 | Projeto executivo de Itueta do Pleito ITUESOB04 - Contratação de empresa para execução de obras para ampliação da rede coletora de esgoto na sede do município apresentado ao banco | milestone | 0d | 2019-07-01 | 2019-07-01 | 1613FS+64d |  |  | 2019-06-28 | 2019-06-28 | 0d | 2019-04-05 | 2019-04-05 | 717d | 0d |  | Verde | Verde | 0% | 0% | Compensatória | Verde | 0% | 0% |  | Município |  |  |  |  |  |
| 1616 | 3.1.3.20.3.2.2 | Analisar projeto executivo |  | 60d | 2019-07-02 | 2019-09-24 | 1615 |  |  | 2019-07-01 | 2019-09-23 | 60d | 2019-04-08 | 2019-05-03 | 717d | 0d |  | Verde | Verde | 0% | 0% | Compensatória | Verde | 0% | 0% | Critério FR | Banco |  |  |  |  |  |
| 1617 | 3.1.3.20.3.2.3 | Projeto executivo de Itueta do Pleito ITUESOB04 - Contratação de empresa para execução de obras para ampliação da rede coletora de esgoto na sede do município aprovado | milestone | 0d | 2019-09-24 | 2019-09-24 | 1616 |  |  | 2019-09-23 | 2019-09-23 | 0d | 2019-07-05 | 2019-07-05 | 717d | 0d |  | Verde | Verde | 0% | 0% | Compensatória | Verde | 0% | 0% |  | CT/CIF |  |  |  |  |  |
| 1618 | 3.1.3.20.3.3 | **Licitação da Obra** |  | 74d | 2019-09-24 | 2020-01-13 |  |  |  | 2019-09-23 | 2020-01-10 | 74d | 2019-07-05 | 2019-08-26 | 717d |  |  | Verde | Verde | 0% | 0% | Compensatória | Verde | 0% | 0% |  |  |  |  |  |  |  |
| 1619 | 3.1.3.20.3.3.1 | Licitação da obra de Itueta do Pleito ITUESOB04 - Contratação de empresa para execução de obras para ampliação da rede coletora de esgoto na sede do município autorizada pelo banco | milestone | 0d | 2019-09-24 | 2019-09-24 | 1617 |  |  | 2019-09-23 | 2019-09-23 | 0d | 2019-07-05 | 2019-07-05 | 717d | 0d |  | Verde | Verde | 0% | 0% | Compensatória | Verde | 0% | 0% |  | Banco |  |  |  |  |  |
| 1620 | 3.1.3.20.3.3.2 | Licitar Obra |  | 60d | 2019-09-25 | 2019-12-19 | 1619 |  |  | 2019-09-24 | 2019-12-18 | 60d | 2019-07-08 | 2019-08-05 | 717d | 0d |  | Verde | Verde | 0% | 0% | Compensatória | Verde | 0% | 0% | Critério FR | Município |  |  |  |  |  |
| 1621 | 3.1.3.20.3.3.3 | Analisar e emitir resultado da licitação da obra |  | 14d | 2019-12-20 | 2020-01-13 | 1620 |  |  | 2019-12-19 | 2020-01-10 | 14d | 2019-08-06 | 2019-08-26 | 717d | 0d |  | Verde | Verde | 0% | 0% | Compensatória | Verde | 0% | 0% |  | Banco |  |  |  |  |  |
| 1622 | 3.1.3.20.3.3.4 | Licitação da obra de Itueta do Pleito ITUESOB04 - Contratação de empresa para execução de obras para ampliação da rede coletora de esgoto na sede do município concluída | milestone | 0d | 2020-01-13 | 2020-01-13 | 1621 |  |  | 2020-01-10 | 2020-01-10 | 0d | 2019-08-26 | 2019-08-26 | 717d | 0d |  | Verde | Verde | 0% | 0% | Compensatória | Verde | 0% | 0% |  | Município |  |  |  |  |  |
| 1623 | 3.1.3.20.3.4 | Executar obra |  | 80d | 2020-02-13 | 2020-06-12 | 1622FS+22d |  |  | 2020-02-12 | 2020-06-10 | 80d | 2019-08-27 | 2020-02-27 | 717d | 0d |  | Verde | Verde | 0% | 0% | Compensatória | Verde | 0% | 0% |  | Município |  |  |  |  |  |
| 1624 | 3.1.3.20.3.5 | Realizar processo de pré-operação |  | 120d | 2020-06-15 | 2020-12-02 | 1623 |  |  | 2020-06-12 | 2020-12-01 | 120d | 2020-02-28 | 2020-08-31 | 717d | 0d |  | Verde | Verde | 0% | 0% | Compensatória | Verde | 0% | 0% |  | Município |  |  |  |  |  |
| 1625 | 3.1.3.20.3.6 | Recurso da obra de Itueta do Pleito ITUESOB04 - Contratação de empresa para execução de obras para ampliação da rede coletora de esgoto na sede do município repassado | milestone | 0d | 2020-12-09 | 2020-12-09 | 1624FS+5d |  |  | 2020-12-08 | 2020-12-08 | 0d | 2020-09-08 | 2020-09-08 | 717d | 0d |  | Verde | Verde | 0% | 0% | Compensatória | Verde | 0% | 0% |  | Banco |  |  |  |  |  |
| 1626 | 3.1.3.20.3.7 | Pleito ITUESOB04 - Contratação de empresa para execução de obras para ampliação da rede coletora de esgoto na sede do município de Itueta concluído | milestone | 0d | 2020-12-09 | 2020-12-09 | 1625 |  |  | 2020-12-08 | 2020-12-08 | 0d | 2020-09-08 | 2020-09-08 | 717d | 265d |  | Verde | Verde | 0% | 0% | Compensatória | Verde | 0% | 0% |  | Município |  |  |  |  |  |

Notes:
- 1600: 31/05/2019: município está finalizando o projeto e vai entregar ao banco daqui 1 mês / 01/07/2019: município não entregou o projeto ao banco conforme planilha controle gerencial renova. Atividade reprogramada para o próximo ciclo.
- 1608: 31/05/2019: município falou que precisa de 4 meses para a obra.
- 1613: Em 21/04/2019: pleito foi aprovado na deliberação 269 pelo CIF no dia 28/03/2019
- 1615: 21/05/2019: projeto ainda não foi apresentado ao banco; banco cobrou o projeto por e-mail no dia 13/05/2019. Confirmar com município que dia o projeto será apresentado. / 31/05/2019: município está finalizando o projeto e vai entregar ao banco daqui 1 mês / 01/07/2019: município não entregou o projeto ao banco conforme planilha controle gerencial renova. Atividade reprogramada para o próximo ciclo.
- 1616: Em 29/04/2019: atualizado como agendado
- 1623: 31/05/2019: município falou que precisa de 4 meses para a obra.

| ID | WBS | Task | Type | Duration | Start | Finish | Predecessors | Baseline start | Baseline finish | Baseline duration | Baseline 1 start | Baseline 1 finish | Total slack | Free slack | Text1 | Text2 | Text3 | Text6 | Text8 | Text12 | Text14 | Text16 | Text9 | Text18 |
| --- | --- | --- | --- | --- | --- | --- | --- | --- | --- | --- | --- | --- | --- | --- | --- | --- | --- | --- | --- | --- | --- | --- | --- | --- |
| 1627 | 3.1.3.20.4 | **Pleito ITURSOB02 - Manutenção do aterro sanitário consorciado em Resplendor** |  | 412d | 2019-08-01 | 2021-03-31 |  | 2019-08-01 | 2021-03-31 | 412d | 2019-05-08 | 2021-05-07 | 643d |  | Verde | Verde | 0% | 0% | Compensatória | Verde | 0% | 0% |  |  |
| 1628 | 3.1.3.20.4.1 | **Aprovação do Projeto Executivo** |  | 68d | 2019-08-01 | 2019-11-06 |  | 2019-08-01 | 2019-11-06 | 68d | 2019-05-08 | 2019-08-13 | 643d |  | Verde | Verde | 0% | 0% | Compensatória | Verde | 0% | 0% |  |  |
| 1629 | 3.1.3.20.4.1.1 | Projeto de Itueta do Pleito ITURSOB02 - Manutenção do aterro sanitário consorciado em Resplendor apresentado ao banco | milestone | 0d | 2019-08-01 | 2019-08-01 | 2270FS+18d | 2019-08-01 | 2019-08-01 | 0d | 2019-05-08 | 2019-05-08 | 643d | 0d | Verde | Verde | 0% | 0% | Compensatória | Verde | 0% | 0% | Município |  |
| 1630 | 3.1.3.20.4.1.2 | Analisar projeto |  | 68d | 2019-08-02 | 2019-11-06 | 1629 | 2019-08-02 | 2019-11-06 | 68d | 2019-05-09 | 2019-06-11 | 643d | 0d | Verde | Verde | 0% | 0% | Compensatória | Verde | 0% | 0% | Banco | Critério FR |
| 1631 | 3.1.3.20.4.1.3 | Projeto de Itueta do Pleito ITURSOB02 - Manutenção do aterro sanitário consorciado em Resplendor concluído | milestone | 0d | 2019-11-06 | 2019-11-06 | 1630 | 2019-11-06 | 2019-11-06 | 0d | 2019-08-13 | 2019-08-13 | 643d | 0d | Verde | Verde | 0% | 0% | Compensatória | Verde | 0% | 0% | Município |  |
| 1632 | 3.1.3.20.4.2 | **Licitação da obra** |  | 77d | 2019-11-06 | 2020-03-04 |  | 2019-11-06 | 2020-03-04 | 77d | 2019-08-13 | 2019-12-02 | 643d |  | Verde | Verde | 0% | 0% | Compensatória | Verde | 0% | 0% |  |  |
| 1633 | 3.1.3.20.4.2.1 | Licitação da obra de Itueta do Pleito ITURSOB02 - Manutenção do aterro sanitário consorciado em Resplendor autorizada pelo banco | milestone | 0d | 2019-11-06 | 2019-11-06 | 1631 | 2019-11-06 | 2019-11-06 | 0d | 2019-08-13 | 2019-08-13 | 643d | 0d | Verde | Verde | 0% | 0% | Compensatória | Verde | 0% | 0% | Banco |  |
| 1634 | 3.1.3.20.4.2.2 | Licitar obra |  | 63d | 2019-11-07 | 2020-02-10 | 1633 | 2019-11-07 | 2020-02-10 | 63d | 2019-08-14 | 2019-11-11 | 643d | 0d | Verde | Verde | 0% | 0% | Compensatória | Verde | 0% | 0% | Município |  |
| 1635 | 3.1.3.20.4.2.3 | Analisar e emitir resultado da licitação da obra |  | 14d | 2020-02-11 | 2020-03-04 | 1634 | 2020-02-11 | 2020-03-04 | 14d | 2019-11-12 | 2019-12-02 | 643d | 0d | Verde | Verde | 0% | 0% | Compensatória | Verde | 0% | 0% | Banco |  |
| 1636 | 3.1.3.20.4.2.4 | Licitação da obra de Itueta do Pleito ITURSOB02 - Manutenção do aterro sanitário consorciado em Resplendor concluída | milestone | 0d | 2020-03-04 | 2020-03-04 | 1635 | 2020-03-04 | 2020-03-04 | 0d | 2019-12-02 | 2019-12-02 | 643d | 0d | Verde | Verde | 0% | 0% | Compensatória | Verde | 0% | 0% | Município |  |
| 1637 | 3.1.3.20.4.3 | Executar obra |  | 127d | 2020-04-02 | 2020-10-02 | 1636FS+20d | 2020-04-02 | 2020-10-02 | 127d | 2020-01-06 | 2020-07-09 | 643d | 0d | Verde | Verde | 0% | 0% | Compensatória | Verde | 0% | 0% | Município |  |
| 1638 | 3.1.3.20.4.4 | Realizar processo de pré-operação |  | 120d | 2020-10-05 | 2021-03-31 | 1637 | 2020-10-05 | 2021-03-31 | 120d | 2020-07-10 | 2021-01-13 | 643d | 0d | Verde | Verde | 0% | 0% | Compensatória | Verde | 0% | 0% | Município |  |
| 1639 | 3.1.3.20.4.5 | Recurso da obra de Itueta do Pleito ITURSOB02 - Manutenção do aterro sanitário consorciado em Resplendor repassado | milestone | 0d | 2021-03-31 | 2021-03-31 | 1638, 2281FS+5d | 2021-03-31 | 2021-03-31 | 0d | 2021-05-07 | 2021-05-07 | 643d | 0d | Verde | Verde | 0% | 0% | Compensatória | Verde | 0% | 0% | Banco |  |
| 1640 | 3.1.3.20.4.6 | Pleito ITURSOB02 - Manutenção do aterro sanitário consorciado em Resplendor de Itueta concluído | milestone | 0d | 2021-03-31 | 2021-03-31 | 1639 | 2021-03-31 | 2021-03-31 | 0d | 2021-05-07 | 2021-05-07 | 643d | 191d | Verde | Verde | 0% | 0% | Compensatória | Verde | 0% | 0% | Município |  |
| 1641 | 3.1.3.20.5 | **Pleito de Itueta a definir - Obra Vila Nietzel ou Quatituba** |  | 399d | 2020-05-29 | 2022-01-04 |  | 2020-05-29 | 2022-01-04 | 399d | 2020-05-29 | 2022-01-14 | 452d |  | Verde | Verde | 0% | 0% | Compensatória | Verde | 0% | 0% |  |  |
| 1642 | 3.1.3.20.5.1 | Pleito de Itueta a definir - Obra Vila Nietzel ou Quatituba aprovado | milestone | 0d | 2020-05-29 | 2020-05-29 | 3052FS+362d | 2020-05-29 | 2020-05-29 | 0d | 2020-05-29 | 2020-05-29 | 452d | 0d | Verde | Verde | 0% | 0% | Compensatória | Verde | 0% | 0% | CT/CIF |  |
| 1643 | 3.1.3.20.5.2 | **Licitação da Obra** |  | 80d | 2020-06-15 | 2020-10-06 |  | 2020-06-15 | 2020-10-06 | 80d | 2020-06-15 | 2020-10-06 | 452d |  | Verde | Verde | 0% | 0% | Compensatória | Verde | 0% | 0% |  |  |
| 1644 | 3.1.3.20.5.2.1 | Licitação da obra do Pleito de Itueta a definir - Obra Vila Nietzel ou Quatituba autorizada pelo banco | milestone | 0d | 2020-06-15 | 2020-06-15 | 1642FS+10d | 2020-06-15 | 2020-06-15 | 0d | 2020-06-15 | 2020-06-15 | 452d | 0d | Verde | Verde | 0% | 0% | Compensatória | Verde | 0% | 0% | Banco |  |
| 1645 | 3.1.3.20.5.2.2 | Licitar Obra |  | 66d | 2020-06-16 | 2020-09-16 | 1644 | 2020-06-16 | 2020-09-16 | 66d | 2020-06-16 | 2020-09-16 | 452d | 0d | Verde | Verde | 0% | 0% | Compensatória | Verde | 0% | 0% | Município |  |
| 1646 | 3.1.3.20.5.2.3 | Analisar e emitir resultado da licitação da obra |  | 14d | 2020-09-17 | 2020-10-06 | 1645 | 2020-09-17 | 2020-10-06 | 14d | 2020-09-17 | 2020-10-06 | 452d | 0d | Verde | Verde | 0% | 0% | Compensatória | Verde | 0% | 0% | Banco |  |
| 1647 | 3.1.3.20.5.2.4 | Licitação da obra do Pleito de Itueta a definir - Obra Vila Nietzel ou Quatituba concluída | milestone | 0d | 2020-10-06 | 2020-10-06 | 1646 | 2020-10-06 | 2020-10-06 | 0d | 2020-10-06 | 2020-10-06 | 452d | 0d | Verde | Verde | 0% | 0% | Compensatória | Verde | 0% | 0% | Município |  |
| 1648 | 3.1.3.20.5.3 | Executar obra |  | 164d | 2020-11-06 | 2021-07-06 | 1647FS+20d | 2020-11-06 | 2021-07-06 | 164d | 2020-11-06 | 2021-07-06 | 452d | 0d | Verde | Verde | 0% | 0% | Compensatória | Verde | 0% | 0% | Município |  |
| 1649 | 3.1.3.20.5.4 | Realizar processo de pré-operação |  | 120d | 2021-07-07 | 2021-12-28 | 1648 | 2021-07-07 | 2021-12-28 | 120d | 2021-07-07 | 2022-01-07 | 452d | 0d | Verde | Verde | 0% | 0% | Compensatória | Verde | 0% | 0% | Município |  |
| 1650 | 3.1.3.20.5.5 | Recurso da obra do Pleito de Itueta a definir - Obra Vila Nietzel ou Quatituba repassado | milestone | 0d | 2022-01-04 | 2022-01-04 | 1649FS+5d | 2022-01-04 | 2022-01-04 | 0d | 2022-01-14 | 2022-01-14 | 452d | 0d | Verde | Verde | 0% | 0% | Compensatória | Verde | 0% | 0% | Banco |  |
| 1651 | 3.1.3.20.5.6 | Pleito de Itueta a definir - Obra Vila Nietzel ou Quatituba concluído | milestone | 0d | 2022-01-04 | 2022-01-04 | 1650 | 2022-01-04 | 2022-01-04 | 0d | 2022-01-14 | 2022-01-14 | 452d | 0d | Verde | Verde | 0% | 0% | Compensatória | Verde | 0% | 0% | Município |  |
| 1652 | 3.1.3.20.6 | Recursos de Itueta repassados | milestone | 0d | 2022-01-04 | 2022-01-04 | 1597, 1611, 1640, 1651, 1626 | 2022-01-04 | 2022-01-04 | 0d | 2022-01-14 | 2022-01-14 | 452d |  | Verde | Verde | 0% | 0% | Compensatória | Verde | 0% | 0% | Banco |  |

Notes:
- 1629: 21/05/2019: consórcio ainda irá definir o que fazer com o recurso e irá alterar o pleito
- 1642: Em 23/04/2019: o município poderá enviar pleito de obra após protocolo do projeto executivo no banco (07/01/20) e conforme cronograma da NT 33 o pleito só será analisado em maio.
- 1648: 22/05/2019: valor da obra igual a 90% do teto menos os projetos e obras de ES - 1.719.350,01 - 8 meses
- 1652: Valor de recurso destinado ao munícipio: R$2.661.115,58

| ID | WBS | Task | Type | Duration | Start | Finish | Predecessors | Complete | Remaining | Baseline start | Baseline finish | Baseline duration | Baseline 1 start | Baseline 1 finish | Total slack | Free slack | Text1 | Text2 | Text3 | Text6 | Text7 | Text8 | Text12 | Text14 | Text16 | Text4 | Text5 | Text9 | Text15 | Text17 | Text18 |
| --- | --- | --- | --- | --- | --- | --- | --- | --- | --- | --- | --- | --- | --- | --- | --- | --- | --- | --- | --- | --- | --- | --- | --- | --- | --- | --- | --- | --- | --- | --- | --- |
| 1653 | 3.1.3.21 | **Linhares** |  | 827d | 2019-03-14 A | 2022-07-11 |  | 7% | 767.09d | 2019-03-14 | 2022-06-14 | 809d | 2019-03-14 | 2023-07-28 | 324d |  | Verde | Verde | 6% | 83% | 83 | Compensatória | Vermelho | 6% | 5% |  |  |  |  |  |  |
| 1654 | 3.1.3.21.1 | **Pleito LINESOB09 - Outras obras complementares - SES do distrito de Povoação (obra iniciada e paralisada em 2012)** |  | 559d | 2019-03-25 A | 2021-06-23 |  | 12% | 494.65d | 2019-03-25 | 2021-05-27 | 541d | 2019-03-25 | 2020-10-02 | 586d |  | Verde | Verde | 8% | 112% | 112 | Compensatória | Verde | 8% | 9% | 12 |  |  |  |  |  |
| 1655 | 3.1.3.21.1.1 | Alteração do Pleito LINESOB09 - Outras obras complementares - SES do distrito de Povoação (obra iniciada e paralisada em 2012) de Linhares aprovada | milestone | 0d | 2019-05-28 A | 2019-05-28 A | 3052FS+112d | 100% |  | 2019-05-28 | 2019-05-28 | 0d | 2019-05-31 | 2019-05-31 |  |  | Verde | Verde | 100% | 100% | 100 | Compensatória | Verde | 100% | 100% | 100 | 100 | CT/CIF | 100 | 100 |  |
| 1656 | 3.1.3.21.1.2 | **Aprovação do Projeto** |  | 126d | 2019-05-07 A | 2019-11-01 |  | 25% | 94.5d | 2019-05-07 | 2019-11-01 | 126d | 2019-05-06 | 2019-06-24 | 604d |  | Verde | Verde | 14% | 179% | 179 | Compensatória | Verde | 14% | 25% | 25 | 14 |  | 14 | 25 |  |
| 1657 | 3.1.3.21.1.2.1 | Informações complementares do projeto de Linhares do Pleito LINESOB09 - Outras obras complementares - SES do distrito de Povoação (obra iniciada e paralisada em 2012) protocoladas no banco | milestone | 0d | 2019-05-07 A | 2019-05-07 A | 3052FS+97d | 100% |  | 2019-05-07 | 2019-05-07 | 0d | 2019-05-06 | 2019-05-06 |  |  | Verde | Verde | 100% | 100% | 100 | Compensatória | Verde | 100% | 100% | 100 | 100 | Município | 100 | 100 |  |
| 1658 | 3.1.3.21.1.2.2 | Analisar projeto |  | 126d | 2019-05-08 A | 2019-11-01 | 1657 | 25% | 94.5d | 2019-05-08 | 2019-11-01 | 126d | 2019-05-06 | 2019-06-04 | 604d | 0d | Verde | Verde | 14% | 179% | 179 | Compensatória | Verde | 14% | 25% | 25 | 14 | Banco | 14 | 25 | Conforme agendado |
| 1659 | 3.1.3.21.1.2.3 | Projeto de Linhares do Pleito LINESOB09 - Outras obras complementares - SES do distrito de Povoação (obra iniciada e paralisada em 2012) aprovado | milestone | 0d | 2019-11-01 | 2019-11-01 | 1658, 1661, 1660 |  |  | 2019-11-01 | 2019-11-01 | 0d | 2019-06-24 | 2019-06-24 | 604d | 18d | Verde | Verde | 0% | 0% |  | Compensatória | Verde | 0% | 0% |  |  | Município |  |  |  |
| 1660 | 3.1.3.21.1.3 | Regularizar terreno |  | 135d | 2019-03-25 A | 2019-10-04 | 1655FS-46d | 25% | 101.25d | 2019-03-25 | 2019-10-04 | 135d | 2019-03-25 | 2019-06-24 | 624d | 20d | Verde | Verde | 34% | 71% | 71 | Compensatória | Vermelho | 34% | 24% | 25 | 34 | Município | 34 | 24 | Conforme agendado |
| 1661 | 3.1.3.21.1.4 | Realizar Licenciamento Ambiental |  | 135d | 2019-03-25 A | 2019-10-04 | 1655FS-46d | 25% | 101.25d | 2019-03-25 | 2019-10-04 | 135d | 2019-03-25 | 2019-06-24 | 624d | 20d | Verde | Verde | 34% | 71% | 71 | Compensatória | Vermelho | 34% | 24% | 25 | 34 | Município | 34 | 24 | Conforme agendado |
| 1662 | 3.1.3.21.1.5 | **Licitação da Obra** |  | 104d | 2019-07-03 | 2019-11-28 |  |  |  | 2019-06-06 | 2019-11-01 | 104d | 2019-05-06 | 2019-06-24 | 586d |  | Verde | Verde | 0% | 0% |  | Compensatória | Verde | 0% | 0% |  |  |  |  |  |  |
| 1663 | 3.1.3.21.1.5.1 | Licitação da obra de Linhares do Pleito LINESOB09 - Outras obras complementares - SES do distrito de Povoação (obra iniciada e paralisada em 2012) apresentada ao banco | milestone | 0d | 2019-07-03 | 2019-07-03 | 1657FS+40d |  |  | 2019-06-06 | 2019-06-06 | 0d | 2019-05-06 | 2019-05-06 | 586d | 0d | Verde | Verde | 0% | 0% |  | Compensatória | Verde | 0% | 0% |  |  | Município |  |  |  |
| 1664 | 3.1.3.21.1.5.2 | Analisar e emitir resultado da licitação do projeto |  | 104d | 2019-07-04 | 2019-11-28 | 1663 |  |  | 2019-06-07 | 2019-11-01 | 104d | 2019-05-06 | 2019-05-23 | 586d | 0d | Verde | Verde | 0% | 0% |  | Compensatória | Verde | 0% | 0% |  |  | Banco |  |  | Critério FR |
| 1665 | 3.1.3.21.1.5.3 | Licitação da obra de Linhares do Pleito LINESOB09 - Outras obras complementares - SES do distrito de Povoação (obra iniciada e paralisada em 2012) concluída | milestone | 0d | 2019-11-28 | 2019-11-28 | 1664, 1659, 1663 |  |  | 2019-11-01 | 2019-11-01 | 0d | 2019-06-24 | 2019-06-24 | 586d | 0d | Verde | Verde | 0% | 0% |  | Compensatória | Verde | 0% | 0% |  |  | Município |  |  |  |
| 1666 | 3.1.3.21.1.6 | Executar obra |  | 240d | 2020-01-03 | 2020-12-17 | 1665FS+21d |  |  | 2019-12-04 | 2020-11-23 | 240d | 2019-07-24 | 2020-03-25 | 586d | 0d | Verde | Verde | 0% | 0% |  | Compensatória | Verde | 0% | 0% |  |  | Município |  |  |  |
| 1667 | 3.1.3.21.1.7 | Realizar processo de pré-operação |  | 120d | 2020-12-18 | 2021-06-16 | 1666 |  |  | 2020-11-24 | 2021-05-20 | 120d | 2020-03-26 | 2020-09-25 | 586d | 0d | Verde | Verde | 0% | 0% |  | Compensatória | Verde | 0% | 0% |  |  | Município |  |  |  |
| 1668 | 3.1.3.21.1.8 | Recurso da obra de Linhares do Pleito LINESOB09 - Outras obras complementares - SES do distrito de Povoação (obra iniciada e paralisada em 2012) repassado | milestone | 0d | 2021-06-23 | 2021-06-23 | 1667FS+5d |  |  | 2021-05-27 | 2021-05-27 | 0d | 2020-10-02 | 2020-10-02 | 586d | 0d | Verde | Verde | 0% | 0% |  | Compensatória | Verde | 0% | 0% |  |  | Banco |  |  |  |
| 1669 | 3.1.3.21.1.9 | Pleito LINESOB09 - Outras obras complementares - SES do distrito de Povoação (obra iniciada e paralisada em 2012) de Linhares concluído | milestone | 0d | 2021-06-23 | 2021-06-23 | 1668 |  |  | 2021-05-27 | 2021-05-27 | 0d | 2020-10-02 | 2020-10-02 | 586d | 262d | Verde | Verde | 0% | 0% |  | Compensatória | Verde | 0% | 0% |  |  | Município |  |  |  |
| 1670 | 3.1.3.21.2 | **Pleito LINESOB10 - Outras obras complementares - SES do distrito de Regência (obra iniciada e paralisada em 2012)** |  | 559d | 2019-03-25 A | 2021-06-23 |  | 12% | 494.65d | 2019-03-25 | 2021-05-27 | 541d | 2019-03-25 | 2020-10-02 | 586d |  | Verde | Verde | 8% | 100% | 100 | Compensatória | Verde | 7% | 7% | 12 |  |  |  |  |  |
| 1671 | 3.1.3.21.2.1 | Alteração de Linhares do Pleito LINESOB10 - Outras obras complementares - SES do distrito de Regência (obra iniciada e paralisada em 2012) aprovada | milestone | 0d | 2019-05-28 A | 2019-05-28 A | 3052FS+112d | 100% |  | 2019-05-28 | 2019-05-28 | 0d | 2019-05-31 | 2019-05-31 |  |  | Verde | Verde | 100% | 100% | 100 | Compensatória | Verde | 100% | 100% | 100 | 100 | CT/CIF | 100 | 100 |  |
| 1672 | 3.1.3.21.2.2 | **Aprovação do Projeto** |  | 126d | 2019-05-07 A | 2019-11-01 |  | 25% | 94.5d | 2019-05-07 | 2019-11-01 | 126d | 2019-05-06 | 2019-06-24 | 604d |  | Verde | Verde | 14% | 171% | 171 | Compensatória | Verde | 14% | 24% | 25 | 14 |  | 14 | 24 |  |
| 1673 | 3.1.3.21.2.2.1 | Informações complementares do projeto de Linhares do Pleito LINESOB10 - Outras obras complementares - SES do distrito de Regência (obra iniciada e paralisada em 2012) protocoladas no banco | milestone | 0d | 2019-05-07 A | 2019-05-07 A | 3052FS+97d | 100% |  | 2019-05-07 | 2019-05-07 | 0d | 2019-05-06 | 2019-05-06 |  |  | Verde | Verde | 100% | 100% | 100 | Compensatória | Verde | 100% | 100% | 100 | 100 | Município | 100 | 100 |  |
| 1674 | 3.1.3.21.2.2.2 | Analisar projeto |  | 126d | 2019-05-08 A | 2019-11-01 | 1673 | 25% | 94.5d | 2019-05-08 | 2019-11-01 | 126d | 2019-05-06 | 2019-06-04 | 604d | 0d | Verde | Verde | 14% | 171% | 171 | Compensatória | Verde | 14% | 24% | 25 | 14 | Banco | 14 | 24 | Conforme agendado |
| 1675 | 3.1.3.21.2.2.3 | Projeto de Linhares do Pleito LINESOB10 - Outras obras complementares - SES do distrito de Regência (obra iniciada e paralisada em 2012) aprovado | milestone | 0d | 2019-11-01 | 2019-11-01 | 1674, 1677, 1676 |  |  | 2019-11-01 | 2019-11-01 | 0d | 2019-06-24 | 2019-06-24 | 604d | 18d | Verde | Verde | 0% | 0% |  | Compensatória | Verde | 0% | 0% |  |  | Município |  |  |  |
| 1676 | 3.1.3.21.2.3 | Regularizar terreno |  | 135d | 2019-03-25 A | 2019-10-04 | 1671FS-46d | 25% | 101.25d | 2019-03-25 | 2019-10-04 | 135d | 2019-03-25 | 2019-06-24 | 624d | 20d | Verde | Verde | 34% | 68% | 68 | Compensatória | Vermelho | 34% | 23% | 25 | 34 | Município | 34 | 23 | Conforme agendado |
| 1677 | 3.1.3.21.2.4 | Realizar Licenciamento Ambiental |  | 135d | 2019-03-25 A | 2019-10-04 | 1671FS-46d | 25% | 101.25d | 2019-03-25 | 2019-10-04 | 135d | 2019-03-25 | 2019-06-24 | 624d | 20d | Verde | Verde | 34% | 68% | 68 | Compensatória | Vermelho | 34% | 23% | 25 | 34 | Município | 34 | 23 | Conforme agendado |

Notes:
- 1653: Linhares solicitou pediu 51,6% (R$24.628.767,59) dos 90% de recursos destinado para Esgotamento Sanitário e teve todo o pleito aprovado, conforme Deliberação 75. / O pleito de resíduos sólido (10% do total do recurso destinado ao munícipio) foi aprovado.
- 1655: 23/04/2019: O ofício de pleito será analisado na próxima CT e CIF sendo aprovado apenas dia 31/05/2019 / 02/06/2019: alteração do pleito aprovada no dia 28/05/2019 pelo CIF na deliberação 289
- 1657: 31/05/2019: Mônica informou que o município protocolou o projeto no BANDES dia 07/05.
- 1658: 31/05/2019: Mônica informou que o BANDES passou o prazo de 04/06/2019 para finalizar análise e que acha que esse prazo não será cumprido, porque o BANDES ainda não recebeu resultado da alteração do pleito pelo CIF. / 01/07/2019: Está sendo feita a análise dos pleitos pelo Banco e pelo apoio técnico. Segunda -Feira (01/07) haverá uma reunião para discutir sobre o pleito de Complementação da ETE Aviso e até na sexta-feira (05/07) será entregue as análises das ETEs dos distritos de Povoação e Regência.
- 1663: 02/07/2019: município entregou o processo licitatório completo da parte da obra que foi paralisada em 201, mas as obras complementares estão em processo de licitação ainda. Atividade reprogramada para o próximo ciclo.
- 1666: Em 24/04/2019: valor da obra R$ 2,5 milhões / 06/06/2019: valor da obra atualizado R$ 3,8 milhões - 12 meses
- 1671: 02/06/2019: alteração do pleito aprovada no dia 28/05/2019 pelo CIF na deliberação 289
- 1673: 31/05/2019: Mônica informou que o município protocolou o projeto no BANDES dia 07/05.
- 1674: 31/05/2019: Mônica informou que o BANDES passou o prazo de 04/06/2019 para finalizar análise e que acha que esse prazo não será cumprido, porque o BANDES ainda não recebeu resultado da alteração do pleito pelo CIF. / 01/07/2019: Está sendo feita a análise dos pleitos pelo Banco e pelo apoio técnico. Segunda -Feira (01/07) haverá uma reunião para discutir sobre o pleito de Complementação da ETE Aviso e até na sexta-feira (05/07) será entregue as análises das ETEs dos distritos de Povoação e Regência.
- 1676: Em 29/04/2019: atualizado como agendado
- 1677: Em 29/04/2019: atualizado como agendado

| ID | WBS | Task | Type | Duration | Start | Finish | Predecessors | Complete | Remaining | Baseline start | Baseline finish | Baseline duration | Baseline 1 start | Baseline 1 finish | Total slack | Free slack | Text1 | Text2 | Text3 | Text6 | Text8 | Text12 | Text14 | Text16 | Text9 | Text18 | Text4 | Text7 | Text5 | Text15 | Text17 |
| --- | --- | --- | --- | --- | --- | --- | --- | --- | --- | --- | --- | --- | --- | --- | --- | --- | --- | --- | --- | --- | --- | --- | --- | --- | --- | --- | --- | --- | --- | --- | --- |
| 1678 | 3.1.3.21.2.5 | **Licitação da Obra** |  | 104d | 2019-07-03 | 2019-11-28 |  |  |  | 2019-06-06 | 2019-11-01 | 104d | 2019-05-06 | 2019-06-24 | 586d |  | Verde | Verde | 0% | 0% | Compensatória | Verde | 0% | 0% |  |  |  |  |  |  |  |
| 1679 | 3.1.3.21.2.5.1 | Licitação da obra de Linhares do Pleito LINESOB10 - Outras obras complementares - SES do distrito de Regência (obra iniciada e paralisada em 2012) apresentada ao banco | milestone | 0d | 2019-07-03 | 2019-07-03 | 1673FS+40d |  |  | 2019-06-06 | 2019-06-06 | 0d | 2019-05-06 | 2019-05-06 | 586d | 0d | Verde | Verde | 0% | 0% | Compensatória | Verde | 0% | 0% | Município |  |  |  |  |  |  |
| 1680 | 3.1.3.21.2.5.2 | Analisar e emitir resultado da licitação do projeto |  | 104d | 2019-07-04 | 2019-11-28 | 1679 |  |  | 2019-06-07 | 2019-11-01 | 104d | 2019-05-06 | 2019-05-23 | 586d | 0d | Verde | Verde | 0% | 0% | Compensatória | Verde | 0% | 0% | Banco | Critério FR |  |  |  |  |  |
| 1681 | 3.1.3.21.2.5.3 | Licitação da obra de Linhares do Pleito LINESOB10 - Outras obras complementares - SES do distrito de Regência (obra iniciada e paralisada em 2012) concluída | milestone | 0d | 2019-11-28 | 2019-11-28 | 1680, 1675 |  |  | 2019-11-01 | 2019-11-01 | 0d | 2019-06-24 | 2019-06-24 | 586d | 0d | Verde | Verde | 0% | 0% | Compensatória | Verde | 0% | 0% | Município |  |  |  |  |  |  |
| 1682 | 3.1.3.21.2.6 | Executar obra |  | 240d | 2020-01-03 | 2020-12-17 | 1681FS+21d |  |  | 2019-12-04 | 2020-11-23 | 240d | 2019-07-24 | 2020-03-25 | 586d | 0d | Verde | Verde | 0% | 0% | Compensatória | Verde | 0% | 0% | Município |  |  |  |  |  |  |
| 1683 | 3.1.3.21.2.7 | Realizar processo de pré-operação |  | 120d | 2020-12-18 | 2021-06-16 | 1682 |  |  | 2020-11-24 | 2021-05-20 | 120d | 2020-03-26 | 2020-09-25 | 586d | 0d | Verde | Verde | 0% | 0% | Compensatória | Verde | 0% | 0% | Município |  |  |  |  |  |  |
| 1684 | 3.1.3.21.2.8 | Recurso da obra de Linhares do Pleito LINESOB10 - Outras obras complementares - SES do distrito de Regência (obra iniciada e paralisada em 2012) repassado | milestone | 0d | 2021-06-23 | 2021-06-23 | 1683FS+5d |  |  | 2021-05-27 | 2021-05-27 | 0d | 2020-10-02 | 2020-10-02 | 586d | 0d | Verde | Verde | 0% | 0% | Compensatória | Verde | 0% | 0% | Banco |  |  |  |  |  |  |
| 1685 | 3.1.3.21.2.9 | Pleito LINESOB10 - Outras obras complementares - SES do distrito de Regência (obra iniciada e paralisada em 2012) de Linhares concluído | milestone | 0d | 2021-06-23 | 2021-06-23 | 1684 |  |  | 2021-05-27 | 2021-05-27 | 0d | 2020-10-02 | 2020-10-02 | 586d | 262d | Verde | Verde | 0% | 0% | Compensatória | Verde | 0% | 0% | Município |  |  |  |  |  |  |
| 1686 | 3.1.3.21.3 | **Pleito LINESOB12 - Contratação de empresa para conclusão da implantação e recuperação das obras já executadas do SES do distrito de Pontal do Ipiranga** |  | 679d | 2019-03-25 A | 2021-12-14 |  | 10% | 610.41d | 2019-03-25 | 2021-11-18 | 661d | 2019-03-25 | 2020-10-02 | 466d |  | Verde | Verde | 7% | 88% | Compensatória | Vermelho | 8% | 7% |  |  | 10 | 88 |  |  |  |
| 1687 | 3.1.3.21.3.1 | Alteração do Pleito LINESOB12 - Contratação de empresa para conclusão da implantação e recuperação das obras já executadas do SES do distrito de Pontal do Ipiranga de Linhares aprovada | milestone | 0d | 2019-05-28 A | 2019-05-28 A | 3052FS+112d | 100% |  | 2019-05-28 | 2019-05-28 | 0d | 2019-05-31 | 2019-05-31 |  |  | Verde | Verde | 100% | 100% | Compensatória | Verde | 100% | 100% | CT/CIF |  | 100 | 100 | 100 | 100 | 100 |
| 1688 | 3.1.3.21.3.2 | **Aprovação do Projeto** |  | 126d | 2019-05-07 A | 2019-11-01 |  | 25% | 94.5d | 2019-05-07 | 2019-11-01 | 126d | 2019-05-06 | 2019-06-24 | 484d |  | Verde | Verde | 14% | 171% | Compensatória | Verde | 14% | 24% |  |  | 25 | 171 | 14 | 14 | 24 |
| 1689 | 3.1.3.21.3.2.1 | Informações complementares do projeto de Linhares do Pleito LINESOB12 - Contratação de empresa para conclusão da implantação e recuperação das obras já executadas do SES do distrito de Pontal do Ipiranga protocoladas no banco | milestone | 0d | 2019-05-07 A | 2019-05-07 A | 3052FS+97d | 100% |  | 2019-05-07 | 2019-05-07 | 0d | 2019-05-06 | 2019-05-06 |  |  | Verde | Verde | 100% | 100% | Compensatória | Verde | 100% | 100% | Município |  | 100 | 100 | 100 | 100 | 100 |
| 1690 | 3.1.3.21.3.2.2 | Analisar projeto |  | 126d | 2019-05-08 A | 2019-11-01 | 1689 | 25% | 94.5d | 2019-05-08 | 2019-11-01 | 126d | 2019-05-06 | 2019-06-04 | 484d | 0d | Verde | Verde | 14% | 171% | Compensatória | Verde | 14% | 24% | Banco | Conforme agendado | 25 | 171 | 14 | 14 | 24 |
| 1691 | 3.1.3.21.3.2.3 | Projeto de Linhares do Pleito LINESOB12 - Contratação de empresa para conclusão da implantação e recuperação das obras já executadas do SES do distrito de Pontal do Ipiranga aprovado | milestone | 0d | 2019-11-01 | 2019-11-01 | 1690, 1692, 1693 |  |  | 2019-11-01 | 2019-11-01 | 0d | 2019-06-24 | 2019-06-24 | 484d | 18d | Verde | Verde | 0% | 0% | Compensatória | Verde | 0% | 0% | Município |  |  |  |  |  |  |
| 1692 | 3.1.3.21.3.3 | Regularizar terreno |  | 135d | 2019-03-25 A | 2019-10-04 | 1687FS-46d | 25% | 101.25d | 2019-03-25 | 2019-10-04 | 135d | 2019-03-25 | 2019-06-24 | 504d | 20d | Verde | Verde | 34% | 74% | Compensatória | Vermelho | 34% | 25% | Município | Conforme agendado | 25 | 74 | 34 | 34 | 25 |
| 1693 | 3.1.3.21.3.4 | Realizar Licenciamento Ambiental |  | 135d | 2019-03-25 A | 2019-10-04 | 1687FS-46d | 25% | 101.25d | 2019-03-25 | 2019-10-04 | 135d | 2019-03-25 | 2019-06-24 | 504d | 20d | Verde | Verde | 34% | 74% | Compensatória | Vermelho | 34% | 25% | Município | Conforme agendado | 25 | 74 | 34 | 34 | 25 |
| 1694 | 3.1.3.21.3.5 | **Licitação da Obra** |  | 104d | 2019-07-03 | 2019-11-28 |  |  |  | 2019-06-06 | 2019-11-01 | 104d | 2019-05-06 | 2019-06-24 | 466d |  | Verde | Verde | 0% | 0% | Compensatória | Verde | 0% | 0% |  |  |  |  |  |  |  |
| 1695 | 3.1.3.21.3.5.1 | Licitação da obra de Linhares do Pleito LINESOB12 - Contratação de empresa para conclusão da implantação e recuperação das obras já executadas do SES do distrito de Pontal do Ipiranga apresentada ao banco | milestone | 0d | 2019-07-03 | 2019-07-03 | 1689FS+40d |  |  | 2019-06-06 | 2019-06-06 | 0d | 2019-05-06 | 2019-05-06 | 466d | 0d | Verde | Verde | 0% | 0% | Compensatória | Verde | 0% | 0% | Município |  |  |  |  |  |  |
| 1696 | 3.1.3.21.3.5.2 | Analisar e emitir resultado da licitação do projeto |  | 104d | 2019-07-04 | 2019-11-28 | 1695 |  |  | 2019-06-07 | 2019-11-01 | 104d | 2019-05-06 | 2019-05-23 | 466d | 0d | Verde | Verde | 0% | 0% | Compensatória | Verde | 0% | 0% | Banco | Critério FR |  |  |  |  |  |
| 1697 | 3.1.3.21.3.5.3 | Licitação da obra de Linhares do Pleito LINESOB12 - Contratação de empresa para conclusão da implantação e recuperação das obras já executadas do SES do distrito de Pontal do Ipiranga concluída | milestone | 0d | 2019-11-28 | 2019-11-28 | 1696, 1691 |  |  | 2019-11-01 | 2019-11-01 | 0d | 2019-06-24 | 2019-06-24 | 466d | 0d | Verde | Verde | 0% | 0% | Compensatória | Verde | 0% | 0% | Município |  |  |  |  |  |  |
| 1698 | 3.1.3.21.3.6 | Executar obra |  | 360d | 2020-01-03 | 2021-06-16 | 1697FS+21d |  |  | 2019-12-04 | 2021-05-20 | 360d | 2019-07-24 | 2020-03-25 | 466d | 0d | Verde | Verde | 0% | 0% | Compensatória | Verde | 0% | 0% | Município |  |  |  |  |  |  |
| 1699 | 3.1.3.21.3.7 | Realizar processo de pré-operação |  | 120d | 2021-06-17 | 2021-12-07 | 1698 |  |  | 2021-05-21 | 2021-11-10 | 120d | 2020-03-26 | 2020-09-25 | 466d | 0d | Verde | Verde | 0% | 0% | Compensatória | Verde | 0% | 0% | Município |  |  |  |  |  |  |
| 1700 | 3.1.3.21.3.8 | Recurso da obra de Linhares do Pleito LINESOB12 - Contratação de empresa para conclusão da implantação e recuperação das obras já executadas do SES do distrito de Pontal do Ipiranga repassado | milestone | 0d | 2021-12-14 | 2021-12-14 | 1699FS+5d |  |  | 2021-11-18 | 2021-11-18 | 0d | 2020-10-02 | 2020-10-02 | 466d | 0d | Verde | Verde | 0% | 0% | Compensatória | Verde | 0% | 0% | Banco |  |  |  |  |  |  |
| 1701 | 3.1.3.21.3.9 | Pleito LINESOB12 - Contratação de empresa para conclusão da implantação e recuperação das obras já executadas do SES do distrito de Pontal do Ipiranga de Linhares concluído | milestone | 0d | 2021-12-14 | 2021-12-14 | 1700 |  |  | 2021-11-18 | 2021-11-18 | 0d | 2020-10-02 | 2020-10-02 | 466d | 142d | Verde | Verde | 0% | 0% | Compensatória | Verde | 0% | 0% | Município |  |  |  |  |  |  |

Notes:
- 1679: 02/07/2019: município entregou o processo licitatório completo da parte da obra que foi paralisada em 201, mas as obras complementares estão em processo de licitação ainda. Atividade reprogramada para o próximo ciclo.
- 1687: 02/06/2019: alteração do pleito aprovada no dia 28/05/2019 pelo CIF na deliberação 289
- 1689: 31/05/2019: Mônica informou que o município protocolou o projeto no BANDES dia 07/05.
- 1690: 31/05/2019: Mônica informou que o BANDES passou o prazo de 04/06/2019 para finalizar análise e que acha que esse prazo não será cumprido, porque o BANDES ainda não recebeu resultado da alteração do pleito pelo CIF. / 01/07/2019: Está sendo feita a análise dos pleitos pelo Banco e pelo apoio técnico. Segunda -Feira (01/07) haverá uma reunião para discutir sobre o pleito de Complementação da ETE Aviso e até na sexta-feira (05/07) será entregue as análises das ETEs dos distritos de Povoação e Regência.
- 1692: Em 29/04/2019: atualizado como agendado
- 1693: Em 29/04/2019: atualizado como agendado
- 1695: 02/07/2019: Mônica informou que o município ainda não apresentou o processo licitatório ao banco. Atividade reprogramada para o próximo ciclo.
- 1698: 22/05/2019: premissa de obra ajustada - valor da obra 5.000.000,00 - 1 ano; com a alteração do pleito o valor da obra será de R$8.406.298,23 e a premissa será alterada para 18 meses

| ID | WBS | Task | Type | Duration | Start | Finish | Predecessors | Complete | Remaining | Baseline start | Baseline finish | Baseline duration | Baseline 1 start | Baseline 1 finish | Total slack | Free slack | Text1 | Text2 | Text3 | Text6 | Text8 | Text12 | Text14 | Text16 | Text4 | Text5 | Text7 | Text9 | Text15 | Text17 | Text18 |
| --- | --- | --- | --- | --- | --- | --- | --- | --- | --- | --- | --- | --- | --- | --- | --- | --- | --- | --- | --- | --- | --- | --- | --- | --- | --- | --- | --- | --- | --- | --- | --- |
| 1702 | 3.1.3.21.4 | **Pleito LINESOB13 - Execução da obra de sistema de esgotamento sanitário na localidade de Baixo Quartel** |  | 435d | 2019-05-28 A | 2021-02-26 |  |  | 433.55d | 2019-05-28 | 2021-02-26 | 435d | 2019-05-31 | 2023-07-28 | 666d |  | Verde | Verde | 0% | 0% | Compensatória | Verde | 0% | 0% |  |  |  |  |  |  |  |
| 1703 | 3.1.3.21.4.1 | Pleito LINESOB13 - Execução da obra de sistema de esgotamento sanitário na localidade de Baixo Quartel de Linhares aprovado | milestone | 0d | 2019-05-28 A | 2019-05-28 A | 3052FS+112d | 100% |  | 2019-05-28 | 2019-05-28 | 0d | 2019-05-31 | 2019-05-31 |  |  | Verde | Verde | 100% | 100% | Compensatória | Verde | 100% | 100% | 100 | 100 | 100 | CT/CIF | 100 | 100 |  |
| 1704 | 3.1.3.21.4.2 | Iniciar tarefas do Pleito LINESOB13 |  | 1d | 2019-06-06 A | 2019-06-06 A | 1703FS+6d | 100% |  | 2019-06-06 | 2019-06-06 | 1d | 2019-06-17 | 2019-06-17 |  |  | Verde | Verde | 0% | 0% | Compensatória | Verde | 0% | 0% |  |  |  | Município |  |  | Critério FR |
| 1705 | 3.1.3.21.4.3 | Executar obra |  | 180d | 2019-12-02 | 2020-08-24 | 1704FS+123d |  |  | 2019-12-02 | 2020-08-24 | 180d |  |  | 666d | 0d | Verde | Verde | 0% | 0% | Compensatória | Verde | 0% | 0% |  |  |  |  |  |  |  |
| 1706 | 3.1.3.21.4.4 | Realizar pré-operação |  | 120d | 2020-08-25 | 2021-02-19 | 1705 |  |  | 2020-08-25 | 2021-02-19 | 120d |  |  | 666d | 0d | Verde | Verde | 0% | 0% | Compensatória | Verde | 0% | 0% |  |  |  |  |  |  |  |
| 1707 | 3.1.3.21.4.5 | Recuso da obra de Linhares do Pleito LINESOB13 - Execução da obra de sistema de esgotamento sanitário na localidade de Baixo Quartel de Linhares repassado | milestone | 0d | 2021-02-26 | 2021-02-26 | 1706FS+5d |  |  | 2021-02-26 | 2021-02-26 | 0d |  |  | 666d | 0d | Verde | Verde | 0% | 0% | Compensatória | Verde | 0% | 0% |  |  |  |  |  |  |  |
| 1708 | 3.1.3.21.4.6 | Pleito LINESOB13 - Execução da obra de sistema de esgotamento sanitário na localidade de Baixo Quartel de Linhares concluído | milestone | 0d | 2021-02-26 | 2021-02-26 | 1707 |  |  | 2021-02-26 | 2021-02-26 | 0d | 2023-07-28 | 2023-07-28 | 666d | 342d | Verde | Verde | 0% | 0% | Compensatória | Verde | 0% | 0% |  |  |  | Município |  |  |  |
| 1709 | 3.1.3.21.5 | **Pleito LINESOB14 - Execução de obra de sistema de esgotamento sanitário na localidade de Vila Bagueira** |  | 435d | 2019-05-28 A | 2021-02-26 |  |  | 433.55d | 2019-05-28 | 2021-02-26 | 435d |  |  | 666d |  | Verde | Verde | 0% | 0% | Compensatória | Verde | 0% | 0% |  |  |  |  |  |  |  |
| 1710 | 3.1.3.21.5.1 | Pleito LINESOB14 - Execução de obra de sistema de esgotamento sanitário na localidade de Vila Bagueira de Linhares aprovado | milestone | 0d | 2019-05-28 A | 2019-05-28 A | 3052FS+112d | 100% |  | 2019-05-28 | 2019-05-28 | 0d |  |  |  |  | Verde | Verde | 100% | 100% | Compensatória | Verde | 100% | 100% | 100 | 100 | 100 |  | 100 | 100 |  |
| 1711 | 3.1.3.21.5.2 | Iniciar tarefas do Pleito LINESOB14 |  | 1d | 2019-06-06 A | 2019-06-06 A | 1710FS+6d | 100% |  | 2019-06-06 | 2019-06-06 | 1d |  |  |  |  | Verde | Verde | 0% | 0% | Compensatória | Verde | 0% | 0% |  |  |  |  |  |  |  |
| 1712 | 3.1.3.21.5.3 | Executar obra |  | 180d | 2019-12-02 | 2020-08-24 | 1711FS+123d |  |  | 2019-12-02 | 2020-08-24 | 180d |  |  | 666d | 0d | Verde | Verde | 0% | 0% | Compensatória | Verde | 0% | 0% |  |  |  |  |  |  |  |
| 1713 | 3.1.3.21.5.4 | Realizar pré-operação |  | 120d | 2020-08-25 | 2021-02-19 | 1712 |  |  | 2020-08-25 | 2021-02-19 | 120d |  |  | 666d | 0d | Verde | Verde | 0% | 0% | Compensatória | Verde | 0% | 0% |  |  |  |  |  |  |  |
| 1714 | 3.1.3.21.5.5 | Recurso da obra de Linhares do Pleito LINESOB14 - Execução de obra de sistema de esgotamento sanitário na localidade de Vila Bagueira de Linhares repasado | milestone | 0d | 2021-02-26 | 2021-02-26 | 1713FS+5d |  |  | 2021-02-26 | 2021-02-26 | 0d |  |  | 666d | 0d | Verde | Verde | 0% | 0% | Compensatória | Verde | 0% | 0% |  |  |  |  |  |  |  |
| 1715 | 3.1.3.21.5.6 | Pleito LINESOB14 - Execução de obra de sistema de esgotamento sanitário na localidade de Vila Bagueira de Linhares concluído | milestone | 0d | 2021-02-26 | 2021-02-26 | 1714 |  |  | 2021-02-26 | 2021-02-26 | 0d |  |  | 666d | 342d | Verde | Verde | 0% | 0% | Compensatória | Verde | 0% | 0% |  |  |  |  |  |  |  |
| 1716 | 3.1.3.21.6 | **Pleito LINESOB15 - Execução de obra de sistema de esgotamento sanitário na localidade de Humaitá, Distrito de São Rafael** |  | 435d | 2019-05-28 A | 2021-02-26 |  |  | 433.55d | 2019-05-28 | 2021-02-26 | 435d |  |  | 666d |  | Verde | Verde | 0% | 0% | Compensatória | Verde | 0% | 0% |  |  |  |  |  |  |  |
| 1717 | 3.1.3.21.6.1 | Pleito LINESOB15 - Execução de obra de sistema de esgotamento sanitário na localidade de Humaitá, Distrito de São Rafael de Linhares aprovado | milestone | 0d | 2019-05-28 A | 2019-05-28 A | 3052FS+112d | 100% |  | 2019-05-28 | 2019-05-28 | 0d |  |  |  |  | Verde | Verde | 100% | 100% | Compensatória | Verde | 100% | 100% | 100 | 100 | 100 |  | 100 | 100 |  |
| 1718 | 3.1.3.21.6.2 | Iniciar tarefas do Pleito LINESOB15 |  | 1d | 2019-06-06 A | 2019-06-06 A | 1717FS+6d | 100% |  | 2019-06-06 | 2019-06-06 | 1d |  |  |  |  | Verde | Verde | 0% | 0% | Compensatória | Verde | 0% | 0% |  |  |  |  |  |  |  |
| 1719 | 3.1.3.21.6.3 | Executar obra |  | 180d | 2019-12-02 | 2020-08-24 | 1718FS+123d |  |  | 2019-12-02 | 2020-08-24 | 180d |  |  | 666d | 0d | Verde | Verde | 0% | 0% | Compensatória | Verde | 0% | 0% |  |  |  |  |  |  |  |
| 1720 | 3.1.3.21.6.4 | Realizar pré-operação |  | 120d | 2020-08-25 | 2021-02-19 | 1719 |  |  | 2020-08-25 | 2021-02-19 | 120d |  |  | 666d | 0d | Verde | Verde | 0% | 0% | Compensatória | Verde | 0% | 0% |  |  |  |  |  |  |  |
| 1721 | 3.1.3.21.6.5 | Recurso da obra do Pleito LINESOB15 - Execução de obra de sistema de esgotamento sanitário na localidade de Humaitá, Distrito de São Rafael de Linhares repassado | milestone | 0d | 2021-02-26 | 2021-02-26 | 1720FS+5d |  |  | 2021-02-26 | 2021-02-26 | 0d |  |  | 666d | 0d | Verde | Verde | 0% | 0% | Compensatória | Verde | 0% | 0% |  |  |  |  |  |  |  |
| 1722 | 3.1.3.21.6.6 | Pleito LINESOB15 - Execução de obra de sistema de esgotamento sanitário na localidade de Humaitá, Distrito de São Rafael de Linhares concluído | milestone | 0d | 2021-02-26 | 2021-02-26 | 1721 |  |  | 2021-02-26 | 2021-02-26 | 0d |  |  | 666d | 342d | Verde | Verde | 0% | 0% | Compensatória | Verde | 0% | 0% |  |  |  |  |  |  |  |
| 1723 | 3.1.3.21.7 | **Pleito LINESOB16 - Execução de obra de esgotamento sanitario na localidade de Chapadão das Palminhas, Distrito de São Rafael** |  | 435d | 2019-05-28 A | 2021-02-26 |  |  | 433.55d | 2019-05-28 | 2021-02-26 | 435d |  |  | 666d |  | Verde | Verde | 0% | 0% | Compensatória | Verde | 0% | 0% |  |  |  |  |  |  |  |
| 1724 | 3.1.3.21.7.1 | Pleito LINESOB16 - Execução de obra de esgotamento sanitario na localidade de Chapadão das Palminhas, Distrito de São Rafael de Linhares aprovado | milestone | 0d | 2019-05-28 A | 2019-05-28 A | 3052FS+112d | 100% |  | 2019-05-28 | 2019-05-28 | 0d |  |  |  |  | Verde | Verde | 100% | 100% | Compensatória | Verde | 100% | 100% | 100 | 100 | 100 |  | 100 | 100 |  |
| 1725 | 3.1.3.21.7.2 | Iniciar tarefas do Pleito LINESOB16 |  | 1d | 2019-06-06 A | 2019-06-06 A | 1724FS+6d | 100% |  | 2019-06-06 | 2019-06-06 | 1d |  |  |  |  | Verde | Verde | 0% | 0% | Compensatória | Verde | 0% | 0% |  |  |  |  |  |  |  |
| 1726 | 3.1.3.21.7.3 | Executar obra |  | 180d | 2019-12-02 | 2020-08-24 | 1725FS+123d |  |  | 2019-12-02 | 2020-08-24 | 180d |  |  | 666d | 0d | Verde | Verde | 0% | 0% | Compensatória | Verde | 0% | 0% |  |  |  |  |  |  |  |
| 1727 | 3.1.3.21.7.4 | Realizar pré-operação |  | 120d | 2020-08-25 | 2021-02-19 | 1726 |  |  | 2020-08-25 | 2021-02-19 | 120d |  |  | 666d | 0d | Verde | Verde | 0% | 0% | Compensatória | Verde | 0% | 0% |  |  |  |  |  |  |  |
| 1728 | 3.1.3.21.7.5 | Recurso de Linhares do Pleito LINESOB16 - Execução de obra de esgotamento sanitario na localidade de Chapadão das Palminhas, Distrito de São Rafael repassado | milestone | 0d | 2021-02-26 | 2021-02-26 | 1727FS+5d |  |  | 2021-02-26 | 2021-02-26 | 0d |  |  | 666d | 0d | Verde | Verde | 0% | 0% | Compensatória | Verde | 0% | 0% |  |  |  |  |  |  |  |
| 1729 | 3.1.3.21.7.6 | Pleito LINESOB16 - Execução de obra de esgotamento sanitario na localidade de Chapadão das Palminhas, Distrito de São Rafael de Linhares concluído | milestone | 0d | 2021-02-26 | 2021-02-26 | 1728 |  |  | 2021-02-26 | 2021-02-26 | 0d |  |  | 666d | 342d | Verde | Verde | 0% | 0% | Compensatória | Verde | 0% | 0% |  |  |  |  |  |  |  |

Notes:
- 1703: Em 25/04/2019: ofício de pleito foi enviado a CT conforme informado pelo município. Não foi apresentado a Renova e por isso foi considerado apenas início e fim do pleito. O pleito será aprovado na próxima CT/CIF dia 31/05/2019. / 02/06/2019: novo pleito aprovado no dia 28/05/2019 pelo CIF na deliberação 289
- 1704: 07/06/2019: na reunião com o município da 2a rodada de reuniões o mesmo informou que já iniciaram as tarefas do pleito
- 1708: Em 25/04/2019: considerado o valor da obra de R$ 12 milhões (24 meses) com licitação (3,5 meses), mobilização (1 mês) e licenciamento (6 meses) / Pleito será quebrado em quatro pleitos / Contratação de empresa para conclusão da implantação e recuperação das obras já executadas do SES do distrito de Pontal do Ipiranga - R$8.406.298,23 / Execução da obra de sistema de esgotamento sanitário na localidade de Baixo Quartel - R$2.763.545,72 / Execução de obra de sistema de esgotamento sanitário na localidade de Vila Bagueira - R$2.062.758,82 / Execução de obra de sistema de esgotamento sanitário na localidade de Humaitá, Distrito de São Rafael - R$2.064.949,03 / 06/06/2019: latência igual aos 9 meses de obra mais 6 meses de pré-operação
- 1711: 07/06/2019: na reunião com o município da 2a rodada de reuniões o mesmo informou que já iniciaram as tarefas do pleito
- 1718: 07/06/2019: na reunião com o município da 2a rodada de reuniões o mesmo informou que já iniciaram as tarefas do pleito
- 1725: 07/06/2019: na reunião com o município da 2a rodada de reuniões o mesmo informou que já iniciaram as tarefas do pleito

| ID | WBS | Task | Type | Duration | Start | Finish | Predecessors | Complete | Remaining | Baseline start | Baseline finish | Baseline duration | Baseline 1 start | Baseline 1 finish | Total slack | Free slack | Text1 | Text2 | Text3 | Text6 | Text8 | Text12 | Text14 | Text16 | Text4 | Text5 | Text7 | Text15 | Text17 | Text9 | Text18 |
| --- | --- | --- | --- | --- | --- | --- | --- | --- | --- | --- | --- | --- | --- | --- | --- | --- | --- | --- | --- | --- | --- | --- | --- | --- | --- | --- | --- | --- | --- | --- | --- |
| 1730 | 3.1.3.21.8 | **Pleito LINESOB17 - Execução de obra de sistema de esgotamento sanitário na localidade de Japira e São Rafael** |  | 515d | 2019-05-28 A | 2021-06-23 |  |  | 513.65d | 2019-05-28 | 2021-06-23 | 515d |  |  | 586d |  | Verde | Verde | 0% | 0% | Compensatória | Verde | 0% | 0% |  |  |  |  |  |  |  |
| 1731 | 3.1.3.21.8.1 | Pleito LINESOB17 - Execução de obra de sistema de esgotamento sanitário na localidade de Japira e São Rafael de Linhares aprovado | milestone | 0d | 2019-05-28 A | 2019-05-28 A | 3052FS+112d | 100% |  | 2019-05-28 | 2019-05-28 | 0d |  |  |  |  | Verde | Verde | 100% | 100% | Compensatória | Verde | 100% | 100% | 100 | 100 | 100 | 100 | 100 |  |  |
| 1732 | 3.1.3.21.8.2 | Iniciar tarefas do Pleito LINESOB17 |  | 1d | 2019-06-06 A | 2019-06-06 A | 1731FS+6d | 100% |  | 2019-06-06 | 2019-06-06 | 1d |  |  |  |  | Verde | Verde | 0% | 0% | Compensatória | Verde | 0% | 0% |  |  |  |  |  |  |  |
| 1733 | 3.1.3.21.8.3 | Executar obra |  | 260d | 2019-12-02 | 2020-12-17 | 1732FS+123d |  |  | 2019-12-02 | 2020-12-17 | 260d |  |  | 586d | 0d | Verde | Verde | 0% | 0% | Compensatória | Verde | 0% | 0% |  |  |  |  |  |  |  |
| 1734 | 3.1.3.21.8.4 | Realizar pré-operação |  | 120d | 2020-12-18 | 2021-06-16 | 1733 |  |  | 2020-12-18 | 2021-06-16 | 120d |  |  | 586d | 0d | Verde | Verde | 0% | 0% | Compensatória | Verde | 0% | 0% |  |  |  |  |  |  |  |
| 1735 | 3.1.3.21.8.5 | Recurso de Linhares do Pleito LINESOB17 - Execução de obra de sistema de esgotamento sanitário na localidade de Japira e São Rafael repassado | milestone | 0d | 2021-06-23 | 2021-06-23 | 1734FS+5d |  |  | 2021-06-23 | 2021-06-23 | 0d |  |  | 586d | 0d | Verde | Verde | 0% | 0% | Compensatória | Verde | 0% | 0% |  |  |  |  |  |  |  |
| 1736 | 3.1.3.21.8.6 | Pleito LINESOB17 - Execução de obra de sistema de esgotamento sanitário na localidade de Japira e São Rafael de Linhares concluído | milestone | 0d | 2021-06-23 | 2021-06-23 | 1735 |  |  | 2021-06-23 | 2021-06-23 | 0d |  |  | 586d | 262d | Verde | Verde | 0% | 0% | Compensatória | Verde | 0% | 0% |  |  |  |  |  |  |  |
| 1737 | 3.1.3.21.9 | **Pleito LINESOB11 - Outras obras complementares - ampliação do SES da sede municipal - construção de ETE, no bairro Aviso** |  | 821d | 2019-03-25 A | 2022-07-11 |  | 9% | 748.56d | 2019-03-25 | 2022-06-14 | 803d | 2019-03-25 | 2020-10-23 | 324d |  | Verde | Verde | 5% | 88% | Compensatória | Vermelho | 8% | 7% |  |  | 88 |  |  |  |  |
| 1738 | 3.1.3.21.9.1 | Alteração do Pleito LINESOB11 - Outras obras complementares - ampliação do SES da sede municipal - construção de ETE, no bairro Aviso de Linhares aprovada | milestone | 0d | 2019-05-28 A | 2019-05-28 A | 3052FS+112d | 100% |  | 2019-05-28 | 2019-05-28 | 0d | 2019-05-31 | 2019-05-31 |  |  | Verde | Verde | 100% | 100% | Compensatória | Verde | 100% | 100% | 100 | 100 | 100 | 100 | 100 | CT/CIF |  |
| 1739 | 3.1.3.21.9.2 | **Aprovação do Projeto** |  | 126d | 2019-05-07 A | 2019-11-01 |  | 25% | 94.5d | 2019-05-07 | 2019-11-01 | 126d | 2019-05-06 | 2019-06-24 | 364d |  | Verde | Verde | 14% | 179% | Compensatória | Verde | 14% | 25% | 25 | 14 | 179 | 14 | 25 |  |  |
| 1740 | 3.1.3.21.9.2.1 | Informações complementares do projeto de Linhares do Pleito LINESOB11 - Outras obras complementares - ampliação do SES da sede municipal - construção de ETE, no bairro Aviso protocoladas no banco | milestone | 0d | 2019-05-07 A | 2019-05-07 A | 3052FS+97d | 100% |  | 2019-05-07 | 2019-05-07 | 0d | 2019-05-06 | 2019-05-06 |  |  | Verde | Verde | 100% | 100% | Compensatória | Verde | 100% | 100% | 100 | 100 | 100 | 100 | 100 | Município |  |
| 1741 | 3.1.3.21.9.2.2 | Analisar projeto |  | 126d | 2019-05-08 A | 2019-11-01 | 1740 | 25% | 94.5d | 2019-05-08 | 2019-11-01 | 126d | 2019-05-06 | 2019-06-04 | 364d | 0d | Verde | Verde | 14% | 179% | Compensatória | Verde | 14% | 25% | 25 | 14 | 179 | 14 | 25 | Banco | Conforme agendado |
| 1742 | 3.1.3.21.9.2.3 | Projeto de Linhares do Pleito LINESOB11 - Outras obras complementares - ampliação do SES da sede municipal - construção de ETE, no bairro Aviso aprovado | milestone | 0d | 2019-11-01 | 2019-11-01 | 1741, 1743, 1744 |  |  | 2019-11-01 | 2019-11-01 | 0d | 2019-06-24 | 2019-06-24 | 364d | 40d | Verde | Verde | 0% | 0% | Compensatória | Verde | 0% | 0% |  |  |  |  |  | Município |  |
| 1743 | 3.1.3.21.9.3 | Regularizar terreno |  | 135d | 2019-03-25 A | 2019-10-04 | 1738FS-46d | 25% | 101.25d | 2019-03-25 | 2019-10-04 | 135d | 2019-03-25 | 2019-06-24 | 384d | 20d | Verde | Verde | 34% | 74% | Compensatória | Vermelho | 34% | 25% | 25 | 34 | 74 | 34 | 25 | Município | Conforme agendado |
| 1744 | 3.1.3.21.9.4 | Realizar Licenciamento Ambiental |  | 135d | 2019-03-25 A | 2019-10-04 | 1738FS-46d | 25% | 101.25d | 2019-03-25 | 2019-10-04 | 135d | 2019-03-25 | 2019-06-24 | 384d | 20d | Verde | Verde | 34% | 74% | Compensatória | Vermelho | 34% | 25% | 25 | 34 | 74 | 34 | 25 | Município | Conforme agendado |
| 1745 | 3.1.3.21.9.5 | **Licitação da Obra** |  | 126d | 2019-07-03 | 2020-01-03 |  |  |  | 2019-06-06 | 2019-12-04 | 126d | 2019-06-24 | 2019-07-12 | 324d |  | Verde | Verde | 0% | 0% | Compensatória | Verde | 0% | 0% |  |  |  |  |  |  |  |
| 1746 | 3.1.3.21.9.5.1 | Licitação da obra de Linhares do Pleito LINESOB11 - Outras obras complementares - ampliação do SES da sede municipal - construção de ETE, no bairro Aviso apresentada ao banco | milestone | 0d | 2019-07-03 | 2019-07-03 | 1740FS+40d |  |  | 2019-06-06 | 2019-06-06 | 0d | 2019-06-24 | 2019-06-24 | 324d | 0d | Verde | Verde | 0% | 0% | Compensatória | Verde | 0% | 0% |  |  |  |  |  | Município |  |
| 1747 | 3.1.3.21.9.5.2 | Analisar e emitir resultado da licitação do projeto |  | 126d | 2019-07-04 | 2020-01-03 | 1746 |  |  | 2019-06-07 | 2019-12-04 | 126d | 2019-06-25 | 2019-07-12 | 324d | 0d | Verde | Verde | 0% | 0% | Compensatória | Verde | 0% | 0% |  |  |  |  |  | Banco | Critério FR |
| 1748 | 3.1.3.21.9.5.3 | Licitação da obra de Linhares do Pleito LINESOB11 - Outras obras complementares - ampliação do SES da sede municipal - construção de ETE, no bairro Aviso concluída | milestone | 0d | 2020-01-03 | 2020-01-03 | 1747, 1742 |  |  | 2019-12-04 | 2019-12-04 | 0d | 2019-07-12 | 2019-07-12 | 324d | 0d | Verde | Verde | 0% | 0% | Compensatória | Verde | 0% | 0% |  |  |  |  |  | Município |  |
| 1749 | 3.1.3.21.9.6 | Executar obra |  | 480d | 2020-02-04 | 2022-01-07 | 1748FS+21d |  |  | 2020-01-09 | 2021-12-13 | 480d | 2019-08-13 | 2020-04-15 | 324d | 0d | Verde | Verde | 0% | 0% | Compensatória | Verde | 0% | 0% |  |  |  |  |  | Município |  |
| 1750 | 3.1.3.21.9.7 | Realizar processo de pré-operação |  | 120d | 2022-01-10 | 2022-07-04 | 1749 |  |  | 2021-12-14 | 2022-06-07 | 120d | 2020-04-16 | 2020-10-16 | 324d | 0d | Verde | Verde | 0% | 0% | Compensatória | Verde | 0% | 0% |  |  |  |  |  | Município |  |
| 1751 | 3.1.3.21.9.8 | Recurso da obra de Linhares do Pleito LINESOB11 - Outras obras complementares - ampliação do SES da sede municipal - construção de ETE, no bairro Aviso repassado | milestone | 0d | 2022-07-11 | 2022-07-11 | 1750FS+5d |  |  | 2022-06-14 | 2022-06-14 | 0d | 2020-10-23 | 2020-10-23 | 324d | 0d | Verde | Verde | 0% | 0% | Compensatória | Verde | 0% | 0% |  |  |  |  |  | Banco |  |
| 1752 | 3.1.3.21.9.9 | Pleito LINESOB11 - Outras obras complementares - ampliação do SES da sede municipal - construção de ETE, no bairro Aviso de Linhares concluído | milestone | 0d | 2022-07-11 | 2022-07-11 | 1751 |  |  | 2022-06-14 | 2022-06-14 | 0d | 2020-10-23 | 2020-10-23 | 324d | 0d | Verde | Verde | 0% | 0% | Compensatória | Verde | 0% | 0% |  |  |  |  |  | Município |  |
| 1753 | 3.1.3.21.10 | **Pleito LINRSOB01 - Viabilizar a solução consorciada, com objetivo de executar as obras para a implantação da Central de Tratamento de Resíduos – CTR Colatina** |  | 638d | 2019-03-14 A | 2021-10-05 |  | 5% | 606.44d | 2019-03-14 | 2021-10-05 | 638d | 2019-03-14 | 2021-09-15 | 513d |  | Verde | Verde | 8% | 57% | Compensatória | Vermelho | 7% | 4% |  |  | 57 |  |  |  |  |
| 1754 | 3.1.3.21.10.1 | **Licitação da obra** |  | 114d | 2019-03-14 A | 2019-08-28 |  | 28% | 82.54d | 2019-03-14 | 2019-08-28 | 114d | 2019-03-14 | 2019-05-29 | 513d |  | Verde | Verde | 46% | 56% | Compensatória | Vermelho | 45% | 25% | 28 | 46 | 56 | 45 | 25 |  |  |
| 1755 | 3.1.3.21.10.1.1 | Licitação da obra de Linhares do Pleito LINRSOB01 - Viabilizar a solução consorciada, com objetivo de executar as obras para a implantação da Central de Tratamento de Resíduos – CTR Colatina autorizada pelo banco | milestone | 0d | 2019-03-14 A | 2019-03-14 A | 3052FS+62d | 100% |  | 2019-03-14 | 2019-03-14 | 0d | 2019-03-14 | 2019-03-14 |  |  | Verde | Verde | 100% | 100% | Compensatória | Verde | 100% | 100% | 100 | 100 | 100 | 100 | 100 | Banco |  |
| 1756 | 3.1.3.21.10.1.2 | Licitar obra |  | 94d | 2019-03-15 A | 2019-07-30 | 1755 | 32% | 63.92d | 2019-03-15 | 2019-07-30 | 94d | 2019-03-14 | 2019-05-09 | 513d | 0d | Verde | Verde | 56% | 55% | Compensatória | Vermelho | 56% | 31% | 32 | 56 | 55 | 56 | 31 | Município | Conforme agendado |
| 1757 | 3.1.3.21.10.1.3 | Analisar e emitir resultado da licitação da obra |  | 15d | 2019-08-07 | 2019-08-28 | 1756FS+5d |  |  | 2019-08-07 | 2019-08-28 | 15d | 2019-05-20 | 2019-05-29 | 513d | 0d | Verde | Verde | 0% | 0% | Compensatória | Verde | 0% | 0% |  |  |  |  |  | Banco | Critério FR |
| 1758 | 3.1.3.21.10.1.4 | Licitação da obra de Linhares do Pleito LINRSOB01 - Viabilizar a solução consorciada, com objetivo de executar as obras para a implantação da Central de Tratamento de Resíduos – CTR Colatina concluída | milestone | 0d | 2019-08-28 | 2019-08-28 | 1757 |  |  | 2019-08-28 | 2019-08-28 | 0d | 2019-05-29 | 2019-05-29 | 513d | 0d | Verde | Verde | 0% | 0% | Compensatória | Verde | 0% | 0% |  |  |  |  |  | Município |  |
| 1759 | 3.1.3.21.10.2 | Executar obra |  | 249d | 2019-09-26 | 2020-09-25 | 1758FS+20d |  |  | 2019-09-26 | 2020-09-25 | 249d | 2019-07-08 | 2021-03-08 | 513d | 0d | Verde | Verde | 0% | 0% | Compensatória | Verde | 0% | 0% |  |  |  |  |  | Município |  |
| 1760 | 3.1.3.21.10.3 | Realizar processo de pré-operação |  | 250d | 2020-09-28 | 2021-09-28 | 1759 |  |  | 2020-09-28 | 2021-09-28 | 250d | 2021-03-09 | 2021-09-08 | 513d | 0d | Verde | Verde | 0% | 0% | Compensatória | Verde | 0% | 0% |  |  |  |  |  | Município |  |
| 1761 | 3.1.3.21.10.4 | Recurso da obra de Linhares do Pleito LINRSOB01 - Viabilizar a solução consorciada, com objetivo de executar as obras para a implantação da Central de Tratamento de Resíduos – CTR Colatina repassado | milestone | 0d | 2021-10-05 | 2021-10-05 | 1760FS+5d |  |  | 2021-10-05 | 2021-10-05 | 0d | 2021-09-15 | 2021-09-15 | 513d | 0d | Verde | Verde | 0% | 0% | Compensatória | Verde | 0% | 0% |  |  |  |  |  | Banco |  |
| 1762 | 3.1.3.21.10.5 | Pleito LINRSOB01 - Viabilizar a solução consorciada, com objetivo de executar as obras para a implantação da Central de Tratamento de Resíduos – CTR Colatina de Linhares concluído | milestone | 0d | 2021-10-05 | 2021-10-05 | 1761 |  |  | 2021-10-05 | 2021-10-05 | 0d | 2021-09-15 | 2021-09-15 | 513d | 189d | Verde | Verde | 0% | 0% | Compensatória | Verde | 0% | 0% |  |  |  |  |  | Município |  |

Notes:
- 1732: 07/06/2019: na reunião com o município da 2a rodada de reuniões o mesmo informou que já iniciaram as tarefas do pleito
- 1738: 02/06/2019: alteração do pleito aprovada no dia 28/05/2019 pelo CIF na deliberação 289
- 1740: 31/05/2019: Mônica informou que o município protocolou o projeto no BANDES dia 07/05.
- 1741: 31/05/2019: Mônica informou que o BANDES passou o prazo de 04/06/2019 para finalizar análise e que acha que esse prazo não será cumprido, porque o BANDES ainda não recebeu resultado da alteração do pleito pelo CIF. / 01/07/2019: Está sendo feita a análise dos pleitos pelo Banco e pelo apoio técnico. Segunda -Feira (01/07) haverá uma reunião para discutir sobre o pleito de Complementação da ETE Aviso e até na sexta-feira (05/07) será entregue as análises das ETEs dos distritos de Povoação e Regência.
- 1743: Em 29/04/2019: atualizado como agendado
- 1744: Em 29/04/2019: atualizado como agendado
- 1746: 02/07/2019: Mônica informou que município entregou apenas o projeto. Atividade reprogramada para o próximo ciclo.
- 1749: 22/05/2019: premissa de obra ajustada - valor da obra R$8.886.885,84 - 18 meses; com a alteração do pleito o valor da obra será de R$ 13.204.809,74 e a premissa será alterada para 24 meses
- 1756: 31/05/2019: conforme e-mail da Mônica, algumas empresas entraram com recurso e por isso os envelopes de preço ainda não foram abertos. Considerado mais um mês de prazo. / 01/07/2019: e-mail Luiz - Os envelopes serão abertos no dia 03/07. Caso não haja imprevisto e nenhuma empresa entre com recurso, o prazo de término continuará dia 30/07.
- 1759: Em 24/09/2019: o valor da obra do CONDOESTE é de R$ 10,9 milhões - 20 meses

| ID | WBS | Task | Type | Duration | Start | Finish | Predecessors | Complete | Remaining | Baseline start | Baseline finish | Baseline duration | Baseline 1 start | Baseline 1 finish | Total slack | Free slack | Constraint | Text1 | Text2 | Text3 | Text4 | Text5 | Text6 | Text7 | Text8 | Text12 | Text14 | Text15 | Text16 | Text17 | Text9 | Text18 |
| --- | --- | --- | --- | --- | --- | --- | --- | --- | --- | --- | --- | --- | --- | --- | --- | --- | --- | --- | --- | --- | --- | --- | --- | --- | --- | --- | --- | --- | --- | --- | --- | --- |
| 1763 | 3.1.3.21.11 | **Pleito LINESPJ01 - Elaboração de projetos de obras de infraestrutura urbana no município de linhares (em fase de licitação) e elaboração de projetos de SES dos distritos** |  | 1d | 2019-05-28 A | 2019-05-28 A |  | 100% |  | 2019-05-28 | 2019-05-28 | 1d | 2019-06-03 | 2019-06-03 |  |  |  | Verde | Verde | 100% | 100 | 100 | 100% | 100 | Compensatória | Verde | 100% | 100 | 100% | 100 |  |  |
| 1764 | 3.1.3.21.11.1 | Avaliar cancelamento do pleito LINESPJ01 |  | 1d | 2019-05-28 A | 2019-05-28 A | 3052FS+111d | 100% |  | 2019-05-28 | 2019-05-28 | 1d | 2019-06-03 | 2019-06-03 |  |  |  | Verde | Verde | 100% | 100 | 100 | 100% | 100 | Compensatória | Verde | 100% | 100 | 100% | 100 | Município |  |
| 1765 | 3.1.3.21.11.2 | Pleito LINESPJ01 - Elaboração de projetos de obras de infraestrutura urbana no município de linhares (em fase de licitação) e elaboração de projetos de SES dos distritos de Linhares cancelado | milestone | 0d | 2019-05-28 A | 2019-05-28 A | 1764 | 100% |  | 2019-05-28 | 2019-05-28 | 0d | 2019-06-03 | 2019-06-03 |  |  |  | Verde | Verde | 100% | 100 | 100 | 100% | 100 | Compensatória | Verde | 100% | 100 | 100% | 100 | Município |  |
| 1766 | 3.1.3.21.12 | **Pleito LINESOB04 - Construção de EEEB - bairro Canivete** |  | 1d | 2019-05-28 A | 2019-05-28 A |  | 100% |  | 2019-05-28 | 2019-05-28 | 1d | 2019-06-03 | 2019-06-03 |  |  |  | Verde | Verde | 100% | 100 | 100 | 100% | 100 | Compensatória | Verde | 100% | 100 | 100% | 100 |  |  |
| 1767 | 3.1.3.21.12.1 | Avaliar cancelamento do pleito LINESOB04 |  | 1d | 2019-05-28 A | 2019-05-28 A | 3052FS+111d | 100% |  | 2019-05-28 | 2019-05-28 | 1d | 2019-06-03 | 2019-06-03 |  |  |  | Verde | Verde | 100% | 100 | 100 | 100% | 100 | Compensatória | Verde | 100% | 100 | 100% | 100 | Município |  |
| 1768 | 3.1.3.21.12.2 | Pleito LINESOB04 - Construção de EEEB - bairro Canivete de Linhares cancelado | milestone | 0d | 2019-05-28 A | 2019-05-28 A | 1767 | 100% |  | 2019-05-28 | 2019-05-28 | 0d | 2019-06-03 | 2019-06-03 |  |  |  | Verde | Verde | 100% | 100 | 100 | 100% | 100 | Compensatória | Verde | 100% | 100 | 100% | 100 | Município |  |
| 1769 | 3.1.3.21.13 | **Pleito LINESOB05 - Construção de EEEB - bairro Aviso** |  | 1d | 2019-05-28 A | 2019-05-28 A |  | 100% |  | 2019-05-28 | 2019-05-28 | 1d | 2019-06-03 | 2019-06-03 |  |  |  | Verde | Verde | 100% | 100 | 100 | 100% | 100 | Compensatória | Verde | 100% | 100 | 100% | 100 |  |  |
| 1770 | 3.1.3.21.13.1 | Avaliar cancelamento do pleito LINESOB05 |  | 1d | 2019-05-28 A | 2019-05-28 A | 3052FS+111d | 100% |  | 2019-05-28 | 2019-05-28 | 1d | 2019-06-03 | 2019-06-03 |  |  |  | Verde | Verde | 100% | 100 | 100 | 100% | 100 | Compensatória | Verde | 100% | 100 | 100% | 100 | Município |  |
| 1771 | 3.1.3.21.13.2 | Pleito LINESOB05 - Construção de EEEB - bairro Aviso de Linhares cancelado | milestone | 0d | 2019-05-28 A | 2019-05-28 A | 1770 | 100% |  | 2019-05-28 | 2019-05-28 | 0d | 2019-06-03 | 2019-06-03 |  |  |  | Verde | Verde | 100% | 100 | 100 | 100% | 100 | Compensatória | Verde | 100% | 100 | 100% | 100 | Município |  |
| 1772 | 3.1.3.21.14 | **Pleito LINESOB06 - Implantação de biodigestor para tratamento de esgoto (beneficiará 210 agricultores)** |  | 1d | 2019-05-28 A | 2019-05-28 A |  | 100% |  | 2019-05-28 | 2019-05-28 | 1d | 2019-06-03 | 2019-06-03 |  |  |  | Verde | Verde | 100% | 100 | 100 | 100% | 100 | Compensatória | Verde | 100% | 100 | 100% | 100 |  |  |
| 1773 | 3.1.3.21.14.1 | Avaliar cancelamento do pleito LINESOB06 |  | 1d | 2019-05-28 A | 2019-05-28 A | 3052FS+111d | 100% |  | 2019-05-28 | 2019-05-28 | 1d | 2019-06-03 | 2019-06-03 |  |  |  | Verde | Verde | 100% | 100 | 100 | 100% | 100 | Compensatória | Verde | 100% | 100 | 100% | 100 | Município |  |
| 1774 | 3.1.3.21.14.2 | Pleito LINESOB06 - Implantação de biodigestor para tratamento de esgoto (beneficiará 210 agricultores) de Linhares cancelado | milestone | 0d | 2019-05-28 A | 2019-05-28 A | 1773 | 100% |  | 2019-05-28 | 2019-05-28 | 0d | 2019-06-03 | 2019-06-03 |  |  |  | Verde | Verde | 100% | 100 | 100 | 100% | 100 | Compensatória | Verde | 100% | 100 | 100% | 100 | Município |  |
| 1775 | 3.1.3.21.15 | **Pleito LINESOB08 - Reforma das 65 EEEBs** |  | 1d | 2019-05-28 A | 2019-05-28 A |  | 100% |  | 2019-05-28 | 2019-05-28 | 1d | 2019-06-03 | 2019-06-03 |  |  |  | Verde | Verde | 100% | 100 | 100 | 100% | 100 | Compensatória | Verde | 100% | 100 | 100% | 100 |  |  |
| 1776 | 3.1.3.21.15.1 | Avaliar cancelamento do pleito LINESOB08 |  | 1d | 2019-05-28 A | 2019-05-28 A | 3052FS+111d | 100% |  | 2019-05-28 | 2019-05-28 | 1d | 2019-06-03 | 2019-06-03 |  |  |  | Verde | Verde | 100% | 100 | 100 | 100% | 100 | Compensatória | Verde | 100% | 100 | 100% | 100 | Município |  |
| 1777 | 3.1.3.21.15.2 | Pleito LINESOB08 - Reforma das 65 EEEBs de Linhares cancelado | milestone | 0d | 2019-05-28 A | 2019-05-28 A | 1776 | 100% |  | 2019-05-28 | 2019-05-28 | 0d | 2019-06-03 | 2019-06-03 |  |  |  | Verde | Verde | 100% | 100 | 100 | 100% | 100 | Compensatória | Verde | 100% | 100 | 100% | 100 | Município |  |
| 1778 | 3.1.3.21.16 | Recursos de Linhares repassados | milestone | 0d | 2022-07-11 | 2022-07-11 | 1765, 1701, 1669, 1685, 1752, 1768, 1771, 1774, 1777, 1762, 1708, 1715, 1722, 1729, 1736 |  |  | 2022-06-14 | 2022-06-14 | 0d | 2023-07-28 | 2023-07-28 | 324d |  |  | Verde | Verde | 0% |  |  | 0% |  | Compensatória | Verde | 0% |  | 0% |  | Banco |  |
| 1779 | 3.1.3.22 | **Mariana** |  | 1142d | 2019-03-28 A | 2023-10-30 |  | 3% | 1106.6d | 2019-03-28 | 2023-10-30 | 1142d | 2019-02-19 | 2024-01-30 | 0d |  |  | Verde | Verde | 3% |  |  | 0% |  | Compensatória | Vermelho | 0% |  | 0% |  |  |  |
| 1780 | 3.1.3.22.1 | **Pleito MRNESPJ03 - Elaboração de projetos de engenharia Distritos de Rita Durão, Monsenhor Horta, Bandeirantes, Cláudio Manoel, Furquim, Barroca e Passagem de Mariana, incluindo o bairro Liberdade e os subdistritos de Mainart, Barro Branco e Águas Claras** |  | 266d | 2019-03-28 A | 2020-04-23 |  | 11% | 235.71d | 2019-03-28 | 2020-04-20 | 264d | 2019-03-28 | 2020-07-07 | 876d |  |  | Verde | Verde | 16% | 10 | 16 | 100% | 100 | Compensatória | Verde | 8% |  | 8% |  |  |  |
| 1781 | 3.1.3.22.1.1 | Pleito MRNESPJ03 - Elaboração de projetos de engenharia dos distritos e bairros de Mariana aprovado pelo CIF na Deliberação 269 | milestone | 0d | 2019-03-28 A | 2019-03-28 A |  | 100% |  | 2019-03-28 | 2019-03-28 | 0d | 2019-03-28 | 2019-03-28 |  |  | must start on 2019-03-28 | Verde | Verde | 100% | 100 | 100 | 100% | 100 | Compensatória | Verde | 100% | 100 | 100% | 100 | CT/CIF |  |
| 1782 | 3.1.3.22.1.2 | **Licitação do Projeto** |  | 66d | 2019-03-28 A | 2019-07-03 |  | 81% | 12.83d | 2019-03-28 | 2019-07-01 | 64d | 2019-04-08 | 2019-07-01 | 876d |  |  | Verde | Verde | 68% | 74 | 68 | 100% | 100 | Compensatória | Verde | 77% | 77 | 77% | 77 |  |  |
| 1783 | 3.1.3.22.1.2.1 | Licitação do projeto de Marina do Pleito MRNESPJ03 - Elaboração de projetos de engenharia dos distritos e bairros de Mariana autorizada pelo banco | milestone | 0d | 2019-03-28 A | 2019-03-28 A | 1781 | 100% |  | 2019-03-28 | 2019-03-28 | 0d | 2019-04-08 | 2019-04-08 |  |  |  | Verde | Verde | 100% | 100 | 100 | 100% | 100 | Compensatória | Verde | 100% | 100 | 100% | 100 | Banco |  |
| 1784 | 3.1.3.22.1.2.2 | Licitar projeto |  | 40d | 2019-03-28 A | 2019-05-27 A | 1783 | 100% |  | 2019-03-28 | 2019-05-27 | 40d | 2019-04-09 | 2019-06-10 |  |  |  | Verde | Verde | 100% | 100 | 100 | 100% | 100 | Compensatória | Verde | 100% | 100 | 100% | 100 | Município |  |
| 1785 | 3.1.3.22.1.2.3 | Documentação de licitação de Mariana do Pleito MRNESPJ03 - Elaboração de projetos de engenharia dos distritos e bairros de Mariana apresentada ao banco | milestone | 0d | 2019-06-27 A | 2019-06-27 A | 1784FS+22d | 100% |  | 2019-06-10 | 2019-06-10 | 0d | 2019-06-10 | 2019-06-10 |  |  |  | Verde | Verde | 0% |  |  | 0% |  | Compensatória | Verde | 0% |  | 0% |  | Município |  |
| 1786 | 3.1.3.22.1.2.4 | Analisar e emitir resultado da licitação do projeto |  | 14d | 2019-06-13 A | 2019-07-03 | 1785FS-10d | 25% | 10.5d | 2019-06-11 | 2019-07-01 | 14d | 2019-06-11 | 2019-07-01 | 876d | 0d |  | Verde | Verde | 0% |  |  | 0% |  | Compensatória | Verde | 0% |  | 0% |  | Banco | Critério FR |
| 1787 | 3.1.3.22.1.2.5 | Licitação do projeto de Mariana do Pleito MRNESPJ03 - Elaboração de projetos de engenharia dos distritos e bairros de Mariana concluída | milestone | 0d | 2019-07-03 | 2019-07-03 | 1786 |  |  | 2019-07-01 | 2019-07-01 | 0d | 2019-07-01 | 2019-07-01 | 876d | 0d |  | Verde | Verde | 0% |  |  | 0% |  | Compensatória | Verde | 0% |  | 0% |  | Município |  |

Notes:
- 1764: Em 25/04/2019: o ofício de cancelamento de pleito foi enviado dia 13/03/2019. Considerado que na próxima reunião do CIF o pleito será cancelado dia 31/05/2019. / 02/06/2019: alteração do pleito aprovada no dia 28/05/2019 pelo CIF na deliberação 289
- 1767: Em 25/04/2019: o ofício de cancelamento de pleito foi enviado dia 13/03/2019. Considerado que na próxima reunião do CIF o pleito será cancelado dia 31/05/2019. / 02/06/2019: alteração do pleito aprovada no dia 28/05/2019 pelo CIF na deliberação 289
- 1770: Em 25/04/2019: o ofício de cancelamento de pleito foi enviado dia 13/03/2019. Considerado que na próxima reunião do CIF o pleito será cancelado dia 31/05/2019. / 02/06/2019: alteração do pleito aprovada no dia 28/05/2019 pelo CIF na deliberação 289
- 1773: Em 25/04/2019: o ofício de cancelamento de pleito foi enviado dia 13/03/2019. Considerado que na próxima reunião do CIF o pleito será cancelado dia 31/05/2019. / 02/06/2019: alteração do pleito aprovada no dia 28/05/2019 pelo CIF na deliberação 289
- 1776: Em 25/04/2019: o ofício de cancelamento de pleito foi enviado dia 13/03/2019. Considerado que na próxima reunião do CIF o pleito será cancelado dia 31/05/2019.
- 1778: Valor de recurso destinado ao munícipio: R$47.755.824,41
- 1779: Mariana solicitou 96,8% do total de recurso destinado ao munícipio para Esgotamento Sanitário, mas foi aprovado 90% do valor teto para este fim (R$64.166.980,38), conforme Deliberação 75. / O município teve o pleito de resíduos sólidos negado (R$7.129.664,49), equivalente a 10% do total do recurso). / Aderiu à ata de registro de preço. / Como ainda não está definido quantas obras seram realizadas, foi considerado o valor total de obras, dividido por 6 para o critério de prazo, de forma a não impactar no prazo final do programa.
- 1781: Em 24/04/2019: pleito foi aprovado na deliberação 269 no dia 28/03/2019
- 1783: Em 24/04/2019: considerando que alteração do pleito foi aprovada em 28/03/2019 e desconsiderando o processo licitatório apresentado anteriormente. / 27/05/2019: conforme planilha Controle Gerencial Renova, o banco autorizou a nova licitação no dia 28/03/2019
- 1784: Em 29/04/2019: atualizado como agendado / 21/05/2019: confirmar andamento da licitação com o município na reunião da semana 27/05/2019 / 27/05/2019: município apresentou o novo processo licitatório dia 28/03/2019. Banco encaminhou para o jurídico e solicitou pendências ao município. Considerada a data da reunião como data de término.
- 1785: 27/05/2019: o município precisa entregar mais alguns documentos ao banco e solicitou mais duas semanas para essa entrega / 01/07/2019: no dia 27/06/2019 foram recebidas as pendências por email. Repassado para Gislaine emitir a Autorização para elaboração dos Estudos e Concepções, conforme planilha controle gerencial Renova
- 1786: 02/07/2019: Gislaine informou que a análise estava em andamento e que o banco estava aguardando apenas a declaração para autorizar a elaboração do projeto. Ela disse que amanhã o Francisco enviará uma autorização ao município. Considerado data de início 14 dias úteis antes da data de término prevista.

| ID | WBS | Task | Type | Duration | Start | Finish | Predecessors | Complete | Remaining | Baseline start | Baseline finish | Baseline duration | Baseline 1 start | Baseline 1 finish | Total slack | Free slack | Constraint | Text1 | Text2 | Text3 | Text6 | Text8 | Text12 | Text14 | Text16 | Text18 | Text9 | Text5 | Text7 | Text15 | Text4 | Text17 |
| --- | --- | --- | --- | --- | --- | --- | --- | --- | --- | --- | --- | --- | --- | --- | --- | --- | --- | --- | --- | --- | --- | --- | --- | --- | --- | --- | --- | --- | --- | --- | --- | --- |
| 1788 | 3.1.3.22.1.3 | **Elaboração de Estudo de Concepção** |  | 120d | 2019-07-04 | 2019-12-23 |  |  |  | 2019-07-02 | 2019-12-19 | 120d |  |  | 876d |  |  | Verde | Verde | 0% | 0% | Compensatória | Verde | 0% | 0% |  |  |  |  |  |  |  |
| 1789 | 3.1.3.22.1.3.1 | Elaborar estudo |  | 44d | 2019-07-04 | 2019-09-04 | 1787 |  |  | 2019-07-02 | 2019-09-02 | 44d |  |  | 876d | 0d |  | Verde | Verde | 0% | 0% | Compensatória | Verde | 0% | 0% | Critério FR |  |  |  |  |  |  |
| 1790 | 3.1.3.22.1.3.2 | Estudo de concepção de Mariana do Pleito MRNESPJ03 - Elaboração de projetos de engenharia dos distritos e bairros de Mariana apresentado ao banco | milestone | 0d | 2019-09-06 | 2019-09-06 | 1789FS+2d |  |  | 2019-09-04 | 2019-09-04 | 0d |  |  | 946d | 0d |  | Verde | Verde | 0% | 0% | Compensatória | Verde | 0% | 0% |  |  |  |  |  |  |  |
| 1791 | 3.1.3.22.1.3.3 | Analisar estudo |  | 69d | 2019-09-09 | 2019-12-16 | 1790 |  |  | 2019-09-05 | 2019-12-11 | 69d |  |  | 946d | 0d |  | Verde | Verde | 0% | 0% | Compensatória | Verde | 0% | 0% | Critério FR |  |  |  |  |  |  |
| 1792 | 3.1.3.22.1.3.4 | Estudo de concepção de Mariana do Pleito MRNESPJ03 - Elaboração de projetos de engenharia dos distritos e bairros de Mariana concluído | milestone | 0d | 2019-12-16 | 2019-12-16 | 1791 |  |  | 2019-12-11 | 2019-12-11 | 0d |  |  | 946d | 0d |  | Verde | Verde | 0% | 0% | Compensatória | Verde | 0% | 0% |  |  |  |  |  |  |  |
| 1793 | 3.1.3.22.1.3.5 | Recurso do estudo de concepção de Mariana do Pleito MRNESPJ03 - Elaboração de projetos de engenharia dos distritos e bairros de Mariana repassado | milestone | 0d | 2019-12-23 | 2019-12-23 | 1792FS+5d |  |  | 2019-12-19 | 2019-12-19 | 0d |  |  | 946d | 37d |  | Verde | Verde | 0% | 0% | Compensatória | Verde | 0% | 0% |  |  |  |  |  |  |  |
| 1794 | 3.1.3.22.1.4 | **Elaboração do Projeto Básico** |  | 118d | 2019-09-05 | 2020-02-27 |  |  |  | 2019-09-03 | 2020-02-20 | 118d | 2019-07-02 | 2020-02-10 | 876d |  |  | Verde | Verde | 0% | 0% | Compensatória | Verde | 0% | 0% |  |  |  |  |  |  |  |
| 1795 | 3.1.3.22.1.4.1 | Elaborar projeto básico |  | 45d | 2019-09-05 | 2019-11-06 | 1789 |  |  | 2019-09-03 | 2019-11-04 | 45d | 2019-07-02 | 2019-10-28 | 876d | 0d |  | Verde | Verde | 0% | 0% | Compensatória | Verde | 0% | 0% | Critério FR | Município |  |  |  |  |  |
| 1796 | 3.1.3.22.1.4.2 | Projeto Básico de Mariana do Pleito MRNESPJ03 - Elaboração de projetos de engenharia dos distritos e bairros de Mariana apresentado ao banco | milestone | 0d | 2019-11-08 | 2019-11-08 | 1795FS+2d |  |  | 2019-11-06 | 2019-11-06 | 0d | 2019-10-28 | 2019-10-28 | 909d | 0d |  | Verde | Verde | 0% | 0% | Compensatória | Verde | 0% | 0% |  | Município |  |  |  |  |  |
| 1797 | 3.1.3.22.1.4.3 | Analisar projeto básico |  | 66d | 2019-11-11 | 2020-02-17 | 1796 |  |  | 2019-11-07 | 2020-02-13 | 66d | 2019-10-29 | 2019-11-28 | 909d | 0d |  | Verde | Verde | 0% | 0% | Compensatória | Verde | 0% | 0% | Critério FR | Banco |  |  |  |  |  |
| 1798 | 3.1.3.22.1.4.4 | Projeto básico de Mariana do Pleito MRNESPJ03 - Elaboração de projetos de engenharia dos distritos e bairros de Mariana concluído | milestone | 0d | 2020-02-17 | 2020-02-17 | 1793, 1797 |  |  | 2020-02-13 | 2020-02-13 | 0d | 2020-02-03 | 2020-02-03 | 909d | 0d |  | Verde | Verde | 0% | 0% | Compensatória | Verde | 0% | 0% |  | Município |  |  |  |  |  |
| 1799 | 3.1.3.22.1.4.5 | Recurso do projeto básico de Mariana do Pleito MRNESPJ03 - Elaboração de projetos de engenharia dos distritos e bairros de Mariana repassado | milestone | 0d | 2020-02-27 | 2020-02-27 | 1798FS+5d |  |  | 2020-02-20 | 2020-02-20 | 0d | 2020-02-10 | 2020-02-10 | 909d | 33d |  | Verde | Verde | 0% | 0% | Compensatória | Verde | 0% | 0% |  | Banco |  |  |  |  |  |
| 1800 | 3.1.3.22.1.5 | **Elaboração do Projeto Executivo** |  | 111d | 2019-11-07 | 2020-04-23 |  |  |  | 2019-11-05 | 2020-04-20 | 111d | 2020-02-03 | 2020-07-07 | 876d |  |  | Verde | Verde | 0% | 0% | Compensatória | Verde | 0% | 0% |  |  |  |  |  |  |  |
| 1801 | 3.1.3.22.1.5.1 | Elaborar de projeto executivo |  | 40d | 2019-11-07 | 2020-01-08 | 1795 |  |  | 2019-11-05 | 2020-01-06 | 40d | 2020-02-03 | 2020-04-03 | 876d | 0d |  | Verde | Verde | 0% | 0% | Compensatória | Verde | 0% | 0% |  | Município |  |  |  |  |  |
| 1802 | 3.1.3.22.1.5.2 | Projeto Executivo de Mariana do Pleito MRNESPJ03 - Elaboração de projetos de engenharia dos distritos e bairros de Mariana apresentado ao banco | milestone | 0d | 2020-01-10 | 2020-01-10 | 1801FS+2d |  |  | 2020-01-08 | 2020-01-08 | 0d | 2020-04-03 | 2020-04-03 | 876d | 0d |  | Verde | Verde | 0% | 0% | Compensatória | Verde | 0% | 0% |  | Município |  |  |  |  |  |
| 1803 | 3.1.3.22.1.5.3 | Analisar projeto executivo |  | 64d | 2020-01-13 | 2020-04-15 | 1802 |  |  | 2020-01-09 | 2020-04-13 | 64d | 2020-04-06 | 2020-05-05 | 876d | 0d |  | Verde | Verde | 0% | 0% | Compensatória | Verde | 0% | 0% |  | Banco |  |  |  |  |  |
| 1804 | 3.1.3.22.1.5.4 | Projeto executivo de Mariana do Pleito MRNESPJ03 - Elaboração de projetos de engenharia dos distritos e bairros de Mariana concluído | milestone | 0d | 2020-04-15 | 2020-04-15 | 1799, 1803 |  |  | 2020-04-13 | 2020-04-13 | 0d | 2020-06-30 | 2020-06-30 | 876d | 0d |  | Verde | Verde | 0% | 0% | Compensatória | Verde | 0% | 0% |  | Município |  |  |  |  |  |
| 1805 | 3.1.3.22.1.5.5 | Recurso do projeto executivo de Mariana do Pleito MRNESPJ03 - Elaboração de projetos de engenharia dos distritos e bairros de Mariana repassado | milestone | 0d | 2020-04-23 | 2020-04-23 | 1804FS+5d |  |  | 2020-04-20 | 2020-04-20 | 0d | 2020-07-07 | 2020-07-07 | 876d | 0d |  | Verde | Verde | 0% | 0% | Compensatória | Verde | 0% | 0% |  | Banco |  |  |  |  |  |
| 1806 | 3.1.3.22.1.6 | Pleito MRNESPJ03 - Elaboração de projetos de engenharia distritos e bairros de Mariana concluído | milestone | 0d | 2020-04-23 | 2020-04-23 | 1805 |  |  | 2020-04-20 | 2020-04-20 | 0d | 2020-07-07 | 2020-07-07 | 876d |  |  | Verde | Verde | 0% | 0% | Compensatória | Verde | 0% | 0% |  | Município |  |  |  |  |  |
| 1807 | 3.1.3.22.2 | **Pleito MRNESPJ04 - Adequação dos projetos básicos e elaboração dos projetos executivos dos SES de Padre Viegas e Cachoeira do Brumado** |  | 277d | 2019-03-28 A | 2020-05-11 |  | 10% | 250.18d | 2019-03-28 | 2020-04-29 | 270d | 2019-03-28 | 2020-04-20 | 369d |  |  | Verde | Verde | 16% | 60% | Compensatória | Vermelho | 10% | 6% |  |  | 16 | 60 | 10 |  |  |
| 1808 | 3.1.3.22.2.1 | Alteração do Pleito MRNESPJ04 - Adequação dos projetos básicos e elaboração dos projetos executivos dos SES de Padre Viegas e Cachoeira do Brumado de Mariana aprovada | milestone | 0d | 2019-03-28 A | 2019-03-28 A |  | 100% |  | 2019-03-28 | 2019-03-28 | 0d | 2019-03-28 | 2019-03-28 |  |  | must start on 2019-03-28 | Verde | Verde | 100% | 100% | Compensatória | Verde | 100% | 100% |  | CT/CIF | 100 | 100 | 100 | 100 | 100 |
| 1809 | 3.1.3.22.2.2 | **Licitação do Projeto** |  | 69d | 2019-04-16 A | 2019-07-26 |  | 38% | 42.59d | 2019-04-16 | 2019-07-17 | 62d | 2019-04-08 | 2019-07-09 | 369d |  |  | Verde | Verde | 48% | 58% | Compensatória | Vermelho | 53% | 31% |  |  | 48 | 58 | 53 | 37 | 31 |
| 1810 | 3.1.3.22.2.2.1 | Licitação do projeto de Mariana do Pleito MRNESPJ04 - Adequação dos projetos básicos e elaboração dos projetos executivos dos SES de Padre Viegas e Cachoeira do Brumado autorizada pelo banco | milestone | 0d | 2019-04-16 A | 2019-04-16 A | 1808FS+14d | 100% |  | 2019-04-16 | 2019-04-16 | 0d | 2019-04-08 | 2019-04-08 |  |  |  | Verde | Verde | 100% | 100% | Compensatória | Verde | 100% | 100% |  | Banco | 100 | 100 | 100 | 100 | 100 |
| 1811 | 3.1.3.22.2.2.2 | Licitar projeto |  | 50d | 2019-04-17 A | 2019-07-01 | 1810 | 49% | 25.5d | 2019-04-17 | 2019-06-19 | 43d | 2019-04-09 | 2019-06-11 | 369d | 0d |  | Verde | Verde | 69% | 58% | Compensatória | Vermelho | 69% | 40% | Conforme agendado | Município | 69 | 58 | 69 | 49 | 40 |
| 1812 | 3.1.3.22.2.2.3 | Documentação de licitação de Mariana do Pleito MRNESPJ04 - Adequação dos projetos básicos e elaboração dos projetos executivos dos SES de Padre Viegas e Cachoeira do Brumado apresentada ao banco | milestone | 0d | 2019-07-08 | 2019-07-08 | 1811FS+5d |  |  | 2019-06-27 | 2019-06-27 | 0d | 2019-06-18 | 2019-06-18 | 369d | 0d |  | Verde | Verde | 0% | 0% | Compensatória | Verde | 0% | 0% |  | Município |  |  |  |  |  |
| 1813 | 3.1.3.22.2.2.4 | Analisar e emitir resultado da licitação do projeto |  | 14d | 2019-07-09 | 2019-07-26 | 1812 |  |  | 2019-06-28 | 2019-07-17 | 14d | 2019-06-19 | 2019-07-09 | 369d | 0d |  | Verde | Verde | 0% | 0% | Compensatória | Verde | 0% | 0% | Critério FR | Banco |  |  |  |  |  |
| 1814 | 3.1.3.22.2.2.5 | Licitação do projeto de Mariana do Pleito MRNESPJ04 - Adequação dos projetos básicos e elaboração dos projetos executivos dos SES de Padre Viegas e Cachoeira do Brumado concluída | milestone | 0d | 2019-07-26 | 2019-07-26 | 1813 |  |  | 2019-07-17 | 2019-07-17 | 0d | 2019-07-09 | 2019-07-09 | 369d | 0d |  | Verde | Verde | 0% | 0% | Compensatória | Verde | 0% | 0% |  | Município |  |  |  |  |  |

Notes:
- 1808: Em 24/04/2019: pleito foi aprovado na deliberação 269 no dia 28/03/2019
- 1810: 21/05/2019: atualizado conforme planilha Controle Gerencial (aba pleitos - status pleito)
- 1811: 21/05/2019: confirmar na reunião com o município o andamento da licitação / 02/07/2019: Telefonema com Danielle - Ainda não foi publicado o edital e o processo continua na prefeitura. Danielle não tem a data de término prevista e por isso a atividade foi reprogramada para o próximo ciclo.

| ID | WBS | Task | Type | Duration | Start | Finish | Predecessors | Complete | Remaining | Baseline start | Baseline finish | Baseline duration | Baseline 1 start | Baseline 1 finish | Total slack | Free slack | Constraint | Text1 | Text2 | Text3 | Text6 | Text8 | Text12 | Text14 | Text16 | Text9 | Text4 | Text5 | Text7 | Text15 | Text17 |
| --- | --- | --- | --- | --- | --- | --- | --- | --- | --- | --- | --- | --- | --- | --- | --- | --- | --- | --- | --- | --- | --- | --- | --- | --- | --- | --- | --- | --- | --- | --- | --- |
| 1815 | 3.1.3.22.2.3 | **Elaboração do Projeto Executivo** |  | 194d | 2019-07-29 | 2020-05-11 |  |  |  | 2019-07-18 | 2020-04-29 | 194d | 2019-07-10 | 2020-04-20 | 369d |  |  | Verde | Verde | 0% | 0% | Compensatória | Verde | 0% | 0% |  |  |  |  |  |  |
| 1816 | 3.1.3.22.2.3.1 | Elaborar projeto executivo |  | 125d | 2019-07-29 | 2020-01-27 | 1814 |  |  | 2019-07-18 | 2020-01-16 | 125d | 2019-07-10 | 2020-01-08 | 369d | 0d |  | Verde | Verde | 0% | 0% | Compensatória | Verde | 0% | 0% | Município |  |  |  |  |  |
| 1817 | 3.1.3.22.2.3.2 | Projeto Executivo de Mariana do Pleito MRNESPJ04 - Adequação dos projetos básicos e elaboração dos projetos executivos dos SES de Padre Viegas e Cachoeira do Brumado apresentado ao banco | milestone | 0d | 2020-01-27 | 2020-01-27 | 1816 |  |  | 2020-01-16 | 2020-01-16 | 0d | 2020-01-08 | 2020-01-08 | 369d | 0d |  | Verde | Verde | 0% | 0% | Compensatória | Verde | 0% | 0% | Município |  |  |  |  |  |
| 1818 | 3.1.3.22.2.3.3 | Analisar projeto executivo |  | 64d | 2020-01-28 | 2020-05-04 | 1817 |  |  | 2020-01-17 | 2020-04-22 | 64d | 2020-01-09 | 2020-02-10 | 369d | 0d |  | Verde | Verde | 0% | 0% | Compensatória | Verde | 0% | 0% | Banco |  |  |  |  |  |
| 1819 | 3.1.3.22.2.3.4 | Projeto executivo de Mariana do Pleito MRNESPJ04 - Adequação dos projetos básicos e elaboração dos projetos executivos dos SES de Padre Viegas e Cachoeira do Brumado concluído | milestone | 0d | 2020-05-04 | 2020-05-04 | 1818 |  |  | 2020-04-22 | 2020-04-22 | 0d | 2020-04-13 | 2020-04-13 | 369d | 0d |  | Verde | Verde | 0% | 0% | Compensatória | Verde | 0% | 0% | Município |  |  |  |  |  |
| 1820 | 3.1.3.22.2.3.5 | Recurso do projeto de Mariana do Pleito MRNESPJ04 - Adequação dos projetos básicos e elaboração dos projetos executivos dos SES de Padre Viegas e Cachoeira do Brumado repassado | milestone | 0d | 2020-05-11 | 2020-05-11 | 1819FS+5d |  |  | 2020-04-29 | 2020-04-29 | 0d | 2020-04-20 | 2020-04-20 | 369d | 0d |  | Verde | Verde | 0% | 0% | Compensatória | Verde | 0% | 0% | Banco |  |  |  |  |  |
| 1821 | 3.1.3.22.2.4 | Pleito MRNESPJ04 - Adequação dos projetos básicos e elaboração dos projetos executivos dos SES de Padre Viegas e Cachoeira do Brumado de Mariana concluído | milestone | 0d | 2020-05-11 | 2020-05-11 | 1820 |  |  | 2020-04-29 | 2020-04-29 | 0d | 2020-04-20 | 2020-04-20 | 369d | 0d |  | Verde | Verde | 0% | 0% | Compensatória | Verde | 0% | 0% | Município |  |  |  |  |  |
| 1822 | 3.1.3.22.3 | **Pleito MRNESPJ05 - Adequação de projetos de engenharia, referente à licenciamento, para Distritos de Padre Viegas e Cachoeira do Brumado** |  | 539d | 2019-03-28 A | 2021-05-28 |  |  | 539d | 2019-03-28 | 2021-05-19 | 532d | 2019-02-19 | 2020-03-20 | 603d |  |  | Verde | Verde | 8% | 0% | Compensatória | Vermelho | 0% | 0% |  |  |  |  |  |  |
| 1823 | 3.1.3.22.3.1 | Pleito MRNESPJ05 - Adequação de projetos de engenharia, referente à licenciamento, para Distritos de Padre Viegas e Cachoeira do Brumado de Mariana aprovado | milestone | 0d | 2019-03-28 A | 2019-03-28 A |  | 100% |  | 2019-03-28 | 2019-03-28 | 0d | 2019-03-28 | 2019-03-28 |  |  | must start on 2019-03-28 | Verde | Verde | 100% | 100% | Compensatória | Verde | 100% | 100% | CT/CIF | 100 | 100 | 100 | 100 | 100 |
| 1824 | 3.1.3.22.3.2 | **Licitação de Empresa para Licenciamento Ambiental** |  | 257d | 2019-04-16 A | 2020-04-30 |  |  | 257d | 2019-04-16 | 2020-04-20 | 250d | 2019-04-08 | 2019-07-10 | 603d |  |  | Verde | Verde | 12% | 0% | Compensatória | Vermelho | 0% | 0% |  |  | 12 |  |  |  |
| 1825 | 3.1.3.22.3.2.1 | Licitação da empresa para Licenciamento Ambiental de Mariana do Pleito MRNESPJ05 - Adequação de projetos de engenharia, referente à licenciamento, para Distritos de Padre Viegas e Cachoeira do Brumado autorizada pelo banco | milestone | 0d | 2019-04-16 A | 2019-04-16 A | 1823FS+14d | 100% |  | 2019-04-16 | 2019-04-16 | 0d | 2019-04-08 | 2019-04-08 |  |  |  | Verde | Verde | 100% | 100% | Compensatória | Verde | 100% | 100% | Banco | 100 | 100 | 100 | 100 | 100 |
| 1826 | 3.1.3.22.3.2.2 | Licitar empresa para Licenciamento Ambiental |  | 44d | 2020-01-28 | 2020-04-01 | 1825, 1816 |  |  | 2020-01-17 | 2020-03-23 | 44d | 2019-04-09 | 2019-06-12 | 603d | 0d |  | Verde | Verde | 0% | 0% | Compensatória | Verde | 0% | 0% | Município |  |  |  |  |  |
| 1827 | 3.1.3.22.3.2.3 | Documentação de licitação de Mariana do Pleito MRNESPJ05 - Adequação de projetos de engenharia, referente à licenciamento, para Distritos de Padre Viegas e Cachoeira do Brumado apresentada ao banco | milestone | 0d | 2020-04-08 | 2020-04-08 | 1826FS+5d |  |  | 2020-03-30 | 2020-03-30 | 0d | 2019-06-19 | 2019-06-19 | 603d | 0d |  | Verde | Verde | 0% | 0% | Compensatória | Verde | 0% | 0% | Município |  |  |  |  |  |
| 1828 | 3.1.3.22.3.2.4 | Analisar e emitir resultado da licitação do empresa para Licenciamento Ambiental |  | 14d | 2020-04-09 | 2020-04-30 | 1827 |  |  | 2020-03-31 | 2020-04-20 | 14d | 2019-06-21 | 2019-07-10 | 603d | 0d |  | Verde | Verde | 0% | 0% | Compensatória | Verde | 0% | 0% | Banco |  |  |  |  |  |
| 1829 | 3.1.3.22.3.2.5 | Licitação da empresa para Licenciamento Ambiental de Mariana do Pleito MRNESPJ05 - Adequação de projetos de engenharia, referente à licenciamento, para Distritos de Padre Viegas e Cachoeira do Brumado concluída | milestone | 0d | 2020-04-30 | 2020-04-30 | 1828 |  |  | 2020-04-20 | 2020-04-20 | 0d | 2019-07-10 | 2019-07-10 | 603d | 0d |  | Verde | Verde | 0% | 0% | Compensatória | Verde | 0% | 0% | Município |  |  |  |  |  |
| 1830 | 3.1.3.22.3.3 | Executar o Licenciamento Ambiental |  | 263d | 2020-05-04 | 2021-05-21 | 1829 |  |  | 2020-04-22 | 2021-05-12 | 263d | 2019-02-19 | 2020-03-13 | 603d | 0d |  | Verde | Verde | 0% | 0% | Compensatória | Verde | 0% | 0% | Município |  |  |  |  |  |
| 1831 | 3.1.3.22.3.4 | Recurso do serviço de Mariana do Pleito MRNESPJ05 - Adequação de projetos de engenharia, referente à licenciamento, para Distritos de Padre Viegas e Cachoeira do Brumado repassado | milestone | 0d | 2021-05-28 | 2021-05-28 | 1830FS+5d |  |  | 2021-05-19 | 2021-05-19 | 0d | 2020-03-20 | 2020-03-20 | 603d | 0d |  | Verde | Verde | 0% | 0% | Compensatória | Verde | 0% | 0% | Banco |  |  |  |  |  |
| 1832 | 3.1.3.22.3.5 | Pleito MRNESPJ05 - Adequação de projetos de engenharia, referente à licenciamento, para Distritos de Padre Viegas e Cachoeira do Brumado de Mariana concluído | milestone | 0d | 2021-05-28 | 2021-05-28 | 1831 |  |  | 2021-05-19 | 2021-05-19 | 0d | 2020-03-20 | 2020-03-20 | 603d |  |  | Verde | Verde | 0% | 0% | Compensatória | Verde | 0% | 0% | Município |  |  |  |  |  |
| 1833 | 3.1.3.22.4 | **Pleito MRNESOB06 - Execução de obras de implantação do SES para distrito de Cachoeira do Brumado** |  | 496d | 2020-05-11 | 2022-05-06 |  |  |  | 2020-04-29 | 2022-04-27 | 496d | 2020-04-20 | 2022-04-29 | 369d |  |  | Verde | Verde | 0% | 0% | Compensatória | Verde | 0% | 0% |  |  |  |  |  |  |
| 1834 | 3.1.3.22.4.1 | **Licitação da obra** |  | 102d | 2020-05-11 | 2020-10-02 |  |  |  | 2020-04-29 | 2020-09-23 | 102d | 2020-04-20 | 2020-09-15 | 369d |  |  | Verde | Verde | 0% | 0% | Compensatória | Verde | 0% | 0% |  |  |  |  |  |  |
| 1835 | 3.1.3.22.4.1.1 | Licitação da obra de Mariana do Pleito MRNESOB06 - Execução de obras de implantação do SES para distrito de Cachoeira do Brumado autorizada pelo banco | milestone | 0d | 2020-05-11 | 2020-05-11 | 1821 |  |  | 2020-04-29 | 2020-04-29 | 0d | 2020-04-20 | 2020-04-20 | 369d | 0d |  | Verde | Verde | 0% | 0% | Compensatória | Verde | 0% | 0% | Banco |  |  |  |  |  |
| 1836 | 3.1.3.22.4.1.2 | Licitar Obra |  | 87d | 2020-05-12 | 2020-09-11 | 1835 |  |  | 2020-04-30 | 2020-09-01 | 87d | 2020-04-22 | 2020-08-24 | 369d | 0d |  | Verde | Verde | 0% | 0% | Compensatória | Verde | 0% | 0% | Município |  |  |  |  |  |
| 1837 | 3.1.3.22.4.1.3 | Analisar e emitir resultado da licitação da obra |  | 15d | 2020-09-14 | 2020-10-02 | 1836 |  |  | 2020-09-02 | 2020-09-23 | 15d | 2020-08-25 | 2020-09-15 | 369d | 0d |  | Verde | Verde | 0% | 0% | Compensatória | Verde | 0% | 0% | Banco |  |  |  |  |  |
| 1838 | 3.1.3.22.4.1.4 | Licitação da obra de Mariana do Pleito MRNESOB06 - Execução de obras de implantação do SES para distrito de Cachoeira do Brumado concluída | milestone | 0d | 2020-10-02 | 2020-10-02 | 1837 |  |  | 2020-09-23 | 2020-09-23 | 0d | 2020-09-15 | 2020-09-15 | 369d | 0d |  | Verde | Verde | 0% | 0% | Compensatória | Verde | 0% | 0% | Município |  |  |  |  |  |
| 1839 | 3.1.3.22.4.2 | Executar obra |  | 249d | 2020-11-04 | 2021-11-03 | 1838FS+20d |  |  | 2020-10-23 | 2021-10-22 | 249d | 2020-10-15 | 2021-10-14 | 369d | 0d |  | Verde | Verde | 0% | 0% | Compensatória | Verde | 0% | 0% | Município |  |  |  |  |  |
| 1840 | 3.1.3.22.4.3 | Realizar processo de pré-operação |  | 120d | 2021-11-04 | 2022-04-29 | 1839 |  |  | 2021-10-25 | 2022-04-19 | 120d | 2021-10-15 | 2022-04-22 | 369d | 0d |  | Verde | Verde | 0% | 0% | Compensatória | Verde | 0% | 0% | Município |  |  |  |  |  |
| 1841 | 3.1.3.22.4.4 | Recurso da obra de Mariana do Pleito MRNESOB06 - Execução de obras de implantação do SES para distrito de Cachoeira do Brumado repassado | milestone | 0d | 2022-05-06 | 2022-05-06 | 1840FS+5d |  |  | 2022-04-27 | 2022-04-27 | 0d | 2022-04-29 | 2022-04-29 | 369d | 0d |  | Verde | Verde | 0% | 0% | Compensatória | Verde | 0% | 0% | Banco |  |  |  |  |  |
| 1842 | 3.1.3.22.4.5 | Pleito MRNESOB06 - Execução de obras de implantação do SES para distrito de Cachoeira do Brumado de Mariana concluído | milestone | 0d | 2022-05-06 | 2022-05-06 | 1841 |  |  | 2022-04-27 | 2022-04-27 | 0d | 2022-04-29 | 2022-04-29 | 369d |  |  | Verde | Verde | 0% | 0% | Compensatória | Verde | 0% | 0% | Município |  |  |  |  |  |

Notes:
- 1823: Em 24/04/2019: pleito foi aprovado na deliberação 269 no dia 28/03/2019
- 1825: 21/05/2019: atualizado conforme planilha Controle Gerencial (aba pleitos - status pleito)
- 1826: Em 29/04/2019: atualizado como agendado / 21/05/2019: confirmar na reunião com o município o andamento da licitação / 27/05/2019: não começaram a licitação do serviço, porque estão esperando o projeto básico.
- 1830: 21/05/2019: confirmar na reunião com o município o andamento do licenciamento
- 1839: Em 24/04/2019: valor da obra R$ 3.045.229,52

| ID | WBS | Task | Type | Duration | Start | Finish | Predecessors | Complete | Remaining | Baseline start | Baseline finish | Baseline duration | Baseline 1 start | Baseline 1 finish | Total slack | Free slack | Constraint | Text1 | Text2 | Text3 | Text6 | Text8 | Text12 | Text14 | Text16 | Text9 | Text5 | Text7 | Text15 | Text4 | Text17 | Text18 |
| --- | --- | --- | --- | --- | --- | --- | --- | --- | --- | --- | --- | --- | --- | --- | --- | --- | --- | --- | --- | --- | --- | --- | --- | --- | --- | --- | --- | --- | --- | --- | --- | --- |
| 1843 | 3.1.3.22.5 | **Pleito MRNESOB05 - Execução de obras de implantação do SES para o distrito Padre Viegas** |  | 412d | 2020-05-11 | 2022-01-03 |  |  |  | 2020-04-29 | 2021-12-22 | 412d | 2020-04-20 | 2021-12-27 | 453d |  |  | Verde | Verde | 0% | 0% | Compensatória | Verde | 0% | 0% |  |  |  |  |  |  |  |
| 1844 | 3.1.3.22.5.1 | **Licitação da obra** |  | 102d | 2020-05-11 | 2020-10-02 |  |  |  | 2020-04-29 | 2020-09-23 | 102d | 2020-04-20 | 2020-09-15 | 453d |  |  | Verde | Verde | 0% | 0% | Compensatória | Verde | 0% | 0% |  |  |  |  |  |  |  |
| 1845 | 3.1.3.22.5.1.1 | Licitação da obra de Mariana do Pleito MRNESOB05 - Execução de obras de implantação do SES para o distrito Padre Viegas autorizada pelo banco | milestone | 0d | 2020-05-11 | 2020-05-11 | 1821 |  |  | 2020-04-29 | 2020-04-29 | 0d | 2020-04-20 | 2020-04-20 | 453d | 0d |  | Verde | Verde | 0% | 0% | Compensatória | Verde | 0% | 0% | Banco |  |  |  |  |  |  |
| 1846 | 3.1.3.22.5.1.2 | Licitar Obra |  | 87d | 2020-05-12 | 2020-09-11 | 1845 |  |  | 2020-04-30 | 2020-09-01 | 87d | 2020-04-22 | 2020-08-24 | 453d | 0d |  | Verde | Verde | 0% | 0% | Compensatória | Verde | 0% | 0% | Município |  |  |  |  |  |  |
| 1847 | 3.1.3.22.5.1.3 | Analisar e emitir resultado da licitação da obra |  | 15d | 2020-09-14 | 2020-10-02 | 1846 |  |  | 2020-09-02 | 2020-09-23 | 15d | 2020-08-25 | 2020-09-15 | 453d | 0d |  | Verde | Verde | 0% | 0% | Compensatória | Verde | 0% | 0% | Banco |  |  |  |  |  |  |
| 1848 | 3.1.3.22.5.1.4 | Licitação da obra de Mariana do Pleito MRNESOB05 - Execução de obras de implantação do SES para o distrito Padre Viegas concluída | milestone | 0d | 2020-10-02 | 2020-10-02 | 1847 |  |  | 2020-09-23 | 2020-09-23 | 0d | 2020-09-15 | 2020-09-15 | 453d | 0d |  | Verde | Verde | 0% | 0% | Compensatória | Verde | 0% | 0% | Município |  |  |  |  |  |  |
| 1849 | 3.1.3.22.5.2 | Executar obra |  | 165d | 2020-11-04 | 2021-07-05 | 1848FS+20d |  |  | 2020-10-23 | 2021-06-24 | 165d | 2020-10-15 | 2021-06-16 | 453d | 0d |  | Verde | Verde | 0% | 0% | Compensatória | Verde | 0% | 0% | Município |  |  |  |  |  |  |
| 1850 | 3.1.3.22.5.3 | Realizar processo de pré-operação |  | 120d | 2021-07-06 | 2021-12-27 | 1849 |  |  | 2021-06-25 | 2021-12-15 | 120d | 2021-06-17 | 2021-12-17 | 453d | 0d |  | Verde | Verde | 0% | 0% | Compensatória | Verde | 0% | 0% | Município |  |  |  |  |  |  |
| 1851 | 3.1.3.22.5.4 | Recurso da obra de Mariana do Pleito MRNESOB05 - Execução de obras de implantação do SES para o distrito Padre Viegas repassado | milestone | 0d | 2022-01-03 | 2022-01-03 | 1850FS+5d |  |  | 2021-12-22 | 2021-12-22 | 0d | 2021-12-27 | 2021-12-27 | 453d | 0d |  | Verde | Verde | 0% | 0% | Compensatória | Verde | 0% | 0% | Banco |  |  |  |  |  |  |
| 1852 | 3.1.3.22.5.5 | Pleito MRNESOB05 - Execução de obras de implantação do SES para o distrito Padre Viegas de Mariana concluído | milestone | 0d | 2022-01-03 | 2022-01-03 | 1851 |  |  | 2021-12-22 | 2021-12-22 | 0d | 2021-12-27 | 2021-12-27 | 453d |  |  | Verde | Verde | 0% | 0% | Compensatória | Verde | 0% | 0% | Município |  |  |  |  |  |  |
| 1853 | 3.1.3.22.6 | **Pleito MRNESPJ06 - Elaboração de projetos de engenharia para a Sede de Mariana** |  | 277d | 2019-03-28 A | 2020-05-11 |  | 10% | 250.18d | 2019-03-28 | 2020-04-29 | 270d | 2019-03-28 | 2020-04-20 | 865d |  |  | Verde | Verde | 16% | 73% | Compensatória | Vermelho | 11% | 8% |  | 16 | 73 | 11 |  |  |  |
| 1854 | 3.1.3.22.6.1 | Alteração do Pleito MRNESPJ06 - Elaboração de projetos de engenharia para a Sede de Mariana aprovada | milestone | 0d | 2019-03-28 A | 2019-03-28 A |  | 100% |  | 2019-03-28 | 2019-03-28 | 0d | 2019-03-28 | 2019-03-28 |  |  | must start on 2019-03-28 | Verde | Verde | 100% | 100% | Compensatória | Verde | 100% | 100% | CT/CIF | 100 | 100 | 100 | 100 | 100 |  |
| 1855 | 3.1.3.22.6.2 | **Licitação do Projeto** |  | 69d | 2019-04-16 A | 2019-07-26 |  | 38% | 42.59d | 2019-04-16 | 2019-07-17 | 62d | 2019-04-08 | 2019-07-09 | 373d |  |  | Verde | Verde | 48% | 68% | Compensatória | Vermelho | 56% | 38% |  | 48 | 68 | 56 | 37 | 38 |  |
| 1856 | 3.1.3.22.6.2.1 | Licitação do projeto de Mariana do Pleito MRNESPJ06 - Elaboração de projetos de engenharia para a Sede de Mariana autorizada pelo banco | milestone | 0d | 2019-04-16 A | 2019-04-16 A | 1854FS+14d | 100% |  | 2019-04-16 | 2019-04-16 | 0d | 2019-04-08 | 2019-04-08 |  |  |  | Verde | Verde | 100% | 100% | Compensatória | Verde | 100% | 100% | Banco | 100 | 100 | 100 | 100 | 100 |  |
| 1857 | 3.1.3.22.6.2.2 | Licitar projeto |  | 50d | 2019-04-17 A | 2019-07-01 | 1856 | 49% | 25.5d | 2019-04-17 | 2019-06-19 | 43d | 2019-04-09 | 2019-06-11 | 373d | 0d |  | Verde | Verde | 69% | 68% | Compensatória | Vermelho | 69% | 47% | Município | 69 | 68 | 69 | 49 | 47 | Conforme agendado |
| 1858 | 3.1.3.22.6.2.3 | Documentação de licitação de Mariana do Pleito MRNESPJ06 - Elaboração de projetos de engenharia para a Sede de Mariana apresentada ao banco | milestone | 0d | 2019-07-08 | 2019-07-08 | 1857FS+5d |  |  | 2019-06-27 | 2019-06-27 | 0d | 2019-06-18 | 2019-06-18 | 373d | 0d |  | Verde | Verde | 0% | 0% | Compensatória | Verde | 0% | 0% | Município |  |  |  |  |  |  |
| 1859 | 3.1.3.22.6.2.4 | Analisar e emitir resultado da licitação do projeto |  | 14d | 2019-07-09 | 2019-07-26 | 1858 |  |  | 2019-06-28 | 2019-07-17 | 14d | 2019-06-19 | 2019-07-09 | 373d | 0d |  | Verde | Verde | 0% | 0% | Compensatória | Verde | 0% | 0% | Banco |  |  |  |  |  | Critério FR |
| 1860 | 3.1.3.22.6.2.5 | Licitação do projeto de Mariana do Pleito MRNESPJ06 - Elaboração de projetos de engenharia para a Sede de Mariana concluída | milestone | 0d | 2019-07-26 | 2019-07-26 | 1859 |  |  | 2019-07-17 | 2019-07-17 | 0d | 2019-07-09 | 2019-07-09 | 373d | 0d |  | Verde | Verde | 0% | 0% | Compensatória | Verde | 0% | 0% | Município |  |  |  |  |  |  |
| 1861 | 3.1.3.22.6.3 | **Elaboração do Projeto Executivo** |  | 194d | 2019-07-29 | 2020-05-11 |  |  |  | 2019-07-18 | 2020-04-29 | 194d | 2019-07-10 | 2020-04-20 | 373d |  |  | Verde | Verde | 0% | 0% | Compensatória | Verde | 0% | 0% |  |  |  |  |  |  |  |
| 1862 | 3.1.3.22.6.3.1 | Elaborar projeto executivo |  | 125d | 2019-07-29 | 2020-01-27 | 1860 |  |  | 2019-07-18 | 2020-01-16 | 125d | 2019-07-10 | 2020-01-08 | 373d | 0d |  | Verde | Verde | 0% | 0% | Compensatória | Verde | 0% | 0% | Município |  |  |  |  |  |  |
| 1863 | 3.1.3.22.6.3.2 | Projeto executivo de Mariana do Pleito MRNESPJ06 - Elaboração de projetos de engenharia para a Sede de Mariana apresentado ao banco | milestone | 0d | 2020-01-27 | 2020-01-27 | 1862 |  |  | 2020-01-16 | 2020-01-16 | 0d | 2020-01-08 | 2020-01-08 | 373d | 0d |  | Verde | Verde | 0% | 0% | Compensatória | Verde | 0% | 0% | Município |  |  |  |  |  |  |
| 1864 | 3.1.3.22.6.3.3 | Analisar projeto executivo |  | 64d | 2020-01-28 | 2020-05-04 | 1863 |  |  | 2020-01-17 | 2020-04-22 | 64d | 2020-01-09 | 2020-02-10 | 373d | 0d |  | Verde | Verde | 0% | 0% | Compensatória | Verde | 0% | 0% | Banco |  |  |  |  |  |  |
| 1865 | 3.1.3.22.6.3.4 | Projeto executivo de Mariana do Pleito MRNESPJ06 - Elaboração de projetos de engenharia para a Sede de Mariana concluído | milestone | 0d | 2020-05-04 | 2020-05-04 | 1864 |  |  | 2020-04-22 | 2020-04-22 | 0d | 2020-04-13 | 2020-04-13 | 373d | 0d |  | Verde | Verde | 0% | 0% | Compensatória | Verde | 0% | 0% | Município |  |  |  |  |  |  |
| 1866 | 3.1.3.22.6.3.5 | Recurso do projeto de Mariana do Pleito MRNESPJ06 - Elaboração de projetos de engenharia para a Sede de Mariana repassado | milestone | 0d | 2020-05-11 | 2020-05-11 | 1865FS+5d |  |  | 2020-04-29 | 2020-04-29 | 0d | 2020-04-20 | 2020-04-20 | 865d | 0d |  | Verde | Verde | 0% | 0% | Compensatória | Verde | 0% | 0% | Banco |  |  |  |  |  |  |
| 1867 | 3.1.3.22.6.4 | Pleito MRNESPJ06 - Elaboração de projetos de engenharia para a Sede de Mariana concluído | milestone | 0d | 2020-05-11 | 2020-05-11 | 1866 |  |  | 2020-04-29 | 2020-04-29 | 0d | 2020-04-20 | 2020-04-20 | 865d |  |  | Verde | Verde | 0% | 0% | Compensatória | Verde | 0% | 0% | Município |  |  |  |  |  |  |

Notes:
- 1849: Em 24/04/2019: valor da obra R$ 1,9 milhões
- 1854: Em 24/04/2019: pleito foi aprovado na deliberação 269 no dia 28/03/2019
- 1856: 21/05/2019: atualizado conforme planilha Controle Gerencial (aba pleitos - status pleito)
- 1857: 21/05/2019: confirmar na reunião com o município o andamento da licitação / 27/05/2019: termo de referência encaminhado a prefeitura do município dia 22/04/2019. / 02/07/2019: Telefonema com Danielle - Ainda não foi publicado o edital e o processo continua na prefeitura. Danielle não tem a data de término prevista e por isso a atividade foi reprogramada para o próximo ciclo.

| ID | WBS | Task | Type | Duration | Start | Finish | Predecessors | Baseline start | Baseline finish | Baseline duration | Baseline 1 start | Baseline 1 finish | Total slack | Free slack | Text1 | Text2 | Text3 | Text6 | Text8 | Text12 | Text14 | Text16 | Text9 |
| --- | --- | --- | --- | --- | --- | --- | --- | --- | --- | --- | --- | --- | --- | --- | --- | --- | --- | --- | --- | --- | --- | --- | --- |
| 1868 | 3.1.3.22.7 | **Pleito MRNESOB04 - Execução de obras de implantação do SES para a cidade de Mariana** |  | 497d | 2020-05-04 | 2022-05-02 |  | 2020-04-22 | 2022-04-20 | 497d | 2020-04-13 | 2022-04-25 | 373d |  | Verde | Verde | 0% | 0% | Compensatória | Verde | 0% | 0% |  |
| 1869 | 3.1.3.22.7.1 | **Licitação da obra** |  | 102d | 2020-05-04 | 2020-09-25 |  | 2020-04-22 | 2020-09-16 | 102d | 2020-04-13 | 2020-09-08 | 373d |  | Verde | Verde | 0% | 0% | Compensatória | Verde | 0% | 0% |  |
| 1870 | 3.1.3.22.7.1.1 | Licitação da obra autorizada pelo banco | milestone | 0d | 2020-05-04 | 2020-05-04 | 1865 | 2020-04-22 | 2020-04-22 | 0d | 2020-04-13 | 2020-04-13 | 373d | 0d | Verde | Verde | 0% | 0% | Compensatória | Verde | 0% | 0% | Banco |
| 1871 | 3.1.3.22.7.1.2 | Licitar Obra |  | 87d | 2020-05-05 | 2020-09-03 | 1870 | 2020-04-23 | 2020-08-25 | 87d | 2020-04-14 | 2020-08-17 | 373d | 0d | Verde | Verde | 0% | 0% | Compensatória | Verde | 0% | 0% | Município |
| 1872 | 3.1.3.22.7.1.3 | Analisar e emitir resultado da licitação da obra |  | 15d | 2020-09-04 | 2020-09-25 | 1871 | 2020-08-26 | 2020-09-16 | 15d | 2020-08-18 | 2020-09-08 | 373d | 0d | Verde | Verde | 0% | 0% | Compensatória | Verde | 0% | 0% | Banco |
| 1873 | 3.1.3.22.7.1.4 | Licitação da obra concluída | milestone | 0d | 2020-09-25 | 2020-09-25 | 1872 | 2020-09-16 | 2020-09-16 | 0d | 2020-09-08 | 2020-09-08 | 373d | 0d | Verde | Verde | 0% | 0% | Compensatória | Verde | 0% | 0% | Município |
| 1874 | 3.1.3.22.7.2 | Executar obra |  | 250d | 2020-10-27 | 2021-10-27 | 1873FS+20d | 2020-10-16 | 2021-10-18 | 250d | 2020-10-07 | 2021-10-07 | 373d | 0d | Verde | Verde | 0% | 0% | Compensatória | Verde | 0% | 0% | Município |
| 1875 | 3.1.3.22.7.3 | Realizar processo de pré-operação |  | 120d | 2021-10-28 | 2022-04-25 | 1874 | 2021-10-19 | 2022-04-12 | 120d | 2021-10-08 | 2022-04-14 | 373d | 0d | Verde | Verde | 0% | 0% | Compensatória | Verde | 0% | 0% | Município |
| 1876 | 3.1.3.22.7.4 | Recurso da obra do pleito MRNESOB04 repassado | milestone | 0d | 2022-05-02 | 2022-05-02 | 1875FS+5d | 2022-04-20 | 2022-04-20 | 0d | 2022-04-25 | 2022-04-25 | 373d | 0d | Verde | Verde | 0% | 0% | Compensatória | Verde | 0% | 0% | Banco |
| 1877 | 3.1.3.22.7.5 | Pleito MRNESOB04 - Execução de obras de implantação do SES para a cidade de Mariana concluído | milestone | 0d | 2022-05-02 | 2022-05-02 | 1876 | 2022-04-20 | 2022-04-20 | 0d | 2022-04-25 | 2022-04-25 | 373d |  | Verde | Verde | 0% | 0% | Compensatória | Verde | 0% | 0% | Município |
| 1878 | 3.1.3.22.8 | **Pleito MRNESCT01 - Indenização pela desapropriação da área local onde será implantada a ETE no distrito Sede de Mariana** |  | 143d | 2020-03-04 | 2020-09-25 |  | 2020-02-19 | 2020-09-16 | 143d | 2020-02-11 | 2020-09-08 | 768d |  | Verde | Verde | 0% | 0% | Compensatória | Verde | 0% | 0% |  |
| 1879 | 3.1.3.22.8.1 | **Aquisição de Terreno** |  | 143d | 2020-03-04 | 2020-09-25 |  | 2020-02-19 | 2020-09-16 | 143d | 2020-02-11 | 2020-09-08 | 768d |  | Verde | Verde | 0% | 0% | Compensatória | Verde | 0% | 0% |  |
| 1880 | 3.1.3.22.8.1.1 | Regularizar terreno e apresentar escritura ao banco |  | 82d | 2020-03-04 | 2020-07-01 | 1864FS-41d | 2020-02-19 | 2020-06-22 | 82d | 2020-02-11 | 2020-06-12 | 768d | 0d | Verde | Verde | 0% | 0% | Compensatória | Verde | 0% | 0% | Município |
| 1881 | 3.1.3.22.8.1.2 | Analisar documentação do terreno |  | 10d | 2020-07-02 | 2020-07-15 | 1880 | 2020-06-23 | 2020-07-06 | 10d | 2020-06-15 | 2020-06-26 | 814d | 0d | Verde | Verde | 0% | 0% | Compensatória | Verde | 0% | 0% | Banco |
| 1882 | 3.1.3.22.8.1.3 | 50% do valor do imóvel do pleito MRNESCT01 repassado | milestone | 0d | 2020-07-22 | 2020-07-22 | 1881FS+5d | 2020-07-13 | 2020-07-13 | 0d | 2020-07-03 | 2020-07-03 | 814d | 46d | Verde | Verde | 0% | 0% | Compensatória | Verde | 0% | 0% | Banco |
| 1883 | 3.1.3.22.8.1.4 | Registrar imóvel e apresentar documentação ao banco |  | 46d | 2020-07-02 | 2020-09-03 | 1880 | 2020-06-23 | 2020-08-25 | 46d | 2020-06-15 | 2020-08-17 | 768d | 0d | Verde | Verde | 0% | 0% | Compensatória | Verde | 0% | 0% | Município |
| 1884 | 3.1.3.22.8.1.5 | Analisar documentação do terreno |  | 10d | 2020-09-04 | 2020-09-18 | 1883 | 2020-08-26 | 2020-09-09 | 10d | 2020-08-18 | 2020-08-31 | 768d | 0d | Verde | Verde | 0% | 0% | Compensatória | Verde | 0% | 0% | Banco |
| 1885 | 3.1.3.22.8.1.6 | 50% do valor do imóvel do pleito MRNESCT01 repassado | milestone | 0d | 2020-09-25 | 2020-09-25 | 1884FS+5d | 2020-09-16 | 2020-09-16 | 0d | 2020-09-08 | 2020-09-08 | 768d | 0d | Verde | Verde | 0% | 0% | Compensatória | Verde | 0% | 0% | Banco |
| 1886 | 3.1.3.22.8.1.7 | Aquisição de Terreno concluída | milestone | 0d | 2020-09-25 | 2020-09-25 | 1885, 1882 | 2020-09-16 | 2020-09-16 | 0d | 2020-09-08 | 2020-09-08 | 768d | 0d | Verde | Verde | 0% | 0% | Compensatória | Verde | 0% | 0% | Município |
| 1887 | 3.1.3.22.8.2 | Pleito MRNESCT01 - Indenização pela desapropriação da área local onde será implantada a ETE no distrito Sede de Mariana concluído | milestone | 0d | 2020-09-25 | 2020-09-25 | 1886 | 2020-09-16 | 2020-09-16 | 0d | 2020-09-08 | 2020-09-08 | 768d |  | Verde | Verde | 0% | 0% | Compensatória | Verde | 0% | 0% | Município |
| 1888 | 3.1.3.22.9 | **Pleito MRNESCT02 - Indenização pela desapropriação de área, local onde será implantada a EEE do Ribeirão do Carmo para o SES do distrito Sede de Mariana** |  | 143d | 2020-05-05 | 2020-11-25 |  | 2020-02-19 | 2020-09-16 | 143d | 2020-02-11 | 2020-09-08 | 727d |  | Verde | Verde | 0% | 0% | Compensatória | Verde | 0% | 0% |  |
| 1889 | 3.1.3.22.9.1 | **Aquisição de Terreno** |  | 143d | 2020-05-05 | 2020-11-25 |  | 2020-02-19 | 2020-09-16 | 143d | 2020-02-11 | 2020-09-08 | 727d |  | Verde | Verde | 0% | 0% | Compensatória | Verde | 0% | 0% |  |
| 1890 | 3.1.3.22.9.1.1 | Regularizar terreno e apresentar escritura ao banco |  | 82d | 2020-05-05 | 2020-08-27 | 1864 | 2020-02-19 | 2020-06-22 | 82d | 2020-02-11 | 2020-06-12 | 727d | 0d | Verde | Verde | 0% | 0% | Compensatória | Verde | 0% | 0% | Município |
| 1891 | 3.1.3.22.9.1.2 | Analisar documentação do terreno |  | 10d | 2020-08-28 | 2020-09-11 | 1890 | 2020-06-23 | 2020-07-06 | 10d | 2020-06-15 | 2020-06-26 | 773d | 0d | Verde | Verde | 0% | 0% | Compensatória | Verde | 0% | 0% | Banco |
| 1892 | 3.1.3.22.9.1.3 | 50% do valor do imóvel do pleito MRNESCT02 repassado | milestone | 0d | 2020-09-18 | 2020-09-18 | 1891FS+5d | 2020-07-13 | 2020-07-13 | 0d | 2020-07-03 | 2020-07-03 | 773d | 46d | Verde | Verde | 0% | 0% | Compensatória | Verde | 0% | 0% | Banco |
| 1893 | 3.1.3.22.9.1.4 | Registrar imóvel e apresentar documentação ao banco |  | 46d | 2020-08-28 | 2020-11-04 | 1890 | 2020-06-23 | 2020-08-25 | 46d | 2020-06-15 | 2020-08-17 | 727d | 0d | Verde | Verde | 0% | 0% | Compensatória | Verde | 0% | 0% | Município |
| 1894 | 3.1.3.22.9.1.5 | Analisar documentação do terreno |  | 10d | 2020-11-05 | 2020-11-18 | 1893 | 2020-08-26 | 2020-09-09 | 10d | 2020-08-18 | 2020-08-31 | 727d | 0d | Verde | Verde | 0% | 0% | Compensatória | Verde | 0% | 0% | Banco |
| 1895 | 3.1.3.22.9.1.6 | 50% do valor do imóvel do pleito MRNESCT02 repassado | milestone | 0d | 2020-11-25 | 2020-11-25 | 1894FS+5d | 2020-09-16 | 2020-09-16 | 0d | 2020-09-08 | 2020-09-08 | 727d | 0d | Verde | Verde | 0% | 0% | Compensatória | Verde | 0% | 0% | Banco |
| 1896 | 3.1.3.22.9.1.7 | Aquisição de Terreno concluída | milestone | 0d | 2020-11-25 | 2020-11-25 | 1895, 1892 | 2020-09-16 | 2020-09-16 | 0d | 2020-09-08 | 2020-09-08 | 727d | 0d | Verde | Verde | 0% | 0% | Compensatória | Verde | 0% | 0% | Município |
| 1897 | 3.1.3.22.9.2 | Pleito MRNESCT02 - Indenização pela desapropriação de área, local onde será implantada a EEE do Ribeirão do Carmo para o SES do distrito Sede de Mariana concluído | milestone | 0d | 2020-11-25 | 2020-11-25 | 1896 | 2020-09-16 | 2020-09-16 | 0d | 2020-09-08 | 2020-09-08 | 727d |  | Verde | Verde | 0% | 0% | Compensatória | Verde | 0% | 0% | Município |

Notes:
- 1874: Em 24/04/2019: valor da obra R$ 3 milhões

| ID | WBS | Task | Type | Duration | Start | Finish | Predecessors | Complete | Remaining | Baseline start | Baseline finish | Baseline duration | Baseline 1 start | Baseline 1 finish | Total slack | Free slack | Text1 | Text2 | Text3 | Text6 | Text8 | Text12 | Text14 | Text16 | Text9 | Text18 | Text5 | Text7 | Text4 | Text15 | Text17 |
| --- | --- | --- | --- | --- | --- | --- | --- | --- | --- | --- | --- | --- | --- | --- | --- | --- | --- | --- | --- | --- | --- | --- | --- | --- | --- | --- | --- | --- | --- | --- | --- |
| 1898 | 3.1.3.22.10 | **Pleito MRNESCT03 - Indenização pela desapropriação de área onde será implantada EEE do Córrego Santana** |  | 143d | 2020-05-05 | 2020-11-25 |  |  |  | 2020-02-19 | 2020-09-16 | 143d | 2020-02-11 | 2020-09-08 | 727d |  | Verde | Verde | 0% | 0% | Compensatória | Verde | 0% | 0% |  |  |  |  |  |  |  |
| 1899 | 3.1.3.22.10.1 | **Aquisição de Terreno** |  | 143d | 2020-05-05 | 2020-11-25 |  |  |  | 2020-02-19 | 2020-09-16 | 143d | 2020-02-11 | 2020-09-08 | 727d |  | Verde | Verde | 0% | 0% | Compensatória | Verde | 0% | 0% |  |  |  |  |  |  |  |
| 1900 | 3.1.3.22.10.1.1 | Regularizar terreno e apresentar escritura ao banco |  | 82d | 2020-05-05 | 2020-08-27 | 1864 |  |  | 2020-02-19 | 2020-06-22 | 82d | 2020-02-11 | 2020-06-12 | 727d | 0d | Verde | Verde | 0% | 0% | Compensatória | Verde | 0% | 0% | Município |  |  |  |  |  |  |
| 1901 | 3.1.3.22.10.1.2 | Analisar documentação do terreno |  | 10d | 2020-08-28 | 2020-09-11 | 1900 |  |  | 2020-06-23 | 2020-07-06 | 10d | 2020-06-15 | 2020-06-26 | 773d | 0d | Verde | Verde | 0% | 0% | Compensatória | Verde | 0% | 0% | Banco |  |  |  |  |  |  |
| 1902 | 3.1.3.22.10.1.3 | 50% do valor do imóvel do pleito MRNESCT03 repassado | milestone | 0d | 2020-09-18 | 2020-09-18 | 1901FS+5d |  |  | 2020-07-13 | 2020-07-13 | 0d | 2020-07-03 | 2020-07-03 | 773d | 46d | Verde | Verde | 0% | 0% | Compensatória | Verde | 0% | 0% | Banco |  |  |  |  |  |  |
| 1903 | 3.1.3.22.10.1.4 | Registrar imóvel e apresentar documentação ao banco |  | 46d | 2020-08-28 | 2020-11-04 | 1900 |  |  | 2020-06-23 | 2020-08-25 | 46d | 2020-06-15 | 2020-08-17 | 727d | 0d | Verde | Verde | 0% | 0% | Compensatória | Verde | 0% | 0% | Município |  |  |  |  |  |  |
| 1904 | 3.1.3.22.10.1.5 | Analisar documentação do terreno |  | 10d | 2020-11-05 | 2020-11-18 | 1903 |  |  | 2020-08-26 | 2020-09-09 | 10d | 2020-08-18 | 2020-08-31 | 727d | 0d | Verde | Verde | 0% | 0% | Compensatória | Verde | 0% | 0% | Banco |  |  |  |  |  |  |
| 1905 | 3.1.3.22.10.1.6 | 50% do valor do imóvel do pleito MRNESCT03 repassado | milestone | 0d | 2020-11-25 | 2020-11-25 | 1904FS+5d |  |  | 2020-09-16 | 2020-09-16 | 0d | 2020-09-08 | 2020-09-08 | 727d | 0d | Verde | Verde | 0% | 0% | Compensatória | Verde | 0% | 0% | Banco |  |  |  |  |  |  |
| 1906 | 3.1.3.22.10.1.7 | Aquisição de Terreno concluída | milestone | 0d | 2020-11-25 | 2020-11-25 | 1905, 1902 |  |  | 2020-09-16 | 2020-09-16 | 0d | 2020-09-08 | 2020-09-08 | 727d | 0d | Verde | Verde | 0% | 0% | Compensatória | Verde | 0% | 0% | Município |  |  |  |  |  |  |
| 1907 | 3.1.3.22.10.2 | Pleito MRNESCT03 - Indenização pela desapropriação de área onde será implantada EEE do Córrego Santana concluído | milestone | 0d | 2020-11-25 | 2020-11-25 | 1906 |  |  | 2020-09-16 | 2020-09-16 | 0d | 2020-09-08 | 2020-09-08 | 727d |  | Verde | Verde | 0% | 0% | Compensatória | Verde | 0% | 0% | Município |  |  |  |  |  |  |
| 1908 | 3.1.3.22.11 | **Pleito MRNRSPM01 - Elaboração do Plano Intermunicipal de Gestão Integrada de Resíduos Sólidos para os Municípios associados ao Consórcio Intermunicipal Multissetorial do Vale do Piranga (PIGIRS/CIMVALPI)** |  | 1082d | 2019-06-25 A | 2023-10-30 |  |  | 1082d | 2019-08-30 | 2023-10-30 | 1035d | 2019-08-30 | 2024-01-30 | 0d |  | Verde | Verde | 0% | 0% | Compensatória | Verde | 0% | 0% |  |  |  |  |  |  |  |
| 1909 | 3.1.3.22.11.1 | Pleito MRNRSPM01 - Elaboração do Plano Intermunicipal de Gestão Integrada de Resíduos Sólidos para os Municípios associados ao Consórcio Intermunicipal Multissetorial do Vale do Piranga (PIGIRS/CIMVALPI) de Mariana aprovado pelo CIF | milestone | 0d | 2019-06-25 A | 2019-06-25 A | 3033FS+204d | 100% |  | 2019-08-30 | 2019-08-30 | 0d | 2019-08-30 | 2019-08-30 |  |  | Verde | Verde | 0% | 0% | Compensatória | Verde | 0% | 0% | CT/CIF |  |  |  |  |  |  |
| 1910 | 3.1.3.22.11.2 | Iniciar serviço/projeto/obra do pleito de Mariana de Resíduos Sólidos a definir |  | 1d | 2019-09-02 | 2019-09-02 | 1909FS+47d |  |  | 2019-09-02 | 2019-09-02 | 1d | 2019-09-02 | 2019-09-02 | 0d |  | Verde | Verde | 0% | 0% | Compensatória | Verde | 0% | 0% | Município | Critério FR |  |  |  |  |  |
| 1911 | 3.1.3.22.11.3 | Pleito MRNRSPM01 - Elaboração do Plano Intermunicipal de Gestão Integrada de Resíduos Sólidos para os Municípios associados ao Consórcio Intermunicipal Multissetorial do Vale do Piranga (PIGIRS/CIMVALPI) concluído | milestone | 0d | 2023-10-30 | 2023-10-30 | 1910FS+1034d |  |  | 2023-10-30 | 2023-10-30 | 0d | 2024-01-30 | 2024-01-30 | 0d |  | Verde | Verde | 0% | 0% | Compensatória | Verde | 0% | 0% | Município |  |  |  |  |  |  |
| 1912 | 3.1.3.22.12 | Recursos de Mariana repassados | milestone | 0d | 2023-10-30 | 2023-10-30 | 1806, 1821, 1832, 1842, 1852, 1867, 1887, 1897, 1907, 1911, 1877 |  |  | 2023-10-30 | 2023-10-30 | 0d | 2024-01-30 | 2024-01-30 | 0d |  | Verde | Verde | 0% | 0% | Compensatória | Verde | 0% | 0% | Banco |  |  |  |  |  |  |
| 1913 | 3.1.3.23 | **Marilândia** |  | 961d | 2018-09-26 A | 2022-08-02 |  | 5% | 915.96d | 2018-09-26 | 2022-08-02 | 961d | 2019-02-26 | 2022-04-29 | 308d |  | Verde | Verde | 17% | 0% | Compensatória | Vermelho | 1% | 0% |  |  | 17 |  |  |  |  |
| 1914 | 3.1.3.23.1 | **Pleito MRLESPJ07 - Adequação e elaboração de projetos dos sistemas de esgotamento sanitário das localidadesde São Marcos, Monte Sinai, Patrão Mor, Brejal, Alto Liberdade e da Sede Municipal** |  | 443d | 2018-09-26 A | 2020-07-06 |  | 7% | 410.32d | 2018-09-26 | 2020-07-06 | 443d | 2019-02-26 | 2020-03-25 | 826d |  | Verde | Verde | 38% | 33% | Compensatória | Vermelho | 6% | 2% |  |  | 38 | 33 |  |  |  |
| 1915 | 3.1.3.23.1.1 | Pleito MRLESPJ07 - Adequação e elaboração de projetos dos sistemas de esgotamento sanitário das localidadesde São Marcos, Monte Sinai, Patrão Mor, Brejal, Alto Liberdade e da Sede Municipal de Marilândia aprovado | milestone | 0d | 2019-02-26 A | 2019-02-26 A | 3052FS+53d | 100% |  | 2019-02-26 | 2019-02-26 | 0d | 2019-02-26 | 2019-02-26 |  |  | Verde | Verde | 100% | 100% | Compensatória | Verde | 100% | 100% | CT/CIF |  | 100 | 100 | 100 | 100 | 100 |
| 1916 | 3.1.3.23.1.2 | **Licitação do Projeto** |  | 254d | 2018-09-26 A | 2019-09-27 |  | 23% | 194.33d | 2018-09-26 | 2019-09-27 | 254d | 2019-06-03 | 2019-08-21 | 308d |  | Verde | Verde | 67% | 28% | Compensatória | Vermelho | 61% | 17% |  |  | 67 | 28 | 23 | 61 | 17 |
| 1917 | 3.1.3.23.1.2.1 | Licitar projeto |  | 234d | 2018-09-26 A | 2019-08-30 | 1915FS-109d | 25% | 175.5d | 2018-09-26 | 2019-08-30 | 234d | 2019-06-04 | 2019-08-01 | 308d | 0d | Verde | Verde | 73% | 27% | Compensatória | Vermelho | 73% | 20% | Município | Critério FR | 73 | 27 | 25 | 73 | 20 |
| 1918 | 3.1.3.23.1.2.2 | Documentação de licitação de Marilândia do Pleito MRLESPJ07 - Adequação e elaboração de projetos dos sistemas de esgotamento sanitário das localidadesde São Marcos, Monte Sinai, Patrão Mor, Brejal, Alto Liberdade e da Sede Municipal apresentada ao banco | milestone | 0d | 2019-09-06 | 2019-09-06 | 1917FS+5d |  |  | 2019-09-06 | 2019-09-06 | 0d | 2019-08-13 | 2019-08-13 | 308d | 0d | Verde | Verde | 0% | 0% | Compensatória | Verde | 0% | 0% | Município |  |  |  |  |  |  |
| 1919 | 3.1.3.23.1.2.3 | Analisar e emitir resultado da licitação do projeto |  | 15d | 2019-09-09 | 2019-09-27 | 1918 |  |  | 2019-09-09 | 2019-09-27 | 15d | 2019-08-14 | 2019-08-21 | 308d | 0d | Verde | Verde | 0% | 0% | Compensatória | Verde | 0% | 0% | Banco | Critério FR |  |  |  |  |  |
| 1920 | 3.1.3.23.1.2.4 | Licitação de Marilândia do Pleito MRLESPJ07 - Adequação e elaboração de projetos dos sistemas de esgotamento sanitário das localidadesde São Marcos, Monte Sinai, Patrão Mor, Brejal, Alto Liberdade e da Sede Municipal concluída | milestone | 0d | 2019-09-27 | 2019-09-27 | 1919 |  |  | 2019-09-27 | 2019-09-27 | 0d | 2019-08-21 | 2019-08-21 | 308d | 0d | Verde | Verde | 0% | 0% | Compensatória | Verde | 0% | 0% | Município |  |  |  |  |  |  |
| 1921 | 3.1.3.23.1.3 | **Elaboração de Estudo de Concepção** |  | 122d | 2019-09-30 | 2020-03-27 |  |  |  | 2019-09-30 | 2020-03-27 | 122d |  |  | 308d |  | Verde | Verde | 0% | 0% | Compensatória | Verde | 0% | 0% |  |  |  |  |  |  |  |
| 1922 | 3.1.3.23.1.3.1 | Elaborar estudo |  | 62d | 2019-09-30 | 2019-12-30 | 1920 |  |  | 2019-09-30 | 2019-12-30 | 62d |  |  | 308d | 0d | Verde | Verde | 0% | 0% | Compensatória | Verde | 0% | 0% |  |  |  |  |  |  |  |
| 1923 | 3.1.3.23.1.3.2 | Estudo de concepção de Marilândia do Pleito MRLESPJ07 - Adequação e elaboração de projetos dos sistemas de esgotamento sanitário das localidadesde São Marcos, Monte Sinai, Patrão Mor, Brejal, Alto Liberdade e da Sede Municipal apresentado ao banco | milestone | 0d | 2019-12-30 | 2019-12-30 | 1922 |  |  | 2019-12-30 | 2019-12-30 | 0d |  |  | 883d | 0d | Verde | Verde | 0% | 0% | Compensatória | Verde | 0% | 0% |  |  |  |  |  |  |  |
| 1924 | 3.1.3.23.1.3.3 | Analisar estudo |  | 60d | 2019-12-31 | 2020-03-27 | 1923 |  |  | 2019-12-31 | 2020-03-27 | 60d |  |  | 883d | 0d | Verde | Verde | 0% | 0% | Compensatória | Verde | 0% | 0% |  |  |  |  |  |  |  |
| 1925 | 3.1.3.23.1.3.4 | Estudo de concepção de Marilândia do Pleito MRLESPJ07 - Adequação e elaboração de projetos dos sistemas de esgotamento sanitário das localidadesde São Marcos, Monte Sinai, Patrão Mor, Brejal, Alto Liberdade e da Sede Municipal concluído | milestone | 0d | 2020-03-27 | 2020-03-27 | 1924 |  |  | 2020-03-27 | 2020-03-27 | 0d |  |  | 883d | 0d | Verde | Verde | 0% | 0% | Compensatória | Verde | 0% | 0% |  |  |  |  |  |  |  |
| 1926 | 3.1.3.23.1.3.5 | Recurso do estudo de concepção de Marilândia do Pleito MRLESPJ07 - Adequação e elaboração de projetos dos sistemas de esgotamento sanitário das localidadesde São Marcos, Monte Sinai, Patrão Mor, Brejal, Alto Liberdade e da Sede Municipal repassado | milestone | 0d | 2020-03-27 | 2020-03-27 | 1925 |  |  | 2020-03-27 | 2020-03-27 | 0d |  |  | 883d | 40d | Verde | Verde | 0% | 0% | Compensatória | Verde | 0% | 0% |  |  |  |  |  |  |  |

Notes:
- 1912: Valor de recurso destinado ao munícipio: R$71.296.644,86
- 1913: Marilândia fez o pleito de apenas R$270.000,00 (correspondente a apenas 4,3% do valor total para SES destinado ao munícipio), para execução de projetos e foi aprovado conforme Deliberação 75. Somente após o projeto, será feito o pleito para as obras. / O pleito de resíduos sólido (10% do total do recurso destinado ao munícipio) foi aprovado. / O munícipio informou que vai solicitar alteração de pleito ao CIF de R$270.000,00 para R$400.000,00
- 1917: 18/12/2018 - Minuta do edital de licitação foi finalizada, faltando definir o orçamento da pré-operação. / 06/06/2019: TR já está publicado e município prevê a conclusão do processo licitatório dia 30/08/2019

| ID | WBS | Task | Type | Duration | Start | Finish | Predecessors | Baseline start | Baseline finish | Baseline duration | Baseline 1 start | Baseline 1 finish | Total slack | Free slack | Text1 | Text2 | Text3 | Text6 | Text8 | Text12 | Text14 | Text16 | Text9 | Text18 |
| --- | --- | --- | --- | --- | --- | --- | --- | --- | --- | --- | --- | --- | --- | --- | --- | --- | --- | --- | --- | --- | --- | --- | --- | --- |
| 1927 | 3.1.3.23.1.4 | **Elaboração do Projeto Básico** |  | 105d | 2019-12-31 | 2020-06-03 |  | 2019-12-31 | 2020-06-03 | 105d |  |  | 308d |  | Verde | Verde | 0% | 0% | Compensatória | Verde | 0% | 0% |  |  |
| 1928 | 3.1.3.23.1.4.1 | Elaborar Projeto Básico |  | 40d | 2019-12-31 | 2020-02-28 | 1922 | 2019-12-31 | 2020-02-28 | 40d |  |  | 308d | 0d | Verde | Verde | 0% | 0% | Compensatória | Verde | 0% | 0% |  |  |
| 1929 | 3.1.3.23.1.4.2 | Projeto básico de Marilândia do Pleito MRLESPJ07 - Adequação e elaboração de projetos dos sistemas de esgotamento sanitário das localidadesde São Marcos, Monte Sinai, Patrão Mor, Brejal, Alto Liberdade e da Sede Municipal apresentado ao banco | milestone | 0d | 2020-02-28 | 2020-02-28 | 1928 | 2020-02-28 | 2020-02-28 | 0d |  |  | 843d | 0d | Verde | Verde | 0% | 0% | Compensatória | Verde | 0% | 0% |  |  |
| 1930 | 3.1.3.23.1.4.3 | Analisar projeto básico |  | 60d | 2020-03-02 | 2020-05-27 | 1929 | 2020-03-02 | 2020-05-27 | 60d |  |  | 843d | 0d | Verde | Verde | 0% | 0% | Compensatória | Verde | 0% | 0% |  |  |
| 1931 | 3.1.3.23.1.4.4 | Projeto básico de Marilândia do Pleito MRLESPJ07 - Adequação e elaboração de projetos dos sistemas de esgotamento sanitário das localidadesde São Marcos, Monte Sinai, Patrão Mor, Brejal, Alto Liberdade e da Sede Municipal concluído | milestone | 0d | 2020-05-27 | 2020-05-27 | 1926, 1930 | 2020-05-27 | 2020-05-27 | 0d |  |  | 843d | 0d | Verde | Verde | 0% | 0% | Compensatória | Verde | 0% | 0% |  |  |
| 1932 | 3.1.3.23.1.4.5 | Recurso do projeto básico de Marilândia do Pleito MRLESPJ07 - Adequação e elaboração de projetos dos sistemas de esgotamento sanitário das localidadesde São Marcos, Monte Sinai, Patrão Mor, Brejal, Alto Liberdade e da Sede Municipal repassado | milestone | 0d | 2020-06-03 | 2020-06-03 | 1931FS+5d | 2020-06-03 | 2020-06-03 | 0d |  |  | 843d | 17d | Verde | Verde | 0% | 0% | Compensatória | Verde | 0% | 0% |  |  |
| 1933 | 3.1.3.23.1.5 | **Elaboração do Projeto Executivo** |  | 87d | 2020-03-02 | 2020-07-06 |  | 2020-03-02 | 2020-07-06 | 87d | 2019-08-22 | 2020-03-25 | 308d |  | Verde | Verde | 0% | 0% | Compensatória | Verde | 0% | 0% |  |  |
| 1934 | 3.1.3.23.1.5.1 | Elaborar projeto executivo |  | 20d | 2020-03-02 | 2020-03-27 | 1928 | 2020-03-02 | 2020-03-27 | 20d | 2019-08-22 | 2019-12-05 | 308d | 0d | Verde | Verde | 0% | 0% | Compensatória | Verde | 0% | 0% | Município | Critério FR |
| 1935 | 3.1.3.23.1.5.2 | Projeto executivo de Marilândia do Pleito MRLESPJ07 - Adequação e elaboração de projetos dos sistemas de esgotamento sanitário das localidadesde São Marcos, Monte Sinai, Patrão Mor, Brejal, Alto Liberdade e da Sede Municipal apresentado ao banco | milestone | 0d | 2020-03-27 | 2020-03-27 | 1934 | 2020-03-27 | 2020-03-27 | 0d | 2019-12-05 | 2019-12-05 | 308d | 0d | Verde | Verde | 0% | 0% | Compensatória | Verde | 0% | 0% | Município |  |
| 1936 | 3.1.3.23.1.5.3 | Analisar projeto executivo |  | 62d | 2020-03-30 | 2020-06-29 | 1935 | 2020-03-30 | 2020-06-29 | 62d | 2019-12-06 | 2020-01-07 | 308d | 0d | Verde | Verde | 0% | 0% | Compensatória | Verde | 0% | 0% | Banco |  |
| 1937 | 3.1.3.23.1.5.4 | Projeto executivo de Marilândia do Pleito MRLESPJ07 - Adequação e elaboração de projetos dos sistemas de esgotamento sanitário das localidadesde São Marcos, Monte Sinai, Patrão Mor, Brejal, Alto Liberdade e da Sede Municipal concluído | milestone | 0d | 2020-06-29 | 2020-06-29 | 1939, 1940, 1932, 1936 | 2020-06-29 | 2020-06-29 | 0d | 2020-03-18 | 2020-03-18 | 826d | 0d | Verde | Verde | 0% | 0% | Compensatória | Verde | 0% | 0% | Município |  |
| 1938 | 3.1.3.23.1.5.5 | Recurso do projeto executivo de Marilândia do Pleito MRLESPJ07 - Adequação e elaboração de projetos dos sistemas de esgotamento sanitário das localidadesde São Marcos, Monte Sinai, Patrão Mor, Brejal, Alto Liberdade e da Sede Municipal repassado | milestone | 0d | 2020-07-06 | 2020-07-06 | 1937FS+5d | 2020-07-06 | 2020-07-06 | 0d | 2020-03-25 | 2020-03-25 | 826d | 0d | Verde | Verde | 0% | 0% | Compensatória | Verde | 0% | 0% | Banco |  |
| 1939 | 3.1.3.23.1.6 | Realizar Licenciamento Ambiental |  | 120d | 2019-12-31 | 2020-06-25 | 1922 | 2019-12-31 | 2020-06-25 | 120d | 2019-11-20 | 2020-03-18 | 828d | 2d | Verde | Verde | 0% | 0% | Compensatória | Verde | 0% | 0% | Município |  |
| 1940 | 3.1.3.23.1.7 | Aquisição de Terreno |  | 120d | 2019-12-31 | 2020-06-25 | 1922 | 2019-12-31 | 2020-06-25 | 120d | 2019-11-20 | 2020-03-18 | 828d | 2d | Verde | Verde | 0% | 0% | Compensatória | Verde | 0% | 0% | Município |  |
| 1941 | 3.1.3.23.1.8 | Pleito MRLESPJ07 - Adequação e elaboração de projetos dos sistemas de esgotamento sanitário das localidadesde São Marcos, Monte Sinai, Patrão Mor, Brejal, Alto Liberdade e da Sede Municipal de Marilândia concluído | milestone | 0d | 2020-07-06 | 2020-07-06 | 1938 | 2020-07-06 | 2020-07-06 | 0d | 2020-03-25 | 2020-03-25 | 826d | 518d | Verde | Verde | 0% | 0% | Compensatória | Verde | 0% | 0% | Município |  |
| 1942 | 3.1.3.23.2 | **Pleito de Marilândia a definir - Obra da Sede** |  | 520d | 2020-07-02 | 2022-08-02 |  | 2020-07-02 | 2022-08-02 | 520d | 2020-03-16 | 2022-04-29 | 308d |  | Verde | Verde | 0% | 0% | Compensatória | Verde | 0% | 0% |  |  |
| 1943 | 3.1.3.23.2.1 | Pleito de Marilândia a definir - Obra da Sede aprovado | milestone | 0d | 2020-07-02 | 2020-07-02 | 1936FS+3d | 2020-07-02 | 2020-07-02 | 0d | 2020-03-16 | 2020-03-16 | 308d | 0d | Verde | Verde | 0% | 0% | Compensatória | Verde | 0% | 0% | CT/CIF |  |
| 1944 | 3.1.3.23.2.2 | **Licitação da Obra** |  | 55d | 2020-07-10 | 2020-09-28 |  | 2020-07-10 | 2020-09-28 | 55d | 2020-03-24 | 2020-06-15 | 308d |  | Verde | Verde | 0% | 0% | Compensatória | Verde | 0% | 0% |  |  |
| 1945 | 3.1.3.23.2.2.1 | Licitação da obra de Marilândia do Pleito de Marilândia a definir - Obra da Sede autorizada pelo banco | milestone | 0d | 2020-07-10 | 2020-07-10 | 1943FS+6d | 2020-07-10 | 2020-07-10 | 0d | 2020-03-24 | 2020-03-24 | 308d | 0d | Verde | Verde | 0% | 0% | Compensatória | Verde | 0% | 0% | Banco |  |
| 1946 | 3.1.3.23.2.2.2 | Licitar Obra |  | 41d | 2020-07-13 | 2020-09-08 | 1945 | 2020-07-13 | 2020-09-08 | 41d | 2020-03-25 | 2020-05-25 | 308d | 0d | Verde | Verde | 0% | 0% | Compensatória | Verde | 0% | 0% | Município |  |
| 1947 | 3.1.3.23.2.2.3 | Analisar e emitir resultado da licitação da obra |  | 14d | 2020-09-09 | 2020-09-28 | 1946 | 2020-09-09 | 2020-09-28 | 14d | 2020-05-26 | 2020-06-15 | 308d | 0d | Verde | Verde | 0% | 0% | Compensatória | Verde | 0% | 0% | Banco |  |
| 1948 | 3.1.3.23.2.2.4 | Licitação da obra de Marilândia do Pleito de Marilândia a definir - Obra da Sede concluída | milestone | 0d | 2020-09-28 | 2020-09-28 | 1947 | 2020-09-28 | 2020-09-28 | 0d | 2020-06-15 | 2020-06-15 | 308d | 0d | Verde | Verde | 0% | 0% | Compensatória | Verde | 0% | 0% | Município |  |
| 1949 | 3.1.3.23.2.3 | Executar obra |  | 314d | 2020-10-28 | 2022-01-31 | 1948FS+20d | 2020-10-28 | 2022-01-31 | 314d | 2020-07-14 | 2021-10-14 | 308d | 0d | Verde | Verde | 0% | 0% | Compensatória | Verde | 0% | 0% | Município |  |
| 1950 | 3.1.3.23.2.4 | Realizar processo de pré-operação |  | 120d | 2022-02-01 | 2022-07-26 | 1949 | 2022-02-01 | 2022-07-26 | 120d | 2021-10-15 | 2022-04-22 | 308d | 0d | Verde | Verde | 0% | 0% | Compensatória | Verde | 0% | 0% | Município |  |
| 1951 | 3.1.3.23.2.5 | Recurso da obra de Marilândia do Pleito de Marilândia a definir - Obra da Sede repassado | milestone | 0d | 2022-08-02 | 2022-08-02 | 1950FS+5d | 2022-08-02 | 2022-08-02 | 0d | 2022-04-29 | 2022-04-29 | 308d | 0d | Verde | Verde | 0% | 0% | Compensatória | Verde | 0% | 0% | Banco |  |
| 1952 | 3.1.3.23.2.6 | Pleito de Marilândia a definir - Obra da Sede concluído | milestone | 0d | 2022-08-02 | 2022-08-02 | 1951 | 2022-08-02 | 2022-08-02 | 0d | 2022-04-29 | 2022-04-29 | 308d | 0d | Verde | Verde | 0% | 0% | Compensatória | Verde | 0% | 0% | Município |  |

Notes:
- 1949: Em 24/04/2019: valor da obra igual a 90% do teto menos pleito de projeto

| ID | WBS | Task | Type | Duration | Start | Finish | Predecessors | Complete | Remaining | Baseline start | Baseline finish | Baseline duration | Baseline 1 start | Baseline 1 finish | Total slack | Free slack | Constraint | Text1 | Text2 | Text3 | Text6 | Text7 | Text8 | Text12 | Text14 | Text16 | Text4 | Text5 | Text15 | Text17 | Text9 | Text18 |
| --- | --- | --- | --- | --- | --- | --- | --- | --- | --- | --- | --- | --- | --- | --- | --- | --- | --- | --- | --- | --- | --- | --- | --- | --- | --- | --- | --- | --- | --- | --- | --- | --- |
| 1953 | 3.1.3.23.3 | **Pleito MRLRSOB01 - Viabilizar a solução consorciada, com objetivo de executar as obras para a implantação da Central de Tratamento de Resíduos – CTR Colatina** |  | 638d | 2019-03-14 A | 2021-10-05 |  | 5% | 606.44d | 2019-03-14 | 2021-10-05 | 638d | 2019-03-14 | 2021-09-15 | 513d |  |  | Verde | Verde | 8% | 43% | 43 | Compensatória | Vermelho | 7% | 3% |  |  |  |  |  |  |
| 1954 | 3.1.3.23.3.1 | **Licitação da obra** |  | 114d | 2019-03-14 A | 2019-08-28 |  | 28% | 82.54d | 2019-03-14 | 2019-08-28 | 114d | 2019-03-14 | 2019-05-29 | 513d |  |  | Verde | Verde | 46% | 44% | 44 | Compensatória | Vermelho | 45% | 20% | 28 | 46 | 45 | 20 |  |  |
| 1955 | 3.1.3.23.3.1.1 | Licitação da obra de Marilândia do Pleito MRLRSOB01 - Viabilizar a solução consorciada, com objetivo de executar as obras para a implantação da Central de Tratamento de Resíduos – CTR Colatina autorizada pelo banco | milestone | 0d | 2019-03-14 A | 2019-03-14 A | 3052FS+62d | 100% |  | 2019-03-14 | 2019-03-14 | 0d | 2019-03-14 | 2019-03-14 |  |  |  | Verde | Verde | 100% | 100% | 100 | Compensatória | Verde | 100% | 100% | 100 | 100 | 100 | 100 | Banco |  |
| 1956 | 3.1.3.23.3.1.2 | Licitar obra |  | 94d | 2019-03-15 A | 2019-07-30 | 1955 | 32% | 63.92d | 2019-03-15 | 2019-07-30 | 94d | 2019-03-14 | 2019-05-09 | 513d | 0d |  | Verde | Verde | 56% | 45% | 45 | Compensatória | Vermelho | 56% | 25% | 32 | 56 | 56 | 25 | Município | Conforme agendado |
| 1957 | 3.1.3.23.3.1.3 | Analisar e emitir resultado da licitação da obra |  | 15d | 2019-08-07 | 2019-08-28 | 1956FS+5d |  |  | 2019-08-07 | 2019-08-28 | 15d | 2019-05-20 | 2019-05-29 | 513d | 0d |  | Verde | Verde | 0% | 0% |  | Compensatória | Verde | 0% | 0% |  |  |  |  | Banco | Critério FR |
| 1958 | 3.1.3.23.3.1.4 | Licitação da obra de Marilândia do Pleito MRLRSOB01 - Viabilizar a solução consorciada, com objetivo de executar as obras para a implantação da Central de Tratamento de Resíduos – CTR Colatina concluída | milestone | 0d | 2019-08-28 | 2019-08-28 | 1957 |  |  | 2019-08-28 | 2019-08-28 | 0d | 2019-05-29 | 2019-05-29 | 513d | 0d |  | Verde | Verde | 0% | 0% |  | Compensatória | Verde | 0% | 0% |  |  |  |  | Município |  |
| 1959 | 3.1.3.23.3.2 | Executar obra |  | 249d | 2019-09-26 | 2020-09-25 | 1958FS+20d |  |  | 2019-09-26 | 2020-09-25 | 249d | 2019-07-08 | 2021-03-08 | 513d | 0d |  | Verde | Verde | 0% | 0% |  | Compensatória | Verde | 0% | 0% |  |  |  |  | Município |  |
| 1960 | 3.1.3.23.3.3 | Realizar processo de pré-operação |  | 250d | 2020-09-28 | 2021-09-28 | 1959 |  |  | 2020-09-28 | 2021-09-28 | 250d | 2021-03-09 | 2021-09-08 | 513d | 0d |  | Verde | Verde | 0% | 0% |  | Compensatória | Verde | 0% | 0% |  |  |  |  | Município |  |
| 1961 | 3.1.3.23.3.4 | Recurso da obra de Marilândia do Pleito MRLRSOB01 - Viabilizar a solução consorciada, com objetivo de executar as obras para a implantação da Central de Tratamento de Resíduos – CTR Colatina repassado | milestone | 0d | 2021-10-05 | 2021-10-05 | 1960FS+5d |  |  | 2021-10-05 | 2021-10-05 | 0d | 2021-09-15 | 2021-09-15 | 513d | 0d |  | Verde | Verde | 0% | 0% |  | Compensatória | Verde | 0% | 0% |  |  |  |  | Banco |  |
| 1962 | 3.1.3.23.3.5 | Pleito MRLRSOB01 - Viabilizar a solução consorciada, com objetivo de executar as obras para a implantação da Central de Tratamento de Resíduos – CTR Colatina de Marilândia concluído | milestone | 0d | 2021-10-05 | 2021-10-05 | 1961 |  |  | 2021-10-05 | 2021-10-05 | 0d | 2021-09-15 | 2021-09-15 | 513d | 205d |  | Verde | Verde | 0% | 0% |  | Compensatória | Verde | 0% | 0% |  |  |  |  | Município |  |
| 1963 | 3.1.3.23.4 | Recursos de Marilândia repassados | milestone | 0d | 2022-08-02 | 2022-08-02 | 1941, 1962, 1952 |  |  | 2022-08-02 | 2022-08-02 | 0d | 2022-04-29 | 2022-04-29 | 308d |  |  | Verde | Verde | 0% | 0% |  | Compensatória | Verde | 0% | 0% |  |  |  |  | Banco |  |
| 1964 | 3.1.3.24 | **Marliéria** |  | 678d | 2019-02-21 A | 2021-11-16 |  | 6% | 635.84d | 2019-02-21 | 2021-11-16 | 678d | 2019-02-21 | 2021-12-13 | 486d |  |  | Verde | Verde | 9% | 0% |  | Compensatória | Vermelho | 1% | 0% |  |  |  |  |  |  |
| 1965 | 3.1.3.24.1 | **Pleito MREESPJ01 - Elaboração de projeto do sistema de esgotamento sanitário do distrito de Cava Grande** |  | 241d | 2019-02-21 A | 2020-02-11 |  | 17% | 199.71d | 2019-02-21 | 2020-02-11 | 241d | 2019-02-21 | 2020-03-02 | 923d |  |  | Verde | Verde | 27% | 67% | 67 | Compensatória | Vermelho | 21% | 14% | 17 | 27 | 21 | 14 |  |  |
| 1966 | 3.1.3.24.1.1 | **Licitação do Projeto** |  | 36d | 2019-02-21 A | 2019-04-16 A |  | 100% |  | 2019-02-21 | 2019-04-16 | 36d | 2019-02-21 | 2019-05-07 |  |  |  | Verde | Verde | 100% | 100% | 100 | Compensatória | Verde | 100% | 100% | 100 | 100 | 100 | 100 |  |  |
| 1967 | 3.1.3.24.1.1.1 | Licitar projeto |  | 29d | 2019-02-21 A | 2019-04-05 A |  | 100% |  | 2019-02-21 | 2019-04-05 | 29d | 2019-02-21 | 2019-04-05 |  |  | must start on 2019-02-21 | Verde | Verde | 100% | 100% | 100 | Compensatória | Verde | 100% | 100% | 100 | 100 | 100 | 100 | Município |  |
| 1968 | 3.1.3.24.1.1.2 | Documentação de licitação de Marliéria do Pleito MREESPJ01 - Elaboração de projeto do sistema de esgotamento sanitário do distrito de Cava Grande apresentada ao banco | milestone | 0d | 2019-04-12 A | 2019-04-12 A | 1967FS+5d | 100% |  | 2019-04-12 | 2019-04-12 | 0d | 2019-04-12 | 2019-04-12 |  |  |  | Verde | Verde | 100% | 100% | 100 | Compensatória | Verde | 100% | 100% | 100 | 100 | 100 | 100 | Município |  |
| 1969 | 3.1.3.24.1.1.3 | Analisar e emitir resultado da licitação do projeto |  | 2d | 2019-04-15 A | 2019-04-16 A | 1968 | 100% |  | 2019-04-15 | 2019-04-16 | 2d | 2019-04-15 | 2019-05-07 |  |  |  | Verde | Verde | 100% | 100% | 100 | Compensatória | Verde | 100% | 100% | 100 | 100 | 100 | 100 | Banco |  |
| 1970 | 3.1.3.24.1.1.4 | Licitação do projeto de Marliéria do Pleito MREESPJ01 - Elaboração de projeto do sistema de esgotamento sanitário do distrito de Cava Grande concluída | milestone | 0d | 2019-04-16 A | 2019-04-16 A | 1969 | 100% |  | 2019-04-16 | 2019-04-16 | 0d | 2019-05-07 | 2019-05-07 |  |  |  | Verde | Verde | 100% | 100% | 100 | Compensatória | Verde | 100% | 100% | 100 | 100 | 100 | 100 | Município |  |
| 1971 | 3.1.3.24.1.2 | **Elaboração do Projeto Básico** |  | 135d | 2019-04-17 A | 2019-10-29 |  | 23% | 103.85d | 2019-04-17 | 2019-10-29 | 135d | 2019-05-08 | 2019-11-13 | 551d |  |  | Verde | Verde | 22% | 0% |  | Compensatória | Vermelho | 18% | 0% | 23 | 22 | 18 |  |  |  |
| 1972 | 3.1.3.24.1.2.1 | Elaborar Projeto Básico |  | 65d | 2019-04-17 A | 2019-07-22 | 1970 | 46% | 35d | 2019-04-17 | 2019-07-22 | 65d | 2019-05-08 | 2019-08-06 | 486d | 0d |  | Verde | Verde | 46% | 0% |  | Compensatória | Vermelho | 46% | 0% | 46 | 46 | 46 |  | Município | Conforme agendado |
| 1973 | 3.1.3.24.1.2.2 | Projeto básico de Marliéria do Pleito MREESPJ01 - Elaboração de projeto do sistema de esgotamento sanitário do distrito de Cava Grande apresentado ao banco | milestone | 0d | 2019-07-22 | 2019-07-22 | 1972 |  |  | 2019-07-22 | 2019-07-22 | 0d | 2019-08-06 | 2019-08-06 | 486d | 0d |  | Verde | Verde | 0% | 0% |  | Compensatória | Verde | 0% | 0% |  |  |  |  | Município |  |
| 1974 | 3.1.3.24.1.2.3 | Analisar projeto básico |  | 65d | 2019-07-23 | 2019-10-22 | 1973 |  |  | 2019-07-23 | 2019-10-22 | 65d | 2019-08-07 | 2019-09-09 | 551d | 0d |  | Verde | Verde | 0% | 0% |  | Compensatória | Verde | 0% | 0% |  |  |  |  | Banco | Critério FR |
| 1975 | 3.1.3.24.1.2.4 | Projeto básico de Marliéria do Pleito MREESPJ01 - Elaboração de projeto do sistema de esgotamento sanitário do distrito de Cava Grande concluído | milestone | 0d | 2019-10-22 | 2019-10-22 | 1974 |  |  | 2019-10-22 | 2019-10-22 | 0d | 2019-11-06 | 2019-11-06 | 551d | 0d |  | Verde | Verde | 0% | 0% |  | Compensatória | Verde | 0% | 0% |  |  |  |  | Município |  |
| 1976 | 3.1.3.24.1.2.5 | Recurso do estudo de concepção de Marliéria do Pleito MREESPJ01 - Elaboração de projeto do sistema de esgotamento sanitário do distrito de Cava Grande repassado | milestone | 0d | 2019-10-29 | 2019-10-29 | 1975FS+5d |  |  | 2019-10-29 | 2019-10-29 | 0d |  |  | 551d | 65d |  | Verde | Verde | 0% | 0% |  | Compensatória | Verde | 0% | 0% |  |  |  |  |  |  |
| 1977 | 3.1.3.24.1.2.6 | Recurso do projeto básico de Marliéria do Pleito MREESPJ01 - Elaboração de projeto do sistema de esgotamento sanitário do distrito de Cava Grande repassado | milestone | 0d | 2019-10-29 | 2019-10-29 | 1975FS+5d |  |  | 2019-10-29 | 2019-10-29 | 0d | 2019-11-13 | 2019-11-13 | 551d | 65d |  | Verde | Verde | 0% | 0% |  | Compensatória | Verde | 0% | 0% |  |  |  |  | Banco |  |
| 1978 | 3.1.3.24.1.3 | Realizar Licenciamento Ambiental |  | 60d | 2019-07-23 | 2019-10-15 | 1972 |  |  | 2019-07-23 | 2019-10-15 | 60d | 2019-02-21 | 2019-06-04 | 561d | 75d |  | Verde | Verde | 0% | 0% |  | Compensatória | Verde | 0% | 0% |  |  |  |  | Município | Critério FR |

Notes:
- 1956: 31/05/2019: conforme e-mail da Mônica, algumas empresas entraram com recurso e por isso os envelopes de preço ainda não foram abertos. Considerado mais um mês de prazo.
- 1959: Em 24/09/2019: o valor da obra do CONDOESTE é de R$ 10,9 milhões - 20 meses
- 1963: Valor de recurso destinado ao munícipio: R$6.302.657,43
- 1964: Marliéria teve 100% dos pleitos de Esgotamento Sanitário aprovado (R$4.254.293,76), conforme Deliberação 75. / O município teve 0,53%, dos 10% do valor teto destinado a Resíduos Sólidos aprovado (R$24.889,97).
- 1967: Em 24/09/2019: considerada a data da reunião junto aos municípios de estabelecimento de cronograma como data de início / 02/06/2019: licitação recebida dia 16/04/2019 conforme planilha Controle Gerencial Renova
- 1968: 02/06/2019: licitação recebida dia 16/04/2019 conforme planilha Controle Gerencial Renova
- 1969: 21/05/2019: licitação do projeto aprovada dia 16/04/2019 conforme planilha Controle Gerencial Renova (aba PJ - coluna DATA DA AUTORIZAÇÃO PARA ELABORAÇÃO DO PROJETO BÁSICO)
- 1970: 21/05/2019: licitação do projeto aprovada dia 16/04/2019 conforme planilha Controle Gerencial Renova (aba PJ - coluna DATA DA AUTORIZAÇÃO PARA ELABORAÇÃO DO PROJETO BÁSICO)
- 1972: 21/05/2019: conferir na reunião com o município o andamento do projeto / 02/07/2019: Telefonema com a Livia - reunião com o município e apoio técnico em junho foi cancelada, por isso não há status do andamento.
- 1978: Em 29/04/2019: atualizado como agendado / 21/05/2019: conferir na reunião com o município o andamento do projeto / 29/05/2019: licenciamento está paralizado.

| ID | WBS | Task | Type | Duration | Start | Finish | Predecessors | Baseline start | Baseline finish | Baseline duration | Baseline 1 start | Baseline 1 finish | Total slack | Free slack | Text1 | Text2 | Text3 | Text6 | Text8 | Text12 | Text14 | Text16 | Text9 | Text18 |
| --- | --- | --- | --- | --- | --- | --- | --- | --- | --- | --- | --- | --- | --- | --- | --- | --- | --- | --- | --- | --- | --- | --- | --- | --- |
| 1979 | 3.1.3.24.1.4 | **Elaboração do Projeto Executivo** |  | 140d | 2019-07-23 | 2020-02-11 |  | 2019-07-23 | 2020-02-11 | 140d | 2019-08-07 | 2020-03-02 | 486d |  | Verde | Verde | 0% | 0% | Compensatória | Verde | 0% | 0% |  |  |
| 1980 | 3.1.3.24.1.4.1 | Elaborar Projeto Executivo |  | 66d | 2019-07-23 | 2019-10-23 | 1973 | 2019-07-23 | 2019-10-23 | 66d | 2019-08-07 | 2019-11-07 | 486d | 0d | Verde | Verde | 0% | 0% | Compensatória | Verde | 0% | 0% | Município | Critério FR |
| 1981 | 3.1.3.24.1.4.2 | Projeto executivo de Marliéria do Pleito MREESPJ01 - Elaboração de projeto do sistema de esgotamento sanitário do distrito de Cava Grande apresentado ao banco | milestone | 0d | 2019-10-23 | 2019-10-23 | 1980 | 2019-10-23 | 2019-10-23 | 0d | 2019-11-07 | 2019-11-07 | 486d | 0d | Verde | Verde | 0% | 0% | Compensatória | Verde | 0% | 0% | Município |  |
| 1982 | 3.1.3.24.1.4.3 | Analisar projeto executivo |  | 69d | 2019-10-24 | 2020-02-04 | 1981 | 2019-10-24 | 2020-02-04 | 69d | 2019-11-08 | 2019-12-11 | 486d | 0d | Verde | Verde | 0% | 0% | Compensatória | Verde | 0% | 0% | Banco | Critério FR |
| 1983 | 3.1.3.24.1.4.4 | Projeto executivo de Marliéria do Pleito MREESPJ01 - Elaboração de projeto do sistema de esgotamento sanitário do distrito de Cava Grande concluído | milestone | 0d | 2020-02-04 | 2020-02-04 | 1977, 1978, 1976, 1982 | 2020-02-04 | 2020-02-04 | 0d | 2020-02-19 | 2020-02-19 | 486d | 0d | Verde | Verde | 0% | 0% | Compensatória | Verde | 0% | 0% | Município |  |
| 1984 | 3.1.3.24.1.4.5 | Recurso do projeto executivo de Marliéria do Pleito MREESPJ01 - Elaboração de projeto do sistema de esgotamento sanitário do distrito de Cava Grande repassado | milestone | 0d | 2020-02-11 | 2020-02-11 | 1983FS+5d | 2020-02-11 | 2020-02-11 | 0d | 2020-03-02 | 2020-03-02 | 923d | 0d | Verde | Verde | 0% | 0% | Compensatória | Verde | 0% | 0% | Banco |  |
| 1985 | 3.1.3.24.1.5 | Pleito MREESPJ01 - Elaboração de projeto do sistema de esgotamento sanitário do distrito de Cava Grande de Marliéria concluído | milestone | 0d | 2020-02-11 | 2020-02-11 | 1984 | 2020-02-11 | 2020-02-11 | 0d | 2020-03-02 | 2020-03-02 | 923d | 437d | Verde | Verde | 0% | 0% | Compensatória | Verde | 0% | 0% | Município |  |
| 1986 | 3.1.3.24.2 | **Pleito MREESOB01 - Implantação do sistema de esgotamento sanitário do distrito de Cava Grande** |  | 442d | 2020-02-04 | 2021-11-16 |  | 2020-02-04 | 2021-11-16 | 442d | 2020-02-19 | 2021-12-13 | 486d |  | Verde | Verde | 0% | 0% | Compensatória | Verde | 0% | 0% |  |  |
| 1987 | 3.1.3.24.2.1 | **Licitação da Obra** |  | 41d | 2020-02-04 | 2020-04-06 |  | 2020-02-04 | 2020-04-06 | 41d | 2020-02-19 | 2020-04-23 | 486d |  | Verde | Verde | 0% | 0% | Compensatória | Verde | 0% | 0% |  |  |
| 1988 | 3.1.3.24.2.1.1 | Licitação da obra de Marliéria do Pleito MREESOB01 - Implantação do sistema de esgotamento sanitário do distrito de Cava Grande autorizada pelo banco | milestone | 0d | 2020-02-04 | 2020-02-04 | 1983 | 2020-02-04 | 2020-02-04 | 0d | 2020-02-19 | 2020-02-19 | 486d | 0d | Verde | Verde | 0% | 0% | Compensatória | Verde | 0% | 0% | Banco |  |
| 1989 | 3.1.3.24.2.1.2 | Licitar Obra |  | 26d | 2020-02-05 | 2020-03-16 | 1988 | 2020-02-05 | 2020-03-16 | 26d | 2020-02-20 | 2020-03-31 | 486d | 0d | Verde | Verde | 0% | 0% | Compensatória | Verde | 0% | 0% | Município |  |
| 1990 | 3.1.3.24.2.1.3 | Analisar e emitir resultado da licitação da obra |  | 15d | 2020-03-17 | 2020-04-06 | 1989 | 2020-03-17 | 2020-04-06 | 15d | 2020-04-01 | 2020-04-23 | 486d | 0d | Verde | Verde | 0% | 0% | Compensatória | Verde | 0% | 0% | Banco |  |
| 1991 | 3.1.3.24.2.1.4 | Licitação da obra de Marliéria do Pleito MREESOB01 - Implantação do sistema de esgotamento sanitário do distrito de Cava Grande concluída | milestone | 0d | 2020-04-06 | 2020-04-06 | 1990 | 2020-04-06 | 2020-04-06 | 0d | 2020-04-23 | 2020-04-23 | 486d | 0d | Verde | Verde | 0% | 0% | Compensatória | Verde | 0% | 0% | Município |  |
| 1992 | 3.1.3.24.2.2 | Executar obra |  | 257d | 2020-05-07 | 2021-05-18 | 1991FS+19d | 2020-05-07 | 2021-05-18 | 257d | 2020-05-22 | 2021-06-02 | 486d | 0d | Verde | Verde | 0% | 0% | Compensatória | Verde | 0% | 0% | Município |  |
| 1993 | 3.1.3.24.2.3 | Realizar processo de pré-operação |  | 120d | 2021-05-19 | 2021-11-08 | 1992 | 2021-05-19 | 2021-11-08 | 120d | 2021-06-04 | 2021-12-06 | 486d | 0d | Verde | Verde | 0% | 0% | Compensatória | Verde | 0% | 0% | Município |  |
| 1994 | 3.1.3.24.2.4 | Recurso da obra de Marliéria do Pleito MREESOB01 - Implantação do sistema de esgotamento sanitário do distrito de Cava Grande repassado | milestone | 0d | 2021-11-16 | 2021-11-16 | 1993FS+5d | 2021-11-16 | 2021-11-16 | 0d | 2021-12-13 | 2021-12-13 | 486d | 0d | Verde | Verde | 0% | 0% | Compensatória | Verde | 0% | 0% | Banco |  |
| 1995 | 3.1.3.24.2.5 | Pleito MREESOB01 - Implantação do sistema de esgotamento sanitário do distrito de Cava Grande de Marliéria concluído | milestone | 0d | 2021-11-16 | 2021-11-16 | 1994 | 2021-11-16 | 2021-11-16 | 0d | 2021-12-13 | 2021-12-13 | 486d | 0d | Verde | Verde | 0% | 0% | Compensatória | Verde | 0% | 0% | Município |  |
| 1996 | 3.1.3.24.3 | **Pleito MRERSPM01 - Estudos de viabilidade p/ implantação de aterro sanitário regional** |  | 217d | 2019-07-01 | 2020-05-15 |  | 2019-07-01 | 2020-05-15 | 217d | 2019-05-03 | 2020-03-17 | 861d |  | Verde | Verde | 0% | 0% | Compensatória | Verde | 0% | 0% |  |  |
| 1997 | 3.1.3.24.3.1 | **Licitação de Empresa para Estudo de Viabilidade** |  | 63d | 2019-07-01 | 2019-09-27 |  | 2019-07-01 | 2019-09-27 | 63d | 2019-05-03 | 2019-08-01 | 861d |  | Verde | Verde | 0% | 0% | Compensatória | Verde | 0% | 0% |  |  |
| 1998 | 3.1.3.24.3.1.1 | Licitação da empresa para Estudo de Viabilidade de Marliéria do Pleito MRERSPM01 - Estudos de viabilidade p/ implantação de aterro sanitário regional autorizada pelo banco | milestone | 0d | 2019-07-01 | 2019-07-01 | 1091 | 2019-07-01 | 2019-07-01 | 0d | 2019-05-03 | 2019-05-03 | 861d | 0d | Verde | Verde | 0% | 0% | Compensatória | Verde | 0% | 0% | Banco |  |
| 1999 | 3.1.3.24.3.1.2 | Licitar empresa para Estudo de Viabilidade |  | 44d | 2019-07-02 | 2019-09-02 | 1998 | 2019-07-02 | 2019-09-02 | 44d | 2019-05-06 | 2019-07-05 | 861d | 0d | Verde | Verde | 0% | 0% | Compensatória | Verde | 0% | 0% | Município | Critério FR |
| 2000 | 3.1.3.24.3.1.3 | Documentação de licitação de Marliéria do Pleito MRERSPM01 - Estudos de viabilidade p/ implantação de aterro sanitário regional apresentada ao banco | milestone | 0d | 2019-09-09 | 2019-09-09 | 1999FS+5d | 2019-09-09 | 2019-09-09 | 0d | 2019-07-12 | 2019-07-12 | 861d | 0d | Verde | Verde | 0% | 0% | Compensatória | Verde | 0% | 0% | Município |  |
| 2001 | 3.1.3.24.3.1.4 | Analisar e emitir resultado da licitação da empresa para Estudo de Viabilidade |  | 14d | 2019-09-10 | 2019-09-27 | 2000 | 2019-09-10 | 2019-09-27 | 14d | 2019-07-15 | 2019-08-01 | 861d | 0d | Verde | Verde | 0% | 0% | Compensatória | Verde | 0% | 0% | Banco | Critério FR |
| 2002 | 3.1.3.24.3.1.5 | Licitação da empresa para Estudo de Viabilidade de Marliéria do Pleito MRERSPM01 - Estudos de viabilidade p/ implantação de aterro sanitário regional concluída | milestone | 0d | 2019-09-27 | 2019-09-27 | 2001 | 2019-09-27 | 2019-09-27 | 0d | 2019-08-01 | 2019-08-01 | 861d | 0d | Verde | Verde | 0% | 0% | Compensatória | Verde | 0% | 0% | Município |  |

Notes:
- 1980: 24/05/2019: município pactuou com a Renova que vai elaborar projeto executivo em paralelo com o básico
- 1992: Em 24/04/2019: valor da obra R$ 4 milhões

| ID | WBS | Task | Type | Duration | Start | Finish | Predecessors | Baseline start | Baseline finish | Baseline duration | Baseline 1 start | Baseline 1 finish | Total slack | Free slack | Text1 | Text2 | Text3 | Text6 | Text8 | Text12 | Text14 | Text16 | Text9 | Text18 |
| --- | --- | --- | --- | --- | --- | --- | --- | --- | --- | --- | --- | --- | --- | --- | --- | --- | --- | --- | --- | --- | --- | --- | --- | --- |
| 2003 | 3.1.3.24.3.2 | **Elaboração do estudo de viabilidade** |  | 149d | 2019-09-30 | 2020-05-08 |  | 2019-09-30 | 2020-05-08 | 149d | 2019-08-02 | 2020-03-10 | 861d |  | Verde | Verde | 0% | 0% | Compensatória | Verde | 0% | 0% |  |  |
| 2004 | 3.1.3.24.3.2.1 | Elaborar estudo de viabilidade |  | 88d | 2019-09-30 | 2020-02-05 | 2002 | 2019-09-30 | 2020-02-05 | 88d | 2019-08-02 | 2019-12-05 | 861d | 0d | Verde | Verde | 0% | 0% | Compensatória | Verde | 0% | 0% | Município |  |
| 2005 | 3.1.3.24.3.2.2 | Analisar estudo |  | 61d | 2020-02-06 | 2020-05-08 | 2004 | 2020-02-06 | 2020-05-08 | 61d | 2019-12-06 | 2020-01-08 | 861d | 0d | Verde | Verde | 0% | 0% | Compensatória | Verde | 0% | 0% | Banco |  |
| 2006 | 3.1.3.24.3.2.3 | Estudo de viabilidade de Marliéria do Pleito MRERSPM01 - Estudos de viabilidade p/ implantação de aterro sanitário regional concluído | milestone | 0d | 2020-05-08 | 2020-05-08 | 2005 | 2020-05-08 | 2020-05-08 | 0d | 2020-03-10 | 2020-03-10 | 861d | 0d | Verde | Verde | 0% | 0% | Compensatória | Verde | 0% | 0% | Município |  |
| 2007 | 3.1.3.24.3.3 | Recurso do serviço de Marliéria do Pleito MRERSPM01 - Estudos de viabilidade p/ implantação de aterro sanitário regional repassado | milestone | 0d | 2020-05-15 | 2020-05-15 | 2006FS+5d | 2020-05-15 | 2020-05-15 | 0d | 2020-03-17 | 2020-03-17 | 861d | 0d | Verde | Verde | 0% | 0% | Compensatória | Verde | 0% | 0% | Banco |  |
| 2008 | 3.1.3.24.3.4 | Pleito MRERSPM01 - Estudos de viabilidade p/ implantação de aterro sanitário regional de Marliéria concluído | milestone | 0d | 2020-05-15 | 2020-05-15 | 2007 | 2020-05-15 | 2020-05-15 | 0d | 2020-03-17 | 2020-03-17 | 861d | 375d | Verde | Verde | 0% | 0% | Compensatória | Verde | 0% | 0% | Município |  |
| 2009 | 3.1.3.24.4 | Recursos de Marliéria repassados | milestone | 0d | 2021-11-16 | 2021-11-16 | 1995, 1985, 2008 | 2021-11-16 | 2021-11-16 | 0d | 2021-12-13 | 2021-12-13 | 486d |  | Verde | Verde | 0% | 0% | Compensatória | Verde | 0% | 0% | Banco |  |
| 2010 | 3.1.3.25 | **Naque** |  | 807d | 2019-08-01 | 2022-10-28 |  | 2019-08-01 | 2022-10-28 | 807d | 2019-02-01 | 2025-02-25 | 248d |  | Verde | Verde | 0% | 0% | Compensatória | Verde | 0% | 0% |  |  |
| 2011 | 3.1.3.25.1 | **Pleito NAQESPJ01 - Elaboração de projeto de sistema de esgotamento sanitário da sede do município** |  | 287d | 2019-08-01 | 2020-09-25 |  | 2019-08-01 | 2020-09-25 | 287d | 2019-02-01 | 2020-06-30 | 292d |  | Verde | Verde | 0% | 0% | Compensatória | Verde | 0% | 0% |  |  |
| 2012 | 3.1.3.25.1.1 | Alteração do Pleito NAQESPJ01 - Elaboração de projeto de sistema de esgotamento sanitário da sede do município de Naque aprovada | milestone | 0d | 2019-08-01 | 2019-08-01 | 3052FS+158d | 2019-08-01 | 2019-08-01 | 0d | 2019-05-31 | 2019-05-31 | 292d | 0d | Verde | Verde | 0% | 0% | Compensatória | Verde | 0% | 0% | CT/CIF |  |
| 2013 | 3.1.3.25.1.2 | **Licitação do Projeto** |  | 86d | 2019-08-16 | 2019-12-18 |  | 2019-08-16 | 2019-12-18 | 86d | 2019-06-14 | 2019-09-13 | 292d |  | Verde | Verde | 0% | 0% | Compensatória | Verde | 0% | 0% |  |  |
| 2014 | 3.1.3.25.1.2.1 | Licitação do projeto de Naque do Pleito NAQESPJ01 - Elaboração de projeto de sistema de esgotamento sanitário da sede do município autorizada pelo banco | milestone | 0d | 2019-08-16 | 2019-08-16 | 2012FS+10d | 2019-08-16 | 2019-08-16 | 0d | 2019-06-14 | 2019-06-14 | 292d | 0d | Verde | Verde | 0% | 0% | Compensatória | Verde | 0% | 0% | Banco |  |
| 2015 | 3.1.3.25.1.2.2 | Licitar projeto |  | 66d | 2019-08-19 | 2019-11-19 | 2014 | 2019-08-19 | 2019-11-19 | 66d | 2019-06-17 | 2019-08-16 | 292d | 0d | Verde | Verde | 0% | 0% | Compensatória | Verde | 0% | 0% | Município | Critério FR |
| 2016 | 3.1.3.25.1.2.3 | Documentação de licitação de Naque do Pleito NAQESPJ01 - Elaboração de projeto de sistema de esgotamento sanitário da sede do município apresentada ao banco | milestone | 0d | 2019-11-26 | 2019-11-26 | 2015FS+5d | 2019-11-26 | 2019-11-26 | 0d | 2019-08-23 | 2019-08-23 | 292d | 0d | Verde | Verde | 0% | 0% | Compensatória | Verde | 0% | 0% | Município |  |
| 2017 | 3.1.3.25.1.2.4 | Analisar e emitir resultado da licitação do projeto |  | 15d | 2019-11-27 | 2019-12-18 | 2016 | 2019-11-27 | 2019-12-18 | 15d | 2019-08-26 | 2019-09-13 | 292d | 0d | Verde | Verde | 0% | 0% | Compensatória | Verde | 0% | 0% | Banco | Critério FR |
| 2018 | 3.1.3.25.1.2.5 | Licitação do projeto de Naque do Pleito NAQESPJ01 - Elaboração de projeto de sistema de esgotamento sanitário da sede do município concluída | milestone | 0d | 2019-12-18 | 2019-12-18 | 2017 | 2019-12-18 | 2019-12-18 | 0d | 2019-09-13 | 2019-09-13 | 292d | 0d | Verde | Verde | 0% | 0% | Compensatória | Verde | 0% | 0% | Município |  |
| 2019 | 3.1.3.25.1.3 | **Elaboração de Estudo de Concepção** |  | 105d | 2019-12-19 | 2020-05-26 |  | 2019-12-19 | 2020-05-26 | 105d |  |  | 292d |  | Verde | Verde | 0% | 0% | Compensatória | Verde | 0% | 0% |  |  |
| 2020 | 3.1.3.25.1.3.1 | Elaborar estudo |  | 40d | 2019-12-19 | 2020-02-17 | 2018 | 2019-12-19 | 2020-02-17 | 40d |  |  | 292d | 0d | Verde | Verde | 0% | 0% | Compensatória | Verde | 0% | 0% |  |  |
| 2021 | 3.1.3.25.1.3.2 | Estudo de concepção de Naque do Pleito NAQESPJ01 - Elaboração de projeto de sistema de esgotamento sanitário da sede do município apresentado ao banco | milestone | 0d | 2020-02-17 | 2020-02-17 | 2020 | 2020-02-17 | 2020-02-17 | 0d |  |  | 298d | 0d | Verde | Verde | 0% | 0% | Compensatória | Verde | 0% | 0% |  |  |
| 2022 | 3.1.3.25.1.3.3 | Analisar estudo |  | 60d | 2020-02-18 | 2020-05-19 | 2021 | 2020-02-18 | 2020-05-19 | 60d |  |  | 298d | 0d | Verde | Verde | 0% | 0% | Compensatória | Verde | 0% | 0% |  |  |
| 2023 | 3.1.3.25.1.3.4 | Estudo de concepção de Naque do Pleito NAQESPJ01 - Elaboração de projeto de sistema de esgotamento sanitário da sede do município concluído | milestone | 0d | 2020-05-19 | 2020-05-19 | 2022 | 2020-05-19 | 2020-05-19 | 0d |  |  | 368d | 0d | Verde | Verde | 0% | 0% | Compensatória | Verde | 0% | 0% |  |  |
| 2024 | 3.1.3.25.1.3.5 | Recurso do estudo de concepção de Naque do Pleito NAQESPJ01 - Elaboração de projeto de sistema de esgotamento sanitário da sede do município repassado | milestone | 0d | 2020-05-26 | 2020-05-26 | 2023FS+5d | 2020-05-26 | 2020-05-26 | 0d |  |  | 368d | 40d | Verde | Verde | 0% | 0% | Compensatória | Verde | 0% | 0% |  |  |
| 2025 | 3.1.3.25.1.4 | **Elaboração do Projeto Básico** |  | 110d | 2020-02-18 | 2020-07-29 |  | 2020-02-18 | 2020-07-29 | 110d | 2019-09-16 | 2020-03-31 | 292d |  | Verde | Verde | 0% | 0% | Compensatória | Verde | 0% | 0% |  |  |
| 2026 | 3.1.3.25.1.4.1 | Elaborar Projeto Básico |  | 40d | 2020-02-18 | 2020-04-17 | 2020 | 2020-02-18 | 2020-04-17 | 40d | 2019-09-16 | 2019-12-16 | 292d | 0d | Verde | Verde | 0% | 0% | Compensatória | Verde | 0% | 0% | Município |  |
| 2027 | 3.1.3.25.1.4.2 | Projeto básico de Naque do Pleito NAQESPJ01 - Elaboração de projeto de sistema de esgotamento sanitário da sede do município apresentado ao banco | milestone | 0d | 2020-04-17 | 2020-04-17 | 2026 | 2020-04-17 | 2020-04-17 | 0d | 2019-12-16 | 2019-12-16 | 328d | 0d | Verde | Verde | 0% | 0% | Compensatória | Verde | 0% | 0% | Município |  |
| 2028 | 3.1.3.25.1.4.3 | Analisar projeto básico |  | 65d | 2020-04-20 | 2020-07-22 | 2027 | 2020-04-20 | 2020-07-22 | 65d | 2019-12-17 | 2020-01-17 | 328d | 0d | Verde | Verde | 0% | 0% | Compensatória | Verde | 0% | 0% | Banco |  |
| 2029 | 3.1.3.25.1.4.4 | Projeto básico de Naque do Pleito NAQESPJ01 - Elaboração de projeto de sistema de esgotamento sanitário da sede do município concluído | milestone | 0d | 2020-07-22 | 2020-07-22 | 2024, 2028 | 2020-07-22 | 2020-07-22 | 0d | 2020-03-24 | 2020-03-24 | 328d | 0d | Verde | Verde | 0% | 0% | Compensatória | Verde | 0% | 0% | Município |  |
| 2030 | 3.1.3.25.1.4.5 | Recurso do projeto básico de Naque do Pleito NAQESPJ01 - Elaboração de projeto de sistema de esgotamento sanitário da sede do município repassado | milestone | 0d | 2020-07-29 | 2020-07-29 | 2029FS+5d | 2020-07-29 | 2020-07-29 | 0d | 2020-03-31 | 2020-03-31 | 328d | 36d | Verde | Verde | 0% | 0% | Compensatória | Verde | 0% | 0% | Banco |  |
| 2031 | 3.1.3.25.1.5 | Adquirir imóvel |  | 120d | 2020-03-20 | 2020-09-10 | 2022FS-40d | 2020-03-20 | 2020-09-10 | 120d | 2019-11-14 | 2020-05-27 | 298d | 6d | Verde | Verde | 0% | 0% | Compensatória | Verde | 0% | 0% | Município |  |
| 2032 | 3.1.3.25.1.6 | Realizar Licenciamento Ambiental |  | 120d | 2020-03-20 | 2020-09-10 | 2022FS-40d | 2020-03-20 | 2020-09-10 | 120d | 2019-02-01 | 2020-05-22 | 298d | 6d | Verde | Verde | 0% | 0% | Compensatória | Verde | 0% | 0% | Município |  |

Notes:
- 2009: Valor de recurso destinado ao munícipio: R$4.726.993,07
- 2010: Naque teve 100% dos pleitos de Esgotamento Sanitário aprovado (R$4.254.293,76), conforme Deliberação 75. / O município teve o pleito de resíduos sólidos negado (R$472.699,31, equivalente a 10% do total do recurso,). / Naque está pensando em desistir da ata de registro de preço, caso isto aconteça o cronograma vai mudar.
- 2012: 22/01/19 - Município não iniciou o projeto básico devido a indefinição sobre a adesão a ATA de Registro de Preço ou Licitaçao Própria. O município irá solicitar alteração de pleito devido a duplicidade de pleitos para elaboração de projeto, solicitação de PMSB e definição das obras. (Tendo como premissa 3 meses para definição e aprovação do pleito do PMSB junto a CT, 2 meses para licitação e aprovação pelo BDMG, 8 meses para elaboração do PMSB. Após aprovação do PMSB (pela Câmara Municipal do município e BDMG) o município poderá definir os demais pleitos. Em virtude da extensão destas etapas e das indefinições envolvidas, a atividade será adiada 1 ano e 1 mês. / Em 24/04/2019: pleito será protocolado e aprovado pela CT/CIF no dia 31/05
- 2032: Em 29/04/2019: atualizado como agendado / 21/05/2019: conferir na reunião com o município o andamento do projeto / 30/05/2019: município não começou o licenciamento. previsto início após o estudo

| ID | WBS | Task | Type | Duration | Start | Finish | Predecessors | Baseline start | Baseline finish | Baseline duration | Baseline 1 start | Baseline 1 finish | Total slack | Free slack | Text1 | Text2 | Text3 | Text6 | Text8 | Text12 | Text14 | Text16 | Text9 | Text18 |
| --- | --- | --- | --- | --- | --- | --- | --- | --- | --- | --- | --- | --- | --- | --- | --- | --- | --- | --- | --- | --- | --- | --- | --- | --- |
| 2033 | 3.1.3.25.1.7 | **Elaboração do Projeto Executivo** |  | 111d | 2020-04-20 | 2020-09-25 |  | 2020-04-20 | 2020-09-25 | 111d | 2019-12-17 | 2020-06-30 | 292d |  | Verde | Verde | 0% | 0% | Compensatória | Verde | 0% | 0% |  |  |
| 2034 | 3.1.3.25.1.7.1 | Elaborar Projeto Executivo |  | 40d | 2020-04-20 | 2020-06-17 | 2026 | 2020-04-20 | 2020-06-17 | 40d | 2019-12-17 | 2020-03-17 | 292d | 0d | Verde | Verde | 0% | 0% | Compensatória | Verde | 0% | 0% | Município |  |
| 2035 | 3.1.3.25.1.7.2 | Projeto executivo de Naque do Pleito NAQESPJ01 - Elaboração de projeto de sistema de esgotamento sanitário da sede do município apresentado ao banco | milestone | 0d | 2020-06-17 | 2020-06-17 | 2034 | 2020-06-17 | 2020-06-17 | 0d | 2020-03-17 | 2020-03-17 | 292d | 0d | Verde | Verde | 0% | 0% | Compensatória | Verde | 0% | 0% | Município |  |
| 2036 | 3.1.3.25.1.7.3 | Analisar projeto executivo |  | 66d | 2020-06-18 | 2020-09-18 | 2035 | 2020-06-18 | 2020-09-18 | 66d | 2020-03-18 | 2020-04-16 | 292d | 0d | Verde | Verde | 0% | 0% | Compensatória | Verde | 0% | 0% | Banco |  |
| 2037 | 3.1.3.25.1.7.4 | Projeto executivo de Naque do Pleito NAQESPJ01 - Elaboração de projeto de sistema de esgotamento sanitário da sede do município concluído | milestone | 0d | 2020-09-18 | 2020-09-18 | 2030, 2032, 2031, 2036 | 2020-09-18 | 2020-09-18 | 0d | 2020-06-23 | 2020-06-23 | 292d | 0d | Verde | Verde | 0% | 0% | Compensatória | Verde | 0% | 0% | Município |  |
| 2038 | 3.1.3.25.1.7.5 | Recurso do projeto executivo do pleito NAQESPJ01 repassado | milestone | 0d | 2020-09-25 | 2020-09-25 | 2037FS+5d | 2020-09-25 | 2020-09-25 | 0d | 2020-06-30 | 2020-06-30 | 768d | 0d | Verde | Verde | 0% | 0% | Compensatória | Verde | 0% | 0% | Banco |  |
| 2039 | 3.1.3.25.1.8 | Pleito NAQESPJ01 - Elaboração de projeto de sistema de esgotamento sanitário da sede do município de Naque concluído | milestone | 0d | 2020-09-25 | 2020-09-25 | 2038 | 2020-09-25 | 2020-09-25 | 0d | 2020-06-30 | 2020-06-30 | 768d | 520d | Verde | Verde | 0% | 0% | Compensatória | Verde | 0% | 0% | Município |  |
| 2040 | 3.1.3.25.2 | **Pleito NAQESAO01 - Contratação de assessoria técnica para apoio na obtenção de licença ambiental** |  | 1d | 2020-02-18 | 2020-02-18 |  | 2020-02-18 | 2020-02-18 | 1d | 2019-08-30 | 2019-08-30 | 918d |  | Verde | Verde | 0% | 0% | Compensatória | Verde | 0% | 0% |  |  |
| 2041 | 3.1.3.25.2.1 | Avaliar necessidade do pleito NAQESAO01 |  | 1d | 2020-02-18 | 2020-02-18 | 2020 | 2020-02-18 | 2020-02-18 | 1d | 2019-08-30 | 2019-08-30 | 918d | 0d | Verde | Verde | 0% | 0% | Compensatória | Verde | 0% | 0% | Município |  |
| 2042 | 3.1.3.25.2.2 | Pleito NAQESAO01 - Contratação de assessoria técnica para apoio na obtenção de licença ambiental de Naque concluído | milestone | 0d | 2020-02-18 | 2020-02-18 | 2041 | 2020-02-18 | 2020-02-18 | 0d | 2019-08-30 | 2019-08-30 | 918d | 670d | Verde | Verde | 0% | 0% | Compensatória | Verde | 0% | 0% | Município |  |
| 2043 | 3.1.3.25.3 | **Pleito NAQESOB01 - Complementação de recursos de contrapartida** |  | 1d | 2019-08-30 | 2019-08-30 |  | 2019-08-30 | 2019-08-30 | 1d | 2019-08-30 | 2019-08-30 | 1035d |  | Verde | Verde | 0% | 0% | Compensatória | Verde | 0% | 0% |  |  |
| 2044 | 3.1.3.25.3.1 | Avaliar cancelamento do pleito NAQESOB01 |  | 1d | 2019-08-30 | 2019-08-30 | 3052FS+177d | 2019-08-30 | 2019-08-30 | 1d | 2019-08-30 | 2019-08-30 | 1035d | 0d | Verde | Verde | 0% | 0% | Compensatória | Verde | 0% | 0% | Município | Critério FR |
| 2045 | 3.1.3.25.3.2 | Pleito NAQESOB01 - Complementação de recursos de contrapartida de Naque concluído | milestone | 0d | 2019-08-30 | 2019-08-30 | 2044 | 2019-08-30 | 2019-08-30 | 0d | 2019-08-30 | 2019-08-30 | 1035d | 787d | Verde | Verde | 0% | 0% | Compensatória | Verde | 0% | 0% | Município |  |
| 2046 | 3.1.3.25.4 | **Pleito NAQESOB02 - Implantação de SES na sede do município e localidades** |  | 481d | 2020-09-18 | 2022-08-25 |  | 2020-09-18 | 2022-08-25 | 481d | 2020-06-23 | 2022-06-08 | 292d |  | Verde | Verde | 0% | 0% | Compensatória | Verde | 0% | 0% |  |  |
| 2047 | 3.1.3.25.4.1 | **Licitação da obra** |  | 79d | 2020-09-18 | 2021-01-14 |  | 2020-09-18 | 2021-01-14 | 79d | 2020-06-23 | 2020-10-14 | 292d |  | Verde | Verde | 0% | 0% | Compensatória | Verde | 0% | 0% |  |  |
| 2048 | 3.1.3.25.4.1.1 | Licitação da obra de Naque do Pleito NAQESOB02 - Implantação de SES na sede do município e localidades autorizada pelo banco | milestone | 0d | 2020-09-18 | 2020-09-18 | 2037 | 2020-09-18 | 2020-09-18 | 0d | 2020-06-23 | 2020-06-23 | 292d | 0d | Verde | Verde | 0% | 0% | Compensatória | Verde | 0% | 0% | Banco |  |
| 2049 | 3.1.3.25.4.1.2 | Licitar Obra |  | 63d | 2020-09-21 | 2020-12-18 | 2048 | 2020-09-21 | 2020-12-18 | 63d | 2020-06-24 | 2020-09-21 | 292d | 0d | Verde | Verde | 0% | 0% | Compensatória | Verde | 0% | 0% | Município |  |
| 2050 | 3.1.3.25.4.1.3 | Analisar e emitir resultado da licitação da obra |  | 16d | 2020-12-21 | 2021-01-14 | 2049 | 2020-12-21 | 2021-01-14 | 16d | 2020-09-22 | 2020-10-14 | 292d | 0d | Verde | Verde | 0% | 0% | Compensatória | Verde | 0% | 0% | Banco |  |
| 2051 | 3.1.3.25.4.1.4 | Licitação da obra de Naque do Pleito NAQESOB02 - Implantação de SES na sede do município e localidades concluída | milestone | 0d | 2021-01-14 | 2021-01-14 | 2050 | 2021-01-14 | 2021-01-14 | 0d | 2020-10-14 | 2020-10-14 | 292d | 0d | Verde | Verde | 0% | 0% | Compensatória | Verde | 0% | 0% | Município |  |
| 2052 | 3.1.3.25.4.2 | Executar obra |  | 257d | 2021-02-12 | 2022-02-22 | 2051FS+20d | 2021-02-12 | 2022-02-22 | 257d | 2020-11-13 | 2021-11-25 | 292d | 0d | Verde | Verde | 0% | 0% | Compensatória | Verde | 0% | 0% | Município |  |
| 2053 | 3.1.3.25.4.3 | Realizar processo de pré-operação |  | 120d | 2022-02-23 | 2022-08-18 | 2052 | 2022-02-23 | 2022-08-18 | 120d | 2021-11-26 | 2022-06-01 | 292d | 0d | Verde | Verde | 0% | 0% | Compensatória | Verde | 0% | 0% | Município |  |
| 2054 | 3.1.3.25.4.4 | Recurso da obra de Naque do Pleito NAQESOB02 - Implantação de SES na sede do município e localidades repassado | milestone | 0d | 2022-08-25 | 2022-08-25 | 2053FS+5d | 2022-08-25 | 2022-08-25 | 0d | 2022-06-08 | 2022-06-08 | 292d | 0d | Verde | Verde | 0% | 0% | Compensatória | Verde | 0% | 0% | Banco |  |
| 2055 | 3.1.3.25.4.5 | Pleito NAQESOB02 - Implantação de SES na sede do município e localidades de Naque concluído | milestone | 0d | 2022-08-25 | 2022-08-25 | 2054 | 2022-08-25 | 2022-08-25 | 0d | 2022-06-08 | 2022-06-08 | 292d | 44d | Verde | Verde | 0% | 0% | Compensatória | Verde | 0% | 0% | Município |  |
| 2056 | 3.1.3.25.5 | **Pleito de Naque de Resíduos Sólidos a definir** |  | 787d | 2019-08-30 | 2022-10-28 |  | 2019-08-30 | 2022-10-28 | 787d | 2019-08-30 | 2025-02-25 | 248d |  | Verde | Verde | 0% | 0% | Compensatória | Verde | 0% | 0% |  |  |
| 2057 | 3.1.3.25.5.1 | Pleito de Naque de Resíduos Sólidos a definir aprovado | milestone | 0d | 2019-08-30 | 2019-08-30 | 418 | 2019-08-30 | 2019-08-30 | 0d | 2019-08-30 | 2019-08-30 | 248d | 0d | Verde | Verde | 0% | 0% | Compensatória | Verde | 0% | 0% | CT/CIF |  |
| 2058 | 3.1.3.25.5.2 | Iniciar serviço/projeto/obra do pleito de Naque de Resíduos Sólidos a definir |  | 1d | 2019-09-02 | 2019-09-02 | 2057 | 2019-09-02 | 2019-09-02 | 1d | 2019-09-02 | 2019-09-02 | 248d | 0d | Verde | Verde | 0% | 0% | Compensatória | Verde | 0% | 0% | Município | Critério FR |
| 2059 | 3.1.3.25.5.3 | Pleito de Naque de Resíduos Sólidos a definir concluído | milestone | 0d | 2022-10-28 | 2022-10-28 | 2058FS+786d | 2022-10-28 | 2022-10-28 | 0d | 2025-02-25 | 2025-02-25 | 248d | 0d | Verde | Verde | 0% | 0% | Compensatória | Verde | 0% | 0% | Município |  |
| 2060 | 3.1.3.25.6 | Recursos de Naque repassados | milestone | 0d | 2022-10-28 | 2022-10-28 | 2039, 2042, 2045, 2055, 2059 | 2022-10-28 | 2022-10-28 | 0d | 2025-02-25 | 2025-02-25 | 248d |  | Verde | Verde | 0% | 0% | Compensatória | Verde | 0% | 0% | Banco |  |

Notes:
- 2034: 24/05/2019: município pactuou com a Renova 3 meses para elaborar projeto executivo
- 2041: Em 24/04/2019: foi informado por Sara que o município irá cancelar o pleito, pois acreditam não ser necessário devido ao recebimento de apoio técnico e licenciamento ambiental simplificado. O prazo foi estabelecido com base na nota técnica 33.
- 2044: Em 24/04/2019: considerando o cronograma da NT33 e que município enviará ofício de cancelamento de pleito até o final de julho.
- 2052: Em 24/06/2019: valor da obra R$ 4 milhões
- 2060: Valor de recurso destinado ao munícipio: R$4.726.993,07

| ID | WBS | Task | Type | Duration | Start | Finish | Predecessors | Complete | Remaining | Baseline start | Baseline finish | Baseline duration | Baseline 1 start | Baseline 1 finish | Total slack | Free slack | Text1 | Text2 | Text3 | Text6 | Text8 | Text12 | Text14 | Text16 | Text5 | Text7 | Text4 | Text15 | Text17 | Text9 | Text18 |
| --- | --- | --- | --- | --- | --- | --- | --- | --- | --- | --- | --- | --- | --- | --- | --- | --- | --- | --- | --- | --- | --- | --- | --- | --- | --- | --- | --- | --- | --- | --- | --- |
| 2061 | 3.1.3.26 | **Periquito** |  | 916d | 2019-02-21 A | 2022-10-28 |  | 4% | 880.4d | 2019-02-21 | 2022-10-28 | 916d | 2019-02-21 | 2025-02-25 | 248d |  | Verde | Verde | 7% | 0% | Compensatória | Vermelho | 0% | 0% |  |  |  |  |  |  |  |
| 2062 | 3.1.3.26.1 | **Pleito PERESPJ01 - Elaboração de projetos de sistema de esgotamento sanitário da sede do município e distritos São Sebastião do Baixio, Pedra** |  | 296d | 2019-02-21 A | 2020-05-06 |  | 8% | 271.7d | 2019-02-21 | 2020-05-06 | 296d | 2019-02-21 | 2020-04-30 | 868d |  | Verde | Verde | 22% | 67% | Compensatória | Vermelho | 6% | 4% | 22 | 67 |  |  |  |  |  |
| 2063 | 3.1.3.26.1.1 | **Licitação do Projeto** |  | 105d | 2019-02-21 A | 2019-07-26 |  | 44% | 58.8d | 2019-02-21 | 2019-07-26 | 105d | 2019-02-21 | 2019-07-11 | 400d |  | Verde | Verde | 62% | 65% | Compensatória | Vermelho | 51% | 33% | 62 | 65 | 44 | 51 | 33 |  |  |
| 2064 | 3.1.3.26.1.1.1 | Licitar projeto |  | 86d | 2019-02-21 A | 2019-07-01 | 3037FS+218ed | 51% | 42d | 2019-02-21 | 2019-07-01 | 86d | 2019-02-21 | 2019-06-13 | 400d | 0d | Verde | Verde | 76% | 66% | Compensatória | Vermelho | 76% | 50% | 76 | 66 | 51 | 76 | 50 | Município | Conforme agendado |
| 2065 | 3.1.3.26.1.1.2 | Documentação de licitação de Periquito do Pleito PERESPJ01 - Elaboração de projetos de sistema de esgotamento sanitário da sede do município e distritos São Sebastião do Baixio, Pedra apresentada ao banco | milestone | 0d | 2019-07-08 | 2019-07-08 | 2064FS+5d |  |  | 2019-07-08 | 2019-07-08 | 0d | 2019-06-21 | 2019-06-21 | 400d | 0d | Verde | Verde | 0% | 0% | Compensatória | Verde | 0% | 0% |  |  |  |  |  | Município |  |
| 2066 | 3.1.3.26.1.1.3 | Analisar e emitir resultado da licitação do projeto |  | 14d | 2019-07-09 | 2019-07-26 | 2065 |  |  | 2019-07-09 | 2019-07-26 | 14d | 2019-06-24 | 2019-07-11 | 400d | 0d | Verde | Verde | 0% | 0% | Compensatória | Verde | 0% | 0% |  |  |  |  |  | Banco | Critério FR |
| 2067 | 3.1.3.26.1.1.4 | Licitação do projeto de Periquito do Pleito PERESPJ01 - Elaboração de projetos de sistema de esgotamento sanitário da sede do município e distritos São Sebastião do Baixio, Pedra concluída | milestone | 0d | 2019-07-26 | 2019-07-26 | 2066 |  |  | 2019-07-26 | 2019-07-26 | 0d | 2019-07-11 | 2019-07-11 | 400d | 0d | Verde | Verde | 0% | 0% | Compensatória | Verde | 0% | 0% |  |  |  |  |  | Município |  |
| 2068 | 3.1.3.26.1.2 | **Elaboração do Estudo de Concepção** |  | 105d | 2019-07-29 | 2019-12-27 |  |  |  | 2019-07-29 | 2019-12-27 | 105d |  |  | 400d |  | Verde | Verde | 0% | 0% | Compensatória | Verde | 0% | 0% |  |  |  |  |  |  |  |
| 2069 | 3.1.3.26.1.2.1 | Elaborar estudo |  | 40d | 2019-07-29 | 2019-09-23 | 2067 |  |  | 2019-07-29 | 2019-09-23 | 40d |  |  | 400d | 0d | Verde | Verde | 0% | 0% | Compensatória | Verde | 0% | 0% |  |  |  |  |  |  | Critério FR |
| 2070 | 3.1.3.26.1.2.2 | Estudo de concepção de Periquito do Pleito PERESPJ01 - Elaboração de projetos de sistema de esgotamento sanitário da sede do município e distritos São Sebastião do Baixio, Pedra apresentado ao banco | milestone | 0d | 2019-09-23 | 2019-09-23 | 2069 |  |  | 2019-09-23 | 2019-09-23 | 0d |  |  | 401d | 0d | Verde | Verde | 0% | 0% | Compensatória | Verde | 0% | 0% |  |  |  |  |  |  |  |
| 2071 | 3.1.3.26.1.2.3 | Analisar estudo |  | 60d | 2019-09-24 | 2019-12-18 | 2070 |  |  | 2019-09-24 | 2019-12-18 | 60d |  |  | 401d | 0d | Verde | Verde | 0% | 0% | Compensatória | Verde | 0% | 0% |  |  |  |  |  |  | Critério FR |
| 2072 | 3.1.3.26.1.2.4 | Estudo de concepção de Periquito do Pleito PERESPJ01 - Elaboração de projetos de sistema de esgotamento sanitário da sede do município e distritos São Sebastião do Baixio, Pedra concluído | milestone | 0d | 2019-12-18 | 2019-12-18 | 2071 |  |  | 2019-12-18 | 2019-12-18 | 0d |  |  | 476d | 0d | Verde | Verde | 0% | 0% | Compensatória | Verde | 0% | 0% |  |  |  |  |  |  |  |
| 2073 | 3.1.3.26.1.2.5 | Recurso do estudo de concepção de Periquito do Pleito PERESPJ01 - Elaboração de projetos de sistema de esgotamento sanitário da sede do município e distritos São Sebastião do Baixio, Pedra repassado | milestone | 0d | 2019-12-27 | 2019-12-27 | 2072FS+5d |  |  | 2019-12-27 | 2019-12-27 | 0d |  |  | 476d | 40d | Verde | Verde | 0% | 0% | Compensatória | Verde | 0% | 0% |  |  |  |  |  |  |  |
| 2074 | 3.1.3.26.1.3 | **Elaboração do Projeto Básico** |  | 110d | 2019-09-24 | 2020-03-05 |  |  |  | 2019-09-24 | 2020-03-05 | 110d | 2019-07-12 | 2020-01-22 | 400d |  | Verde | Verde | 0% | 0% | Compensatória | Verde | 0% | 0% |  |  |  |  |  |  |  |
| 2075 | 3.1.3.26.1.3.1 | Elaborar Projeto Básico |  | 40d | 2019-09-24 | 2019-11-19 | 2069 |  |  | 2019-09-24 | 2019-11-19 | 40d | 2019-07-12 | 2019-10-09 | 400d | 0d | Verde | Verde | 0% | 0% | Compensatória | Verde | 0% | 0% |  |  |  |  |  | Município | Critério FR |
| 2076 | 3.1.3.26.1.3.2 | Projeto básico de Periquito do Pleito PERESPJ01 - Elaboração de projetos de sistema de esgotamento sanitário da sede do município e distritos São Sebastião do Baixio, Pedra apresentado ao banco | milestone | 0d | 2019-11-19 | 2019-11-19 | 2075 |  |  | 2019-11-19 | 2019-11-19 | 0d | 2019-10-09 | 2019-10-09 | 436d | 0d | Verde | Verde | 0% | 0% | Compensatória | Verde | 0% | 0% |  |  |  |  |  | Município |  |
| 2077 | 3.1.3.26.1.3.3 | Analisar projeto básico |  | 65d | 2019-11-20 | 2020-02-27 | 2076 |  |  | 2019-11-20 | 2020-02-27 | 65d | 2019-10-10 | 2019-11-11 | 436d | 0d | Verde | Verde | 0% | 0% | Compensatória | Verde | 0% | 0% |  |  |  |  |  | Banco | Critério FR |
| 2078 | 3.1.3.26.1.3.4 | Projeto básico de Periquito do Pleito PERESPJ01 - Elaboração de projetos de sistema de esgotamento sanitário da sede do município e distritos São Sebastião do Baixio, Pedra concluído | milestone | 0d | 2020-02-27 | 2020-02-27 | 2073, 2077 |  |  | 2020-02-27 | 2020-02-27 | 0d | 2020-01-15 | 2020-01-15 | 436d | 0d | Verde | Verde | 0% | 0% | Compensatória | Verde | 0% | 0% |  |  |  |  |  | Município |  |
| 2079 | 3.1.3.26.1.3.5 | Recurso do projeto básico de Periquito do Pleito PERESPJ01 - Elaboração de projetos de sistema de esgotamento sanitário da sede do município e distritos São Sebastião do Baixio, Pedra repassado | milestone | 0d | 2020-03-05 | 2020-03-05 | 2078FS+5d |  |  | 2020-03-05 | 2020-03-05 | 0d | 2020-01-22 | 2020-01-22 | 436d | 36d | Verde | Verde | 0% | 0% | Compensatória | Verde | 0% | 0% |  |  |  |  |  | Banco |  |
| 2080 | 3.1.3.26.1.4 | Realizar Licenciamento Ambiental |  | 125d | 2019-10-22 | 2020-04-27 | 2071FS-40d |  |  | 2019-10-22 | 2020-04-27 | 125d | 2019-10-10 | 2020-04-23 | 401d | 1d | Verde | Verde | 0% | 0% | Compensatória | Verde | 0% | 0% |  |  |  |  |  | Município |  |
| 2081 | 3.1.3.26.1.5 | **Elaboração do Projeto Executivo** |  | 111d | 2019-11-20 | 2020-05-06 |  |  |  | 2019-11-20 | 2020-05-06 | 111d | 2019-10-10 | 2020-04-30 | 400d |  | Verde | Verde | 0% | 0% | Compensatória | Verde | 0% | 0% |  |  |  |  |  |  |  |
| 2082 | 3.1.3.26.1.5.1 | Elaborar Projeto Executivo |  | 40d | 2019-11-20 | 2020-01-20 | 2075 |  |  | 2019-11-20 | 2020-01-20 | 40d | 2019-10-10 | 2020-01-15 | 400d | 0d | Verde | Verde | 0% | 0% | Compensatória | Verde | 0% | 0% |  |  |  |  |  | Município |  |
| 2083 | 3.1.3.26.1.5.2 | Projeto executivo de Periquito do Pleito PERESPJ01 - Elaboração de projetos de sistema de esgotamento sanitário da sede do município e distritos São Sebastião do Baixio, Pedra apresentado ao banco | milestone | 0d | 2020-01-20 | 2020-01-20 | 2082 |  |  | 2020-01-20 | 2020-01-20 | 0d | 2020-01-15 | 2020-01-15 | 400d | 0d | Verde | Verde | 0% | 0% | Compensatória | Verde | 0% | 0% |  |  |  |  |  | Município |  |
| 2084 | 3.1.3.26.1.5.3 | Analisar projeto executivo |  | 66d | 2020-01-21 | 2020-04-28 | 2083 |  |  | 2020-01-21 | 2020-04-28 | 66d | 2020-01-16 | 2020-02-14 | 400d | 0d | Verde | Verde | 0% | 0% | Compensatória | Verde | 0% | 0% |  |  |  |  |  | Banco |  |
| 2085 | 3.1.3.26.1.5.4 | Projeto executivo de Periquito do Pleito PERESPJ01 - Elaboração de projetos de sistema de esgotamento sanitário da sede do município e distritos São Sebastião do Baixio, Pedra concluído | milestone | 0d | 2020-04-28 | 2020-04-28 | 2079, 2080, 2097, 2084 |  |  | 2020-04-28 | 2020-04-28 | 0d | 2020-04-23 | 2020-04-23 | 400d | 0d | Verde | Verde | 0% | 0% | Compensatória | Verde | 0% | 0% |  |  |  |  |  | Município |  |
| 2086 | 3.1.3.26.1.5.5 | Recurso do projeto executivo de Periquito do Pleito PERESPJ01 - Elaboração de projetos de sistema de esgotamento sanitário da sede do município e distritos São Sebastião do Baixio, Pedra repassado | milestone | 0d | 2020-05-06 | 2020-05-06 | 2085FS+5d |  |  | 2020-05-06 | 2020-05-06 | 0d | 2020-04-30 | 2020-04-30 | 868d | 0d | Verde | Verde | 0% | 0% | Compensatória | Verde | 0% | 0% |  |  |  |  |  | Banco |  |
| 2087 | 3.1.3.26.1.6 | Pleito PERESPJ01 - Elaboração de projetos de sistema de esgotamento sanitário da sede do município e distritos São Sebastião do Baixio, Pedra de Periquito concluído | milestone | 0d | 2020-05-06 | 2020-05-06 | 2086 |  |  | 2020-05-06 | 2020-05-06 | 0d | 2020-04-30 | 2020-04-30 | 868d | 620d | Verde | Verde | 0% | 0% | Compensatória | Verde | 0% | 0% |  |  |  |  |  | Município |  |

Notes:
- 2061: Periquito teve 100% dos pleitos de Esgotamento Sanitário aprovado (R$4.254.234,37), conforme Deliberação 75. / O município teve o pleito de resíduos sólidos negado (R$472.699,31, equivalente a 10% do total do recurso,). / Retificado pelo município que está em fase de fechamento da planilha orçamentária do TR.
- 2064: Havia sido informado que o munícipio estava em fase de licitação de projeto (informação passada na planilha para a CT), no entanto em reunião com Apoio Técnico em 04/12 esta informação foi retificada pelo município e informado que está em fase de fechamento da planilha orçamentária do TR. / 22/01/19 - Status continua. / Em 29/04/2019: no dia 15/03 banco cobrou a apresentação do processo licitatório conforme check list enviado. Prazo foi dilatado para finalizar a licitação (validado Sara V.) / 21/05/2019: 17/05/2019 (Gislaine) - E-mail enviado cobrando processo licitatório do município conforme check list encaminhado. (fonte: Controle Gerencial Renova); confirmar data de término na reunião com o município / 30/05/2019: o TR está com o pregoeiro. Será publicado o edital sexta (31/05). município solicitou mais 2 meses para conclusão do processo licitatório. / 02/07/2019: Claudia informou que em reunião no dia 13/06/2019 no município, foi informado pelo representante do Setor de Licitação Sr. Vitor que o termo de referência encaminhado pela equipe técnica, encontrava-se em análise interna das cotações, com previsão para publicação do Edital para o final de junho/2019.
- 2082: 24/05/2019: município pactuou com a Renova 3 meses para elaborar projeto executivo

| ID | WBS | Task | Type | Duration | Start | Finish | Predecessors | Baseline start | Baseline finish | Baseline duration | Baseline 1 start | Baseline 1 finish | Total slack | Free slack | Text1 | Text2 | Text3 | Text6 | Text8 | Text12 | Text14 | Text16 | Text9 | Text18 |
| --- | --- | --- | --- | --- | --- | --- | --- | --- | --- | --- | --- | --- | --- | --- | --- | --- | --- | --- | --- | --- | --- | --- | --- | --- |
| 2088 | 3.1.3.26.2 | **Pleito de Periquito a definir - Aquisição de imóvel** |  | 151d | 2019-08-30 | 2020-04-09 |  | 2019-08-30 | 2020-04-09 | 151d | 2019-08-30 | 2020-04-09 | 411d |  | Verde | Verde | 0% | 0% | Compensatória | Verde | 0% | 0% |  |  |
| 2089 | 3.1.3.26.2.1 | Pleito de Periquito a definir - Aquisição de imóvel aprovado | milestone | 0d | 2019-08-30 | 2019-08-30 | 3052FS+178d | 2019-08-30 | 2019-08-30 | 0d | 2019-08-30 | 2019-08-30 | 411d | 0d | Verde | Verde | 0% | 0% | Compensatória | Verde | 0% | 0% | CT/CIF |  |
| 2090 | 3.1.3.26.2.2 | **Aquisição de Imóvel** |  | 141d | 2019-09-16 | 2020-04-09 |  | 2019-09-16 | 2020-04-09 | 141d | 2019-09-16 | 2020-04-09 | 411d |  | Verde | Verde | 0% | 0% | Compensatória | Verde | 0% | 0% |  |  |
| 2091 | 3.1.3.26.2.2.1 | Regularizar terreno e apresentar escritura ao banco |  | 82d | 2019-09-16 | 2020-01-14 | 2089FS+10d | 2019-09-16 | 2020-01-14 | 82d | 2019-09-16 | 2020-01-14 | 411d | 0d | Verde | Verde | 0% | 0% | Compensatória | Verde | 0% | 0% | Município |  |
| 2092 | 3.1.3.26.2.2.2 | Analisar documentação do terreno |  | 10d | 2020-01-15 | 2020-01-28 | 2091 | 2020-01-15 | 2020-01-28 | 10d | 2020-01-15 | 2020-01-28 | 455d | 0d | Verde | Verde | 0% | 0% | Compensatória | Verde | 0% | 0% | Banco |  |
| 2093 | 3.1.3.26.2.2.3 | 50% do valor do imóvel do Pleito de Periquito a definir - Aquisição de imóvel repassado | milestone | 0d | 2020-02-04 | 2020-02-04 | 2092FS+5d | 2020-02-04 | 2020-02-04 | 0d | 2020-02-04 | 2020-02-04 | 455d | 44d | Verde | Verde | 0% | 0% | Compensatória | Verde | 0% | 0% | Banco |  |
| 2094 | 3.1.3.26.2.2.4 | Registrar imóvel e apresentar documentação ao banco |  | 44d | 2020-01-15 | 2020-03-19 | 2091 | 2020-01-15 | 2020-03-19 | 44d | 2020-01-15 | 2020-03-19 | 411d | 0d | Verde | Verde | 0% | 0% | Compensatória | Verde | 0% | 0% | Município |  |
| 2095 | 3.1.3.26.2.2.5 | Analisar documentação do terreno |  | 10d | 2020-03-20 | 2020-04-02 | 2094 | 2020-03-20 | 2020-04-02 | 10d | 2020-03-20 | 2020-04-02 | 411d | 0d | Verde | Verde | 0% | 0% | Compensatória | Verde | 0% | 0% | Banco |  |
| 2096 | 3.1.3.26.2.2.6 | 50% do valor do imóvel do Pleito de Periquito a definir - Aquisição de imóvel repassado | milestone | 0d | 2020-04-09 | 2020-04-09 | 2095FS+5d | 2020-04-09 | 2020-04-09 | 0d | 2020-04-09 | 2020-04-09 | 411d | 0d | Verde | Verde | 0% | 0% | Compensatória | Verde | 0% | 0% | Banco |  |
| 2097 | 3.1.3.26.2.2.7 | Aquisição do imóvel do Pleito de Periquito a definir - Aquisição de imóvel concluída | milestone | 0d | 2020-04-09 | 2020-04-09 | 2093, 2096 | 2020-04-09 | 2020-04-09 | 0d | 2020-04-09 | 2020-04-09 | 411d | 0d | Verde | Verde | 0% | 0% | Compensatória | Verde | 0% | 0% | Município |  |
| 2098 | 3.1.3.26.2.3 | Pleito de Periquito de Aquisição de imóvel a definir concluído | milestone | 0d | 2020-04-09 | 2020-04-09 | 2097 | 2020-04-09 | 2020-04-09 | 0d | 2020-04-09 | 2020-04-09 | 884d | 636d | Verde | Verde | 0% | 0% | Compensatória | Verde | 0% | 0% | Município |  |
| 2099 | 3.1.3.26.3 | **Pleito PERESOB01 - Implantação de sistema de esgotamento sanitário da sede do município e distritos São Sebastião do Baixio, Pedra Corrida e Serraria** |  | 473d | 2020-04-28 | 2022-03-22 |  | 2020-04-28 | 2022-03-22 | 473d | 2020-04-23 | 2022-03-11 | 400d |  | Verde | Verde | 0% | 0% | Compensatória | Verde | 0% | 0% |  |  |
| 2100 | 3.1.3.26.3.1 | **Licitação da obra** |  | 79d | 2020-04-28 | 2020-08-19 |  | 2020-04-28 | 2020-08-19 | 79d | 2020-04-23 | 2020-08-14 | 400d |  | Verde | Verde | 0% | 0% | Compensatória | Verde | 0% | 0% |  |  |
| 2101 | 3.1.3.26.3.1.1 | Licitação da obra de Periquito do Pleito PERESOB01 - Implantação de sistema de esgotamento sanitário da sede do município e distritos São Sebastião do Baixio, Pedra Corrida e Serraria autorizada pelo banco | milestone | 0d | 2020-04-28 | 2020-04-28 | 2085 | 2020-04-28 | 2020-04-28 | 0d | 2020-04-23 | 2020-04-23 | 400d | 0d | Verde | Verde | 0% | 0% | Compensatória | Verde | 0% | 0% | Banco |  |
| 2102 | 3.1.3.26.3.1.2 | Licitar Obra |  | 63d | 2020-04-29 | 2020-07-28 | 2101 | 2020-04-29 | 2020-07-28 | 63d | 2020-04-24 | 2020-07-23 | 400d | 0d | Verde | Verde | 0% | 0% | Compensatória | Verde | 0% | 0% | Município |  |
| 2103 | 3.1.3.26.3.1.3 | Analisar e emitir resultado da licitação da obra |  | 16d | 2020-07-29 | 2020-08-19 | 2102 | 2020-07-29 | 2020-08-19 | 16d | 2020-07-24 | 2020-08-14 | 400d | 0d | Verde | Verde | 0% | 0% | Compensatória | Verde | 0% | 0% | Banco |  |
| 2104 | 3.1.3.26.3.1.4 | Licitação da obra de Periquito do Pleito PERESOB01 - Implantação de sistema de esgotamento sanitário da sede do município e distritos São Sebastião do Baixio, Pedra Corrida e Serraria concluída | milestone | 0d | 2020-08-19 | 2020-08-19 | 2103 | 2020-08-19 | 2020-08-19 | 0d | 2020-08-14 | 2020-08-14 | 400d | 0d | Verde | Verde | 0% | 0% | Compensatória | Verde | 0% | 0% | Município |  |
| 2105 | 3.1.3.26.3.2 | Executar obra |  | 250d | 2020-09-17 | 2021-09-17 | 2104FS+19d | 2020-09-17 | 2021-09-17 | 250d | 2020-08-17 | 2021-08-26 | 400d | 0d | Verde | Verde | 0% | 0% | Compensatória | Verde | 0% | 0% | Município |  |
| 2106 | 3.1.3.26.3.3 | Realizar processo de pré-operação |  | 120d | 2021-09-20 | 2022-03-15 | 2105 | 2021-09-20 | 2022-03-15 | 120d | 2021-08-27 | 2022-03-04 | 400d | 0d | Verde | Verde | 0% | 0% | Compensatória | Verde | 0% | 0% | Município |  |
| 2107 | 3.1.3.26.3.4 | Recurso da obra de Periquito do Pleito PERESOB01 - Implantação de sistema de esgotamento sanitário da sede do município e distritos São Sebastião do Baixio, Pedra Corrida e Serraria repassado | milestone | 0d | 2022-03-22 | 2022-03-22 | 2106FS+5d | 2022-03-22 | 2022-03-22 | 0d | 2022-03-11 | 2022-03-11 | 400d | 0d | Verde | Verde | 0% | 0% | Compensatória | Verde | 0% | 0% | Banco |  |
| 2108 | 3.1.3.26.3.5 | Pleito PERESOB01 - Implantação de sistema de esgotamento sanitário da sede do município e distritos São Sebastião do Baixio, Pedra Corrida e Serraria de Periquito concluído | milestone | 0d | 2022-03-22 | 2022-03-22 | 2107 | 2022-03-22 | 2022-03-22 | 0d | 2022-03-11 | 2022-03-11 | 400d | 152d | Verde | Verde | 0% | 0% | Compensatória | Verde | 0% | 0% | Município |  |
| 2109 | 3.1.3.26.4 | **Pleito de Periquito Resíduos Sólidos a definir** |  | 787d | 2019-08-30 | 2022-10-28 |  | 2019-08-30 | 2022-10-28 | 787d | 2019-08-30 | 2025-02-25 | 248d |  | Verde | Verde | 0% | 0% | Compensatória | Verde | 0% | 0% |  |  |
| 2110 | 3.1.3.26.4.1 | Pleito de Periquito de Resíduos Sólidos a definir aprovado | milestone | 0d | 2019-08-30 | 2019-08-30 | 418 | 2019-08-30 | 2019-08-30 | 0d | 2019-08-30 | 2019-08-30 | 248d | 0d | Verde | Verde | 0% | 0% | Compensatória | Verde | 0% | 0% | CT/CIF |  |
| 2111 | 3.1.3.26.4.2 | Iniciar serviço/projeto/obra do pleito de Periquito de Resíduos Sólidos a definir |  | 1d | 2019-09-02 | 2019-09-02 | 2110 | 2019-09-02 | 2019-09-02 | 1d | 2019-09-02 | 2019-09-02 | 248d | 0d | Verde | Verde | 0% | 0% | Compensatória | Verde | 0% | 0% | Município | Critério FR |
| 2112 | 3.1.3.26.4.3 | Pleito de Periquito de Resíduos Sólidos a definir concluído | milestone | 0d | 2022-10-28 | 2022-10-28 | 2111FS+786d | 2022-10-28 | 2022-10-28 | 0d | 2025-02-25 | 2025-02-25 | 248d | 0d | Verde | Verde | 0% | 0% | Compensatória | Verde | 0% | 0% | Município |  |
| 2113 | 3.1.3.26.5 | Recursos de Periquito repassados | milestone | 0d | 2022-10-28 | 2022-10-28 | 2087, 2098, 2108, 2112 | 2022-10-28 | 2022-10-28 | 0d | 2025-02-25 | 2025-02-25 | 248d |  | Verde | Verde | 0% | 0% | Compensatória | Verde | 0% | 0% | Banco |  |

Notes:
- 2089: Em 24/09/2019: município deve apresentar pleito até 30 de julho para atender cronograma da NT 33 e não atrasar o término do projeto executivo e obra.
- 2105: Em 24/04/2019: valor da obra R$ 3,9 milhões
- 2113: Valor de recurso destinado ao munícipio: R$4.726.993,07

| ID | WBS | Task | Type | Duration | Start | Finish | Predecessors | Complete | Remaining | Baseline start | Baseline finish | Baseline duration | Baseline 1 start | Baseline 1 finish | Total slack | Free slack | Constraint | Text1 | Text2 | Text3 | Text5 | Text6 | Text8 | Text12 | Text14 | Text16 | Text4 | Text15 | Text7 | Text9 | Text17 | Text18 |
| --- | --- | --- | --- | --- | --- | --- | --- | --- | --- | --- | --- | --- | --- | --- | --- | --- | --- | --- | --- | --- | --- | --- | --- | --- | --- | --- | --- | --- | --- | --- | --- | --- |
| 2114 | 3.1.3.27 | **Pingo D'água** |  | 1039d | 2018-08-31 A | 2022-10-28 |  | 3% | 1002.71d | 2018-08-31 | 2022-10-28 | 1039d | 2018-08-31 | 2025-02-25 | 248d |  |  | Verde | Verde | 18% | 18 | 0% | Compensatória | Vermelho | 0% | 0% |  |  |  |  |  |  |
| 2115 | 3.1.3.27.1 | **Pleito PIAESPJ01 - Elaboração de projeto de sistema de esgotamento sanitário para a sede do município** |  | 533d | 2018-08-31 A | 2020-10-16 |  | 7% | 496.62d | 2018-08-31 | 2020-10-16 | 533d | 2018-08-31 | 2020-07-15 | 754d |  |  | Verde | Verde | 35% | 35 | 0% | Compensatória | Vermelho | 3% | 0% |  |  |  |  |  |  |
| 2116 | 3.1.3.27.1.1 | **Licitação do Projeto** |  | 293d | 2018-08-31 A | 2019-10-28 |  | 26% | 216.18d | 2018-08-31 | 2019-10-28 | 293d | 2018-08-31 | 2019-06-04 | 286d |  |  | Verde | Verde | 64% | 64 | 0% | Compensatória | Vermelho | 22% | 0% | 26 | 22 |  |  |  |  |
| 2117 | 3.1.3.27.1.1.1 | Licitação do projeto de Pingo D'água do Pleito PIAESPJ01 - Elaboração de projeto de sistema de esgotamento sanitário para a sede do município autorizada pelo banco | milestone | 0d | 2018-08-31 A | 2018-08-31 A |  | 100% |  | 2018-08-31 | 2018-08-31 | 0d | 2018-08-31 | 2018-08-31 |  |  | must start on 2018-08-31 | Verde | Verde | 100% | 100 | 100% | Compensatória | Verde | 100% | 100% | 100 | 100 | 100 | Banco | 100 |  |
| 2118 | 3.1.3.27.1.1.2 | Licitar projeto |  | 150d | 2019-02-21 A | 2019-10-01 | 2117FS+124d | 29% | 107d | 2019-02-21 | 2019-10-01 | 150d | 2019-02-21 | 2019-05-15 | 286d | 0d |  | Verde | Verde | 43% | 43 | 0% | Compensatória | Vermelho | 43% | 0% | 29 | 43 |  | Município |  | Conforme agendado |
| 2119 | 3.1.3.27.1.1.3 | Documentação de licitação de Pingo D'água do Pleito PIAESPJ01 - Elaboração de projeto de sistema de esgotamento sanitário para a sede do município apresentada ao banco | milestone | 0d | 2019-10-08 | 2019-10-08 | 2118FS+5d |  |  | 2019-10-08 | 2019-10-08 | 0d | 2019-05-15 | 2019-05-15 | 286d | 0d |  | Verde | Verde | 0% |  | 0% | Compensatória | Verde | 0% | 0% |  |  |  | Município |  |  |
| 2120 | 3.1.3.27.1.1.4 | Analisar e emitir resultado da licitação do projeto |  | 14d | 2019-10-09 | 2019-10-28 | 2119 |  |  | 2019-10-09 | 2019-10-28 | 14d | 2019-05-16 | 2019-06-04 | 286d | 0d |  | Verde | Verde | 0% |  | 0% | Compensatória | Verde | 0% | 0% |  |  |  | Banco |  | Critério FR |
| 2121 | 3.1.3.27.1.1.5 | Licitação do projeto de Pingo D'água do Pleito PIAESPJ01 - Elaboração de projeto de sistema de esgotamento sanitário para a sede do município concluída | milestone | 0d | 2019-10-28 | 2019-10-28 | 2120 |  |  | 2019-10-28 | 2019-10-28 | 0d | 2019-06-04 | 2019-06-04 | 286d | 0d |  | Verde | Verde | 0% |  | 0% | Compensatória | Verde | 0% | 0% |  |  |  | Município |  |  |
| 2122 | 3.1.3.27.1.2 | **Elaboração de Estudo de Concepção** |  | 105d | 2019-10-29 | 2020-04-02 |  |  |  | 2019-10-29 | 2020-04-02 | 105d |  |  | 286d |  |  | Verde | Verde | 0% |  | 0% | Compensatória | Verde | 0% | 0% |  |  |  |  |  |  |
| 2123 | 3.1.3.27.1.2.1 | Elaborar estudo |  | 40d | 2019-10-29 | 2019-12-27 | 2121 |  |  | 2019-10-29 | 2019-12-27 | 40d |  |  | 286d | 0d |  | Verde | Verde | 0% |  | 0% | Compensatória | Verde | 0% | 0% |  |  |  |  |  | Critério FR |
| 2124 | 3.1.3.27.1.2.2 | Estudo de concepção de Pingo D'água do Pleito PIAESPJ01 - Elaboração de projeto de sistema de esgotamento sanitário para a sede do município apresentado ao banco | milestone | 0d | 2019-12-27 | 2019-12-27 | 2123 |  |  | 2019-12-27 | 2019-12-27 | 0d |  |  | 411d | 0d |  | Verde | Verde | 0% |  | 0% | Compensatória | Verde | 0% | 0% |  |  |  |  |  |  |
| 2125 | 3.1.3.27.1.2.3 | Analisar estudo |  | 60d | 2019-12-30 | 2020-03-26 | 2124 |  |  | 2019-12-30 | 2020-03-26 | 60d |  |  | 411d | 0d |  | Verde | Verde | 0% |  | 0% | Compensatória | Verde | 0% | 0% |  |  |  |  |  |  |
| 2126 | 3.1.3.27.1.2.4 | Estudo de concepção de Pingo D'água do Pleito PIAESPJ01 - Elaboração de projeto de sistema de esgotamento sanitário para a sede do município concluído | milestone | 0d | 2020-03-26 | 2020-03-26 | 2125 |  |  | 2020-03-26 | 2020-03-26 | 0d |  |  | 411d | 0d |  | Verde | Verde | 0% |  | 0% | Compensatória | Verde | 0% | 0% |  |  |  |  |  |  |
| 2127 | 3.1.3.27.1.2.5 | Recurso do estudo de concepção de Pingo D'água do Pleito PIAESPJ01 - Elaboração de projeto de sistema de esgotamento sanitário para a sede do município repassado | milestone | 0d | 2020-04-02 | 2020-04-02 | 2126FS+5d |  |  | 2020-04-02 | 2020-04-02 | 0d |  |  | 411d | 21d |  | Verde | Verde | 0% |  | 0% | Compensatória | Verde | 0% | 0% |  |  |  |  |  |  |
| 2128 | 3.1.3.27.1.3 | **Elaboração do Projeto Básico** |  | 91d | 2019-12-30 | 2020-05-13 |  |  |  | 2019-12-30 | 2020-05-13 | 91d | 2019-06-05 | 2019-12-16 | 286d |  |  | Verde | Verde | 0% |  | 0% | Compensatória | Verde | 0% | 0% |  |  |  |  |  |  |
| 2129 | 3.1.3.27.1.3.1 | Elaborar Projeto Básico |  | 20d | 2019-12-30 | 2020-01-27 | 2123 |  |  | 2019-12-30 | 2020-01-27 | 20d | 2019-06-05 | 2019-09-04 | 286d | 0d |  | Verde | Verde | 0% |  | 0% | Compensatória | Verde | 0% | 0% |  |  |  | Município |  |  |
| 2130 | 3.1.3.27.1.3.2 | Projeto básico de Pingo D'água do Pleito PIAESPJ01 - Elaboração de projeto de sistema de esgotamento sanitário para a sede do município apresentado ao banco | milestone | 0d | 2020-01-27 | 2020-01-27 | 2129 |  |  | 2020-01-27 | 2020-01-27 | 0d | 2019-09-04 | 2019-09-04 | 292d | 0d |  | Verde | Verde | 0% |  | 0% | Compensatória | Verde | 0% | 0% |  |  |  | Município |  |  |
| 2131 | 3.1.3.27.1.3.3 | Analisar projeto básico |  | 66d | 2020-01-28 | 2020-05-06 | 2130 |  |  | 2020-01-28 | 2020-05-06 | 66d | 2019-09-05 | 2019-10-04 | 292d | 0d |  | Verde | Verde | 0% |  | 0% | Compensatória | Verde | 0% | 0% |  |  |  | Banco |  |  |
| 2132 | 3.1.3.27.1.3.4 | Projeto básico de Pingo D'água do Pleito PIAESPJ01 - Elaboração de projeto de sistema de esgotamento sanitário para a sede do município concluído | milestone | 0d | 2020-05-06 | 2020-05-06 | 2127, 2131 |  |  | 2020-05-06 | 2020-05-06 | 0d | 2019-12-06 | 2019-12-06 | 390d | 0d |  | Verde | Verde | 0% |  | 0% | Compensatória | Verde | 0% | 0% |  |  |  | Município |  |  |
| 2133 | 3.1.3.27.1.3.5 | Recurso do projeto básico de Pingo D'água do Pleito PIAESPJ01 - Elaboração de projeto de sistema de esgotamento sanitário para a sede do município repassado | milestone | 0d | 2020-05-13 | 2020-05-13 | 2132FS+5d |  |  | 2020-05-13 | 2020-05-13 | 0d | 2019-12-16 | 2019-12-16 | 390d | 104d |  | Verde | Verde | 0% |  | 0% | Compensatória | Verde | 0% | 0% |  |  |  | Banco |  |  |
| 2134 | 3.1.3.27.1.4 | Realizar Licenciamento Ambiental |  | 175d | 2020-01-28 | 2020-10-08 | 2129 |  |  | 2020-01-28 | 2020-10-08 | 175d | 2019-09-05 | 2020-05-21 | 286d | 0d |  | Verde | Verde | 0% |  | 0% | Compensatória | Verde | 0% | 0% |  |  |  | Município |  |  |
| 2135 | 3.1.3.27.1.5 | **Elaboração do Projeto Executivo** |  | 180d | 2020-01-28 | 2020-10-16 |  |  |  | 2020-01-28 | 2020-10-16 | 180d | 2019-12-09 | 2020-07-15 | 356d |  |  | Verde | Verde | 0% |  | 0% | Compensatória | Verde | 0% | 0% |  |  |  |  |  |  |
| 2136 | 3.1.3.27.1.5.1 | Elaborar Projeto Executivo |  | 40d | 2020-01-28 | 2020-03-26 | 2129 |  |  | 2020-01-28 | 2020-03-26 | 40d | 2019-12-09 | 2020-02-12 | 356d | 0d |  | Verde | Verde | 0% |  | 0% | Compensatória | Verde | 0% | 0% |  |  |  | Município |  |  |
| 2137 | 3.1.3.27.1.5.2 | Projeto executivo de Pingo D'água do Pleito PIAESPJ01 - Elaboração de projeto de sistema de esgotamento sanitário para a sede do município apresentado ao banco | milestone | 0d | 2020-03-26 | 2020-03-26 | 2136 |  |  | 2020-03-26 | 2020-03-26 | 0d | 2020-02-12 | 2020-02-12 | 356d | 0d |  | Verde | Verde | 0% |  | 0% | Compensatória | Verde | 0% | 0% |  |  |  | Município |  |  |
| 2138 | 3.1.3.27.1.5.3 | Analisar projeto executivo |  | 65d | 2020-03-27 | 2020-07-01 | 2137 |  |  | 2020-03-27 | 2020-07-01 | 65d | 2020-02-13 | 2020-03-17 | 356d | 70d |  | Verde | Verde | 0% |  | 0% | Compensatória | Verde | 0% | 0% |  |  |  | Banco |  |  |
| 2139 | 3.1.3.27.1.5.4 | Projeto executivo de Pingo D'água do Pleito PIAESPJ01 - Elaboração de projeto de sistema de esgotamento sanitário para a sede do município concluído | milestone | 0d | 2020-10-08 | 2020-10-08 | 2133, 2134, 2152, 2138 |  |  | 2020-10-08 | 2020-10-08 | 0d | 2020-07-08 | 2020-07-08 | 286d | 0d |  | Verde | Verde | 0% |  | 0% | Compensatória | Verde | 0% | 0% |  |  |  | Município |  |  |
| 2140 | 3.1.3.27.1.5.5 | Recurso do projeto executivo de Pingo D'água do Pleito PIAESPJ01 - Elaboração de projeto de sistema de esgotamento sanitário para a sede do município repassado | milestone | 0d | 2020-10-16 | 2020-10-16 | 2139FS+5d |  |  | 2020-10-16 | 2020-10-16 | 0d | 2020-07-15 | 2020-07-15 | 754d | 0d |  | Verde | Verde | 0% |  | 0% | Compensatória | Verde | 0% | 0% |  |  |  | Banco |  |  |
| 2141 | 3.1.3.27.1.6 | Pleito PIAESPJ01 - Elaboração de projeto de sistema de esgotamento sanitário para a sede do município de Pingo D'água concluído | milestone | 0d | 2020-10-16 | 2020-10-16 | 2134, 2140 |  |  | 2020-10-16 | 2020-10-16 | 0d | 2020-07-15 | 2020-07-15 | 754d | 506d |  | Verde | Verde | 0% |  | 0% | Compensatória | Verde | 0% | 0% |  |  |  | Município |  |  |

Notes:
- 2114: Pingo D'água teve 100% dos pleitos de Esgotamento Sanitário aprovado (R$4.254.293,76), conforme Deliberação 75. / O município teve o pleito de resíduos sólidos negado (R$472.699,31, equivalente a 10% do total do recurso).
- 2117: Em 25/04/2019: conforme planilha Controle Gerencial Renova o banco enviou ao município autorização no dia 31/08/2018
- 2118: 18/12/2018 - Município não consegue avançar no preenchimento da planilha oramentária do TR. Apoio técnico irá auxiliar o município com criação da planilha orçamentária, mas por motivo de férias da engenheira em janeiro, o prazo precisou ser extendido. / 25/04/2019: banco cobrou no dia 15/03 o processo licitatório do município. considerado mais 2 meses para apresentação do mesmo em maio de 2019 / 29/05/2019: município vai pedir alteração do pleito do projeto aumentando o valor. Por isso foi premissado 2 meses após aprovação do pleito no CIF de julho.
- 2123: 29/05/2019: conforme TR foi premissado 2 meses para elaboração do estudo
- 2129: 29/05/2019: conforme TR foi premissado 1 meses para elaboração do projeto básico
- 2136: 24/05/2019: município pactuou com a Renova 2 meses para elaborar projeto executivo / 28/05/2019: conforme TR foi premissado 2 meses para elaboração do projeto executivo

| ID | WBS | Task | Type | Duration | Start | Finish | Predecessors | Baseline start | Baseline finish | Baseline duration | Baseline 1 start | Baseline 1 finish | Total slack | Free slack | Text1 | Text2 | Text3 | Text6 | Text8 | Text12 | Text14 | Text16 | Text9 | Text18 |
| --- | --- | --- | --- | --- | --- | --- | --- | --- | --- | --- | --- | --- | --- | --- | --- | --- | --- | --- | --- | --- | --- | --- | --- | --- |
| 2142 | 3.1.3.27.2 | **Pleito de Pingo D'água a definir - Aquisição de Terreno** |  | 206d | 2019-11-29 | 2020-09-30 |  | 2019-11-29 | 2020-09-30 | 206d | 2019-11-29 | 2020-07-08 | 292d |  | Verde | Verde | 0% | 0% | Compensatória | Verde | 0% | 0% |  |  |
| 2143 | 3.1.3.27.2.1 | Pleito de Pingo D'água a definir - Aquisição de Terreno aprovado | milestone | 0d | 2019-11-29 | 2019-11-29 | 3052FS+242d | 2019-11-29 | 2019-11-29 | 0d | 2019-11-29 | 2019-11-29 | 351d | 59d | Verde | Verde | 0% | 0% | Compensatória | Verde | 0% | 0% | CT/CIF |  |
| 2144 | 3.1.3.27.2.2 | **Aquisição de Terreno** |  | 147d | 2020-03-03 | 2020-09-30 |  | 2020-03-03 | 2020-09-30 | 147d | 2019-12-02 | 2020-07-08 | 292d |  | Verde | Verde | 0% | 0% | Compensatória | Verde | 0% | 0% | Município |  |
| 2145 | 3.1.3.27.2.2.1 | Regularizar terreno e apresentar escritura ao banco |  | 88d | 2020-03-03 | 2020-07-08 | 2143, 2131FS-44d | 2020-03-03 | 2020-07-08 | 88d | 2019-12-02 | 2020-04-13 | 292d | 0d | Verde | Verde | 0% | 0% | Compensatória | Verde | 0% | 0% | Município |  |
| 2146 | 3.1.3.27.2.2.2 | Analisar documentação do terreno |  | 10d | 2020-07-09 | 2020-07-22 | 2145 | 2020-07-09 | 2020-07-22 | 10d | 2020-04-14 | 2020-04-28 | 336d | 0d | Verde | Verde | 0% | 0% | Compensatória | Verde | 0% | 0% | Banco |  |
| 2147 | 3.1.3.27.2.2.3 | 50% do valor do imóvel do Pleito de Pingo D'água a definir - Aquisição de Terreno repassado | milestone | 0d | 2020-07-29 | 2020-07-29 | 2146FS+5d | 2020-07-29 | 2020-07-29 | 0d | 2020-05-06 | 2020-05-06 | 336d | 44d | Verde | Verde | 0% | 0% | Compensatória | Verde | 0% | 0% | Banco |  |
| 2148 | 3.1.3.27.2.2.4 | Registrar imóvel e apresentar documentação ao banco |  | 44d | 2020-07-09 | 2020-09-09 | 2145 | 2020-07-09 | 2020-09-09 | 44d | 2020-04-14 | 2020-06-17 | 292d | 0d | Verde | Verde | 0% | 0% | Compensatória | Verde | 0% | 0% | Município |  |
| 2149 | 3.1.3.27.2.2.5 | Analisar documentação do terreno |  | 10d | 2020-09-10 | 2020-09-23 | 2148 | 2020-09-10 | 2020-09-23 | 10d | 2020-06-18 | 2020-07-01 | 292d | 0d | Verde | Verde | 0% | 0% | Compensatória | Verde | 0% | 0% | Banco |  |
| 2150 | 3.1.3.27.2.2.6 | 50% do valor do imóvel do Pleito de Pingo D'água a definir - Aquisição de Terreno repassado | milestone | 0d | 2020-09-30 | 2020-09-30 | 2149FS+5d | 2020-09-30 | 2020-09-30 | 0d | 2020-07-08 | 2020-07-08 | 292d | 0d | Verde | Verde | 0% | 0% | Compensatória | Verde | 0% | 0% | Banco |  |
| 2151 | 3.1.3.27.2.2.7 | Aquisição de Terreno do Pleito de Pingo D'água a definir - Aquisição de Terreno concluída | milestone | 0d | 2020-09-30 | 2020-09-30 | 2147, 2150 | 2020-09-30 | 2020-09-30 | 0d | 2020-07-08 | 2020-07-08 | 292d | 0d | Verde | Verde | 0% | 0% | Compensatória | Verde | 0% | 0% | Município |  |
| 2152 | 3.1.3.27.2.3 | Pleito de Pingo D'água a definir - Aquisição de Terreno concluído | milestone | 0d | 2020-09-30 | 2020-09-30 | 2151 | 2020-09-30 | 2020-09-30 | 0d | 2020-07-08 | 2020-07-08 | 292d | 6d | Verde | Verde | 0% | 0% | Compensatória | Verde | 0% | 0% | Município |  |
| 2153 | 3.1.3.27.3 | **Pleito PIAESOB01 - Implantação do sistema de esgotamento sanitário da sede do município** |  | 473d | 2020-10-08 | 2022-09-02 |  | 2020-10-08 | 2022-09-02 | 473d | 2020-07-08 | 2022-05-26 | 286d |  | Verde | Verde | 0% | 0% | Compensatória | Verde | 0% | 0% |  |  |
| 2154 | 3.1.3.27.3.1 | **Licitação da Obra** |  | 79d | 2020-10-08 | 2021-02-03 |  | 2020-10-08 | 2021-02-03 | 79d | 2020-07-08 | 2020-10-29 | 286d |  | Verde | Verde | 0% | 0% | Compensatória | Verde | 0% | 0% |  |  |
| 2155 | 3.1.3.27.3.1.1 | Licitação da obra de Pingo D'água do Pleito PIAESOB01 - Implantação do sistema de esgotamento asnitário da sede do município autorizada pelo banco | milestone | 0d | 2020-10-08 | 2020-10-08 | 2139 | 2020-10-08 | 2020-10-08 | 0d | 2020-07-08 | 2020-07-08 | 286d | 0d | Verde | Verde | 0% | 0% | Compensatória | Verde | 0% | 0% | Banco |  |
| 2156 | 3.1.3.27.3.1.2 | Licitar Obra |  | 65d | 2020-10-09 | 2021-01-14 | 2155 | 2020-10-09 | 2021-01-14 | 65d | 2020-07-09 | 2020-10-08 | 286d | 0d | Verde | Verde | 0% | 0% | Compensatória | Verde | 0% | 0% | Município |  |
| 2157 | 3.1.3.27.3.1.3 | Analisar e emitir resultado da licitação da obra |  | 14d | 2021-01-15 | 2021-02-03 | 2156 | 2021-01-15 | 2021-02-03 | 14d | 2020-10-09 | 2020-10-29 | 286d | 0d | Verde | Verde | 0% | 0% | Compensatória | Verde | 0% | 0% | Banco |  |
| 2158 | 3.1.3.27.3.1.4 | Licitação da obra de Pingo D'água do Pleito PIAESOB01 - Implantação do sistema de esgotamento asnitário da sede do município concluída | milestone | 0d | 2021-02-03 | 2021-02-03 | 2157 | 2021-02-03 | 2021-02-03 | 0d | 2020-10-29 | 2020-10-29 | 286d | 0d | Verde | Verde | 0% | 0% | Compensatória | Verde | 0% | 0% | Município |  |
| 2159 | 3.1.3.27.3.2 | Executar obra |  | 249d | 2021-03-09 | 2022-03-07 | 2158FS+20d | 2021-03-09 | 2022-03-07 | 249d | 2020-10-30 | 2021-11-11 | 286d | 0d | Verde | Verde | 0% | 0% | Compensatória | Verde | 0% | 0% | Município |  |
| 2160 | 3.1.3.27.3.3 | Realizar processo de pré-operação |  | 120d | 2022-03-08 | 2022-08-26 | 2159 | 2022-03-08 | 2022-08-26 | 120d | 2021-11-12 | 2022-05-19 | 286d | 0d | Verde | Verde | 0% | 0% | Compensatória | Verde | 0% | 0% | Município |  |
| 2161 | 3.1.3.27.3.4 | Recurso da obra de Pingo D'água do Pleito PIAESOB01 - Implantação do sistema de esgotamento asnitário da sede do município repassado | milestone | 0d | 2022-09-02 | 2022-09-02 | 2160FS+5d | 2022-09-02 | 2022-09-02 | 0d | 2022-05-26 | 2022-05-26 | 286d | 0d | Verde | Verde | 0% | 0% | Compensatória | Verde | 0% | 0% | Banco |  |
| 2162 | 3.1.3.27.3.5 | Pleito PIAESOB01 - Implantação do sistema de esgotamento asnitário da sede do município de Pingo D'água concluído | milestone | 0d | 2022-09-02 | 2022-09-02 | 2161 | 2022-09-02 | 2022-09-02 | 0d | 2022-05-26 | 2022-05-26 | 286d | 38d | Verde | Verde | 0% | 0% | Compensatória | Verde | 0% | 0% | Município |  |
| 2163 | 3.1.3.27.4 | **Pleito de Pingo D'agua de Resíduos Sólidos a definir** |  | 787d | 2019-08-30 | 2022-10-28 |  | 2019-08-30 | 2022-10-28 | 787d | 2019-08-30 | 2025-02-25 | 248d |  | Verde | Verde | 0% | 0% | Compensatória | Verde | 0% | 0% |  |  |
| 2164 | 3.1.3.27.4.1 | Pleito de Pingo D'água de Resíduos Sólidos a definir aprovado | milestone | 0d | 2019-08-30 | 2019-08-30 | 418 | 2019-08-30 | 2019-08-30 | 0d | 2019-08-30 | 2019-08-30 | 248d | 0d | Verde | Verde | 0% | 0% | Compensatória | Verde | 0% | 0% | CT/CIF |  |
| 2165 | 3.1.3.27.4.2 | Iniciar serviço/projeto/obra do pleito de Pingo D'agua de Resíudos Sólidos a definir |  | 1d | 2019-09-02 | 2019-09-02 | 2164 | 2019-09-02 | 2019-09-02 | 1d | 2019-09-02 | 2019-09-02 | 248d | 0d | Verde | Verde | 0% | 0% | Compensatória | Verde | 0% | 0% | Município | Critério FR |
| 2166 | 3.1.3.27.4.3 | Pleito de Pingo D'água de Resíduos Sólidos a definir concluído | milestone | 0d | 2022-10-28 | 2022-10-28 | 2165FS+786d | 2022-10-28 | 2022-10-28 | 0d | 2025-02-25 | 2025-02-25 | 248d | 0d | Verde | Verde | 0% | 0% | Compensatória | Verde | 0% | 0% | Município |  |
| 2167 | 3.1.3.27.5 | Recursos de Pingo D'água repassados | milestone | 0d | 2022-10-28 | 2022-10-28 | 2141, 2162, 2166 | 2022-10-28 | 2022-10-28 | 0d | 2025-02-25 | 2025-02-25 | 248d |  | Verde | Verde | 0% | 0% | Compensatória | Verde | 0% | 0% | Banco |  |

Notes:
- 2143: Em 25/04/2019: município mostrou interesse em fazer um pleito de terreno na reunião do dia 21/02/2019. Considerado que o município enviará o pleito e será aprovado no CIF do dia 29/11/2019 conforme NT 33 e após apresentação do projeto básico em setembro.
- 2159: Em 25/04/2019: valor da obra R$ 4 milhões
- 2167: Valor de recurso destinado ao munícipio: R$4.726.993,07

| ID | WBS | Task | Type | Duration | Start | Finish | Predecessors | Complete | Remaining | Baseline start | Baseline finish | Baseline duration | Baseline 1 start | Baseline 1 finish | Total slack | Free slack | Constraint | Text1 | Text2 | Text3 | Text6 | Text8 | Text12 | Text14 | Text16 | Text5 | Text7 | Text4 | Text9 | Text15 | Text17 | Text18 |
| --- | --- | --- | --- | --- | --- | --- | --- | --- | --- | --- | --- | --- | --- | --- | --- | --- | --- | --- | --- | --- | --- | --- | --- | --- | --- | --- | --- | --- | --- | --- | --- | --- |
| 2168 | 3.1.3.28 | **Raul Soares** |  | 1148d | 2019-03-20 A | 2023-10-30 |  | 2% | 1120.72d | 2019-03-20 | 2023-10-30 | 1148d | 2019-03-20 | 2024-01-30 | 0d |  |  | Verde | Verde | 4% | 0% | Compensatória | Vermelho | 0% | 0% |  |  |  |  |  |  |  |
| 2169 | 3.1.3.28.1 | **Pleito RASESPJ02 - Elaboração de projetos de engenharia de sistemas de esgotamento sanitário para a sede municipal, distritos de São Vicente da Estrela, São Sebastião do Óculo, Santana do Tabuleiro, Vermelho Velho e povoado Cornélio Alves** |  | 276d | 2019-03-20 A | 2020-04-29 |  | 6% | 260.6d | 2019-03-20 | 2020-03-26 | 254d | 2019-03-20 | 2020-02-04 | 872d |  |  | Verde | Verde | 19% | 50% | Compensatória | Vermelho | 4% | 2% | 19 | 50 |  |  |  |  |  |
| 2170 | 3.1.3.28.1.1 | Alteração do Pleito RASESPJ02 - Elaboração de projetos de engenharia de sistemas de esgotamento sanitário para a sede municipal e distritos de Raul Soares aprovada | milestone | 0d | 2019-03-20 A | 2019-03-20 A |  | 100% |  | 2019-03-20 | 2019-03-20 | 0d | 2019-03-20 | 2019-03-20 |  |  | must start on 2019-03-20 | Verde | Verde | 100% | 100% | Compensatória | Verde | 100% | 100% | 100 | 100 | 100 | CT/CIF | 100 | 100 |  |
| 2171 | 3.1.3.28.1.2 | **Licitação do Projeto** |  | 125d | 2019-03-27 A | 2019-09-25 |  | 22% | 97.4d | 2019-03-27 | 2019-08-26 | 103d | 2019-03-27 | 2019-06-25 | 238d |  |  | Verde | Verde | 42% | 48% | Compensatória | Vermelho | 42% | 20% | 42 | 48 | 22 |  | 42 | 20 |  |
| 2172 | 3.1.3.28.1.2.1 | Licitação do projeto de Raul Soares do Pleito RASESPJ02 - Elaboração de projetos de engenharia de sistemas de esgotamento sanitário para a sede municipal e distritos autorizada pelo banco | milestone | 0d | 2019-03-27 A | 2019-03-27 A | 2170FS+6d | 100% |  | 2019-03-27 | 2019-03-27 | 0d | 2019-03-27 | 2019-03-27 |  |  |  | Verde | Verde | 100% | 100% | Compensatória | Verde | 100% | 100% | 100 | 100 | 100 | Banco | 100 | 100 |  |
| 2173 | 3.1.3.28.1.2.2 | Licitar projeto |  | 106d | 2019-03-28 A | 2019-08-29 | 2172 | 25% | 79.5d | 2019-03-28 | 2019-07-29 | 84d | 2019-03-28 | 2019-05-28 | 238d | 0d |  | Verde | Verde | 52% | 48% | Compensatória | Vermelho | 52% | 25% | 52 | 48 | 26 | Município | 52 | 25 | Conforme agendado |
| 2174 | 3.1.3.28.1.2.3 | Documentação de licitação de Raul Soares do Pleito RASESPJ02 - Elaboração de projetos de engenharia de sistemas de esgotamento sanitário para a sede municipal e distritos apresentada ao banco | milestone | 0d | 2019-09-05 | 2019-09-05 | 2173FS+5d |  |  | 2019-08-05 | 2019-08-05 | 0d | 2019-06-04 | 2019-06-04 | 238d | 0d |  | Verde | Verde | 0% | 0% | Compensatória | Verde | 0% | 0% |  |  |  | Município |  |  |  |
| 2175 | 3.1.3.28.1.2.4 | Analisar e emitir resultado da licitação do projeto |  | 14d | 2019-09-06 | 2019-09-25 | 2174 |  |  | 2019-08-06 | 2019-08-26 | 14d | 2019-06-05 | 2019-06-25 | 238d | 0d |  | Verde | Verde | 0% | 0% | Compensatória | Verde | 0% | 0% |  |  |  | Banco |  |  | Critério FR |
| 2176 | 3.1.3.28.1.2.5 | Licitação do projeto de Raul Soares do Pleito RASESPJ02 - Elaboração de projetos de engenharia de sistemas de esgotamento sanitário para a sede municipal e distritos concluída | milestone | 0d | 2019-09-25 | 2019-09-25 | 2175 |  |  | 2019-08-26 | 2019-08-26 | 0d | 2019-06-25 | 2019-06-25 | 238d | 0d |  | Verde | Verde | 0% | 0% | Compensatória | Verde | 0% | 0% |  |  |  | Município |  |  |  |
| 2177 | 3.1.3.28.1.3 | **Elaboração do Estudo de Concepção** |  | 95d | 2019-09-26 | 2020-02-12 |  |  |  | 2019-08-27 | 2020-01-13 | 95d |  |  | 238d |  |  | Verde | Verde | 0% | 0% | Compensatória | Verde | 0% | 0% |  |  |  |  |  |  |  |
| 2178 | 3.1.3.28.1.3.1 | Elaborar estudo |  | 30d | 2019-09-26 | 2019-11-06 | 2176 |  |  | 2019-08-27 | 2019-10-07 | 30d |  |  | 238d | 0d |  | Verde | Verde | 0% | 0% | Compensatória | Verde | 0% | 0% |  |  |  |  |  |  | Critério FR |
| 2179 | 3.1.3.28.1.3.2 | Estudo de concepção de Raul Soares do Pleito RASESPJ02 - Elaboração de projetos de engenharia de sistemas de esgotamento sanitário para a sede municipal e distritos apresentado ao banco | milestone | 0d | 2019-11-06 | 2019-11-06 | 2178 |  |  | 2019-10-07 | 2019-10-07 | 0d |  |  | 912d | 0d |  | Verde | Verde | 0% | 0% | Compensatória | Verde | 0% | 0% |  |  |  |  |  |  |  |
| 2180 | 3.1.3.28.1.3.3 | Analisar estudo |  | 60d | 2019-11-07 | 2020-02-05 | 2179 |  |  | 2019-10-08 | 2020-01-06 | 60d |  |  | 912d | 0d |  | Verde | Verde | 0% | 0% | Compensatória | Verde | 0% | 0% |  |  |  |  |  |  | Critério FR |
| 2181 | 3.1.3.28.1.3.4 | Estudo de concepção de Raul Soares do Pleito RASESPJ02 - Elaboração de projetos de engenharia de sistemas de esgotamento sanitário para a sede municipal e distritos concluído | milestone | 0d | 2020-02-05 | 2020-02-05 | 2180 |  |  | 2020-01-06 | 2020-01-06 | 0d |  |  | 912d | 0d |  | Verde | Verde | 0% | 0% | Compensatória | Verde | 0% | 0% |  |  |  |  |  |  |  |
| 2182 | 3.1.3.28.1.3.5 | Recurso do estudo de Raul Soares do Pleito RASESPJ02 - Elaboração de projetos de engenharia de sistemas de esgotamento sanitário para a sede municipal e distritos repassado | milestone | 0d | 2020-02-12 | 2020-02-12 | 2181FS+5d |  |  | 2020-01-13 | 2020-01-13 | 0d |  |  | 912d | 25d |  | Verde | Verde | 0% | 0% | Compensatória | Verde | 0% | 0% |  |  |  |  |  |  |  |
| 2183 | 3.1.3.28.1.4 | **Elaboração do Projeto Básico** |  | 95d | 2019-11-07 | 2020-03-30 |  |  |  | 2019-10-08 | 2020-02-27 | 95d |  |  | 238d |  |  | Verde | Verde | 0% | 0% | Compensatória | Verde | 0% | 0% |  |  |  |  |  |  |  |
| 2184 | 3.1.3.28.1.4.1 | Elaborar projeto básico |  | 30d | 2019-11-07 | 2019-12-20 | 2178 |  |  | 2019-10-08 | 2019-11-19 | 30d |  |  | 238d | 0d |  | Verde | Verde | 0% | 0% | Compensatória | Verde | 0% | 0% |  |  |  |  |  |  | Critério FR |
| 2185 | 3.1.3.28.1.4.2 | Projeto básico de Raul Soares do Pleito RASESPJ02 - Elaboração de projetos de engenharia de sistemas de esgotamento sanitário para a sede municipal e distritos apresentado ao banco | milestone | 0d | 2019-12-20 | 2019-12-20 | 2184 |  |  | 2019-11-19 | 2019-11-19 | 0d |  |  | 887d | 0d |  | Verde | Verde | 0% | 0% | Compensatória | Verde | 0% | 0% |  |  |  |  |  |  |  |
| 2186 | 3.1.3.28.1.4.3 | Analisar projeto básico |  | 60d | 2019-12-23 | 2020-03-23 | 2185 |  |  | 2019-11-20 | 2020-02-17 | 60d |  |  | 887d | 0d |  | Verde | Verde | 0% | 0% | Compensatória | Verde | 0% | 0% |  |  |  |  |  |  | Critério FR |
| 2187 | 3.1.3.28.1.4.4 | Projeto básico de Raul Soares do Pleito RASESPJ02 - Elaboração de projetos de engenharia de sistemas de esgotamento sanitário para a sede municipal e distritos concluído | milestone | 0d | 2020-03-23 | 2020-03-23 | 2182, 2186 |  |  | 2020-02-17 | 2020-02-17 | 0d |  |  | 887d | 0d |  | Verde | Verde | 0% | 0% | Compensatória | Verde | 0% | 0% |  |  |  |  |  |  |  |
| 2188 | 3.1.3.28.1.4.5 | Recurso do projeto básico de Raul Soares do Pleito RASESPJ02 - Elaboração de projetos de engenharia de sistemas de esgotamento sanitário para a sede municipal e distritos repassado | milestone | 0d | 2020-03-30 | 2020-03-30 | 2187FS+5d |  |  | 2020-02-27 | 2020-02-27 | 0d |  |  | 887d | 15d |  | Verde | Verde | 0% | 0% | Compensatória | Verde | 0% | 0% |  |  |  |  |  |  |  |
| 2189 | 3.1.3.28.1.5 | **Elaboração do Projeto Executivo** |  | 85d | 2019-12-23 | 2020-04-29 |  |  |  | 2019-11-20 | 2020-03-26 | 85d | 2019-06-26 | 2020-02-04 | 238d |  |  | Verde | Verde | 0% | 0% | Compensatória | Verde | 0% | 0% |  |  |  |  |  |  |  |
| 2190 | 3.1.3.28.1.5.1 | Elaborar projeto executivo |  | 20d | 2019-12-23 | 2020-01-22 | 2184 |  |  | 2019-11-20 | 2019-12-18 | 20d | 2019-06-26 | 2019-10-22 | 238d | 0d |  | Verde | Verde | 0% | 0% | Compensatória | Verde | 0% | 0% |  |  |  | Município |  |  | Critério FR |
| 2191 | 3.1.3.28.1.5.2 | Projeto executivo de Raul Soares do Pleito RASESPJ02 - Elaboração de projetos de engenharia de sistemas de esgotamento sanitário para a sede municipal e distritos apresentado ao banco | milestone | 0d | 2020-01-22 | 2020-01-22 | 2190 |  |  | 2019-12-18 | 2019-12-18 | 0d | 2019-10-22 | 2019-10-22 | 238d | 0d |  | Verde | Verde | 0% | 0% | Compensatória | Verde | 0% | 0% |  |  |  | Município |  |  |  |
| 2192 | 3.1.3.28.1.5.3 | Analisar projeto |  | 60d | 2020-01-23 | 2020-04-22 | 2191 |  |  | 2019-12-19 | 2020-03-19 | 60d | 2019-10-23 | 2019-11-21 | 872d | 0d |  | Verde | Verde | 0% | 0% | Compensatória | Verde | 0% | 0% |  |  |  | Banco |  |  |  |
| 2193 | 3.1.3.28.1.5.4 | Projeto de Raul Soares do Pleito RASESPJ02 - Elaboração de projetos de engenharia de sistemas de esgotamento sanitário para a sede municipal e distritos concluído | milestone | 0d | 2020-04-22 | 2020-04-22 | 2195, 2188, 2192 |  |  | 2020-03-19 | 2020-03-19 | 0d | 2020-01-28 | 2020-01-28 | 872d | 0d |  | Verde | Verde | 0% | 0% | Compensatória | Verde | 0% | 0% |  |  |  | Município |  |  |  |
| 2194 | 3.1.3.28.1.5.5 | Recurso do projeto executivo de Raul Soares do Pleito RASESPJ02 - Elaboração de projetos de engenharia de sistemas de esgotamento sanitário para a sede municipal e distritos repassado | milestone | 0d | 2020-04-29 | 2020-04-29 | 2193FS+5d |  |  | 2020-03-26 | 2020-03-26 | 0d | 2020-02-04 | 2020-02-04 | 872d | 0d |  | Verde | Verde | 0% | 0% | Compensatória | Verde | 0% | 0% |  |  |  | Banco |  |  |  |
| 2195 | 3.1.3.28.1.6 | Realizar Licenciamento Ambiental |  | 95d | 2019-11-07 | 2020-03-30 | 2178 |  |  | 2019-10-08 | 2020-02-27 | 95d | 2019-09-26 | 2020-01-28 | 887d | 15d |  | Verde | Verde | 0% | 0% | Compensatória | Verde | 0% | 0% |  |  |  | Município |  |  |  |
| 2196 | 3.1.3.28.1.7 | Pleito RASESPJ02 - Elaboração de projetos de engenharia de sistemas de esgotamento sanitário para a sede municipal e distritos de Raul Soares concluído | milestone | 0d | 2020-04-29 | 2020-04-29 | 2194 |  |  | 2020-03-26 | 2020-03-26 | 0d | 2020-02-04 | 2020-02-04 | 872d |  |  | Verde | Verde | 0% | 0% | Compensatória | Verde | 0% | 0% |  |  |  | Município |  |  |  |

Notes:
- 2168: Raul Soares teve 4,4% dos pleitos de Esgotamento Sanitário aprovado (R$486.705,20), conforme Deliberação 75. / O município teve o pleito de resíduos sólidos negado (R$1.102.965,05), equivalente a 10% do total do recurso). / Aderiu à ata de registro de preço.
- 2170: Em 25/04/2019: pleito aprovado pela Renova no dia 20/03/2019 conforme planilha Gestão de Pleitos_V2
- 2172: 02/06/2019: autorização encaminhada pelo banco dia 27/03/2019 conforme planilha Controle Gerencial Renova
- 2173: 21/05/2019: confirmar andamento da tarefa na reunião com o município / 02/07/2019: Telefonema com Danielle - TR estava pronto, mas mudaram a modalidade de licitação e por isso será necessária a alteração da licitação. Com essa alteração a data de término provavelmente não será 29/07/2019 e sim 29/08/2019.

| ID | WBS | Task | Type | Duration | Start | Finish | Predecessors | Complete | Remaining | Baseline start | Baseline finish | Baseline duration | Baseline 1 start | Baseline 1 finish | Total slack | Free slack | Text1 | Text2 | Text3 | Text6 | Text8 | Text12 | Text14 | Text16 | Text9 | Text18 |
| --- | --- | --- | --- | --- | --- | --- | --- | --- | --- | --- | --- | --- | --- | --- | --- | --- | --- | --- | --- | --- | --- | --- | --- | --- | --- | --- |
| 2197 | 3.1.3.28.2 | **Pleito de Raul Soares a definir - Obra** |  | 672d | 2020-03-04 | 2022-11-14 |  |  |  | 2020-01-29 | 2022-10-11 | 672d | 2019-11-29 | 2022-07-27 | 238d |  | Verde | Verde | 0% | 0% | Compensatória | Verde | 0% | 0% |  |  |
| 2198 | 3.1.3.28.2.1 | Pleito de Raul Soares a definir - Obra aprovado | milestone | 0d | 2020-03-04 | 2020-03-04 | 2191FS+27d |  |  | 2020-01-29 | 2020-01-29 | 0d | 2019-11-29 | 2019-11-29 | 238d | 0d | Verde | Verde | 0% | 0% | Compensatória | Verde | 0% | 0% | CT/CIF |  |
| 2199 | 3.1.3.28.2.2 | **Licitação da Obra** |  | 77d | 2020-03-18 | 2020-07-09 |  |  |  | 2020-02-12 | 2020-06-08 | 77d | 2019-12-16 | 2020-04-09 | 238d |  | Verde | Verde | 0% | 0% | Compensatória | Verde | 0% | 0% |  |  |
| 2200 | 3.1.3.28.2.2.1 | Licitação da obra do Pleito de Raul Soares a definir - Obra autorizada pelo banco | milestone | 0d | 2020-03-18 | 2020-03-18 | 2198FS+10d |  |  | 2020-02-12 | 2020-02-12 | 0d | 2019-12-16 | 2019-12-16 | 238d | 0d | Verde | Verde | 0% | 0% | Compensatória | Verde | 0% | 0% | Banco |  |
| 2201 | 3.1.3.28.2.2.2 | Licitar Obra |  | 63d | 2020-03-19 | 2020-06-19 | 2200 |  |  | 2020-02-13 | 2020-05-19 | 63d | 2019-12-17 | 2020-03-20 | 238d | 0d | Verde | Verde | 0% | 0% | Compensatória | Verde | 0% | 0% | Município |  |
| 2202 | 3.1.3.28.2.2.3 | Analisar e emitir resultado da licitação da obra |  | 14d | 2020-06-22 | 2020-07-09 | 2201 |  |  | 2020-05-20 | 2020-06-08 | 14d | 2020-03-23 | 2020-04-09 | 238d | 0d | Verde | Verde | 0% | 0% | Compensatória | Verde | 0% | 0% | Banco |  |
| 2203 | 3.1.3.28.2.2.4 | Licitação da obra do Pleito de Raul Soares a definir - Obra concluída | milestone | 0d | 2020-07-09 | 2020-07-09 | 2202 |  |  | 2020-06-08 | 2020-06-08 | 0d | 2020-04-09 | 2020-04-09 | 238d | 0d | Verde | Verde | 0% | 0% | Compensatória | Verde | 0% | 0% | Município |  |
| 2204 | 3.1.3.28.2.3 | Executar obra |  | 442d | 2020-08-05 | 2022-05-16 | 2203FS+18d |  |  | 2020-07-06 | 2022-04-12 | 442d | 2020-04-13 | 2022-01-13 | 238d | 0d | Verde | Verde | 0% | 0% | Compensatória | Verde | 0% | 0% | Município |  |
| 2205 | 3.1.3.28.2.4 | Realizar processo de pré-operação |  | 120d | 2022-05-17 | 2022-11-07 | 2204 |  |  | 2022-04-13 | 2022-10-04 | 120d | 2022-01-14 | 2022-07-20 | 238d | 0d | Verde | Verde | 0% | 0% | Compensatória | Verde | 0% | 0% | Município |  |
| 2206 | 3.1.3.28.2.5 | Recurso da obra do Pleito de Raul Soares a definir - Obra repassado | milestone | 0d | 2022-11-14 | 2022-11-14 | 2205FS+5d |  |  | 2022-10-11 | 2022-10-11 | 0d | 2022-07-27 | 2022-07-27 | 238d | 0d | Verde | Verde | 0% | 0% | Compensatória | Verde | 0% | 0% | Banco |  |
| 2207 | 3.1.3.28.2.6 | Pleito de Raul Soares a definir - Obra concluído | milestone | 0d | 2022-11-14 | 2022-11-14 | 2206 |  |  | 2022-10-11 | 2022-10-11 | 0d | 2022-07-27 | 2022-07-27 | 238d |  | Verde | Verde | 0% | 0% | Compensatória | Verde | 0% | 0% | Município |  |
| 2208 | 3.1.3.28.3 | **Pleito RASRSPM01 - Elaboração do Plano Intermunicipal de Gestão Integrada de Resíduos Sólidos para os Municípios associados ao Consórcio Intermunicipal Multissetorial do Vale do Piranga (PIGIRS/CIMVALPI)** |  | 1082d | 2019-06-25 A | 2023-10-30 |  |  | 1082d | 2019-08-30 | 2023-10-30 | 1035d | 2019-08-30 | 2024-01-30 | 0d |  | Verde | Verde | 0% | 0% | Compensatória | Verde | 0% | 0% |  |  |
| 2209 | 3.1.3.28.3.1 | Pleito RASRSPM01 - Elaboração do Plano Intermunicipal de Gestão Integrada de Resíduos Sólidos para os Municípios associados ao Consórcio Intermunicipal Multissetorial do Vale do Piranga (PIGIRS/CIMVALPI) de Raul Soares aprovado pelo CIF | milestone | 0d | 2019-06-25 A | 2019-06-25 A | 3039FS+236d | 100% |  | 2019-08-30 | 2019-08-30 | 0d | 2019-08-30 | 2019-08-30 |  |  | Verde | Verde | 0% | 0% | Compensatória | Verde | 0% | 0% | CT/CIF |  |
| 2210 | 3.1.3.28.3.2 | Iniciar serviço/projeto/obra de Raul Soares de Resíduos Sólidos a definir |  | 1d | 2019-09-02 | 2019-09-02 | 2209FS+47d |  |  | 2019-09-02 | 2019-09-02 | 1d | 2019-09-02 | 2019-09-02 | 0d |  | Verde | Verde | 0% | 0% | Compensatória | Verde | 0% | 0% | Município | Critério FR |
| 2211 | 3.1.3.28.3.3 | Pleito RASRSPM01 - Elaboração do Plano Intermunicipal de Gestão Integrada de Resíduos Sólidos para os Municípios associados ao Consórcio Intermunicipal Multissetorial do Vale do Piranga (PIGIRS/CIMVALPI) concluído | milestone | 0d | 2023-10-30 | 2023-10-30 | 2210FS+1034d |  |  | 2023-10-30 | 2023-10-30 | 0d | 2024-01-30 | 2024-01-30 | 0d |  | Verde | Verde | 0% | 0% | Compensatória | Verde | 0% | 0% | Município |  |
| 2212 | 3.1.3.28.4 | Recursos de Raul Soares repassados | milestone | 0d | 2023-10-30 | 2023-10-30 | 2196, 2207, 2211 |  |  | 2023-10-30 | 2023-10-30 | 0d | 2024-01-30 | 2024-01-30 | 0d |  | Verde | Verde | 0% | 0% | Compensatória | Verde | 0% | 0% | Banco |  |
| 2213 | 3.1.3.29 | **Resplendor** |  | 833d | 2019-05-08 A | 2022-09-08 |  | 1% | 823.85d | 2019-05-08 | 2022-09-08 | 833d | 2019-05-08 | 2022-10-18 | 283d |  | Verde | Verde | 2% | 0% | Compensatória | Vermelho | 0% | 0% |  |  |
| 2214 | 3.1.3.29.1 | **Pleito de Resplendor a definir - Projeto dos distritos de Calixto, Nicolândia, Campo Alegre e Independência** |  | 283d | 2019-08-01 | 2020-09-21 |  |  |  | 2019-08-01 | 2020-09-21 | 283d | 2019-05-31 | 2020-07-02 | 283d |  | Verde | Verde | 0% | 0% | Compensatória | Verde | 0% | 0% |  |  |
| 2215 | 3.1.3.29.1.1 | Pleito de Resplendor a definir - Projeto dos distritos de Calixto, Nicolândia, Campo Alegre e Independência aprovado | milestone | 0d | 2019-08-01 | 2019-08-01 | 3052FS+158d |  |  | 2019-08-01 | 2019-08-01 | 0d | 2019-05-31 | 2019-05-31 | 283d | 0d | Verde | Verde | 0% | 0% | Compensatória | Verde | 0% | 0% | CT/CIF |  |
| 2216 | 3.1.3.29.1.2 | **Licitação do Projeto** |  | 83d | 2019-08-16 | 2019-12-13 |  |  |  | 2019-08-16 | 2019-12-13 | 83d | 2019-06-14 | 2019-09-10 | 283d |  | Verde | Verde | 0% | 0% | Compensatória | Verde | 0% | 0% |  |  |
| 2217 | 3.1.3.29.1.2.1 | Licitação do projeto do Pleito de Resplendor a definir - Projeto dos distritos de Calixto, Nicolândia, Campo Alegre e Independência autorizada pelo banco | milestone | 0d | 2019-08-16 | 2019-08-16 | 2215FS+10d |  |  | 2019-08-16 | 2019-08-16 | 0d | 2019-06-14 | 2019-06-14 | 283d | 0d | Verde | Verde | 0% | 0% | Compensatória | Verde | 0% | 0% | Banco |  |
| 2218 | 3.1.3.29.1.2.2 | Licitar projeto |  | 66d | 2019-08-19 | 2019-11-19 | 2217 |  |  | 2019-08-19 | 2019-11-19 | 66d | 2019-06-17 | 2019-08-16 | 283d | 0d | Verde | Verde | 0% | 0% | Compensatória | Verde | 0% | 0% | Município | Critério FR |
| 2219 | 3.1.3.29.1.2.3 | Documentação de licitação do Pleito de Resplendor a definir - Projeto dos distritos de Calixto, Nicolândia, Campo Alegre e Independência apresentada ao banco | milestone | 0d | 2019-11-26 | 2019-11-26 | 2218FS+5d |  |  | 2019-11-26 | 2019-11-26 | 0d | 2019-08-23 | 2019-08-23 | 283d | 0d | Verde | Verde | 0% | 0% | Compensatória | Verde | 0% | 0% | Município |  |
| 2220 | 3.1.3.29.1.2.4 | Analisar e emitir resultado da licitação do projeto |  | 12d | 2019-11-27 | 2019-12-13 | 2219 |  |  | 2019-11-27 | 2019-12-13 | 12d | 2019-08-26 | 2019-09-10 | 283d | 0d | Verde | Verde | 0% | 0% | Compensatória | Verde | 0% | 0% | Banco | Critério FR |
| 2221 | 3.1.3.29.1.2.5 | Licitação do projeto do Pleito de Resplendor a definir - Projeto dos distritos de Calixto, Nicolândia, Campo Alegre e Independência concluída | milestone | 0d | 2019-12-13 | 2019-12-13 | 2220 |  |  | 2019-12-13 | 2019-12-13 | 0d | 2019-09-10 | 2019-09-10 | 283d | 0d | Verde | Verde | 0% | 0% | Compensatória | Verde | 0% | 0% | Município |  |

Notes:
- 2198: Em 25/04/2019: considerado que após a apresentação do projeto no banco o município enviará ofício e o pleito será aprovado pela CT/CIF na reunião de novembro.
- 2204: Em 24/05/2019: valor da obra R$ 9,4 milhões (valor teto menos valor do projeto)
- 2212: Valor de recurso destinado ao munícipio: R$11.029.650,50
- 2213: Resplendor teve 100% dos pleitos de Esgotamento Sanitário aprovado (R$8.508.587,53), conforme Deliberação 75. / O município teve 5,6%, dos 10% do valor teto destinado a Resíduos Sólidos aprovado (R$529.000,00). / Munícipio vai solicitar mudança de pleito para projetos nos distriitos de Calixto, Nicolândia, Campo Alegre e Independência (ainda não tem o valor do pleito). Posteriormente a aprovação das alternativas de concepção a serem implantadas, deverá ser solicitado recursos para desapropriação e priorização da execução das obras, considerando o saldo de recursos disponíveis.
- 2215: Em 25/04/2019: município pediu a substituição do pleito de obra da sede por meio do ofício 508/2018 e utilização dos recursos para projeto e obra dos distritos de Calixto, Nicolândia, Campo Alegre e Independência. Visto que o pleito não foi julgado no pleito de abril 2019, foi considerado que o pleito será cancelado no próximo CIF de maio (31/05/2019).
- 2218: Munícipio vai mudar o pleito e solicitar projetos. / Município irá definir os novos pleitos em distritos não atendidos pela Copasa, (já possui conceção para a sede). O pleito de RS tbm irá mudar para obras de melhoria no aterro e não projeto de ampliação.

| ID | WBS | Task | Type | Duration | Start | Finish | Predecessors | Baseline start | Baseline finish | Baseline duration | Baseline 1 start | Baseline 1 finish | Total slack | Free slack | Text1 | Text2 | Text3 | Text6 | Text8 | Text12 | Text14 | Text16 | Text9 |
| --- | --- | --- | --- | --- | --- | --- | --- | --- | --- | --- | --- | --- | --- | --- | --- | --- | --- | --- | --- | --- | --- | --- | --- |
| 2222 | 3.1.3.29.1.3 | **Elaboração do Estudo de Concepção** |  | 105d | 2019-12-16 | 2020-05-21 |  | 2019-12-16 | 2020-05-21 | 105d |  |  | 283d |  | Verde | Verde | 0% | 0% | Compensatória | Verde | 0% | 0% |  |
| 2223 | 3.1.3.29.1.3.1 | Elaborar estudo |  | 40d | 2019-12-16 | 2020-02-12 | 2221 | 2019-12-16 | 2020-02-12 | 40d |  |  | 283d | 0d | Verde | Verde | 0% | 0% | Compensatória | Verde | 0% | 0% |  |
| 2224 | 3.1.3.29.1.3.2 | Estudo de concepção do Pleito de Resplendor a definir - Projeto dos distritos de Calixto, Nicolândia, Campo Alegre e Independência apresentado ao banco | milestone | 0d | 2020-02-12 | 2020-02-12 | 2223 | 2020-02-12 | 2020-02-12 | 0d |  |  | 288d | 0d | Verde | Verde | 0% | 0% | Compensatória | Verde | 0% | 0% |  |
| 2225 | 3.1.3.29.1.3.3 | Analisar estudo |  | 60d | 2020-02-13 | 2020-05-14 | 2224 | 2020-02-13 | 2020-05-14 | 60d |  |  | 288d | 0d | Verde | Verde | 0% | 0% | Compensatória | Verde | 0% | 0% |  |
| 2226 | 3.1.3.29.1.3.4 | Estudo de concepção do Pleito de Resplendor a definir - Projeto dos distritos de Calixto, Nicolândia, Campo Alegre e Independência concluído | milestone | 0d | 2020-05-14 | 2020-05-14 | 2225 | 2020-05-14 | 2020-05-14 | 0d |  |  | 358d | 0d | Verde | Verde | 0% | 0% | Compensatória | Verde | 0% | 0% |  |
| 2227 | 3.1.3.29.1.3.5 | Recurso do estudo do Pleito de Resplendor a definir - Projeto dos distritos de Calixto, Nicolândia, Campo Alegre e Independência repassado | milestone | 0d | 2020-05-21 | 2020-05-21 | 2226FS+5d | 2020-05-21 | 2020-05-21 | 0d |  |  | 358d | 39d | Verde | Verde | 0% | 0% | Compensatória | Verde | 0% | 0% |  |
| 2228 | 3.1.3.29.1.4 | **Elaboração do Projeto Básico** |  | 109d | 2020-02-13 | 2020-07-23 |  | 2020-02-13 | 2020-07-23 | 109d | 2019-09-11 | 2020-02-21 | 283d |  | Verde | Verde | 0% | 0% | Compensatória | Verde | 0% | 0% |  |
| 2229 | 3.1.3.29.1.4.1 | Elaborar Projeto Básico |  | 40d | 2020-02-13 | 2020-04-14 | 2223 | 2020-02-13 | 2020-04-14 | 40d | 2019-09-11 | 2019-11-11 | 283d | 0d | Verde | Verde | 0% | 0% | Compensatória | Verde | 0% | 0% | Município |
| 2230 | 3.1.3.29.1.4.2 | Projeto básico do Pleito de Resplendor a definir - Projeto dos distritos de Calixto, Nicolândia, Campo Alegre e Independência apresentado ao banco | milestone | 0d | 2020-04-14 | 2020-04-14 | 2229 | 2020-04-14 | 2020-04-14 | 0d | 2019-11-11 | 2019-11-11 | 319d | 0d | Verde | Verde | 0% | 0% | Compensatória | Verde | 0% | 0% | Município |
| 2231 | 3.1.3.29.1.4.3 | Analisar projeto básico |  | 64d | 2020-04-15 | 2020-07-16 | 2230 | 2020-04-15 | 2020-07-16 | 64d | 2019-11-12 | 2019-12-13 | 319d | 0d | Verde | Verde | 0% | 0% | Compensatória | Verde | 0% | 0% | Banco |
| 2232 | 3.1.3.29.1.4.4 | Projeto básico do Pleito de Resplendor a definir - Projeto dos distritos de Calixto, Nicolândia, Campo Alegre e Independência concluído | milestone | 0d | 2020-07-16 | 2020-07-16 | 2227, 2231 | 2020-07-16 | 2020-07-16 | 0d | 2020-02-14 | 2020-02-14 | 319d | 0d | Verde | Verde | 0% | 0% | Compensatória | Verde | 0% | 0% | Município |
| 2233 | 3.1.3.29.1.4.5 | Recurso do projeto básico do Pleito de Resplendor a definir - Projeto dos distritos de Calixto, Nicolândia, Campo Alegre e Independência repassado | milestone | 0d | 2020-07-23 | 2020-07-23 | 2232FS+5d | 2020-07-23 | 2020-07-23 | 0d | 2020-02-21 | 2020-02-21 | 319d | 36d | Verde | Verde | 0% | 0% | Compensatória | Verde | 0% | 0% | Banco |
| 2234 | 3.1.3.29.1.5 | Adquirir imóvel |  | 120d | 2020-03-17 | 2020-09-04 | 2225FS-40d | 2020-03-17 | 2020-09-04 | 120d | 2019-12-16 | 2020-06-25 | 288d | 5d | Verde | Verde | 0% | 0% | Compensatória | Verde | 0% | 0% | Município |
| 2235 | 3.1.3.29.1.6 | Realizar Licenciamento Ambiental |  | 120d | 2020-03-17 | 2020-09-04 | 2225FS-40d | 2020-03-17 | 2020-09-04 | 120d | 2019-11-12 | 2020-05-26 | 288d | 5d | Verde | Verde | 0% | 0% | Compensatória | Verde | 0% | 0% | Município |
| 2236 | 3.1.3.29.1.7 | **Elaboração do Projeto Executivo** |  | 110d | 2020-04-15 | 2020-09-21 |  | 2020-04-15 | 2020-09-21 | 110d | 2019-11-12 | 2020-07-02 | 283d |  | Verde | Verde | 0% | 0% | Compensatória | Verde | 0% | 0% |  |
| 2237 | 3.1.3.29.1.7.1 | Elaborar Projeto Executivo |  | 40d | 2020-04-15 | 2020-06-12 | 2229 | 2020-04-15 | 2020-06-12 | 40d | 2019-11-12 | 2020-02-17 | 283d | 0d | Verde | Verde | 0% | 0% | Compensatória | Verde | 0% | 0% | Município |
| 2238 | 3.1.3.29.1.7.2 | Projeto executivo do Pleito de Resplendor a definir - Projeto dos distritos de Calixto, Nicolândia, Campo Alegre e Independência apresentado ao banco | milestone | 0d | 2020-06-12 | 2020-06-12 | 2237 | 2020-06-12 | 2020-06-12 | 0d | 2020-02-17 | 2020-02-17 | 283d | 0d | Verde | Verde | 0% | 0% | Compensatória | Verde | 0% | 0% | Município |
| 2239 | 3.1.3.29.1.7.3 | Analisar projeto executivo |  | 65d | 2020-06-15 | 2020-09-14 | 2238 | 2020-06-15 | 2020-09-14 | 65d | 2020-02-18 | 2020-03-23 | 283d | 0d | Verde | Verde | 0% | 0% | Compensatória | Verde | 0% | 0% | Banco |
| 2240 | 3.1.3.29.1.7.4 | Projeto executivo do Pleito de Resplendor a definir - Projeto dos distritos de Calixto, Nicolândia, Campo Alegre e Independência concluído | milestone | 0d | 2020-09-14 | 2020-09-14 | 2233, 2235, 2234, 2239 | 2020-09-14 | 2020-09-14 | 0d | 2020-06-25 | 2020-06-25 | 283d | 0d | Verde | Verde | 0% | 0% | Compensatória | Verde | 0% | 0% | Município |
| 2241 | 3.1.3.29.1.7.5 | Recurso do projeto executivo do Pleito de Resplendor a definir - Projeto dos distritos de Calixto, Nicolândia, Campo Alegre e Independência repassado | milestone | 0d | 2020-09-21 | 2020-09-21 | 2240FS+5d | 2020-09-21 | 2020-09-21 | 0d | 2020-07-02 | 2020-07-02 | 772d | 0d | Verde | Verde | 0% | 0% | Compensatória | Verde | 0% | 0% | Banco |
| 2242 | 3.1.3.29.1.8 | Pleito de Resplendor a definir - Projeto dos distritos de Calixto, Nicolândia, Campo Alegre e Independência concluído | milestone | 0d | 2020-09-21 | 2020-09-21 | 2241 | 2020-09-21 | 2020-09-21 | 0d | 2020-07-02 | 2020-07-02 | 772d | 489d | Verde | Verde | 0% | 0% | Compensatória | Verde | 0% | 0% | Município |
| 2243 | 3.1.3.29.2 | **Pleito de Resplendor a definir - Obra dos distritos de Calixto, Nicolândia, Campo Alegre e Independência** |  | 730d | 2019-10-01 | 2022-09-08 |  | 2019-10-01 | 2022-09-08 | 730d | 2019-05-31 | 2022-10-18 | 283d |  | Verde | Verde | 0% | 0% | Compensatória | Verde | 0% | 0% |  |
| 2244 | 3.1.3.29.2.1 | Pleito de Resplendor a definir - Obra dos distritos de Calixto, Nicolândia, Campo Alegre e Independência aprovado | milestone | 0d | 2019-10-01 | 2019-10-01 | 3052FS+200d | 2019-10-01 | 2019-10-01 | 0d | 2019-05-31 | 2019-05-31 | 509d | 226d | Verde | Verde | 0% | 0% | Compensatória | Verde | 0% | 0% | CT/CIF |
| 2245 | 3.1.3.29.2.2 | **Licitação da Obra** |  | 58d | 2020-09-14 | 2020-12-07 |  | 2020-09-14 | 2020-12-07 | 58d | 2020-06-25 | 2020-09-16 | 283d |  | Verde | Verde | 0% | 0% | Compensatória | Verde | 0% | 0% |  |
| 2246 | 3.1.3.29.2.2.1 | Licitação da obra do Pleito de Resplendor a definir - Obra dos distritos de Calixto, Nicolândia, Campo Alegre e Independência autorizada pelo banco | milestone | 0d | 2020-09-14 | 2020-09-14 | 2240, 2244FS+10d | 2020-09-14 | 2020-09-14 | 0d | 2020-06-25 | 2020-06-25 | 283d | 0d | Verde | Verde | 0% | 0% | Compensatória | Verde | 0% | 0% | Banco |
| 2247 | 3.1.3.29.2.2.2 | Licitar Obra |  | 43d | 2020-09-15 | 2020-11-16 | 2246 | 2020-09-15 | 2020-11-16 | 43d | 2020-06-26 | 2020-08-25 | 283d | 0d | Verde | Verde | 0% | 0% | Compensatória | Verde | 0% | 0% | Município |
| 2248 | 3.1.3.29.2.2.3 | Analisar e emitir resultado da licitação da obra |  | 15d | 2020-11-17 | 2020-12-07 | 2247 | 2020-11-17 | 2020-12-07 | 15d | 2020-08-26 | 2020-09-16 | 283d | 0d | Verde | Verde | 0% | 0% | Compensatória | Verde | 0% | 0% | Banco |
| 2249 | 3.1.3.29.2.2.4 | Licitação da obra do Pleito de Resplendor a definir - Obra dos distritos de Calixto, Nicolândia, Campo Alegre e Independência concluída | milestone | 0d | 2020-12-07 | 2020-12-07 | 2248 | 2020-12-07 | 2020-12-07 | 0d | 2020-09-16 | 2020-09-16 | 283d | 0d | Verde | Verde | 0% | 0% | Compensatória | Verde | 0% | 0% | Município |
| 2250 | 3.1.3.29.2.3 | Executar obra |  | 291d | 2021-01-08 | 2022-03-10 | 2249FS+20d | 2021-01-08 | 2022-03-10 | 291d | 2020-09-17 | 2022-04-06 | 283d | 0d | Verde | Verde | 0% | 0% | Compensatória | Verde | 0% | 0% | Município |
| 2251 | 3.1.3.29.2.4 | Realizar processo de pré-operação |  | 120d | 2022-03-11 | 2022-08-31 | 2250 | 2022-03-11 | 2022-08-31 | 120d | 2022-04-07 | 2022-10-10 | 283d | 0d | Verde | Verde | 0% | 0% | Compensatória | Verde | 0% | 0% | Município |
| 2252 | 3.1.3.29.2.5 | Recurso da obra do Pleito de Resplendor a definir - Obra dos distritos de Calixto, Nicolândia, Campo Alegre e Independência repassado | milestone | 0d | 2022-09-08 | 2022-09-08 | 2251FS+5d | 2022-09-08 | 2022-09-08 | 0d | 2022-10-18 | 2022-10-18 | 283d | 0d | Verde | Verde | 0% | 0% | Compensatória | Verde | 0% | 0% | Banco |
| 2253 | 3.1.3.29.2.6 | Pleito de Resplendor a definir - Obra dos distritos de Calixto, Nicolândia, Campo Alegre e Independência concluído | milestone | 0d | 2022-09-08 | 2022-09-08 | 2252 | 2022-09-08 | 2022-09-08 | 0d | 2022-10-18 | 2022-10-18 | 283d | 0d | Verde | Verde | 0% | 0% | Compensatória | Verde | 0% | 0% | Município |

Notes:
- 2229: 23/05/2019: município pactuou com a Renova 2 meses para elaboração do projeto básico
- 2237: 24/05/2019: município pactuou com a Renova 3 meses para elaborar projeto executivo
- 2244: Em 25/04/2019: município pediu a substituição do pleito de obra da sede por meio do ofício 508/2018 e utilização dos recursos para projeto e obra dos distritos de Calixto, Nicolândia, Campo Alegre e Independência. Visto que o pleito não foi julgado no pleito de abril 2019, foi considerado que o pleito será cancelado no próximo CIF de maio (31/05/2019).
- 2250: Em 25/04/2019: valor da obra R$ 8 milhões

| ID | WBS | Task | Type | Duration | Start | Finish | Predecessors | Complete | Remaining | Baseline start | Baseline finish | Baseline duration | Baseline 1 start | Baseline 1 finish | Total slack | Free slack | Text1 | Text2 | Text3 | Text6 | Text8 | Text12 | Text14 | Text16 | Text9 | Text18 | Text4 | Text5 | Text15 |
| --- | --- | --- | --- | --- | --- | --- | --- | --- | --- | --- | --- | --- | --- | --- | --- | --- | --- | --- | --- | --- | --- | --- | --- | --- | --- | --- | --- | --- | --- |
| 2254 | 3.1.3.29.3 | **Pleito RESESOB01 - Construção do sistema de esgotamento sanitário da sede do município** |  | 1d | 2019-08-01 | 2019-08-01 |  |  |  | 2019-08-01 | 2019-08-01 | 1d | 2019-05-31 | 2019-05-31 | 1055d |  | Verde | Verde | 0% | 0% | Compensatória | Verde | 0% | 0% |  |  |  |  |  |
| 2255 | 3.1.3.29.3.1 | Avaliar cancelamento do pleito RESESOB01 |  | 1d | 2019-08-01 | 2019-08-01 | 3052FS+157d |  |  | 2019-08-01 | 2019-08-01 | 1d | 2019-05-31 | 2019-05-31 | 1055d | 0d | Verde | Verde | 0% | 0% | Compensatória | Verde | 0% | 0% | Município | Critério FR |  |  |  |
| 2256 | 3.1.3.29.3.2 | Pleito RESESOB01 - Construção do sistema de esgotamento sanitário da sede do município de Resplendor concluído | milestone | 0d | 2019-08-01 | 2019-08-01 | 2255 |  |  | 2019-08-01 | 2019-08-01 | 0d | 2019-05-31 | 2019-05-31 | 1055d | 772d | Verde | Verde | 0% | 0% | Compensatória | Verde | 0% | 0% | Município |  |  |  |  |
| 2257 | 3.1.3.29.4 | **Pleito RESRSPM01 - Elaboração de estudos ambientais para a formalização do processo de regularização ambiental junto ao órgão ambiental competente** |  | 117d | 2021-03-15 | 2021-08-27 |  |  |  | 2021-03-15 | 2021-08-27 | 117d | 2019-06-11 | 2019-11-25 | 539d |  | Verde | Verde | 0% | 0% | Compensatória | Verde | 0% | 0% |  |  |  |  |  |
| 2258 | 3.1.3.29.4.1 | Avaliar a necessidade do pleito RESRSPM01 |  | 1d | 2021-03-15 | 2021-03-15 | 2282 |  |  | 2021-03-15 | 2021-03-15 | 1d |  |  | 539d | 0d | Verde | Verde | 0% | 0% | Compensatória | Verde | 0% | 0% |  |  |  |  |  |
| 2259 | 3.1.3.29.4.2 | **Licitação de Empresa para Licenciamento Ambiental** |  | 63d | 2021-03-15 | 2021-06-15 |  |  |  | 2021-03-15 | 2021-06-15 | 63d | 2019-06-11 | 2019-09-10 | 539d |  | Verde | Verde | 0% | 0% | Compensatória | Verde | 0% | 0% |  |  |  |  |  |
| 2260 | 3.1.3.29.4.2.1 | Licitação da empresa para Licenciamento Ambiental de Resplendor do Pleito RESRSPM01 - Elaboração de estudos ambientais para a formalização do processo de regularização ambiental junto ao órgão ambiental competente autorizada pelo banco | milestone | 0d | 2021-03-15 | 2021-03-15 | 2258 |  |  | 2021-03-15 | 2021-03-15 | 0d | 2019-06-11 | 2019-06-11 | 539d | 0d | Verde | Verde | 0% | 0% | Compensatória | Verde | 0% | 0% | Banco |  |  |  |  |
| 2261 | 3.1.3.29.4.2.2 | Licitar empresa para Licenciamento Ambiental |  | 44d | 2021-03-16 | 2021-05-18 | 2260 |  |  | 2021-03-16 | 2021-05-18 | 44d | 2019-06-12 | 2019-08-13 | 539d | 0d | Verde | Verde | 0% | 0% | Compensatória | Verde | 0% | 0% | Município |  |  |  |  |
| 2262 | 3.1.3.29.4.2.3 | Documentação de licitação de Resplendor do Pleito RESRSPM01 - Elaboração de estudos ambientais para a formalização do processo de regularização ambiental junto ao órgão ambiental competente apresentada ao banco | milestone | 0d | 2021-05-25 | 2021-05-25 | 2261FS+5d |  |  | 2021-05-25 | 2021-05-25 | 0d | 2019-08-21 | 2019-08-21 | 539d | 0d | Verde | Verde | 0% | 0% | Compensatória | Verde | 0% | 0% | Município |  |  |  |  |
| 2263 | 3.1.3.29.4.2.4 | Analisar e emitir resultado da licitação do empresa para Licenciamento Ambiental |  | 14d | 2021-05-26 | 2021-06-15 | 2262 |  |  | 2021-05-26 | 2021-06-15 | 14d | 2019-08-22 | 2019-09-10 | 539d | 0d | Verde | Verde | 0% | 0% | Compensatória | Verde | 0% | 0% | Banco |  |  |  |  |
| 2264 | 3.1.3.29.4.2.5 | Licitação da empresa para Licenciamento Ambiental de Resplendor do Pleito RESRSPM01 - Elaboração de estudos ambientais para a formalização do processo de regularização ambiental junto ao órgão ambiental competente comcluída | milestone | 0d | 2021-06-15 | 2021-06-15 | 2263 |  |  | 2021-06-15 | 2021-06-15 | 0d | 2019-09-10 | 2019-09-10 | 539d | 0d | Verde | Verde | 0% | 0% | Compensatória | Verde | 0% | 0% | Município |  |  |  |  |
| 2265 | 3.1.3.29.4.3 | Executar o Licenciamento Ambiental |  | 48d | 2021-06-16 | 2021-08-20 | 2264 |  |  | 2021-06-16 | 2021-08-20 | 48d | 2019-09-11 | 2019-11-18 | 539d | 0d | Verde | Verde | 0% | 0% | Compensatória | Verde | 0% | 0% | Município |  |  |  |  |
| 2266 | 3.1.3.29.4.4 | Recurso do serviço de Resplendor do Pleito RESRSPM01 - Elaboração de estudos ambientais para a formalização do processo de regularização ambiental junto ao órgão ambiental competente repassado | milestone | 0d | 2021-08-27 | 2021-08-27 | 2265FS+5d |  |  | 2021-08-27 | 2021-08-27 | 0d | 2019-11-25 | 2019-11-25 | 539d | 0d | Verde | Verde | 0% | 0% | Compensatória | Verde | 0% | 0% | Banco |  |  |  |  |
| 2267 | 3.1.3.29.4.5 | Pleito RESRSPM01 - Elaboração de estudos ambientais para a formalização do processo de regularização ambiental junto ao órgão ambiental competente de Resplendor concluído | milestone | 0d | 2021-08-27 | 2021-08-27 | 2266 |  |  | 2021-08-27 | 2021-08-27 | 0d | 2019-11-25 | 2019-11-25 | 539d | 256d | Verde | Verde | 0% | 0% | Compensatória | Verde | 0% | 0% | Município |  |  |  |  |
| 2268 | 3.1.3.29.5 | **Pleito RESRSOB02 - Obras emergenciais no aterro do CIGIRS** |  | 460d | 2019-05-08 A | 2021-03-12 |  | 4% | 440.97d | 2019-05-08 | 2021-03-12 | 460d | 2019-05-08 | 2021-04-30 | 539d |  | Verde | Verde | 3% | 0% | Compensatória | Vermelho | 0% | 0% |  |  |  |  |  |
| 2269 | 3.1.3.29.5.1 | **Aprovação do Projeto Executivo** |  | 68d | 2019-07-08 | 2019-10-11 |  |  |  | 2019-07-08 | 2019-10-11 | 68d | 2019-05-08 | 2019-11-18 | 539d |  | Verde | Verde | 0% | 0% | Compensatória | Verde | 0% | 0% |  |  |  |  |  |
| 2270 | 3.1.3.29.5.1.1 | Projeto de Resplendor do Pleito RESRSOB02 - Obras emergenciais no aterro do CIGIRS apresentado ao banco | milestone | 0d | 2019-07-08 | 2019-07-08 | 3052FS+140d |  |  | 2019-07-08 | 2019-07-08 | 0d | 2019-05-08 | 2019-05-08 | 539d | 0d | Verde | Verde | 0% | 0% | Compensatória | Verde | 0% | 0% | Município |  |  |  |  |
| 2271 | 3.1.3.29.5.1.2 | Analisar projeto |  | 68d | 2019-07-09 | 2019-10-11 | 2270 |  |  | 2019-07-09 | 2019-10-11 | 68d | 2019-05-09 | 2019-06-11 | 539d | 0d | Verde | Verde | 0% | 0% | Compensatória | Verde | 0% | 0% | Banco | Critério FR |  |  |  |
| 2272 | 3.1.3.29.5.1.3 | Projeto de Resplendor do Pleito RESRSOB02 - Obras emergenciais no aterro do CIGIRS aprovado | milestone | 0d | 2019-10-11 | 2019-10-11 | 2273, 2271 |  |  | 2019-10-11 | 2019-10-11 | 0d | 2019-11-18 | 2019-11-18 | 539d | 0d | Verde | Verde | 0% | 0% | Compensatória | Verde | 0% | 0% | Município |  |  |  |  |
| 2273 | 3.1.3.29.5.2 | Realizar Licenciamento Ambiental |  | 43d | 2019-05-08 A | 2019-07-08 | 3052FS+97d | 42% | 25d | 2019-05-08 | 2019-07-08 | 43d |  |  | 607d | 68d | Verde | Verde | 41% | 0% | Compensatória | Vermelho | 41% | 0% |  | Conforme agendado | 42 | 41 | 41 |
| 2274 | 3.1.3.29.5.3 | **Licitação da obra** |  | 77d | 2019-10-11 | 2020-02-04 |  |  |  | 2019-10-11 | 2020-02-04 | 77d | 2019-11-18 | 2020-03-13 | 539d |  | Verde | Verde | 0% | 0% | Compensatória | Verde | 0% | 0% |  |  |  |  |  |
| 2275 | 3.1.3.29.5.3.1 | Licitação da obra de Resplendor do Pleito RESRSOB02 - Obras emergenciais no aterro do CIGIRS autorizada pelo banco | milestone | 0d | 2019-10-11 | 2019-10-11 | 2272 |  |  | 2019-10-11 | 2019-10-11 | 0d | 2019-11-18 | 2019-11-18 | 539d | 0d | Verde | Verde | 0% | 0% | Compensatória | Verde | 0% | 0% | Banco |  |  |  |  |
| 2276 | 3.1.3.29.5.3.2 | Licitar obra |  | 63d | 2019-10-14 | 2020-01-15 | 2275 |  |  | 2019-10-14 | 2020-01-15 | 63d | 2019-11-19 | 2020-02-19 | 539d | 0d | Verde | Verde | 0% | 0% | Compensatória | Verde | 0% | 0% | Município |  |  |  |  |
| 2277 | 3.1.3.29.5.3.3 | Analisar e emitir resultado da licitação da obra |  | 14d | 2020-01-16 | 2020-02-04 | 2276 |  |  | 2020-01-16 | 2020-02-04 | 14d | 2020-02-20 | 2020-03-13 | 539d | 0d | Verde | Verde | 0% | 0% | Compensatória | Verde | 0% | 0% | Banco |  |  |  |  |
| 2278 | 3.1.3.29.5.3.4 | Licitação da obra de Resplendor do Pleito RESRSOB02 - Obras emergenciais no aterro do CIGIRS concluída | milestone | 0d | 2020-02-04 | 2020-02-04 | 2277 |  |  | 2020-02-04 | 2020-02-04 | 0d | 2020-03-13 | 2020-03-13 | 539d | 0d | Verde | Verde | 0% | 0% | Compensatória | Verde | 0% | 0% | Município |  |  |  |  |
| 2279 | 3.1.3.29.5.4 | Executar obra |  | 127d | 2020-03-09 | 2020-09-08 | 2278FS+20d |  |  | 2020-03-09 | 2020-09-08 | 127d | 2020-04-14 | 2020-10-14 | 539d | 0d | Verde | Verde | 0% | 0% | Compensatória | Verde | 0% | 0% | Município |  |  |  |  |
| 2280 | 3.1.3.29.5.5 | Realizar processo de pré-operação |  | 120d | 2020-09-09 | 2021-03-05 | 2279 |  |  | 2020-09-09 | 2021-03-05 | 120d | 2020-10-15 | 2021-04-23 | 539d | 0d | Verde | Verde | 0% | 0% | Compensatória | Verde | 0% | 0% | Município |  |  |  |  |
| 2281 | 3.1.3.29.5.6 | Recurso da obra de Resplendor do Pleito RESRSOB02 - Obras emergenciais no aterro do CIGIRS repassado | milestone | 0d | 2021-03-12 | 2021-03-12 | 2280FS+5d |  |  | 2021-03-12 | 2021-03-12 | 0d | 2021-04-30 | 2021-04-30 | 539d | 0d | Verde | Verde | 0% | 0% | Compensatória | Verde | 0% | 0% | Banco |  |  |  |  |
| 2282 | 3.1.3.29.5.7 | Pleito RESRSOB02 - Obras emergenciais no aterro do CIGIRS de Resplendor concluído | milestone | 0d | 2021-03-12 | 2021-03-12 | 2281 |  |  | 2021-03-12 | 2021-03-12 | 0d | 2021-04-30 | 2021-04-30 | 539d | 0d | Verde | Verde | 0% | 0% | Compensatória | Verde | 0% | 0% | Município |  |  |  |  |
| 2283 | 3.1.3.29.6 | Recursos de Resplendor repassados | milestone | 0d | 2022-09-08 | 2022-09-08 | 2256, 2282, 2267, 2253, 2242 |  |  | 2022-09-08 | 2022-09-08 | 0d | 2022-10-18 | 2022-10-18 | 283d |  | Verde | Verde | 0% | 0% | Compensatória | Verde | 0% | 0% | Banco |  |  |  |  |

Notes:
- 2255: Em 25/04/2019: município pediu a substituição do pleito de obra da sede por meio do ofício 508/2018 e utilização dos recursos para projeto e obra dos distritos de Calixto, Nicolândia, Campo Alegre e Independência. Visto que o pleito não foi julgado na reunião de abril 2019, foi considerado que o pleito será cancelado no próximo CIF de maio (31/05/2019).
- 2260: Em 24/04/2019: foi solicitado ao banco a autorização para licitação da empresa de licenciamento após a primeira análise do projeto a fim de agilizar o processo de licenciamento.
- 2270: Em 24/04/2019: banco encaminhará lista de documentos necessários ao município e município em 15 dias encaminhará tudo conforme conversar com Gislaine e Fernanda. / 21/05/2019: E-mail enviado ao município solicitando projeto para análise, para autorização de licitação de obra. Foi enviado cartilha de projeto e anexos. (planilha Controle Gerencial Renova - aba pleitos - coluna observação - data 24/04/2019). Conferir na reunião com o município o prazo para entrega / 31/05/2019: conforme cronograma do consórcio CIGIRS o município entregará o projeto até o dia 08/07/2019.
- 2273: 31/05/2019: Licenciamento em andamento - município entregou documentos para consultora e protocolam na SUPRAM até 15/06
- 2279: Em 24/04/2019: valor da obra R$ 0,9 milhões
- 2283: Valor de recurso destinado ao munícipio: R$9.453.986,14

| ID | WBS | Task | Type | Duration | Start | Finish | Predecessors | Complete | Remaining | Baseline start | Baseline finish | Baseline duration | Baseline 1 start | Baseline 1 finish | Total slack | Free slack | Text1 | Text2 | Text3 | Text4 | Text5 | Text6 | Text7 | Text8 | Text12 | Text14 | Text16 | Text9 | Text15 | Text17 | Text18 |
| --- | --- | --- | --- | --- | --- | --- | --- | --- | --- | --- | --- | --- | --- | --- | --- | --- | --- | --- | --- | --- | --- | --- | --- | --- | --- | --- | --- | --- | --- | --- | --- |
| 2284 | 3.1.3.30 | **Rio Casca** |  | 1342d | 2018-06-15 A | 2023-10-30 |  | 15% | 1144.08d | 2018-06-15 | 2023-10-30 | 1342d | 2018-06-15 | 2024-01-30 | 0d |  | Verde | Verde | 18% | 11 | 18 | 67% | 67 | Compensatória | Vermelho | 3% | 2% |  |  |  |  |
| 2285 | 3.1.3.30.1 | **Pleito RICESPJ02 - Elaboração de projeto básico e executivo para SES completo na Sede do Município de Rio Casca/MG (SEGUNDA ETAPA)** |  | 218d | 2019-05-28 A | 2020-04-13 |  | 3% | 210.46d | 2019-05-28 | 2020-04-13 | 218d | 2019-05-31 | 2020-03-10 | 883d |  | Verde | Verde | 1% |  |  | 0% |  | Compensatória | Vermelho | 0% | 0% |  |  |  |  |
| 2286 | 3.1.3.30.1.1 | Pleito de Rio Casca RICESPJ02 - Elaboração de projeto básico e executivo para SES completo na Sede do Município de Rio Casca/MG (SEGUNDA ETAPA) a definir aprovado | milestone | 0d | 2019-05-28 A | 2019-05-28 A | 3052FS+112d | 100% |  | 2019-05-28 | 2019-05-28 | 0d | 2019-05-31 | 2019-05-31 |  |  | Verde | Verde | 100% | 100 | 100 | 100% | 100 | Compensatória | Verde | 100% | 100% | CT/CIF | 100 | 100 |  |
| 2287 | 3.1.3.30.1.2 | **Licitação do Projeto** |  | 67d | 2019-06-05 A | 2019-09-10 |  | 19% | 54.29d | 2019-06-11 | 2019-09-10 | 63d | 2019-06-14 | 2019-09-18 | 429d |  | Verde | Verde | 0% |  |  | 0% |  | Compensatória | Verde | 0% | 0% |  |  |  |  |
| 2288 | 3.1.3.30.1.2.1 | Licitação do projeto básico e executivo para SES completo na Sede do Município de Rio Casca/MG (SEGUNDA ETAPA) autorizada pelo banco | milestone | 0d | 2019-06-05 A | 2019-06-05 A | 2286FS+6d | 100% |  | 2019-06-11 | 2019-06-11 | 0d | 2019-06-14 | 2019-06-14 |  |  | Verde | Verde | 0% |  |  | 0% |  | Compensatória | Verde | 0% | 0% | Banco |  |  |  |
| 2289 | 3.1.3.30.1.2.2 | Licitar projeto |  | 44d | 2019-06-12 A | 2019-08-13 | 2288FS+4d | 25% | 33d | 2019-06-12 | 2019-08-13 | 44d | 2019-06-17 | 2019-08-16 | 429d | 0d | Verde | Verde | 0% |  |  | 0% |  | Compensatória | Verde | 0% | 0% | Município |  |  | Critério FR |
| 2290 | 3.1.3.30.1.2.3 | Documentação de licitação para projeto básico e executivo para SES completo na Sede do Município de Rio Casca/MG (SEGUNDA ETAPA) apresentada ao banco | milestone | 0d | 2019-08-21 | 2019-08-21 | 2289FS+5d |  |  | 2019-08-21 | 2019-08-21 | 0d | 2019-08-16 | 2019-08-16 | 429d | 0d | Verde | Verde | 0% |  |  | 0% |  | Compensatória | Verde | 0% | 0% | Município |  |  |  |
| 2291 | 3.1.3.30.1.2.4 | Analisar e emitir resultado da licitação do projeto |  | 14d | 2019-08-22 | 2019-09-10 | 2290 |  |  | 2019-08-22 | 2019-09-10 | 14d | 2019-08-19 | 2019-09-18 | 429d | 0d | Verde | Verde | 0% |  |  | 0% |  | Compensatória | Verde | 0% | 0% | Banco |  |  | Critério FR |
| 2292 | 3.1.3.30.1.2.5 | Licitação do projeto básico e executivo de Rio Casca do Pleito RICESPJ02 - Elaboração de projeto básico e executivo para SES completo na Sede do Município de Rio Casca/MG (SEGUNDA ETAPA) concluída | milestone | 0d | 2019-09-10 | 2019-09-10 | 2291 |  |  | 2019-09-10 | 2019-09-10 | 0d | 2019-09-18 | 2019-09-18 | 429d | 0d | Verde | Verde | 0% |  |  | 0% |  | Compensatória | Verde | 0% | 0% | Município |  |  |  |
| 2293 | 3.1.3.30.1.3 | **Estudo de concepção** |  | 95d | 2019-09-11 | 2020-01-28 |  |  |  | 2019-09-11 | 2020-01-28 | 95d |  |  | 429d |  | Verde | Verde | 0% |  |  | 0% |  | Compensatória | Verde | 0% | 0% |  |  |  |  |
| 2294 | 3.1.3.30.1.3.1 | Elaborar estudo |  | 30d | 2019-09-11 | 2019-10-22 | 2292 |  |  | 2019-09-11 | 2019-10-22 | 30d |  |  | 429d | 0d | Verde | Verde | 0% |  |  | 0% |  | Compensatória | Verde | 0% | 0% |  |  |  | Critério FR |
| 2295 | 3.1.3.30.1.3.2 | Estudo do projeto básico e executivo para SES completo na Sede do Município de Rio Casca/MG (SEGUNDA ETAPA) apresentado ao banco | milestone | 0d | 2019-10-22 | 2019-10-22 | 2294 |  |  | 2019-10-22 | 2019-10-22 | 0d |  |  | 923d | 0d | Verde | Verde | 0% |  |  | 0% |  | Compensatória | Verde | 0% | 0% |  |  |  |  |
| 2296 | 3.1.3.30.1.3.3 | Analisar estudo |  | 60d | 2019-10-23 | 2020-01-21 | 2295 |  |  | 2019-10-23 | 2020-01-21 | 60d |  |  | 923d | 0d | Verde | Verde | 0% |  |  | 0% |  | Compensatória | Verde | 0% | 0% |  |  |  | Critério FR |
| 2297 | 3.1.3.30.1.3.4 | Estudo do projeto básico e executivo para SES completo na Sede do Município de Rio Casca/MG (SEGUNDA ETAPA) concluído | milestone | 0d | 2020-01-21 | 2020-01-21 | 2296 |  |  | 2020-01-21 | 2020-01-21 | 0d |  |  | 923d | 0d | Verde | Verde | 0% |  |  | 0% |  | Compensatória | Verde | 0% | 0% |  |  |  |  |
| 2298 | 3.1.3.30.1.3.5 | Recurso do estudo do pleito de Rio Casca do Pleito RICESPJ02 - Elaboração de projeto básico e executivo para SES completo na Sede do Município de Rio Casca/MG (SEGUNDA ETAPA) repassado | milestone | 0d | 2020-01-28 | 2020-01-28 | 2297FS+5d |  |  | 2020-01-28 | 2020-01-28 | 0d |  |  | 923d | 25d | Verde | Verde | 0% |  |  | 0% |  | Compensatória | Verde | 0% | 0% |  |  |  |  |
| 2299 | 3.1.3.30.1.4 | **Elaboração do Projeto Básico** |  | 95d | 2019-10-23 | 2020-03-13 |  |  |  | 2019-10-23 | 2020-03-13 | 95d |  |  | 429d |  | Verde | Verde | 0% |  |  | 0% |  | Compensatória | Verde | 0% | 0% |  |  |  |  |
| 2300 | 3.1.3.30.1.4.1 | Elaborar Projeto Básico |  | 30d | 2019-10-23 | 2019-12-04 | 2294 |  |  | 2019-10-23 | 2019-12-04 | 30d |  |  | 429d | 0d | Verde | Verde | 0% |  |  | 0% |  | Compensatória | Verde | 0% | 0% |  |  |  | Critério FR |
| 2301 | 3.1.3.30.1.4.2 | Projeto básico para SES completo na Sede do Município de Rio Casca/MG (SEGUNDA ETAPA) apresentado ao banco | milestone | 0d | 2019-12-04 | 2019-12-04 | 2300 |  |  | 2019-12-04 | 2019-12-04 | 0d |  |  | 429d | 0d | Verde | Verde | 0% |  |  | 0% |  | Compensatória | Verde | 0% | 0% |  |  |  |  |
| 2302 | 3.1.3.30.1.4.3 | Analisar projeto básico |  | 60d | 2019-12-05 | 2020-03-06 | 2301 |  |  | 2019-12-05 | 2020-03-06 | 60d |  |  | 898d | 0d | Verde | Verde | 0% |  |  | 0% |  | Compensatória | Verde | 0% | 0% |  |  |  |  |
| 2303 | 3.1.3.30.1.4.4 | Projeto básico para SES completo na Sede do Município de Rio Casca/MG (SEGUNDA ETAPA) concluído | milestone | 0d | 2020-03-06 | 2020-03-06 | 2298, 2302 |  |  | 2020-03-06 | 2020-03-06 | 0d |  |  | 898d | 0d | Verde | Verde | 0% |  |  | 0% |  | Compensatória | Verde | 0% | 0% |  |  |  |  |
| 2304 | 3.1.3.30.1.4.5 | Recurso do projeto básico de Rio Casca do Pleito RICESPJ02 - Elaboração de projeto básico e executivo para SES completo na Sede do Município de Rio Casca/MG (SEGUNDA ETAPA) repassado | milestone | 0d | 2020-03-13 | 2020-03-13 | 2303FS+5d |  |  | 2020-03-13 | 2020-03-13 | 0d |  |  | 898d | 15d | Verde | Verde | 0% |  |  | 0% |  | Compensatória | Verde | 0% | 0% |  |  |  |  |
| 2305 | 3.1.3.30.1.5 | **Elaboração do Projeto Executivo** |  | 85d | 2019-12-05 | 2020-04-13 |  |  |  | 2019-12-05 | 2020-04-13 | 85d | 2019-09-19 | 2020-03-10 | 883d |  | Verde | Verde | 0% |  |  | 0% |  | Compensatória | Verde | 0% | 0% |  |  |  |  |
| 2306 | 3.1.3.30.1.5.1 | Elaborar Projeto Executivo |  | 20d | 2019-12-05 | 2020-01-07 | 2300 |  |  | 2019-12-05 | 2020-01-07 | 20d | 2019-09-19 | 2019-11-20 | 883d | 0d | Verde | Verde | 0% |  |  | 0% |  | Compensatória | Verde | 0% | 0% | Município |  |  |  |
| 2307 | 3.1.3.30.1.5.2 | Projeto executivo para SES completo na Sede do Município de Rio Casca/MG (SEGUNDA ETAPA) apresentado ao banco | milestone | 0d | 2020-01-07 | 2020-01-07 | 2306 |  |  | 2020-01-07 | 2020-01-07 | 0d | 2019-11-20 | 2019-11-20 | 883d | 0d | Verde | Verde | 0% |  |  | 0% |  | Compensatória | Verde | 0% | 0% | Município |  |  |  |
| 2308 | 3.1.3.30.1.5.3 | Analisar projeto executivo |  | 60d | 2020-01-08 | 2020-04-03 | 2307 |  |  | 2020-01-08 | 2020-04-03 | 60d | 2019-11-21 | 2019-12-23 | 883d | 0d | Verde | Verde | 0% |  |  | 0% |  | Compensatória | Verde | 0% | 0% | Banco |  |  |  |
| 2309 | 3.1.3.30.1.5.4 | Projeto executivo para SES completo na Sede do Município de Rio Casca/MG (SEGUNDA ETAPA)concluído | milestone | 0d | 2020-04-03 | 2020-04-03 | 2304, 2308 |  |  | 2020-04-03 | 2020-04-03 | 0d | 2020-03-03 | 2020-03-03 | 883d | 0d | Verde | Verde | 0% |  |  | 0% |  | Compensatória | Verde | 0% | 0% | Município |  |  |  |
| 2310 | 3.1.3.30.1.5.5 | Recurso do projeto executivo do pleito RICESPJ02 repassado | milestone | 0d | 2020-04-13 | 2020-04-13 | 2309FS+5d |  |  | 2020-04-13 | 2020-04-13 | 0d | 2020-03-10 | 2020-03-10 | 883d | 0d | Verde | Verde | 0% |  |  | 0% |  | Compensatória | Verde | 0% | 0% | Banco |  |  |  |
| 2311 | 3.1.3.30.1.6 | Pleito RICESPJ02 - Elaboração de projeto básico e executivo para SES completo na Sede do Município de Rio Casca/MG (SEGUNDA ETAPA) de Rio Casca concluído | milestone | 0d | 2020-04-13 | 2020-04-13 | 2310 |  |  | 2020-04-13 | 2020-04-13 | 0d | 2020-03-10 | 2020-03-10 | 883d |  | Verde | Verde | 0% |  |  | 0% |  | Compensatória | Verde | 0% | 0% | Município |  |  |  |

Notes:
- 2284: Rio Casca teve 100% dos pleitos de Esgotamento Sanitário aprovado(R$7.087.789,81), conforme Deliberação 75. / O município não fez pleito de resíduos sólidos. / Vai pedir mudança de pleito, devido a uma grande enchente ocorrida no munícipio, que afetou as áreas destinadas à rede interceptora e uma elevatória. Com isto, vai pedir alteração do distrito de jurumirim para sede. / Será necessário fazer alteração de projeto já existente. / Na obra em curso, o recurso da Renova só será empregado após o uso do recurso da FUNASA e como só foi utilizado 20% deste recurso, o munícipio tem um prazo grande para dar entrada com este projeto
- 2286: Em 25/04/2019: o pleito será substituido dos distritos para a sede na próxima CT/CIF de maio dia 31/05/2019. Ofício 199/2019 enviado dia 27/02/2019.
- 2288: 13/06/2019: o banco autorizou o início da licitação no dia 05/06 conforme planilha Controle Gerencial Renova
- 2289: 13/06/2019: município começou o processo licitatório no dia 12/06 (fonte: e-mail Danielle) / 02/07/2019: município está trabalhando no edital do processo licitatório (fonte: telefonema com Lauro - Apoio Técnico).

| ID | WBS | Task | Type | Duration | Start | Finish | Predecessors | Complete | Remaining | Baseline start | Baseline finish | Baseline duration | Baseline 1 start | Baseline 1 finish | Total slack | Free slack | Constraint | Text1 | Text2 | Text3 | Text6 | Text8 | Text12 | Text14 | Text16 | Text9 | Text4 | Text5 | Text7 | Text15 | Text17 | Text18 |
| --- | --- | --- | --- | --- | --- | --- | --- | --- | --- | --- | --- | --- | --- | --- | --- | --- | --- | --- | --- | --- | --- | --- | --- | --- | --- | --- | --- | --- | --- | --- | --- | --- |
| 2312 | 3.1.3.30.2 | **Pleito de Rio Casca a definir - Obra da Sede** |  | 546d | 2019-11-26 | 2022-02-04 |  |  |  | 2019-11-26 | 2022-02-04 | 546d | 2019-11-29 | 2022-02-22 | 429d |  |  | Verde | Verde | 0% | 0% | Compensatória | Verde | 0% | 0% |  |  |  |  |  |  |  |
| 2313 | 3.1.3.30.2.1 | Pleito de Rio Casca a definir - Obra da Sede aprovado | milestone | 0d | 2019-11-26 | 2019-11-26 | 2301FS-7d |  |  | 2019-11-26 | 2019-11-26 | 0d | 2019-11-29 | 2019-11-29 | 429d | 0d |  | Verde | Verde | 0% | 0% | Compensatória | Verde | 0% | 0% | CT/CIF |  |  |  |  |  |  |
| 2314 | 3.1.3.30.2.2 | **Licitação da Obra** |  | 78d | 2019-12-09 | 2020-04-06 |  |  |  | 2019-12-09 | 2020-04-06 | 78d | 2019-12-16 | 2020-04-13 | 429d |  |  | Verde | Verde | 0% | 0% | Compensatória | Verde | 0% | 0% |  |  |  |  |  |  |  |
| 2315 | 3.1.3.30.2.2.1 | Licitação da obra do Pleito de Rio Casca a definir - Obra da Sede autorizada pelo banco | milestone | 0d | 2019-12-09 | 2019-12-09 | 2313FS+10d |  |  | 2019-12-09 | 2019-12-09 | 0d | 2019-12-16 | 2019-12-16 | 429d | 0d |  | Verde | Verde | 0% | 0% | Compensatória | Verde | 0% | 0% | Banco |  |  |  |  |  |  |
| 2316 | 3.1.3.30.2.2.2 | Licitar Obra |  | 64d | 2019-12-10 | 2020-03-17 | 2315 |  |  | 2019-12-10 | 2020-03-17 | 64d | 2019-12-17 | 2020-03-23 | 429d | 0d |  | Verde | Verde | 0% | 0% | Compensatória | Verde | 0% | 0% | Município |  |  |  |  |  |  |
| 2317 | 3.1.3.30.2.2.3 | Analisar e emitir resultado da licitação da obra |  | 14d | 2020-03-18 | 2020-04-06 | 2316 |  |  | 2020-03-18 | 2020-04-06 | 14d | 2020-03-24 | 2020-04-13 | 429d | 0d |  | Verde | Verde | 0% | 0% | Compensatória | Verde | 0% | 0% | Banco |  |  |  |  |  |  |
| 2318 | 3.1.3.30.2.2.4 | Licitação da obra do Pleito de Rio Casca a definir - Obra da Sede concluída | milestone | 0d | 2020-04-06 | 2020-04-06 | 2317 |  |  | 2020-04-06 | 2020-04-06 | 0d | 2020-04-13 | 2020-04-13 | 429d | 0d |  | Verde | Verde | 0% | 0% | Compensatória | Verde | 0% | 0% | Município |  |  |  |  |  |  |
| 2319 | 3.1.3.30.2.3 | Executar obra |  | 313d | 2020-05-08 | 2021-08-06 | 2318FS+20d |  |  | 2020-05-08 | 2021-08-06 | 313d | 2020-05-14 | 2021-08-12 | 429d | 0d |  | Verde | Verde | 0% | 0% | Compensatória | Verde | 0% | 0% | Município |  |  |  |  |  |  |
| 2320 | 3.1.3.30.2.4 | Realizar processo de pré-operação |  | 120d | 2021-08-09 | 2022-01-28 | 2319 |  |  | 2021-08-09 | 2022-01-28 | 120d | 2021-08-13 | 2022-02-15 | 429d | 0d |  | Verde | Verde | 0% | 0% | Compensatória | Verde | 0% | 0% | Município |  |  |  |  |  |  |
| 2321 | 3.1.3.30.2.5 | Recurso da obra do Pleito de Rio Casca a definir - Obra da Sede repassado | milestone | 0d | 2022-02-04 | 2022-02-04 | 2320FS+5d |  |  | 2022-02-04 | 2022-02-04 | 0d | 2022-02-22 | 2022-02-22 | 429d | 0d |  | Verde | Verde | 0% | 0% | Compensatória | Verde | 0% | 0% | Banco |  |  |  |  |  |  |
| 2322 | 3.1.3.30.2.6 | Pleito de Rio Casca a definir - Obra da Sede concluído | milestone | 0d | 2022-02-04 | 2022-02-04 | 2321 |  |  | 2022-02-04 | 2022-02-04 | 0d | 2022-02-22 | 2022-02-22 | 429d |  |  | Verde | Verde | 0% | 0% | Compensatória | Verde | 0% | 0% | Município |  |  |  |  |  |  |
| 2323 | 3.1.3.30.3 | **Pleito RICESOB01 - Complementação de recursos de contrapartida para TC/PAC 0352/14** |  | 303d | 2019-12-31 | 2021-03-22 |  |  |  | 2019-12-31 | 2021-03-22 | 303d | 2019-12-31 | 2021-04-01 | 650d |  |  | Verde | Verde | 0% | 0% | Compensatória | Verde | 0% | 0% |  |  |  |  |  |  |  |
| 2324 | 3.1.3.30.3.1 | Executar obra |  | 178d | 2019-12-31 | 2020-09-16 | 3052FS+260d |  |  | 2019-12-31 | 2020-09-16 | 178d | 2019-12-31 | 2020-09-16 | 650d | 0d |  | Verde | Verde | 0% | 0% | Compensatória | Verde | 0% | 0% | Município |  |  |  |  |  |  |
| 2325 | 3.1.3.30.3.2 | Realizar processo de pré-operação |  | 120d | 2020-09-17 | 2021-03-15 | 2324 |  |  | 2020-09-17 | 2021-03-15 | 120d | 2020-09-17 | 2021-03-25 | 650d | 0d |  | Verde | Verde | 0% | 0% | Compensatória | Verde | 0% | 0% | Município |  |  |  |  |  |  |
| 2326 | 3.1.3.30.3.3 | Recurso da obra de Rio Casca do Pleito RICESOB01 - Complementação de recursos de contrapartida para TC/PAC 0352/14 repassado | milestone | 0d | 2021-03-22 | 2021-03-22 | 2325FS+5d |  |  | 2021-03-22 | 2021-03-22 | 0d | 2021-04-01 | 2021-04-01 | 650d | 0d |  | Verde | Verde | 0% | 0% | Compensatória | Verde | 0% | 0% | Banco |  |  |  |  |  |  |
| 2327 | 3.1.3.30.3.4 | Pleito RICESOB01 - Complementação de recursos de contrapartida para TC/PAC 0352/14 de Rio Casca concluído | milestone | 0d | 2021-03-22 | 2021-03-22 | 2326 |  |  | 2021-03-22 | 2021-03-22 | 0d | 2021-04-01 | 2021-04-01 | 650d |  |  | Verde | Verde | 0% | 0% | Compensatória | Verde | 0% | 0% | Município |  |  |  |  |  |  |
| 2328 | 3.1.3.30.4 | **Pleito RICESAO01 - Contratação de assessoria técnica para acompanhamento técnico de obras do TC/PAC 0352/14** |  | 297d | 2018-06-15 A | 2019-08-16 |  | 87% | 39.31d | 2018-06-15 | 2019-08-16 | 297d | 2018-06-15 | 2019-12-11 | 1045d |  |  | Verde | Verde | 82% | 80% | Compensatória | Vermelho | 76% | 61% |  | 67 | 82 | 80 | 76 | 61 |  |
| 2329 | 3.1.3.30.4.1 | **Licitação da empresa de assessoria técnica** |  | 69d | 2018-06-15 A | 2018-09-19 A |  | 100% |  | 2018-06-15 | 2018-09-19 | 69d | 2018-06-15 | 2018-09-19 |  |  |  | Verde | Verde | 100% | 100% | Compensatória | Verde | 100% | 100% |  | 100 | 100 | 100 | 100 | 100 |  |
| 2330 | 3.1.3.30.4.1.1 | Licitação da empresa de assessoria técnica para acompanhamento técnico de obras do TC/PAC 0352/14 autorizada pelo banco | milestone | 0d | 2018-06-15 A | 2018-06-15 A |  | 100% |  | 2018-06-15 | 2018-06-15 | 0d | 2018-06-15 | 2018-06-15 |  |  | must start on 2018-06-15 | Verde | Verde | 100% | 100% | Compensatória | Verde | 100% | 100% | Banco | 100 | 100 | 100 | 100 | 100 |  |
| 2331 | 3.1.3.30.4.1.2 | Licitar empresa de assessoria técnica |  | 58d | 2018-06-15 A | 2018-09-04 A | 2330 | 100% |  | 2018-06-15 | 2018-09-04 | 58d | 2018-06-15 | 2018-09-04 |  |  |  | Verde | Verde | 100% | 100% | Compensatória | Verde | 100% | 100% | Município | 100 | 100 | 100 | 100 | 100 |  |
| 2332 | 3.1.3.30.4.1.3 | Documentação de licitação para acompanhamento técnico de obras do TC/PAC 0352/14 apresentada ao banco | milestone | 0d | 2018-09-11 A | 2018-09-11 A | 2331FS+5d | 100% |  | 2018-09-11 | 2018-09-11 | 0d | 2018-09-11 | 2018-09-11 |  |  |  | Verde | Verde | 100% | 100% | Compensatória | Verde | 100% | 100% | Município | 100 | 100 | 100 | 100 | 100 |  |
| 2333 | 3.1.3.30.4.1.4 | Analisar e emitir resultado da licitação da empresa de assessoria técnica |  | 6d | 2018-09-12 A | 2018-09-19 A | 2332 | 100% |  | 2018-09-12 | 2018-09-19 | 6d | 2018-09-12 | 2018-09-19 |  |  |  | Verde | Verde | 100% | 100% | Compensatória | Verde | 100% | 100% | Banco | 100 | 100 | 100 | 100 | 100 |  |
| 2334 | 3.1.3.30.4.1.5 | Licitação da empresa de assessoria técnica para acompanhamento técnico de obras do TC/PAC 0352/14 concluída | milestone | 0d | 2018-09-19 A | 2018-09-19 A | 2333 | 100% |  | 2018-09-19 | 2018-09-19 | 0d | 2018-09-19 | 2018-09-19 |  |  |  | Verde | Verde | 100% | 100% | Compensatória | Verde | 100% | 100% | Município | 100 | 100 | 100 | 100 | 100 |  |
| 2335 | 3.1.3.30.4.2 | Contratar e executar serviço de assessoria técnica |  | 147d | 2018-12-21 A | 2019-08-08 | 2334FS+67d | 81% | 27.93d | 2018-12-21 | 2019-08-08 | 147d | 2018-12-21 | 2019-12-04 | 1045d | 0d |  | Verde | Verde | 69% | 72% | Compensatória | Vermelho | 69% | 50% | Município | 52 | 69 | 72 | 69 | 50 | Conforme agendado |
| 2336 | 3.1.3.30.4.3 | Recurso de assessoria técnica de Rio Casca do Pleito RICESAO01 - Contratação de assessoria técnica para acompanhamento técnico de obras do TC/PAC 0352/14 repassado | milestone | 0d | 2019-08-16 | 2019-08-16 | 2335FS+5d |  |  | 2019-08-16 | 2019-08-16 | 0d | 2019-12-11 | 2019-12-11 | 1045d | 0d |  | Verde | Verde | 0% | 0% | Compensatória | Verde | 0% | 0% | Banco |  |  |  |  |  |  |
| 2337 | 3.1.3.30.4.4 | Pleito RICESAO01 - Contratação de assessoria técnica para acompanhamento técnico de obras do TC/PAC 0352/14 de Rio Casca concluído | milestone | 0d | 2019-08-16 | 2019-08-16 | 2336 |  |  | 2019-08-16 | 2019-08-16 | 0d | 2019-12-11 | 2019-12-11 | 1045d |  |  | Verde | Verde | 0% | 0% | Compensatória | Verde | 0% | 0% | Município |  |  |  |  |  |  |

Notes:
- 2313: Em 25/05/2019: o pleito deve ser apresentado e aprovado em novembro de 2019, visto que novembro, dezembro, janeiro e fevereiro não são passíveis de apresentação de pleito, ou seja, o pleito só seria aprovado em final de maio (NT33).
- 2319: Em 25/04/2019: valor da obra > R$ 5 milhões
- 2324: Em 25/04/2019: obra está em andamento e sendo paga com o recurso da Funasa. Foi considerado que a Renova iniciará o pagamento da obra em 02/01/2020, com base no cálculo da duração da obra da Funasa. Em fevereiro de 2019 a obra estava com avanço de 40% (planilha plano de aceleração). Considerando que o recurso da Funasa é de 10,5 milhões, o que representa 20 meses de acordo com as premissas utilizadas nesse cronograma, 60% seriam mais 12 meses de obra. Portanto, a parte da obra com recurso Funasa será concluída em fevereiro de 2020.
- 2330: Em 25/04/2019: banco autorizou a licitação da empresa no dia 15/06/2018 conforme planilha controle gerencial Renova
- 2331: Em 25/04/2019: conforme planilha controle gerencial Renova o município protocolou a licitação no dia 11/09/2018
- 2332: Em 25/04/2019: conforme planilha controle gerencial Renova o município protocolou a licitação no dia 11/09/2018
- 2333: Em 25/04/2019: conforme planilha controle gerencial Renova o banco autorizou a contratação da empresa no dia 19/09/2018
- 2334: Em 25/04/2019: conforme planilha controle gerencial Renova o banco autorizou a contratação da empresa no dia 19/09/2018
- 2335: 18/12/2018 - Municipio está avaliando se manterá o pleito de Vista Alegre e alterou a data para 15/01/2019 / Em 29/04/2019: atualizado como agendado / 21/05/2019: confirmar com o município se a data de término está certa; / 02/07/2019: a última medição foi protocolada no banco dia 08/05/2019 e foi feito o repasse dia 13/06/2019.

| ID | WBS | Task | Type | Duration | Start | Finish | Predecessors | Complete | Remaining | Baseline start | Baseline finish | Baseline duration | Baseline 1 start | Baseline 1 finish | Total slack | Free slack | Constraint | Text1 | Text2 | Text3 | Text6 | Text8 | Text12 | Text14 | Text16 | Text9 | Text18 | Text4 | Text5 | Text7 | Text15 | Text17 |
| --- | --- | --- | --- | --- | --- | --- | --- | --- | --- | --- | --- | --- | --- | --- | --- | --- | --- | --- | --- | --- | --- | --- | --- | --- | --- | --- | --- | --- | --- | --- | --- | --- |
| 2338 | 3.1.3.30.5 | **Pleito RICRSPM01 - Elaboração do Plano Intermunicipal de Gestão Integrada de Resíduos Sólidos para os Municípios associados ao Consórcio Intermunicipal Multissetorial do Vale do Piranga (PIGIRS/CIMVALPI),** |  | 1082d | 2019-06-25 A | 2023-10-30 |  |  | 1082d | 2019-08-30 | 2023-10-30 | 1035d | 2019-08-30 | 2024-01-30 | 0d |  |  | Verde | Verde | 0% | 0% | Compensatória | Verde | 0% | 0% |  |  |  |  |  |  |  |
| 2339 | 3.1.3.30.5.1 | Pleito RICRSPM01 - Elaboração do Plano Intermunicipal de Gestão Integrada de Resíduos Sólidos para os Municípios associados ao Consórcio Intermunicipal Multissetorial do Vale do Piranga (PIGIRS/CIMVALPI) aprovado pelo CIF | milestone | 0d | 2019-06-25 A | 2019-06-25 A | 3041FS+240d | 100% |  | 2019-08-30 | 2019-08-30 | 0d | 2019-08-30 | 2019-08-30 |  |  |  | Verde | Verde | 0% | 0% | Compensatória | Verde | 0% | 0% | CT/CIF |  |  |  |  |  |  |
| 2340 | 3.1.3.30.5.2 | Iniciar serviço/projeto/obra de Rio Casca de Resíduos Sólidos a definir |  | 1d | 2019-09-02 | 2019-09-02 | 2339FS+47d |  |  | 2019-09-02 | 2019-09-02 | 1d | 2019-09-02 | 2019-09-02 | 0d |  |  | Verde | Verde | 0% | 0% | Compensatória | Verde | 0% | 0% | Município | Critério FR |  |  |  |  |  |
| 2341 | 3.1.3.30.5.3 | Pleito RICRSPM01 - Elaboração do Plano Intermunicipal de Gestão Integrada de Resíduos Sólidos para os Municípios associados ao Consórcio Intermunicipal Multissetorial do Vale do Piranga (PIGIRS/CIMVALPI) concluído | milestone | 0d | 2023-10-30 | 2023-10-30 | 2340FS+1034d |  |  | 2023-10-30 | 2023-10-30 | 0d | 2024-01-30 | 2024-01-30 | 0d |  |  | Verde | Verde | 0% | 0% | Compensatória | Verde | 0% | 0% | Município |  |  |  |  |  |  |
| 2342 | 3.1.3.30.6 | **Pleito RICESPJ01 - Elaboração de Projeto do sistema de esgotamento sanitário do vilarejo de Jurumirim** |  | 1d | 2019-05-28 A | 2019-05-28 A |  | 100% |  | 2019-05-28 | 2019-05-28 | 1d | 2019-05-31 | 2019-05-31 |  |  |  | Verde | Verde | 100% | 100% | Compensatória | Verde | 100% | 100% |  |  | 100 | 100 | 100 | 100 | 100 |
| 2343 | 3.1.3.30.6.1 | Avaliar cancelamento do pleito RICESPJ01 |  | 1d | 2019-05-28 A | 2019-05-28 A | 3052FS+111d | 100% |  | 2019-05-28 | 2019-05-28 | 1d | 2019-05-31 | 2019-05-31 |  |  |  | Verde | Verde | 100% | 100% | Compensatória | Verde | 100% | 100% | Município |  | 100 | 100 | 100 | 100 | 100 |
| 2344 | 3.1.3.30.6.2 | Pleito RICESPJ01 - Elaboração de Projeto do sistema de esgotamento sanitário do vilarejo de Jurumirim de Rio Casca cancelado | milestone | 0d | 2019-05-28 A | 2019-05-28 A | 2343 | 100% |  | 2019-05-28 | 2019-05-28 | 0d | 2019-05-31 | 2019-05-31 |  |  |  | Verde | Verde | 100% | 100% | Compensatória | Verde | 100% | 100% | Município |  | 100 | 100 | 100 | 100 | 100 |
| 2345 | 3.1.3.30.7 | **Pleito RICESOB02 - Implantação de sistema de esgotamento sanitário do povoado de Vista Alegre** |  | 1d | 2019-05-28 A | 2019-05-28 A |  | 100% |  | 2019-05-28 | 2019-05-28 | 1d | 2019-05-31 | 2019-05-31 |  |  |  | Verde | Verde | 100% | 100% | Compensatória | Verde | 100% | 100% |  |  | 100 | 100 | 100 | 100 | 100 |
| 2346 | 3.1.3.30.7.1 | Avaliar cancelamento do pleito RICESOB02 |  | 1d | 2019-05-28 A | 2019-05-28 A | 3052FS+111d | 100% |  | 2019-05-28 | 2019-05-28 | 1d | 2019-05-31 | 2019-05-31 |  |  |  | Verde | Verde | 100% | 100% | Compensatória | Verde | 100% | 100% | Município |  | 100 | 100 | 100 | 100 | 100 |
| 2347 | 3.1.3.30.7.2 | Pleito RICESOB02 - Implantação de sistema de esgotamento sanitário do povoado de Vista Alegre de Rio Casca cancelado | milestone | 0d | 2019-05-28 A | 2019-05-28 A | 2346 | 100% |  | 2019-05-28 | 2019-05-28 | 0d | 2019-05-31 | 2019-05-31 |  |  |  | Verde | Verde | 100% | 100% | Compensatória | Verde | 100% | 100% | Município |  | 100 | 100 | 100 | 100 | 100 |
| 2348 | 3.1.3.30.8 | **Pleito RICESOB03 - Implantação de sistema de esgotamento sanitário do vilarejo de Jurumirim** |  | 1d | 2019-05-28 A | 2019-05-28 A |  | 100% |  | 2019-05-28 | 2019-05-28 | 1d | 2019-05-31 | 2019-05-31 |  |  |  | Verde | Verde | 100% | 100% | Compensatória | Verde | 100% | 100% |  |  | 100 | 100 | 100 | 100 | 100 |
| 2349 | 3.1.3.30.8.1 | Avaliar cancelamento do pleito RICESOB03 |  | 1d | 2019-05-28 A | 2019-05-28 A | 3052FS+111d | 100% |  | 2019-05-28 | 2019-05-28 | 1d | 2019-05-31 | 2019-05-31 |  |  |  | Verde | Verde | 100% | 100% | Compensatória | Verde | 100% | 100% | Município |  | 100 | 100 | 100 | 100 | 100 |
| 2350 | 3.1.3.30.8.2 | Pleito RICESOB03 - Implantação de sistema de esgotamento sanitário do vilarejo de Jurumirim de Rio Casca cancelado | milestone | 0d | 2019-05-28 A | 2019-05-28 A | 2349 | 100% |  | 2019-05-28 | 2019-05-28 | 0d | 2019-05-31 | 2019-05-31 |  |  |  | Verde | Verde | 100% | 100% | Compensatória | Verde | 100% | 100% | Município |  | 100 | 100 | 100 | 100 | 100 |
| 2351 | 3.1.3.30.9 | **Pleito RICESAO02 - Contratação de assessoria técnica para apoio na obtenção de licença ambiental das ETEs do distrito de vista Alegre e Jurumirim** |  | 1d | 2019-05-28 A | 2019-05-28 A |  | 100% |  | 2019-05-28 | 2019-05-28 | 1d | 2019-05-31 | 2019-05-31 |  |  |  | Verde | Verde | 100% | 100% | Compensatória | Verde | 100% | 100% |  |  | 100 | 100 | 100 | 100 | 100 |
| 2352 | 3.1.3.30.9.1 | Avaliar cancelamento do pleito RICESAO02 |  | 1d | 2019-05-28 A | 2019-05-28 A | 3052FS+111d | 100% |  | 2019-05-28 | 2019-05-28 | 1d | 2019-05-31 | 2019-05-31 |  |  |  | Verde | Verde | 100% | 100% | Compensatória | Verde | 100% | 100% | Município |  | 100 | 100 | 100 | 100 | 100 |
| 2353 | 3.1.3.30.9.2 | Pleito RICESAO02 - Contratação de assessoria técnica para apoio na obtenção de licença ambiental das ETEs do distrito de vista Alegre e Jurumirim de Rio Casca cancelado | milestone | 0d | 2019-05-28 A | 2019-05-28 A | 2352 | 100% |  | 2019-05-28 | 2019-05-28 | 0d | 2019-05-31 | 2019-05-31 |  |  |  | Verde | Verde | 100% | 100% | Compensatória | Verde | 100% | 100% | Município |  | 100 | 100 | 100 | 100 | 100 |
| 2354 | 3.1.3.30.10 | Recursos de Rio Casca repassados | milestone | 0d | 2023-10-30 | 2023-10-30 | 2344, 2353, 2327, 2337, 2347, 2350, 2311, 2322, 2341 |  |  | 2023-10-30 | 2023-10-30 | 0d | 2018-12-21 | 2018-12-21 | 0d |  |  | Verde | Verde | 0% | 0% | Compensatória | Verde | 0% | 0% | Banco |  |  |  |  |  |  |
| 2355 | 3.1.3.31 | **Rio Doce** |  | 1154d | 2019-03-12 A | 2023-10-30 |  | 6% | 1082.37d | 2019-03-12 | 2023-10-30 | 1154d | 2019-03-12 | 2024-01-30 | 0d |  |  | Verde | Verde | 4% | 0% | Compensatória | Vermelho | 2% | 0% |  |  |  |  |  |  |  |
| 2356 | 3.1.3.31.1 | **Pleito RIDESOB01 - Construção de SES para o distrito de Matadouro** |  | 449d | 2019-03-12 A | 2020-12-29 |  | 6% | 421.92d | 2019-03-12 | 2020-12-29 | 449d | 2019-03-12 | 2020-11-26 | 705d |  |  | Verde | Verde | 12% | 0% | Compensatória | Vermelho | 3% | 0% |  |  |  | 12 |  |  |  |
| 2357 | 3.1.3.31.1.1 | **Aprovação do Projeto** |  | 103d | 2019-03-12 A | 2019-08-07 |  | 25% | 77.25d | 2019-03-12 | 2019-08-07 | 103d | 2019-03-12 | 2019-07-15 | 705d |  |  | Verde | Verde | 54% | 0% | Compensatória | Vermelho | 30% | 0% |  |  | 15 | 54 |  | 30 |  |
| 2358 | 3.1.3.31.1.1.1 | Projeto do pleito RIDESOB01 de Rio Doce de Construção de SES para o distrito de Matadouro apresentado ao banco | milestone | 0d | 2019-03-12 A | 2019-03-12 A |  | 100% |  | 2019-03-12 | 2019-03-12 | 0d | 2019-03-12 | 2019-03-12 |  |  | must start on 2019-03-12 | Verde | Verde | 100% | 100% | Compensatória | Verde | 100% | 100% | Município |  | 100 | 100 | 100 | 100 | 100 |
| 2359 | 3.1.3.31.1.1.2 | Analisar projeto |  | 103d | 2019-03-12 A | 2019-08-07 | 2358 | 25% | 77.25d | 2019-03-12 | 2019-08-07 | 103d | 2019-03-12 | 2019-05-16 | 705d | 0d |  | Verde | Verde | 90% | 0% | Compensatória | Vermelho | 90% | 0% | Banco | Conforme agendado | 25 | 90 |  | 90 |  |
| 2360 | 3.1.3.31.1.1.3 | Projeto do pleito RIDESOB01 de Rio Doce de Construção de SES para o distrito de Matadouro aprovado | milestone | 0d | 2019-08-07 | 2019-08-07 | 2359 |  |  | 2019-08-07 | 2019-08-07 | 0d | 2019-07-15 | 2019-07-15 | 705d | 0d |  | Verde | Verde | 0% | 0% | Compensatória | Verde | 0% | 0% | Município |  |  |  |  |  |  |
| 2361 | 3.1.3.31.1.2 | **Licitação da Obra** |  | 80d | 2019-08-07 | 2019-11-29 |  |  |  | 2019-08-07 | 2019-11-29 | 80d | 2019-07-15 | 2019-11-05 | 705d |  |  | Verde | Verde | 0% | 0% | Compensatória | Verde | 0% | 0% |  |  |  |  |  |  |  |
| 2362 | 3.1.3.31.1.2.1 | Licitação da obra de Construção de SES para o distrito de Matadouro autorizada pelo banco | milestone | 0d | 2019-08-07 | 2019-08-07 | 2360 |  |  | 2019-08-07 | 2019-08-07 | 0d | 2019-07-15 | 2019-07-15 | 705d | 0d |  | Verde | Verde | 0% | 0% | Compensatória | Verde | 0% | 0% | Banco |  |  |  |  |  |  |
| 2363 | 3.1.3.31.1.2.2 | Licitar Obra |  | 66d | 2019-08-08 | 2019-11-08 | 2362 |  |  | 2019-08-08 | 2019-11-08 | 66d | 2019-07-16 | 2019-10-16 | 705d | 0d |  | Verde | Verde | 0% | 0% | Compensatória | Verde | 0% | 0% | Município | Critério FR |  |  |  |  |  |
| 2364 | 3.1.3.31.1.2.3 | Analisar e emitir resultado da licitação da obra |  | 14d | 2019-11-11 | 2019-11-29 | 2363 |  |  | 2019-11-11 | 2019-11-29 | 14d | 2019-10-17 | 2019-11-05 | 705d | 0d |  | Verde | Verde | 0% | 0% | Compensatória | Verde | 0% | 0% | Banco | Critério FR |  |  |  |  |  |
| 2365 | 3.1.3.31.1.2.4 | Licitação de Construção de SES para o distrito de Matadouro da obra concluída | milestone | 0d | 2019-11-29 | 2019-11-29 | 2364 |  |  | 2019-11-29 | 2019-11-29 | 0d | 2019-11-05 | 2019-11-05 | 705d | 0d |  | Verde | Verde | 0% | 0% | Compensatória | Verde | 0% | 0% | Município |  |  |  |  |  |  |
| 2366 | 3.1.3.31.1.3 | Executar obra |  | 124d | 2019-12-30 | 2020-06-30 | 2365FS+17d |  |  | 2019-12-30 | 2020-06-30 | 124d | 2019-11-06 | 2020-05-18 | 705d | 0d |  | Verde | Verde | 0% | 0% | Compensatória | Verde | 0% | 0% | Município |  |  |  |  |  |  |
| 2367 | 3.1.3.31.1.4 | Realizar processo de pré-operação |  | 120d | 2020-07-01 | 2020-12-18 | 2366 |  |  | 2020-07-01 | 2020-12-18 | 120d | 2020-05-19 | 2020-11-19 | 705d | 0d |  | Verde | Verde | 0% | 0% | Compensatória | Verde | 0% | 0% | Município |  |  |  |  |  |  |
| 2368 | 3.1.3.31.1.5 | Recurso da obra do pleito RIDESOB01 repassado | milestone | 0d | 2020-12-29 | 2020-12-29 | 2367FS+5d |  |  | 2020-12-29 | 2020-12-29 | 0d | 2020-11-26 | 2020-11-26 | 705d | 0d |  | Verde | Verde | 0% | 0% | Compensatória | Verde | 0% | 0% | Banco |  |  |  |  |  |  |
| 2369 | 3.1.3.31.1.6 | Pleito RIDESOB01 - Construção de SES para o distrito de Matadouro de Rio Doce concluído | milestone | 0d | 2020-12-29 | 2020-12-29 | 2368 |  |  | 2020-12-29 | 2020-12-29 | 0d | 2020-11-26 | 2020-11-26 | 705d |  |  | Verde | Verde | 0% | 0% | Compensatória | Verde | 0% | 0% | Município |  |  |  |  |  |  |

Notes:
- 2343: Em 25/04/2019: o pleito será substituido dos distritos para a sede na próxima CT/CIF de maio dia 31/05/2019. Ofício 199/2019 enviado dia 27/02/2019.
- 2344: 02/06/2019: pleito cancelado na deliberação 290
- 2346: Em 25/04/2019: o pleito será substituido dos distritos para a sede na próxima CT/CIF de maio dia 31/05/2019. Ofício 199/2019 enviado dia 27/02/2019.
- 2347: 02/06/2019: pleito cancelado na deliberação 290
- 2349: Em 25/04/2019: o pleito será substituido dos distritos para a sede na próxima CT/CIF de maio dia 31/05/2019. Ofício 199/2019 enviado dia 27/02/2019.
- 2350: 02/06/2019: pleito cancelado na deliberação 290
- 2352: Em 25/04/2019: o pleito será substituido dos distritos para a sede na próxima CT/CIF de maio dia 31/05/2019. Ofício 199/2019 enviado dia 27/02/2019.
- 2353: 02/06/2019: pleito cancelado na deliberação 290
- 2354: Valor de recurso destinado ao munícipio: R$7.878.321,79
- 2355: Rio Doce pediu 82% (R$2.180.814,79) dos 90% de recursos destinado para Esgotamento Sanitário e teve todo o pleito aprovado, conforme Deliberação 75. / Não fez pleitos de resíduos sólidos. (10% do total do recurso destinado ao munícipio).
- 2358: Em 25/04/2019: o projeto foi protocolado no banco pelo município no dia 12/03/2019 conforme planilha controle gerencial Renova
- 2359: 25/04/2019: conforme planilha controle gerencial Renova o banco cobrou pendências do projeto no dia 02/04/2019. Considerado mais 1 mês e meio para resolução da análise ou solicitação de revisão. / 21/05/2019: conforme planilha controle gerencial Renova o banco repassou o projeto para análise da Eng. Andréa dia 09/05/2019. Previsão de término da análise é dia 09/06/2019 (1 mês) (fonte: e-mail Gislaine) / 11/06/2019: Eng. Andréa encaminhou resultado da análise ao município dia 10/06 (fonte: e-mail Gislaine) / 13/06/2019: Danielle informou que o município não conseguirá sanar todas as pendências solicitadas pelo banco no prazo estabelecido de 1 mês. O engenheiro informará uma nova previsão de término. (fonte: e-mail Danielle)
- 2366: Em 25/04/2019: valor da obra R$ 839 mil

| ID | WBS | Task | Type | Duration | Start | Finish | Predecessors | Complete | Remaining | Baseline start | Baseline finish | Baseline duration | Baseline 1 start | Baseline 1 finish | Total slack | Free slack | Text1 | Text2 | Text3 | Text5 | Text6 | Text8 | Text12 | Text14 | Text16 | Text15 | Text4 | Text7 | Text9 | Text17 | Text18 |
| --- | --- | --- | --- | --- | --- | --- | --- | --- | --- | --- | --- | --- | --- | --- | --- | --- | --- | --- | --- | --- | --- | --- | --- | --- | --- | --- | --- | --- | --- | --- | --- |
| 2370 | 3.1.3.31.2 | **Pleito RIDESOB02 - Construção de SES para o distrito de Jorge** |  | 496d | 2019-03-12 A | 2021-03-10 |  | 8% | 458.54d | 2019-03-12 | 2021-03-10 | 496d | 2019-03-12 | 2020-10-26 | 658d |  | Verde | Verde | 11% | 11 | 0% | Compensatória | Vermelho | 2% | 0% |  |  |  |  |  |  |
| 2371 | 3.1.3.31.2.1 | **Aprovação do Projeto** |  | 142d | 2019-03-12 A | 2019-10-02 |  | 25% | 106.5d | 2019-03-12 | 2019-10-02 | 142d | 2019-03-12 | 2019-07-15 | 658d |  | Verde | Verde | 39% | 39 | 0% | Compensatória | Vermelho | 19% | 0% | 19 |  |  |  |  |  |
| 2372 | 3.1.3.31.2.1.1 | Projeto de Rio Doce do Pleito RIDESOB02 - Construção de SES para o distrito de Jorge apresentado ao banco | milestone | 0d | 2019-03-12 A | 2019-03-12 A | 2358 | 100% |  | 2019-03-12 | 2019-03-12 | 0d | 2019-03-12 | 2019-03-12 |  |  | Verde | Verde | 100% | 100 | 100% | Compensatória | Verde | 100% | 100% | 100 | 100 | 100 | Município | 100 |  |
| 2373 | 3.1.3.31.2.1.2 | Analisar projeto |  | 142d | 2019-03-12 A | 2019-10-02 | 2372 | 25% | 106.5d | 2019-03-12 | 2019-10-02 | 142d | 2019-03-12 | 2019-05-16 | 658d | 0d | Verde | Verde | 58% | 58 | 0% | Compensatória | Vermelho | 58% | 0% | 58 | 13 |  | Banco |  | Conforme agendado |
| 2374 | 3.1.3.31.2.1.3 | Projeto de Rio Doce do Pleito RIDESOB02 - Construção de SES para o distrito de Jorge aprovado | milestone | 0d | 2019-10-02 | 2019-10-02 | 2373 |  |  | 2019-10-02 | 2019-10-02 | 0d | 2019-07-15 | 2019-07-15 | 658d | 0d | Verde | Verde | 0% |  | 0% | Compensatória | Verde | 0% | 0% |  |  |  | Município |  |  |
| 2375 | 3.1.3.31.2.2 | **Licitação da Obra** |  | 80d | 2019-10-02 | 2020-01-29 |  |  |  | 2019-10-02 | 2020-01-29 | 80d | 2019-07-15 | 2019-09-05 | 658d |  | Verde | Verde | 0% |  | 0% | Compensatória | Verde | 0% | 0% |  |  |  |  |  |  |
| 2376 | 3.1.3.31.2.2.1 | Licitação da obra de Rio Doce do Pleito RIDESOB02 - Construção de SES para o distrito de Jorge autorizada pelo banco | milestone | 0d | 2019-10-02 | 2019-10-02 | 2374 |  |  | 2019-10-02 | 2019-10-02 | 0d | 2019-07-15 | 2019-07-15 | 658d | 0d | Verde | Verde | 0% |  | 0% | Compensatória | Verde | 0% | 0% |  |  |  | Banco |  |  |
| 2377 | 3.1.3.31.2.2.2 | Licitar Obra |  | 66d | 2019-10-03 | 2020-01-09 | 2376 |  |  | 2019-10-03 | 2020-01-09 | 66d | 2019-07-16 | 2019-08-16 | 658d | 0d | Verde | Verde | 0% |  | 0% | Compensatória | Verde | 0% | 0% |  |  |  | Município |  |  |
| 2378 | 3.1.3.31.2.2.3 | Analisar e emitir resultado da licitação da obra |  | 14d | 2020-01-10 | 2020-01-29 | 2377 |  |  | 2020-01-10 | 2020-01-29 | 14d | 2019-08-19 | 2019-09-05 | 658d | 0d | Verde | Verde | 0% |  | 0% | Compensatória | Verde | 0% | 0% |  |  |  | Banco |  |  |
| 2379 | 3.1.3.31.2.2.4 | Licitação da obra de Rio Doce do Pleito RIDESOB02 - Construção de SES para o distrito de Jorge concluída | milestone | 0d | 2020-01-29 | 2020-01-29 | 2378 |  |  | 2020-01-29 | 2020-01-29 | 0d | 2019-09-05 | 2019-09-05 | 658d | 0d | Verde | Verde | 0% |  | 0% | Compensatória | Verde | 0% | 0% |  |  |  | Município |  |  |
| 2380 | 3.1.3.31.2.3 | Executar obra |  | 128d | 2020-03-04 | 2020-09-03 | 2379FS+21d |  |  | 2020-03-04 | 2020-09-03 | 128d | 2019-10-07 | 2020-04-14 | 658d | 0d | Verde | Verde | 0% |  | 0% | Compensatória | Verde | 0% | 0% |  |  |  | Município |  |  |
| 2381 | 3.1.3.31.2.4 | Realizar processo de pré-operação |  | 120d | 2020-09-04 | 2021-03-03 | 2380 |  |  | 2020-09-04 | 2021-03-03 | 120d | 2020-04-15 | 2020-10-19 | 658d | 0d | Verde | Verde | 0% |  | 0% | Compensatória | Verde | 0% | 0% |  |  |  | Município |  |  |
| 2382 | 3.1.3.31.2.5 | Recurso da obra de Rio Doce do Pleito RIDESOB02 - Construção de SES para o distrito de Jorge repassado | milestone | 0d | 2021-03-10 | 2021-03-10 | 2381FS+5d |  |  | 2021-03-10 | 2021-03-10 | 0d | 2020-10-26 | 2020-10-26 | 658d | 0d | Verde | Verde | 0% |  | 0% | Compensatória | Verde | 0% | 0% |  |  |  | Banco |  |  |
| 2383 | 3.1.3.31.2.6 | Pleito RIDESOB02 - Construção de SES para o distrito de Jorge de Rio Doce concluído | milestone | 0d | 2021-03-10 | 2021-03-10 | 2382 |  |  | 2021-03-10 | 2021-03-10 | 0d | 2020-10-26 | 2020-10-26 | 658d |  | Verde | Verde | 0% |  | 0% | Compensatória | Verde | 0% | 0% |  |  |  | Município |  |  |
| 2384 | 3.1.3.31.3 | **Pleito RIDESOB03 - Construção de SES para o distrito de São José de Entre Montes** |  | 434d | 2019-04-26 A | 2021-01-22 |  | 5% | 412.94d | 2019-04-26 | 2021-01-22 | 434d | 2019-05-31 | 2021-02-19 | 688d |  | Verde | Verde | 5% |  | 0% | Compensatória | Vermelho | 2% | 0% |  |  |  |  |  |  |
| 2385 | 3.1.3.31.3.1 | **Aprovação do Projeto** |  | 79d | 2019-04-26 A | 2019-08-20 |  | 25% | 59.25d | 2019-04-26 | 2019-08-20 | 79d | 2019-05-31 | 2019-08-30 | 688d |  | Verde | Verde | 30% | 30 | 0% | Compensatória | Vermelho | 25% | 0% | 25 | 12 |  |  |  |  |
| 2386 | 3.1.3.31.3.1.1 | Projeto de Rio Doce do pleito RIDESOB03 de Construção de SES para o distrito de São José de Entre Montes apresentado ao banco | milestone | 0d | 2019-04-26 A | 2019-04-26 A | 3052FS+91d | 100% |  | 2019-04-26 | 2019-04-26 | 0d | 2019-05-31 | 2019-05-31 |  |  | Verde | Verde | 100% | 100 | 100% | Compensatória | Verde | 100% | 100% | 100 | 100 | 100 | Município | 100 |  |
| 2387 | 3.1.3.31.3.1.2 | Analisar projeto |  | 79d | 2019-04-29 A | 2019-08-20 | 2386 | 25% | 59.25d | 2019-04-29 | 2019-08-20 | 79d | 2019-06-03 | 2019-07-03 | 688d | 0d | Verde | Verde | 63% | 63 | 0% | Compensatória | Vermelho | 63% | 0% | 63 | 25 |  | Banco |  | Conforme agendado |
| 2388 | 3.1.3.31.3.1.3 | Projeto de Rio Doce do pleito RIDESOB03 de Rio Doce de Construção de SES para distrito de São José de Entre Montes aprovado | milestone | 0d | 2019-08-20 | 2019-08-20 | 2387 |  |  | 2019-08-20 | 2019-08-20 | 0d | 2019-08-30 | 2019-08-30 | 688d | 0d | Verde | Verde | 0% |  | 0% | Compensatória | Verde | 0% | 0% |  |  |  | Município |  |  |
| 2389 | 3.1.3.31.3.2 | **Licitação da Obra** |  | 80d | 2019-08-20 | 2019-12-11 |  |  |  | 2019-08-20 | 2019-12-11 | 80d | 2019-08-30 | 2019-12-26 | 688d |  | Verde | Verde | 0% |  | 0% | Compensatória | Verde | 0% | 0% |  |  |  |  |  |  |
| 2390 | 3.1.3.31.3.2.1 | Licitação da obra de Rio Doce de Construção de SES para o distrito de São José de Entre Montes autorizada pelo banco | milestone | 0d | 2019-08-20 | 2019-08-20 | 2388 |  |  | 2019-08-20 | 2019-08-20 | 0d | 2019-08-30 | 2019-08-30 | 688d | 0d | Verde | Verde | 0% |  | 0% | Compensatória | Verde | 0% | 0% |  |  |  | Banco |  |  |
| 2391 | 3.1.3.31.3.2.2 | Licitar Obra |  | 66d | 2019-08-21 | 2019-11-21 | 2390 |  |  | 2019-08-21 | 2019-11-21 | 66d | 2019-09-02 | 2019-12-03 | 688d | 0d | Verde | Verde | 0% |  | 0% | Compensatória | Verde | 0% | 0% |  |  |  | Município |  | Critério FR |
| 2392 | 3.1.3.31.3.2.3 | Analisar e emitir resultado da licitação da obra |  | 14d | 2019-11-22 | 2019-12-11 | 2391 |  |  | 2019-11-22 | 2019-12-11 | 14d | 2019-12-04 | 2019-12-26 | 688d | 0d | Verde | Verde | 0% |  | 0% | Compensatória | Verde | 0% | 0% |  |  |  | Banco |  | Critério FR |
| 2393 | 3.1.3.31.3.2.4 | Licitação da obra de Rio Doce de Construção de SES para o distrito de São José de Entre Montes concluída | milestone | 0d | 2019-12-11 | 2019-12-11 | 2392 |  |  | 2019-12-11 | 2019-12-11 | 0d | 2019-12-26 | 2019-12-26 | 688d | 0d | Verde | Verde | 0% |  | 0% | Compensatória | Verde | 0% | 0% |  |  |  | Município |  |  |
| 2394 | 3.1.3.31.3.3 | Executar obra |  | 128d | 2020-01-17 | 2020-07-23 | 2393FS+22d |  |  | 2020-01-17 | 2020-07-23 | 128d | 2020-01-29 | 2020-08-04 | 688d | 0d | Verde | Verde | 0% |  | 0% | Compensatória | Verde | 0% | 0% |  |  |  | Município |  |  |
| 2395 | 3.1.3.31.3.4 | Realizar processo de pré-operação |  | 120d | 2020-07-24 | 2021-01-15 | 2394 |  |  | 2020-07-24 | 2021-01-15 | 120d | 2020-08-05 | 2021-02-09 | 688d | 0d | Verde | Verde | 0% |  | 0% | Compensatória | Verde | 0% | 0% |  |  |  | Município |  |  |
| 2396 | 3.1.3.31.3.5 | Recurso da obra de Rio Doce do pleito RIDESOB03 repassado | milestone | 0d | 2021-01-22 | 2021-01-22 | 2395FS+5d |  |  | 2021-01-22 | 2021-01-22 | 0d | 2021-02-19 | 2021-02-19 | 688d | 0d | Verde | Verde | 0% |  | 0% | Compensatória | Verde | 0% | 0% |  |  |  | Banco |  |  |
| 2397 | 3.1.3.31.3.6 | Pleito RIDESOB03 - Construção de SES para o distrito de São José de Entre Montes de Rio Doce concluído | milestone | 0d | 2021-01-22 | 2021-01-22 | 2396 |  |  | 2021-01-22 | 2021-01-22 | 0d | 2021-02-19 | 2021-02-19 | 688d |  | Verde | Verde | 0% |  | 0% | Compensatória | Verde | 0% | 0% |  |  |  | Município |  |  |

Notes:
- 2373: 22/05/2019: alterada a data de término para dia 24/05/2019 (fonte: e-mail Gislaine) / 27/05/2019: o município entregará as pendências solicitadas pela Eng. Andréa dia 24/05/2019 daqui 1 mês e o banco terá 1 mês para analisar as pendências recebidas.
- 2386: Em 25/04/2019: o município não apresentou o projeto ao banco, foi considerado que o projeto será apresentado dia 31/05/2019. / 21/05/2019: Município protocolou projeto para análise no BDMG no dia 26/04/2019 conforme planilha Controle Gerencial Renova
- 2387: 21/05/2019: dia 15/05/2019 o banco enviou e-mail ao município com algumas pendências. / 23/05/2019: Deiwid enviou e-mail em 20/05 com pendências para o Município. Aguardando retorno do município. (fonte: e-mail Gislaine) / 27/05/2019: 20/05/2019 o município respondeu e-mail com pendências solicitadas. Banco analisará o projeto até o dia 21/06/2019 / 01/07/2019: Eng. Andréa solicitou algumas pendências ao município no dia 28/06/2019. Município teria até o dia 29/07/2019 para dar um retorno

| ID | WBS | Task | Type | Duration | Start | Finish | Predecessors | Complete | Remaining | Baseline start | Baseline finish | Baseline duration | Baseline 1 start | Baseline 1 finish | Total slack | Free slack | Text1 | Text2 | Text3 | Text6 | Text8 | Text12 | Text14 | Text16 | Text9 | Text18 |
| --- | --- | --- | --- | --- | --- | --- | --- | --- | --- | --- | --- | --- | --- | --- | --- | --- | --- | --- | --- | --- | --- | --- | --- | --- | --- | --- |
| 2398 | 3.1.3.31.4 | **Pleito RIDRSPM01 - Elaboração do Plano Intermunicipal de Gestão Integrada de Resíduos Sólidos para os Municípios associados ao Consórcio Intermunicipal Multissetorial do Vale do Piranga (PIGIRS/CIMVALPI),** |  | 1082d | 2019-06-25 A | 2023-10-30 |  |  | 1082d | 2019-08-30 | 2023-10-30 | 1035d | 2019-08-30 | 2024-01-30 | 0d |  | Verde | Verde | 0% | 0% | Compensatória | Verde | 0% | 0% |  |  |
| 2399 | 3.1.3.31.4.1 | Pleito RIDRSPM01 - Elaboração do Plano Intermunicipal de Gestão Integrada de Resíduos Sólidos para os Municípios associados ao Consórcio Intermunicipal Multissetorial do Vale do Piranga (PIGIRS/CIMVALPI) de Rio Doce aprovado pelo CIF | milestone | 0d | 2019-06-25 A | 2019-06-25 A | 3042FS+236d | 100% |  | 2019-08-30 | 2019-08-30 | 0d | 2019-08-30 | 2019-08-30 |  |  | Verde | Verde | 0% | 0% | Compensatória | Verde | 0% | 0% | CT/CIF |  |
| 2400 | 3.1.3.31.4.2 | Iniciar serviço/projeto/obra do pleito de Rio Doce de Resíduos Sólidos a definir |  | 1d | 2019-09-02 | 2019-09-02 | 2399FS+47d |  |  | 2019-09-02 | 2019-09-02 | 1d | 2019-09-02 | 2019-09-02 | 0d |  | Verde | Verde | 0% | 0% | Compensatória | Verde | 0% | 0% | Município | Critério FR |
| 2401 | 3.1.3.31.4.3 | Pleito RIDRSPM01 - Elaboração do Plano Intermunicipal de Gestão Integrada de Resíduos Sólidos para os Municípios associados ao Consórcio Intermunicipal Multissetorial do Vale do Piranga (PIGIRS/CIMVALPI) de Rio Doce concluído | milestone | 0d | 2023-10-30 | 2023-10-30 | 2400FS+1034d |  |  | 2023-10-30 | 2023-10-30 | 0d | 2024-01-30 | 2024-01-30 | 0d |  | Verde | Verde | 0% | 0% | Compensatória | Verde | 0% | 0% | Município |  |
| 2402 | 3.1.3.31.5 | Recursos de Rio Doce repassados | milestone | 0d | 2023-10-30 | 2023-10-30 | 2369, 2383, 2397, 2401 |  |  | 2023-10-30 | 2023-10-30 | 0d | 2024-01-30 | 2024-01-30 | 0d |  | Verde | Verde | 0% | 0% | Compensatória | Verde | 0% | 0% | Banco |  |
| 2403 | 3.1.3.32 | **Santa Cruz do Escalvado** |  | 1082d | 2019-06-25 A | 2023-10-30 |  |  | 1082d | 2019-08-30 | 2023-10-30 | 1035d | 2019-08-30 | 2024-01-30 | 0d |  | Verde | Verde | 0% | 0% | Compensatória | Verde | 0% | 0% |  |  |
| 2404 | 3.1.3.32.1 | **Pleito SCEESPJ01 - Elaboração de projetos de engenharia para a sede do município, distritos de Nova Soberbo e Zito Soares, povoados de São José da Vargem Alegre e Sagrado Coração de Jesus e outras 32 comunidades rurais** |  | 349d | 2019-08-30 | 2021-01-26 |  |  |  | 2019-08-30 | 2021-01-26 | 349d | 2019-08-30 | 2021-01-26 | 210d |  | Verde | Verde | 0% | 0% | Compensatória | Verde | 0% | 0% |  |  |
| 2405 | 3.1.3.32.1.1 | Alteração do Pleito SCEESPJ01 - Elaboração de projetos de engenharia para a sede do município, distritos e comunidades rurais de Santa Cruz do Escalvado aprovada | milestone | 0d | 2019-08-30 | 2019-08-30 | 3052FS+178d |  |  | 2019-08-30 | 2019-08-30 | 0d | 2019-08-30 | 2019-08-30 | 210d | 0d | Verde | Verde | 0% | 0% | Compensatória | Verde | 0% | 0% | CT/CIF |  |
| 2406 | 3.1.3.32.1.2 | **Licitação do Projeto** |  | 61d | 2019-08-30 | 2019-11-26 |  |  |  | 2019-08-30 | 2019-11-26 | 61d | 2019-08-30 | 2019-11-26 | 210d |  | Verde | Verde | 0% | 0% | Compensatória | Verde | 0% | 0% |  |  |
| 2407 | 3.1.3.32.1.2.1 | Licitação do projeto de Santa Cruz do Escalvado do Pleito SCEESPJ01 - Elaboração de projetos de engenharia para a sede do município, distritos e comunidades rurais autorizada pelo banco | milestone | 0d | 2019-08-30 | 2019-08-30 | 2405 |  |  | 2019-08-30 | 2019-08-30 | 0d | 2019-08-30 | 2019-08-30 | 210d | 0d | Verde | Verde | 0% | 0% | Compensatória | Verde | 0% | 0% | Banco |  |
| 2408 | 3.1.3.32.1.2.2 | Licitar projeto |  | 42d | 2019-09-02 | 2019-10-29 | 2407 |  |  | 2019-09-02 | 2019-10-29 | 42d | 2019-09-02 | 2019-10-29 | 210d | 0d | Verde | Verde | 0% | 0% | Compensatória | Verde | 0% | 0% | Município | Critério FR |
| 2409 | 3.1.3.32.1.2.3 | Documentação de licitação de Santa Cruz do Escalvado do Pleito SCEESPJ01 - Elaboração de projetos de engenharia para a sede do município, distritos e comunidades rurais apresentada ao banco | milestone | 0d | 2019-11-05 | 2019-11-05 | 2408FS+5d |  |  | 2019-11-05 | 2019-11-05 | 0d | 2019-11-05 | 2019-11-05 | 210d | 0d | Verde | Verde | 0% | 0% | Compensatória | Verde | 0% | 0% | Município |  |
| 2410 | 3.1.3.32.1.2.4 | Analisar e emitir resultado da licitação do projeto |  | 14d | 2019-11-06 | 2019-11-26 | 2409 |  |  | 2019-11-06 | 2019-11-26 | 14d | 2019-11-06 | 2019-11-26 | 210d | 0d | Verde | Verde | 0% | 0% | Compensatória | Verde | 0% | 0% | Banco | Critério FR |
| 2411 | 3.1.3.32.1.2.5 | Licitação do projeto de Santa Cruz do Escalvado do Pleito SCEESPJ01 - Elaboração de projetos de engenharia para a sede do município, distritos e comunidades rurais concluída | milestone | 0d | 2019-11-26 | 2019-11-26 | 2410 |  |  | 2019-11-26 | 2019-11-26 | 0d | 2019-11-26 | 2019-11-26 | 210d | 0d | Verde | Verde | 0% | 0% | Compensatória | Verde | 0% | 0% | Município |  |
| 2412 | 3.1.3.32.1.3 | **Elaboração do Projeto Básico** |  | 136d | 2019-11-27 | 2020-06-18 |  |  |  | 2019-11-27 | 2020-06-18 | 136d | 2019-11-27 | 2020-06-18 | 210d |  | Verde | Verde | 0% | 0% | Compensatória | Verde | 0% | 0% |  |  |
| 2413 | 3.1.3.32.1.3.1 | Elaborar Projeto Básico |  | 64d | 2019-11-27 | 2020-03-04 | 2411 |  |  | 2019-11-27 | 2020-03-04 | 64d | 2019-11-27 | 2020-03-04 | 210d | 0d | Verde | Verde | 0% | 0% | Compensatória | Verde | 0% | 0% | Município |  |
| 2414 | 3.1.3.32.1.3.2 | Projeto básico de Santa Cruz do Escalvado do Pleito SCEESPJ01 - Elaboração de projetos de engenharia para a sede do município, distritos e comunidades rurais apresentado ao banco | milestone | 0d | 2020-03-04 | 2020-03-04 | 2413 |  |  | 2020-03-04 | 2020-03-04 | 0d | 2020-03-04 | 2020-03-04 | 210d | 0d | Verde | Verde | 0% | 0% | Compensatória | Verde | 0% | 0% | Município |  |
| 2415 | 3.1.3.32.1.3.3 | Analisar projeto básico |  | 67d | 2020-03-05 | 2020-06-10 | 2414 |  |  | 2020-03-05 | 2020-06-10 | 67d | 2020-03-05 | 2020-04-02 | 210d | 0d | Verde | Verde | 0% | 0% | Compensatória | Verde | 0% | 0% | Banco |  |
| 2416 | 3.1.3.32.1.3.4 | Projeto básico de Santa Cruz do Escalvado do Pleito SCEESPJ01 - Elaboração de projetos de engenharia para a sede do município, distritos e comunidades rurais concluído | milestone | 0d | 2020-06-10 | 2020-06-10 | 2415 |  |  | 2020-06-10 | 2020-06-10 | 0d | 2020-06-10 | 2020-06-10 | 210d | 0d | Verde | Verde | 0% | 0% | Compensatória | Verde | 0% | 0% | Município |  |
| 2417 | 3.1.3.32.1.3.5 | Recurso do projeto básico de Santa Cruz do Escalvado do Pleito SCEESPJ01 - Elaboração de projetos de engenharia para a sede do município, distritos e comunidades rurais repassado | milestone | 0d | 2020-06-18 | 2020-06-18 | 2416FS+5d |  |  | 2020-06-18 | 2020-06-18 | 0d | 2020-06-18 | 2020-06-18 | 357d | 147d | Verde | Verde | 0% | 0% | Compensatória | Verde | 0% | 0% | Banco |  |
| 2418 | 3.1.3.32.1.4 | Realizar Licenciamento Ambiental |  | 147d | 2019-09-02 | 2020-04-03 | 2407 |  |  | 2019-09-02 | 2020-04-03 | 147d | 2019-09-02 | 2020-04-03 | 407d | 197d | Verde | Verde | 0% | 0% | Compensatória | Verde | 0% | 0% | Município |  |
| 2419 | 3.1.3.32.1.5 | **Elaboração do Projeto Executivo** |  | 157d | 2020-06-12 | 2021-01-26 |  |  |  | 2020-06-12 | 2021-01-26 | 157d | 2020-06-12 | 2021-01-26 | 210d |  | Verde | Verde | 0% | 0% | Compensatória | Verde | 0% | 0% |  |  |
| 2420 | 3.1.3.32.1.5.1 | Elaborar Projeto Executivo |  | 87d | 2020-06-12 | 2020-10-14 | 2416 |  |  | 2020-06-12 | 2020-10-14 | 87d | 2020-06-12 | 2020-10-14 | 210d | 0d | Verde | Verde | 0% | 0% | Compensatória | Verde | 0% | 0% | Município |  |
| 2421 | 3.1.3.32.1.5.2 | Projeto executivo de Santa Cruz do Escalvado do Pleito SCEESPJ01 - Elaboração de projetos de engenharia para a sede do município, distritos e comunidades rurais apresentado ao banco | milestone | 0d | 2020-10-14 | 2020-10-14 | 2420 |  |  | 2020-10-14 | 2020-10-14 | 0d | 2020-10-14 | 2020-10-14 | 210d | 0d | Verde | Verde | 0% | 0% | Compensatória | Verde | 0% | 0% | Município |  |
| 2422 | 3.1.3.32.1.5.3 | Analisar projeto executivo |  | 65d | 2020-10-15 | 2021-01-19 | 2421 |  |  | 2020-10-15 | 2021-01-19 | 65d | 2020-10-15 | 2020-11-13 | 210d | 0d | Verde | Verde | 0% | 0% | Compensatória | Verde | 0% | 0% | Banco |  |
| 2423 | 3.1.3.32.1.5.4 | Projeto executivo de Santa Cruz do Escalvado do Pleito SCEESPJ01 - Elaboração de projetos de engenharia para a sede do município, distritos e comunidades rurais concluído | milestone | 0d | 2021-01-19 | 2021-01-19 | 2417, 2418, 2422 |  |  | 2021-01-19 | 2021-01-19 | 0d | 2021-01-19 | 2021-01-19 | 210d | 0d | Verde | Verde | 0% | 0% | Compensatória | Verde | 0% | 0% | Município |  |
| 2424 | 3.1.3.32.1.5.5 | Recurso do projeto executivo de Santa Cruz do Escalvado do Pleito SCEESPJ01 - Elaboração de projetos de engenharia para a sede do município, distritos e comunidades rurais repassado | milestone | 0d | 2021-01-26 | 2021-01-26 | 2423FS+5d |  |  | 2021-01-26 | 2021-01-26 | 0d | 2021-01-26 | 2021-01-26 | 210d | 0d | Verde | Verde | 0% | 0% | Compensatória | Verde | 0% | 0% | Banco |  |
| 2425 | 3.1.3.32.1.6 | Pleito SCEESPJ01 - Elaboração de projetos de engenharia para a sede do município, distritos de Nova Soberbo e Zito Soares, povoados de São José da Vargem Alegre e Sagrado Coração de Jesus e outras 32 comunidades rurais de Santa Cruz do Escalvado concluído | milestone | 0d | 2021-01-26 | 2021-01-26 | 2424 |  |  | 2021-01-26 | 2021-01-26 | 0d | 2021-01-26 | 2021-01-26 | 210d | 0d | Verde | Verde | 0% | 0% | Compensatória | Verde | 0% | 0% | Município |  |

Notes:
- 2402: Valor de recurso destinado ao munícipio: R$2.661.115,58
- 2403: Santa Cruz do Escalvado teve 100% dos pleitos de Esgotamento Sanitário aprovado (R$4.254.293,75), conforme Deliberação 75. / O município teve o pleito de resíduos sólidos negado (R$472.699,31, equivalente a 10% do total do recurso). / O município ainda possui dúvidas se irá atender a todas localidades listadas no pleito atualmente aprovado pelo CIF. Munícipio deverá estabelecer as áreas prioritarias de atendimento do programa e rever o pleito.
- 2405: Em 25/04/2019: o município não enviou ofício de alteração de pleito até o momento, por isso considerou-se que o pleito será enviado no mês que vem e só será analisado pela CT/CIF em agosto conforme NT 33

| ID | WBS | Task | Type | Duration | Start | Finish | Predecessors | Complete | Remaining | Baseline start | Baseline finish | Baseline duration | Baseline 1 start | Baseline 1 finish | Total slack | Free slack | Text1 | Text2 | Text3 | Text6 | Text8 | Text12 | Text14 | Text16 | Text9 | Text18 | Text5 | Text4 | Text7 | Text15 | Text17 |
| --- | --- | --- | --- | --- | --- | --- | --- | --- | --- | --- | --- | --- | --- | --- | --- | --- | --- | --- | --- | --- | --- | --- | --- | --- | --- | --- | --- | --- | --- | --- | --- |
| 2426 | 3.1.3.32.2 | **Pleito SCEESOB01 - Execução da obra dos SES que serão projetados com os recursos destinados à prioridade 1** |  | 476d | 2021-01-26 | 2022-12-26 |  |  |  | 2021-01-26 | 2022-12-26 | 476d | 2021-01-26 | 2022-12-19 | 210d |  | Verde | Verde | 0% | 0% | Compensatória | Verde | 0% | 0% |  |  |  |  |  |  |  |
| 2427 | 3.1.3.32.2.1 | **Licitação da Obra** |  | 79d | 2021-01-26 | 2021-05-24 |  |  |  | 2021-01-26 | 2021-05-24 | 79d | 2021-01-26 | 2021-05-24 | 210d |  | Verde | Verde | 0% | 0% | Compensatória | Verde | 0% | 0% |  |  |  |  |  |  |  |
| 2428 | 3.1.3.32.2.1.1 | Licitação da obra de Santa Cruz do Escalvado do Pleito SCEESOB01 - Execução da obra dos SES que serão projetados com os recursos destinados à prioridade 1 autorizada pelo banco | milestone | 0d | 2021-01-26 | 2021-01-26 | 2425 |  |  | 2021-01-26 | 2021-01-26 | 0d | 2021-01-26 | 2021-01-26 | 210d | 0d | Verde | Verde | 0% | 0% | Compensatória | Verde | 0% | 0% | Banco |  |  |  |  |  |  |
| 2429 | 3.1.3.32.2.1.2 | Licitar Obra |  | 65d | 2021-01-27 | 2021-05-04 | 2428 |  |  | 2021-01-27 | 2021-05-04 | 65d | 2021-01-27 | 2021-05-04 | 210d | 0d | Verde | Verde | 0% | 0% | Compensatória | Verde | 0% | 0% | Município |  |  |  |  |  |  |
| 2430 | 3.1.3.32.2.1.3 | Analisar e emitir resultado da licitação da obra |  | 14d | 2021-05-05 | 2021-05-24 | 2429 |  |  | 2021-05-05 | 2021-05-24 | 14d | 2021-05-05 | 2021-05-24 | 210d | 0d | Verde | Verde | 0% | 0% | Compensatória | Verde | 0% | 0% | Banco |  |  |  |  |  |  |
| 2431 | 3.1.3.32.2.1.4 | Licitação da obra de Santa Cruz do Escalvado do Pleito SCEESOB01 - Execução da obra dos SES que serão projetados com os recursos destinados à prioridade 1 concluída | milestone | 0d | 2021-05-24 | 2021-05-24 | 2430 |  |  | 2021-05-24 | 2021-05-24 | 0d | 2021-05-24 | 2021-05-24 | 210d | 0d | Verde | Verde | 0% | 0% | Compensatória | Verde | 0% | 0% | Município |  |  |  |  |  |  |
| 2432 | 3.1.3.32.2.2 | Executar obra |  | 251d | 2021-06-24 | 2022-06-24 | 2431FS+21d |  |  | 2021-06-24 | 2022-06-24 | 251d | 2021-05-25 | 2022-06-02 | 210d | 0d | Verde | Verde | 0% | 0% | Compensatória | Verde | 0% | 0% | Município |  |  |  |  |  |  |
| 2433 | 3.1.3.32.2.3 | Realizar processo de pré-operação |  | 120d | 2022-06-27 | 2022-12-19 | 2432 |  |  | 2022-06-27 | 2022-12-19 | 120d | 2022-06-03 | 2022-12-09 | 210d | 0d | Verde | Verde | 0% | 0% | Compensatória | Verde | 0% | 0% | Município |  |  |  |  |  |  |
| 2434 | 3.1.3.32.2.4 | Recurso da obra de Santa Cruz do Escalvado do Pleito SCEESOB01 - Execução da obra dos SES que serão projetados com os recursos destinados à prioridade 1 repassado | milestone | 0d | 2022-12-26 | 2022-12-26 | 2433FS+5d |  |  | 2022-12-26 | 2022-12-26 | 0d | 2022-12-19 | 2022-12-19 | 210d | 0d | Verde | Verde | 0% | 0% | Compensatória | Verde | 0% | 0% | Banco |  |  |  |  |  |  |
| 2435 | 3.1.3.32.2.5 | Pleito SCEESOB01 - Execução da obra dos SES que serão projetados com os recursos destinados à prioridade 1 de Santa Cruz do Escalvado concluído | milestone | 0d | 2022-12-26 | 2022-12-26 | 2434 |  |  | 2022-12-26 | 2022-12-26 | 0d | 2022-12-19 | 2022-12-19 | 210d |  | Verde | Verde | 0% | 0% | Compensatória | Verde | 0% | 0% | Município |  |  |  |  |  |  |
| 2436 | 3.1.3.32.3 | **Pleito SCERSPM01 - Elaboração do Plano Intermunicipal de Gestão Integrada de Resíduos Sólidos para os Municípios associados ao Consórcio Intermunicipal Multissetorial do Vale do Piranga (PIGIRS/CIMVALPI),** |  | 1082d | 2019-06-25 A | 2023-10-30 |  |  | 1082d | 2019-08-30 | 2023-10-30 | 1035d | 2019-08-30 | 2024-01-30 | 0d |  | Verde | Verde | 0% | 0% | Compensatória | Verde | 0% | 0% |  |  |  |  |  |  |  |
| 2437 | 3.1.3.32.3.1 | Pleito SCERSPM01 - Elaboração do Plano Intermunicipal de Gestão Integrada de Resíduos Sólidos para os Municípios associados ao Consórcio Intermunicipal Multissetorial do Vale do Piranga (PIGIRS/CIMVALPI) de Santa Cruz do Escalvado aprovado pelo CIF | milestone | 0d | 2019-06-25 A | 2019-06-25 A | 3043FS+204d | 100% |  | 2019-08-30 | 2019-08-30 | 0d | 2019-08-30 | 2019-08-30 |  |  | Verde | Verde | 0% | 0% | Compensatória | Verde | 0% | 0% | CT/CIF |  |  |  |  |  |  |
| 2438 | 3.1.3.32.3.2 | Iniciar serviço/projeto/obra do pleito de Santa Cruz do Escalvado de Resíduos Sólidos a definir |  | 1d | 2019-09-02 | 2019-09-02 | 2437FS+47d |  |  | 2019-09-02 | 2019-09-02 | 1d | 2019-09-02 | 2019-09-02 | 0d |  | Verde | Verde | 0% | 0% | Compensatória | Verde | 0% | 0% | Município | Critério FR |  |  |  |  |  |
| 2439 | 3.1.3.32.3.3 | Pleito SCERSPM01 - Elaboração do Plano Intermunicipal de Gestão Integrada de Resíduos Sólidos para os Municípios associados ao Consórcio Intermunicipal Multissetorial do Vale do Piranga (PIGIRS/CIMVALPI) de Santa Cruz do Escalvado concluído | milestone | 0d | 2023-10-30 | 2023-10-30 | 2438FS+1034d |  |  | 2023-10-30 | 2023-10-30 | 0d | 2024-01-30 | 2024-01-30 | 0d |  | Verde | Verde | 0% | 0% | Compensatória | Verde | 0% | 0% | Município |  |  |  |  |  |  |
| 2440 | 3.1.3.32.4 | Recursos de Santa Cruz do Escalvado repassados | milestone | 0d | 2023-10-30 | 2023-10-30 | 2425, 2435, 2439 |  |  | 2023-10-30 | 2023-10-30 | 0d | 2024-01-30 | 2024-01-30 | 0d |  | Verde | Verde | 0% | 0% | Compensatória | Verde | 0% | 0% | Banco |  |  |  |  |  |  |
| 2441 | 3.1.3.33 | **Santana do Paraíso** |  | 1250d | 2018-08-22 A | 2023-08-25 |  | 5% | 1190.73d | 2018-08-22 | 2023-08-25 | 1250d | 2018-08-22 | 2023-09-12 | 44d |  | Verde | Verde | 15% | 0% | Compensatória | Vermelho | 0% | 0% |  |  | 15 |  |  |  |  |
| 2442 | 3.1.3.33.1 | **Pleito SAPESPJ01 - Elaboração/adequação de projetos de engenharia para a prestação dos serviços de esgotamento sanitário nas localidades de Santana do Paráiso** |  | 416d | 2019-04-23 A | 2020-12-21 |  | 4% | 400.1d | 2019-04-23 | 2020-12-21 | 416d | 2019-04-23 | 2020-12-28 | 44d |  | Verde | Verde | 6% | 0% | Compensatória | Vermelho | 1% | 0% |  |  |  |  |  |  |  |
| 2443 | 3.1.3.33.1.1 | Alteração do Pleito SAPESPJ01 - Elaboração/adequação de projetos de engenharia para a prestação dos serviços de esgotamento sanitário nas localidades de Santana do Paráiso aprovada | milestone | 0d | 2019-04-23 A | 2019-04-23 A | 3052FS+88d | 100% |  | 2019-04-23 | 2019-04-23 | 0d | 2019-04-23 | 2019-04-23 |  |  | Verde | Verde | 100% | 100% | Compensatória | Verde | 100% | 100% | CT/CIF |  | 100 | 100 | 100 | 100 | 100 |
| 2444 | 3.1.3.33.1.2 | **Licitação do Projeto** |  | 117d | 2019-05-13 A | 2019-10-25 |  | 22% | 91.41d | 2019-05-13 | 2019-10-25 | 117d | 2019-05-08 | 2019-09-06 | 44d |  | Verde | Verde | 11% | 0% | Compensatória | Vermelho | 11% | 0% |  |  | 11 | 13 |  | 11 |  |
| 2445 | 3.1.3.33.1.2.1 | Licitação do projeto do Pleito SAPESPJ01 - Elaboração/adequação de projetos de engenharia para a prestação dos serviços de esgotamento sanitário nas localidades de Santana do Paráiso autorizada pelo banco | milestone | 0d | 2019-05-13 A | 2019-05-13 A | 2443FS+13d | 100% |  | 2019-05-13 | 2019-05-13 | 0d | 2019-05-08 | 2019-05-08 |  |  | Verde | Verde | 100% | 100% | Compensatória | Verde | 100% | 100% | Banco |  | 100 | 100 | 100 | 100 | 100 |
| 2446 | 3.1.3.33.1.2.2 | Licitar projeto |  | 98d | 2019-05-14 A | 2019-09-30 | 2445 | 25% | 73.5d | 2019-05-14 | 2019-09-30 | 98d | 2019-05-09 | 2019-08-09 | 44d | 0d | Verde | Verde | 14% | 0% | Compensatória | Vermelho | 14% | 0% | Município | Conforme agendado | 14 | 14 |  | 14 |  |
| 2447 | 3.1.3.33.1.2.3 | Documentação de licitação do Pleito SAPESPJ01 - Elaboração/adequação de projetos de engenharia para a prestação dos serviços de esgotamento sanitário nas localidades de Santana do Paráiso apresentada ao banco | milestone | 0d | 2019-10-07 | 2019-10-07 | 2446FS+5d |  |  | 2019-10-07 | 2019-10-07 | 0d | 2019-08-19 | 2019-08-19 | 44d | 0d | Verde | Verde | 0% | 0% | Compensatória | Verde | 0% | 0% | Município |  |  |  |  |  |  |
| 2448 | 3.1.3.33.1.2.4 | Analisar e emitir resultado da licitação do projeto |  | 14d | 2019-10-08 | 2019-10-25 | 2447 |  |  | 2019-10-08 | 2019-10-25 | 14d | 2019-08-20 | 2019-09-06 | 44d | 0d | Verde | Verde | 0% | 0% | Compensatória | Verde | 0% | 0% | Banco | Critério FR |  |  |  |  |  |
| 2449 | 3.1.3.33.1.2.5 | Licitação do projeto do Pleito SAPESPJ01 - Elaboração/adequação de projetos de engenharia para a prestação dos serviços de esgotamento sanitário nas localidades de Santana do Paráiso concluída | milestone | 0d | 2019-10-25 | 2019-10-25 | 2448 |  |  | 2019-10-25 | 2019-10-25 | 0d | 2019-09-06 | 2019-09-06 | 44d | 0d | Verde | Verde | 0% | 0% | Compensatória | Verde | 0% | 0% | Município |  |  |  |  |  |  |

Notes:
- 2440: Valor de recurso destinado ao munícipio: R$4.726.993,07
- 2441: Santana do Paraíso teve 100% dos pleitos de Esgotamento Sanitário Aprovado (R$11.338.753,82), conforme Deliberação 75. / O município teve 2,4%, dos 10% do valor teto destinado a Resíduos Sólidos aprovado (R$300.000,00). / Santana do Paraíso solicitou mudança de pleito, mas ainda não foi autorizado pelo CIF. / · Substituição da execução do Sistema de Esgotamento Sanitário na Bacia do Córrego do Garrafa para Sede.
- 2443: Em 25/04/2019: pleito aprovado na deliberação 276 no dia 23/04/2019
- 2445: 21/05/2019: o banco autorizou a licitação do projeto dia 13/05/2019 conforme planilha controle gerencial Renova - aba pleitos - coluna data de status do pleito.
- 2446: 21/05/2019: conferir com município data de início e término da tarefa na reunião de atualização do cronograma / 02/07/2019: o município solicitou ajuda do apoio técnico para elaboração do TR.

| ID | WBS | Task | Type | Duration | Start | Finish | Predecessors | Baseline start | Baseline finish | Baseline duration | Baseline 1 start | Baseline 1 finish | Total slack | Free slack | Text1 | Text2 | Text3 | Text6 | Text8 | Text12 | Text14 | Text16 | Text9 |
| --- | --- | --- | --- | --- | --- | --- | --- | --- | --- | --- | --- | --- | --- | --- | --- | --- | --- | --- | --- | --- | --- | --- | --- |
| 2450 | 3.1.3.33.1.3 | **Elaboração do Estudo de Concepção** |  | 125d | 2019-10-28 | 2020-05-04 |  | 2019-10-28 | 2020-05-04 | 125d |  |  | 44d |  | Verde | Verde | 0% | 0% | Compensatória | Verde | 0% | 0% |  |
| 2451 | 3.1.3.33.1.3.1 | Elaborar estudo |  | 60d | 2019-10-28 | 2020-01-24 | 2449 | 2019-10-28 | 2020-01-24 | 60d |  |  | 44d | 0d | Verde | Verde | 0% | 0% | Compensatória | Verde | 0% | 0% |  |
| 2452 | 3.1.3.33.1.3.2 | Estudo do Pleito SAPESPJ01 - Elaboração/adequação de projetos de engenharia para a prestação dos serviços de esgotamento sanitário nas localidades de Santana do Paráiso apresentado ao banco | milestone | 0d | 2020-01-24 | 2020-01-24 | 2451 | 2020-01-24 | 2020-01-24 | 0d |  |  | 109d | 0d | Verde | Verde | 0% | 0% | Compensatória | Verde | 0% | 0% |  |
| 2453 | 3.1.3.33.1.3.3 | Analisar estudo |  | 60d | 2020-01-27 | 2020-04-24 | 2452 | 2020-01-27 | 2020-04-24 | 60d |  |  | 109d | 0d | Verde | Verde | 0% | 0% | Compensatória | Verde | 0% | 0% |  |
| 2454 | 3.1.3.33.1.3.4 | Estudo do Pleito SAPESPJ01 - Elaboração/adequação de projetos de engenharia para a prestação dos serviços de esgotamento sanitário nas localidades de Santana do Paráiso concluído | milestone | 0d | 2020-04-24 | 2020-04-24 | 2453 | 2020-04-24 | 2020-04-24 | 0d |  |  | 195d | 0d | Verde | Verde | 0% | 0% | Compensatória | Verde | 0% | 0% |  |
| 2455 | 3.1.3.33.1.3.5 | Recurso do estudo do Pleito SAPESPJ01 - Elaboração/adequação de projetos de engenharia para a prestação dos serviços de esgotamento sanitário nas localidades de Santana do Paráiso repassado | milestone | 0d | 2020-05-04 | 2020-05-04 | 2454FS+5d | 2020-05-04 | 2020-05-04 | 0d |  |  | 195d | 56d | Verde | Verde | 0% | 0% | Compensatória | Verde | 0% | 0% |  |
| 2456 | 3.1.3.33.1.4 | **Elaboração do Projeto Básico** |  | 126d | 2020-01-27 | 2020-07-29 |  | 2020-01-27 | 2020-07-29 | 126d | 2019-09-09 | 2020-05-19 | 44d |  | Verde | Verde | 0% | 0% | Compensatória | Verde | 0% | 0% |  |
| 2457 | 3.1.3.33.1.4.1 | Elaborar Projeto Básico |  | 60d | 2020-01-27 | 2020-04-24 | 2451 | 2020-01-27 | 2020-04-24 | 60d | 2019-09-09 | 2020-02-07 | 44d | 0d | Verde | Verde | 0% | 0% | Compensatória | Verde | 0% | 0% | Município |
| 2458 | 3.1.3.33.1.4.2 | Projeto básico do Pleito SAPESPJ01 - Elaboração/adequação de projetos de engenharia para a prestação dos serviços de esgotamento sanitário nas localidades de Santana do Paráiso apresentado ao banco | milestone | 0d | 2020-04-24 | 2020-04-24 | 2457 | 2020-04-24 | 2020-04-24 | 0d | 2020-02-07 | 2020-02-07 | 44d | 0d | Verde | Verde | 0% | 0% | Compensatória | Verde | 0% | 0% | Município |
| 2459 | 3.1.3.33.1.4.3 | Analisar projeto básico |  | 61d | 2020-04-27 | 2020-07-22 | 2458 | 2020-04-27 | 2020-07-22 | 61d | 2020-02-10 | 2020-03-10 | 139d | 0d | Verde | Verde | 0% | 0% | Compensatória | Verde | 0% | 0% | Banco |
| 2460 | 3.1.3.33.1.4.4 | Projeto básico do Pleito SAPESPJ01 - Elaboração/adequação de projetos de engenharia para a prestação dos serviços de esgotamento sanitário nas localidades de Santana do Paráiso concluído | milestone | 0d | 2020-07-22 | 2020-07-22 | 2455, 2459 | 2020-07-22 | 2020-07-22 | 0d | 2020-05-12 | 2020-05-12 | 139d | 0d | Verde | Verde | 0% | 0% | Compensatória | Verde | 0% | 0% | Município |
| 2461 | 3.1.3.33.1.4.5 | Recurso do projeto básico do Pleito SAPESPJ01 - Elaboração/adequação de projetos de engenharia para a prestação dos serviços de esgotamento sanitário nas localidades de Santana do Paráiso repassado | milestone | 0d | 2020-07-29 | 2020-07-29 | 2460FS+5d | 2020-07-29 | 2020-07-29 | 0d | 2020-05-19 | 2020-05-19 | 139d | 95d | Verde | Verde | 0% | 0% | Compensatória | Verde | 0% | 0% | Banco |
| 2462 | 3.1.3.33.1.5 | Realizar Licenciamento Ambiental |  | 161d | 2020-04-27 | 2020-12-14 | 2458 | 2020-04-27 | 2020-12-14 | 161d | 2020-02-10 | 2020-10-01 | 44d | 0d | Verde | Verde | 0% | 0% | Compensatória | Verde | 0% | 0% | Município |
| 2463 | 3.1.3.33.1.6 | **Elaboração do Projeto Executivo** |  | 166d | 2020-04-27 | 2020-12-21 |  | 2020-04-27 | 2020-12-21 | 166d | 2020-05-13 | 2020-12-28 | 44d |  | Verde | Verde | 0% | 0% | Compensatória | Verde | 0% | 0% |  |
| 2464 | 3.1.3.33.1.6.1 | Elaborar Projeto Executivo |  | 60d | 2020-04-27 | 2020-07-21 | 2457 | 2020-04-27 | 2020-07-21 | 60d | 2020-05-13 | 2020-09-11 | 78d | 0d | Verde | Verde | 0% | 0% | Compensatória | Verde | 0% | 0% | Município |
| 2465 | 3.1.3.33.1.6.2 | Projeto executivo do Pleito SAPESPJ01 - Elaboração/adequação de projetos de engenharia para a prestação dos serviços de esgotamento sanitário nas localidades de Santana do Paráiso apresentado ao banco | milestone | 0d | 2020-07-21 | 2020-07-21 | 2464 | 2020-07-21 | 2020-07-21 | 0d | 2020-09-11 | 2020-09-11 | 78d | 0d | Verde | Verde | 0% | 0% | Compensatória | Verde | 0% | 0% | Município |
| 2466 | 3.1.3.33.1.6.3 | Analisar projeto executivo |  | 67d | 2020-07-22 | 2020-10-26 | 2465 | 2020-07-22 | 2020-10-26 | 67d | 2020-09-14 | 2020-10-14 | 78d | 34d | Verde | Verde | 0% | 0% | Compensatória | Verde | 0% | 0% | Banco |
| 2467 | 3.1.3.33.1.6.4 | Projeto executivo Pleito SAPESPJ01 - Elaboração/adequação de projetos de engenharia para a prestação dos serviços de esgotamento sanitário nas localidades de Santana do Paráiso concluído | milestone | 0d | 2020-12-14 | 2020-12-14 | 2472, 2462, 2461, 2466 | 2020-12-14 | 2020-12-14 | 0d | 2020-12-17 | 2020-12-17 | 44d | 0d | Verde | Verde | 0% | 0% | Compensatória | Verde | 0% | 0% | Município |
| 2468 | 3.1.3.33.1.6.5 | Recurso do projeto executivo do Pleito SAPESPJ01 - Elaboração/adequação de projetos de engenharia para a prestação dos serviços de esgotamento sanitário nas localidades de Santana do Paráiso repassado | milestone | 0d | 2020-12-21 | 2020-12-21 | 2467FS+5d | 2020-12-21 | 2020-12-21 | 0d | 2020-12-28 | 2020-12-28 | 44d | 0d | Verde | Verde | 0% | 0% | Compensatória | Verde | 0% | 0% | Banco |
| 2469 | 3.1.3.33.1.7 | Pleito SAPESPJ01 - Elaboração/adequação de projetos de engenharia para a prestação dos serviços de esgotamento sanitário nas localidades de Santana do Paráiso concluído | milestone | 0d | 2020-12-21 | 2020-12-21 | 2468 | 2020-12-21 | 2020-12-21 | 0d | 2020-12-28 | 2020-12-28 | 44d | 0d | Verde | Verde | 0% | 0% | Compensatória | Verde | 0% | 0% | Município |
| 2470 | 3.1.3.33.2 | **Pleito Santana do Paraíso a definir - Aquisição de Terreno** |  | 137d | 2020-02-21 | 2020-09-10 |  | 2020-02-21 | 2020-09-10 | 136d | 2020-05-29 | 2020-12-11 | 109d |  | Verde | Verde | 0% | 0% | Compensatória | Verde | 0% | 0% |  |
| 2471 | 3.1.3.33.2.1 | Pleito de Santana do Paraíso a definir - Aquisição de Terreno aprovado | milestone | 0d | 2020-02-21 | 2020-02-21 | 2453FS-41d | 2020-02-21 | 2020-02-21 | 0d | 2020-05-29 | 2020-05-29 | 109d | 0d | Verde | Verde | 0% | 0% | Compensatória | Verde | 0% | 0% | CT/CIF |
| 2472 | 3.1.3.33.2.2 | **Aquisição de Imóvel** |  | 126d | 2020-03-12 | 2020-09-10 |  | 2020-03-12 | 2020-09-10 | 126d | 2020-06-16 | 2020-12-11 | 109d | 65d | Verde | Verde | 0% | 0% | Compensatória | Verde | 0% | 0% |  |
| 2473 | 3.1.3.33.2.2.1 | Regularizar terreno e apresentar escritura ao banco |  | 78d | 2020-03-12 | 2020-07-03 | 2471FS+11d | 2020-03-12 | 2020-07-03 | 78d | 2020-06-16 | 2020-10-02 | 109d | 0d | Verde | Verde | 0% | 0% | Compensatória | Verde | 0% | 0% | Município |
| 2474 | 3.1.3.33.2.2.2 | Analisar documentação do terreno |  | 10d | 2020-07-06 | 2020-07-17 | 2473 | 2020-07-06 | 2020-07-17 | 10d | 2020-10-05 | 2020-10-19 | 147d | 0d | Verde | Verde | 0% | 0% | Compensatória | Verde | 0% | 0% | Banco |
| 2475 | 3.1.3.33.2.2.3 | 50% do valor do imóvel do pleito de Santana do Paraíso a definir - Aquisição de Terreno repassado | milestone | 0d | 2020-07-17 | 2020-07-17 | 2474 | 2020-07-17 | 2020-07-17 | 0d | 2020-10-19 | 2020-10-19 | 147d | 38d | Verde | Verde | 0% | 0% | Compensatória | Verde | 0% | 0% | Banco |
| 2476 | 3.1.3.33.2.2.4 | Registrar imóvel e apresentar documentação ao banco |  | 38d | 2020-07-06 | 2020-08-26 | 2473 | 2020-07-06 | 2020-08-26 | 38d | 2020-10-05 | 2020-11-27 | 109d | 0d | Verde | Verde | 0% | 0% | Compensatória | Verde | 0% | 0% | Município |
| 2477 | 3.1.3.33.2.2.5 | Analisar documentação do terreno |  | 10d | 2020-08-27 | 2020-09-10 | 2476 | 2020-08-27 | 2020-09-10 | 10d | 2020-11-30 | 2020-12-11 | 109d | 0d | Verde | Verde | 0% | 0% | Compensatória | Verde | 0% | 0% | Banco |
| 2478 | 3.1.3.33.2.2.6 | 50% do valor do imóvel do pleito de Santana do Paraíso a definir - Aquisição de Terreno a definir repassado | milestone | 0d | 2020-09-10 | 2020-09-10 | 2477 | 2020-09-10 | 2020-09-10 | 0d | 2020-12-11 | 2020-12-11 | 109d | 0d | Verde | Verde | 0% | 0% | Compensatória | Verde | 0% | 0% | Banco |
| 2479 | 3.1.3.33.2.2.7 | Aquisição de imóvel do pleito de Santana do Paraáiso a definir - Aquisição de Terreno concluída | milestone | 0d | 2020-09-10 | 2020-09-10 | 2478, 2475 | 2020-09-10 | 2020-09-10 | 0d | 2020-12-11 | 2020-12-11 | 109d | 0d | Verde | Verde | 0% | 0% | Compensatória | Verde | 0% | 0% | Município |
| 2480 | 3.1.3.33.2.3 | Pleito Santana do Paraíso a definir - Aquisição de Terreno concluído | milestone | 0d | 2020-09-10 | 2020-09-10 | 2479 | 2020-09-10 | 2020-09-10 | 0d | 2020-12-11 | 2020-12-11 | 779d | 735d | Verde | Verde | 0% | 0% | Compensatória | Verde | 0% | 0% | Município |

Notes:
- 2471: Em 25/04/2019: pleito aprovado no final de maio de 2020 conforme NT 33.

| ID | WBS | Task | Type | Duration | Start | Finish | Predecessors | Complete | Remaining | Baseline start | Baseline finish | Baseline duration | Baseline 1 start | Baseline 1 finish | Total slack | Free slack | Text1 | Text2 | Text3 | Text6 | Text8 | Text12 | Text14 | Text16 | Text9 | Text5 | Text4 | Text15 | Text7 | Text17 | Text18 |
| --- | --- | --- | --- | --- | --- | --- | --- | --- | --- | --- | --- | --- | --- | --- | --- | --- | --- | --- | --- | --- | --- | --- | --- | --- | --- | --- | --- | --- | --- | --- | --- |
| 2481 | 3.1.3.33.3 | **Pleito de Santana do Paraíso a definir - Obra de SES para área rural** |  | 680d | 2020-11-30 | 2023-08-25 |  |  |  | 2020-11-30 | 2023-08-25 | 680d | 2020-11-30 | 2023-09-12 | 44d |  | Verde | Verde | 0% | 0% | Compensatória | Verde | 0% | 0% |  |  |  |  |  |  |  |
| 2482 | 3.1.3.33.3.1 | Pleito de Santana do Paraíso a definir - Obra de SES para área rural aprovado | milestone | 0d | 2020-11-30 | 2020-11-30 | 3052FS+489d |  |  | 2020-11-30 | 2020-11-30 | 0d | 2020-11-30 | 2020-11-30 | 49d | 5d | Verde | Verde | 0% | 0% | Compensatória | Verde | 0% | 0% | CT/CIF |  |  |  |  |  |  |
| 2483 | 3.1.3.33.3.2 | **Licitação da Obra** |  | 80d | 2020-12-21 | 2021-04-22 |  |  |  | 2020-12-21 | 2021-04-22 | 80d | 2020-12-28 | 2021-04-27 | 44d |  | Verde | Verde | 0% | 0% | Compensatória | Verde | 0% | 0% |  |  |  |  |  |  |  |
| 2484 | 3.1.3.33.3.2.1 | Licitação da obra do Pleito de Santana do Paraíso a definir - Obra de SES para área rural autorizada pelo banco | milestone | 0d | 2020-12-21 | 2020-12-21 | 2482FS+10d, 2469 |  |  | 2020-12-21 | 2020-12-21 | 0d | 2020-12-28 | 2020-12-28 | 44d | 0d | Verde | Verde | 0% | 0% | Compensatória | Verde | 0% | 0% | Banco |  |  |  |  |  |  |
| 2485 | 3.1.3.33.3.2.2 | Licitar Obra |  | 66d | 2020-12-22 | 2021-03-31 | 2484 |  |  | 2020-12-22 | 2021-03-31 | 66d | 2020-12-29 | 2021-04-06 | 44d | 0d | Verde | Verde | 0% | 0% | Compensatória | Verde | 0% | 0% | Município |  |  |  |  |  |  |
| 2486 | 3.1.3.33.3.2.3 | Analisar e emitir resultado da licitação da obra |  | 14d | 2021-04-01 | 2021-04-22 | 2485 |  |  | 2021-04-01 | 2021-04-22 | 14d | 2021-04-07 | 2021-04-27 | 44d | 0d | Verde | Verde | 0% | 0% | Compensatória | Verde | 0% | 0% | Banco |  |  |  |  |  |  |
| 2487 | 3.1.3.33.3.2.4 | Licitação da obra do Pleito de Santana do Paraíso a definir - Obra de SES para área rural concluída | milestone | 0d | 2021-04-22 | 2021-04-22 | 2486 |  |  | 2021-04-22 | 2021-04-22 | 0d | 2021-04-27 | 2021-04-27 | 44d | 0d | Verde | Verde | 0% | 0% | Compensatória | Verde | 0% | 0% | Município |  |  |  |  |  |  |
| 2488 | 3.1.3.33.3.3 | Executar obra |  | 440d | 2021-05-21 | 2023-02-24 | 2487FS+20d |  |  | 2021-05-21 | 2023-02-24 | 440d | 2021-05-26 | 2023-03-01 | 44d | 0d | Verde | Verde | 0% | 0% | Compensatória | Verde | 0% | 0% | Município |  |  |  |  |  |  |
| 2489 | 3.1.3.33.3.4 | Realizar processo de pré-operação |  | 120d | 2023-02-27 | 2023-08-18 | 2488 |  |  | 2023-02-27 | 2023-08-18 | 120d | 2023-03-02 | 2023-09-04 | 44d | 0d | Verde | Verde | 0% | 0% | Compensatória | Verde | 0% | 0% | Município |  |  |  |  |  |  |
| 2490 | 3.1.3.33.3.5 | Recurso da obra do Pleito de Santana do Paraíso a definir - Obra de SES para área rural repassado | milestone | 0d | 2023-08-25 | 2023-08-25 | 2489FS+5d |  |  | 2023-08-25 | 2023-08-25 | 0d | 2023-09-12 | 2023-09-12 | 44d | 0d | Verde | Verde | 0% | 0% | Compensatória | Verde | 0% | 0% | Banco |  |  |  |  |  |  |
| 2491 | 3.1.3.33.3.6 | Pleito de Santana do Paraíso a definir - Obra de SES para área rural concluído | milestone | 0d | 2023-08-25 | 2023-08-25 | 2490 |  |  | 2023-08-25 | 2023-08-25 | 0d | 2023-09-12 | 2023-09-12 | 44d | 0d | Verde | Verde | 0% | 0% | Compensatória | Verde | 0% | 0% | Município |  |  |  |  |  |  |
| 2492 | 3.1.3.33.4 | **Pleito SAPRSPM01 - Revisão do PGIRS** |  | 470d | 2018-08-22 A | 2020-07-08 |  | 14% | 404.1d | 2018-08-22 | 2020-07-08 | 470d | 2018-08-22 | 2019-07-11 | 824d |  | Verde | Verde | 41% | 0% | Compensatória | Vermelho | 7% | 0% |  | 41 |  |  |  |  |  |
| 2493 | 3.1.3.33.4.1 | **Licitação de Empresa para Elaboração de PGIRS** |  | 277d | 2018-08-22 A | 2019-09-25 |  | 24% | 211.31d | 2018-08-22 | 2019-09-25 | 277d | 2018-08-22 | 2018-11-16 | 824d |  | Verde | Verde | 70% | 0% | Compensatória | Vermelho | 56% | 0% |  | 70 | 15 | 56 |  |  |  |
| 2494 | 3.1.3.33.4.1.1 | Licitação da empresa para elaboração de PGIRS de Santana do Paraíso do Pleito SAPRSPM01 - Revisão do PGIRS autorizada pelo banco | milestone | 0d | 2018-08-22 A | 2018-08-22 A | 3052FS-81d | 100% |  | 2018-08-22 | 2018-08-22 | 0d | 2018-08-22 | 2018-08-22 |  |  | Verde | Verde | 100% | 100% | Compensatória | Verde | 100% | 100% | Banco | 100 | 100 | 100 | 100 | 100 |  |
| 2495 | 3.1.3.33.4.1.2 | Licitar empresa de elaboração de PGIRS |  | 258d | 2018-08-22 A | 2019-08-29 | 2494 | 25% | 193.5d | 2018-08-22 | 2019-08-29 | 258d | 2018-08-22 | 2018-10-22 | 824d | 0d | Verde | Verde | 75% | 0% | Compensatória | Vermelho | 75% | 0% | Município | 75 | 15 | 75 |  |  | Conforme agendado |
| 2496 | 3.1.3.33.4.1.3 | Documentação de licitação de Santana do Paraíso do Pleito SAPRSPM01 - Revisão do PGIRS apresentada ao banco | milestone | 0d | 2019-09-05 | 2019-09-05 | 2495FS+5d |  |  | 2019-09-05 | 2019-09-05 | 0d | 2018-10-29 | 2018-10-29 | 824d | 0d | Verde | Verde | 0% | 0% | Compensatória | Verde | 0% | 0% | Município |  |  |  |  |  |  |
| 2497 | 3.1.3.33.4.1.4 | Analisar licitação da empresa para elaboração de PGIRS |  | 14d | 2019-09-06 | 2019-09-25 | 2496 |  |  | 2019-09-06 | 2019-09-25 | 14d | 2018-10-30 | 2018-11-16 | 824d | 0d | Verde | Verde | 0% | 0% | Compensatória | Verde | 0% | 0% | Banco |  |  |  |  |  | Critério FR |
| 2498 | 3.1.3.33.4.1.5 | Licitação da empresa para elaboração de PGIRS de Santana do Paraíso do Pleito SAPRSPM01 - Revisão do PGIRS aprovada | milestone | 0d | 2019-09-25 | 2019-09-25 | 2497 |  |  | 2019-09-25 | 2019-09-25 | 0d | 2018-11-16 | 2018-11-16 | 824d | 0d | Verde | Verde | 0% | 0% | Compensatória | Verde | 0% | 0% | Município |  |  |  |  |  |  |
| 2499 | 3.1.3.33.4.2 | **Elaboração do PGIRS** |  | 188d | 2019-09-26 | 2020-07-01 |  |  |  | 2019-09-26 | 2020-07-01 | 188d | 2018-11-19 | 2019-07-04 | 824d |  | Verde | Verde | 0% | 0% | Compensatória | Verde | 0% | 0% |  |  |  |  |  |  |  |
| 2500 | 3.1.3.33.4.2.1 | Elaborar PGIRS |  | 120d | 2019-09-26 | 2020-03-23 | 2498 |  |  | 2019-09-26 | 2020-03-23 | 120d | 2018-11-19 | 2019-03-26 | 824d | 0d | Verde | Verde | 0% | 0% | Compensatória | Verde | 0% | 0% | Município |  |  |  |  |  |  |
| 2501 | 3.1.3.33.4.2.2 | PGIRS de Santana do Paraíso do Pleito SAPRSPM01 - Revisão do PGIRS apresentado ao banco | milestone | 0d | 2020-03-23 | 2020-03-23 | 2500 |  |  | 2020-03-23 | 2020-03-23 | 0d | 2019-03-26 | 2019-03-26 | 824d | 0d | Verde | Verde | 0% | 0% | Compensatória | Verde | 0% | 0% | Município |  |  |  |  |  |  |
| 2502 | 3.1.3.33.4.2.3 | Analisar PGIRS |  | 68d | 2020-03-24 | 2020-07-01 | 2501 |  |  | 2020-03-24 | 2020-07-01 | 68d | 2019-03-27 | 2019-05-02 | 824d | 0d | Verde | Verde | 0% | 0% | Compensatória | Verde | 0% | 0% | Banco |  |  |  |  |  |  |
| 2503 | 3.1.3.33.4.2.4 | PGIRS de Santana do Paraíso do Pleito SAPRSPM01 - Revisão do PGIRS concluído | milestone | 0d | 2020-07-01 | 2020-07-01 | 2502 |  |  | 2020-07-01 | 2020-07-01 | 0d | 2019-07-04 | 2019-07-04 | 824d | 0d | Verde | Verde | 0% | 0% | Compensatória | Verde | 0% | 0% | Município |  |  |  |  |  |  |
| 2504 | 3.1.3.33.4.3 | Recurso do serviço de Santana do Paraíso do Pleito SAPRSPM01 - Revisão do PGIRS repassado | milestone | 0d | 2020-07-08 | 2020-07-08 | 2503FS+5d |  |  | 2020-07-08 | 2020-07-08 | 0d | 2019-07-11 | 2019-07-11 | 824d | 0d | Verde | Verde | 0% | 0% | Compensatória | Verde | 0% | 0% | Banco |  |  |  |  |  |  |
| 2505 | 3.1.3.33.4.4 | Pleito SAPRSPM01 - Revisão do PGIRS de Santana do Paraíso concluído | milestone | 0d | 2020-07-08 | 2020-07-08 | 2504 |  |  | 2020-07-08 | 2020-07-08 | 0d | 2019-07-11 | 2019-07-11 | 824d | 780d | Verde | Verde | 0% | 0% | Compensatória | Verde | 0% | 0% | Município |  |  |  |  |  |  |
| 2506 | 3.1.3.33.5 | Recursos de Santa do Paraíso repassados | milestone | 0d | 2023-08-25 | 2023-08-25 | 2469, 2505, 2480, 2491 |  |  | 2023-08-25 | 2023-08-25 | 0d | 2023-09-12 | 2023-09-12 | 44d |  | Verde | Verde | 0% | 0% | Compensatória | Verde | 0% | 0% | Banco |  |  |  |  |  |  |

Notes:
- 2482: Em 25/04/2019: o pleito deve ser enviado em setembro após conclusão do projeto executivo e será aprovado no próximo CT/CIF 30/11/2020 conforme NT 33
- 2488: Em 25/04/2019: valor da obra considerando teto menos projeto igual a R$ 10,7 milhões
- 2494: Em 24/04/2019: licitação de empresa para PGIRS autorizada pelo banco no dia 22/08/2018 conforme planilha controle gerencial renova. / 29/05/2019: após alteração do pleito banco terá que enviar outra autorização de licitação.
- 2495: 02/07/2019: o município solicitou ajuda do apoio técnico para elaboração do TR.
- 2502: Em 29/04/2019: atualizado como agendado
- 2506: Valor de recurso destinado ao munícipio: R$12.605.314,86 / Em 19/03/19: por solicitação da A&M foi modificada a duração da atividade Santana do Paraíso de 1177 dias para 1171 dias para atendimento à demanda do MP e igualar as datas de término tendência às da definição do programa.

| ID | WBS | Task | Type | Duration | Start | Finish | Predecessors | Complete | Remaining | Baseline start | Baseline finish | Baseline duration | Baseline 1 start | Baseline 1 finish | Total slack | Free slack | Constraint | Text1 | Text2 | Text3 | Text4 | Text5 | Text6 | Text7 | Text8 | Text12 | Text14 | Text16 | Text15 | Text17 | Text9 | Text18 |
| --- | --- | --- | --- | --- | --- | --- | --- | --- | --- | --- | --- | --- | --- | --- | --- | --- | --- | --- | --- | --- | --- | --- | --- | --- | --- | --- | --- | --- | --- | --- | --- | --- |
| 2507 | 3.1.3.34 | **São Domingos do Prata** |  | 818d | 2018-10-22 A | 2022-01-31 |  | 19% | 661.98d | 2018-10-22 | 2022-01-06 | 801d | 2018-10-22 | 2021-11-16 | 433d |  |  | Verde | Verde | 19% | 13 | 19 | 83% | 83 | Compensatória | Vermelho | 6% | 5% |  |  |  |  |
| 2508 | 3.1.3.34.1 | **Pleito SDPESOB05 - Construção do sistema de esgotamento sanitário da sede do município** |  | 727d | 2019-02-27 A | 2022-01-31 |  | 11% | 649.62d | 2019-02-27 | 2022-01-06 | 710d | 2019-02-04 | 2021-11-16 | 433d |  |  | Verde | Verde | 8% |  |  | 80% | 80 | Compensatória | Vermelho | 5% | 4% |  |  |  |  |
| 2509 | 3.1.3.34.1.1 | **Aprovação do Projeto Executivo** |  | 106d | 2019-02-27 A | 2019-08-02 |  | 76% | 25d | 2019-02-27 | 2019-07-10 | 89d | 2019-02-27 | 2019-07-08 | 492d |  |  | Verde | Verde | 69% | 45 | 69 | 80% | 80 | Compensatória | Vermelho | 64% | 51% | 64 | 51 |  |  |
| 2510 | 3.1.3.34.1.1.1 | Projeto executivo de São Domingos do Prata do Pleito SDPESOB05 - Construção do sistema de esgotamento sanitário da sede do município apresentado ao banco | milestone | 0d | 2019-02-27 A | 2019-02-27 A |  | 100% |  | 2019-02-27 | 2019-02-27 | 0d | 2019-02-27 | 2019-02-27 |  |  | must start on 2019-02-27 | Verde | Verde | 100% | 100 | 100 | 100% | 100 | Compensatória | Verde | 100% | 100% | 100 | 100 | Município |  |
| 2511 | 3.1.3.34.1.1.2 | Analisar projeto executivo |  | 11d | 2019-02-27 A | 2019-03-18 A | 2510 | 100% |  | 2019-02-27 | 2019-03-18 | 11d | 2019-02-27 | 2019-03-18 |  |  |  | Verde | Verde | 100% | 100 | 100 | 100% | 100 | Compensatória | Verde | 100% | 100% | 100 | 100 | Banco |  |
| 2512 | 3.1.3.34.1.1.3 | Adequar/revisar projeto executivo |  | 73d | 2019-03-19 A | 2019-07-03 | 2511 | 96% | 3d | 2019-03-19 | 2019-06-07 | 56d | 2019-03-19 | 2019-06-03 | 433d | 0d |  | Verde | Verde | 91% | 52 | 91 | 57% | 57 | Compensatória | Vermelho | 91% | 52% | 91 | 52 | Município | Conforme agendado |
| 2513 | 3.1.3.34.1.1.4 | Analisar projeto executivo - final |  | 22d | 2019-07-04 | 2019-08-02 | 2512 |  |  | 2019-06-10 | 2019-07-10 | 22d | 2019-06-04 | 2019-07-08 | 433d | 0d |  | Verde | Verde | 0% |  |  | 0% |  | Compensatória | Verde | 0% | 0% |  |  | Banco | Critério FR |
| 2514 | 3.1.3.34.1.1.5 | Projeto de São Domingos do Prata do Pleito SDPESOB05 - Construção do sistema de esgotamento sanitário da sede do município concluído | milestone | 0d | 2019-08-02 | 2019-08-02 | 2513 |  |  | 2019-07-10 | 2019-07-10 | 0d | 2019-07-08 | 2019-07-08 | 492d | 0d |  | Verde | Verde | 0% |  |  | 0% |  | Compensatória | Verde | 0% | 0% |  |  | Município |  |
| 2515 | 3.1.3.34.1.2 | Realizar Licenciamento Ambiental |  | 120d | 2019-08-05 | 2020-01-27 | 2513 |  |  | 2019-07-11 | 2020-01-02 | 120d | 2019-02-04 | 2019-10-11 | 460d | 27d |  | Verde | Verde | 0% |  |  | 0% |  | Compensatória | Verde | 0% | 0% |  |  | Município |  |
| 2516 | 3.1.3.34.1.3 | **Licitação da Obra** |  | 66d | 2019-08-02 | 2019-11-05 |  |  |  | 2019-07-10 | 2019-10-11 | 66d | 2019-07-08 | 2019-10-09 | 492d |  |  | Verde | Verde | 0% |  |  | 0% |  | Compensatória | Verde | 0% | 0% |  |  |  |  |
| 2517 | 3.1.3.34.1.3.1 | Licitação da obra de São Domingos do Prata do Pleito SDPESOB05 - Construção do sistema de esgotamento sanitário da sede do município autorizada pelo banco | milestone | 0d | 2019-08-02 | 2019-08-02 | 2514 |  |  | 2019-07-10 | 2019-07-10 | 0d | 2019-07-08 | 2019-07-08 | 492d | 0d |  | Verde | Verde | 0% |  |  | 0% |  | Compensatória | Verde | 0% | 0% |  |  | Banco |  |
| 2518 | 3.1.3.34.1.3.2 | Licitar Obra |  | 43d | 2019-08-05 | 2019-10-03 | 2517 |  |  | 2019-07-11 | 2019-09-10 | 43d | 2019-07-09 | 2019-09-06 | 492d | 0d |  | Verde | Verde | 0% |  |  | 0% |  | Compensatória | Verde | 0% | 0% |  |  | Município | Critério FR |
| 2519 | 3.1.3.34.1.3.3 | Analisar e emitir resultado da licitação da obra |  | 23d | 2019-10-04 | 2019-11-05 | 2518 |  |  | 2019-09-11 | 2019-10-11 | 23d | 2019-09-09 | 2019-10-09 | 492d | 0d |  | Verde | Verde | 0% |  |  | 0% |  | Compensatória | Verde | 0% | 0% |  |  | Banco | Critério FR |
| 2520 | 3.1.3.34.1.3.4 | Licitação da obra de São Domingos do Prata do Pleito SDPESOB05 - Construção do sistema de esgotamento sanitário da sede do município concluída | milestone | 0d | 2019-11-05 | 2019-11-05 | 2519 |  |  | 2019-10-11 | 2019-10-11 | 0d | 2019-10-09 | 2019-10-09 | 492d | 59d |  | Verde | Verde | 0% |  |  | 0% |  | Compensatória | Verde | 0% | 0% |  |  | Município |  |
| 2521 | 3.1.3.34.1.4 | Executar obra |  | 349d | 2020-03-10 | 2021-08-02 | 2520FS+22d, 2515, 2535 |  |  | 2020-02-11 | 2021-07-08 | 349d | 2019-10-14 | 2021-05-06 | 433d | 0d |  | Verde | Verde | 0% |  |  | 0% |  | Compensatória | Verde | 0% | 0% |  |  | Município |  |
| 2522 | 3.1.3.34.1.5 | Realizar processo de pré-operação |  | 120d | 2021-08-03 | 2022-01-24 | 2521 |  |  | 2021-07-09 | 2021-12-30 | 120d | 2021-05-07 | 2021-11-08 | 433d | 0d |  | Verde | Verde | 0% |  |  | 0% |  | Compensatória | Verde | 0% | 0% |  |  | Município |  |
| 2523 | 3.1.3.34.1.6 | Recurso da obra de São Domingos do Prata do Pleito SDPESOB05 - Construção do sistema de esgotamento sanitário da sede do município repassado | milestone | 0d | 2022-01-31 | 2022-01-31 | 2522FS+5d |  |  | 2022-01-06 | 2022-01-06 | 0d | 2021-11-16 | 2021-11-16 | 433d | 0d |  | Verde | Verde | 0% |  |  | 0% |  | Compensatória | Verde | 0% | 0% |  |  | Banco |  |
| 2524 | 3.1.3.34.1.7 | Pleito SDPESOB05 - Construção do sistema de esgotamento sanitário da sede do município de São Domingos do Prata concluído | milestone | 0d | 2022-01-31 | 2022-01-31 | 2523 |  |  | 2022-01-06 | 2022-01-06 | 0d | 2021-11-16 | 2021-11-16 | 433d | 0d |  | Verde | Verde | 0% |  |  | 0% |  | Compensatória | Verde | 0% | 0% |  |  | Município |  |
| 2525 | 3.1.3.34.2 | **Pleito SDPESCT02 - Aquisição de imóvel para a construção de estação de tratamento de esgotos e indenização da faixa de servidão.** |  | 147d | 2019-08-02 | 2020-03-09 |  |  |  | 2019-07-10 | 2020-02-10 | 147d | 2019-03-18 | 2019-10-16 | 433d |  |  | Verde | Verde | 0% |  |  | 0% |  | Compensatória | Verde | 0% | 0% |  |  |  |  |
| 2526 | 3.1.3.34.2.1 | Aquisição de imóvel de São Domingos do Prata do Pleito SDPESCT02 - Aquisição de imóvel para a construção de estação de tratamento de esgotos e indenização da faixa de servidão autorizada pelo banco | milestone | 0d | 2019-08-02 | 2019-08-02 | 2513 |  |  | 2019-07-10 | 2019-07-10 | 0d | 2019-03-18 | 2019-03-18 | 433d | 0d |  | Verde | Verde | 0% |  |  | 0% |  | Compensatória | Verde | 0% | 0% |  |  | Banco |  |
| 2527 | 3.1.3.34.2.2 | **Aquisição de Imóvel** |  | 147d | 2019-08-05 | 2020-03-09 |  |  |  | 2019-07-11 | 2020-02-10 | 147d | 2019-03-19 | 2019-10-16 | 433d |  |  | Verde | Verde | 0% |  |  | 0% |  | Compensatória | Verde | 0% | 0% |  |  |  |  |
| 2528 | 3.1.3.34.2.2.1 | Regularizar terreno e apresentar escritura ao banco |  | 88d | 2019-08-05 | 2019-12-06 | 2526 |  |  | 2019-07-11 | 2019-11-12 | 88d | 2019-03-19 | 2019-07-24 | 433d | 0d |  | Verde | Verde | 0% |  |  | 0% |  | Compensatória | Verde | 0% | 0% |  |  | Município | Critério FR |
| 2529 | 3.1.3.34.2.2.2 | Analisar documentação do terreno |  | 10d | 2019-12-09 | 2019-12-23 | 2528 |  |  | 2019-11-13 | 2019-11-27 | 10d | 2019-07-25 | 2019-08-07 | 477d | 0d |  | Verde | Verde | 0% |  |  | 0% |  | Compensatória | Verde | 0% | 0% |  |  | Banco | Critério FR |
| 2530 | 3.1.3.34.2.2.3 | 50% do valor do imóvel de São Domingos do Prata do Pleito SDPESCT02 - Aquisição de imóvel para a construção de estação de tratamento de esgotos e indenização da faixa de servidão repassado | milestone | 0d | 2020-01-02 | 2020-01-02 | 2529FS+5d |  |  | 2019-12-04 | 2019-12-04 | 0d | 2019-08-14 | 2019-08-14 | 477d | 44d |  | Verde | Verde | 0% |  |  | 0% |  | Compensatória | Verde | 0% | 0% |  |  | Banco |  |
| 2531 | 3.1.3.34.2.2.4 | Registrar imóvel e apresentar documentação ao banco |  | 44d | 2019-12-09 | 2020-02-12 | 2528 |  |  | 2019-11-13 | 2020-01-20 | 44d | 2019-07-25 | 2019-09-25 | 433d | 0d |  | Verde | Verde | 0% |  |  | 0% |  | Compensatória | Verde | 0% | 0% |  |  | Município |  |
| 2532 | 3.1.3.34.2.2.5 | Analisar documentação do terreno |  | 10d | 2020-02-13 | 2020-03-02 | 2531 |  |  | 2020-01-21 | 2020-02-03 | 10d | 2019-09-26 | 2019-10-09 | 433d | 0d |  | Verde | Verde | 0% |  |  | 0% |  | Compensatória | Verde | 0% | 0% |  |  | Banco |  |
| 2533 | 3.1.3.34.2.2.6 | 50% do valor do imóvel de São Domingos do Prata do Pleito SDPESCT02 - Aquisição de imóvel para a construção de estação de tratamento de esgotos e indenização da faixa de servidão repassado | milestone | 0d | 2020-03-09 | 2020-03-09 | 2532FS+5d |  |  | 2020-02-10 | 2020-02-10 | 0d | 2019-10-16 | 2019-10-16 | 433d | 0d |  | Verde | Verde | 0% |  |  | 0% |  | Compensatória | Verde | 0% | 0% |  |  | Banco |  |
| 2534 | 3.1.3.34.2.2.7 | Aquisição de imóvel de São Domingos do Prata do Pleito SDPESCT02 - Aquisição de imóvel para a construção de estação de tratamento de esgotos e indenização da faixa de servidão concluída | milestone | 0d | 2020-03-09 | 2020-03-09 | 2530, 2533 |  |  | 2020-02-10 | 2020-02-10 | 0d | 2019-10-16 | 2019-10-16 | 433d | 0d |  | Verde | Verde | 0% |  |  | 0% |  | Compensatória | Verde | 0% | 0% |  |  | Município |  |
| 2535 | 3.1.3.34.2.3 | Pleito SDPESCT02 - Aquisição de imóvel para a construção de estação de tratamento de esgotos e indenização da faixa de servidão de São Domingos do Prata concluído | milestone | 0d | 2020-03-09 | 2020-03-09 | 2534 |  |  | 2020-02-10 | 2020-02-10 | 0d | 2019-10-16 | 2019-10-16 | 433d | 0d |  | Verde | Verde | 0% |  |  | 0% |  | Compensatória | Verde | 0% | 0% |  |  | Município |  |

Notes:
- 2507: São Domingos do Prata teve 100% dos pleitos de Esgotamento Sanitário aprovado (R$8.508.587,53), conforme Deliberação 75. / O município teve 1,6% dos 10% do valor teto destinado a Resíduos Sólidos aprovado (R$155.746,00). / Foi solicitado alteração de pleito, cancelamento de todos os pleitos anteriores para SES e pleito de execução do SES da sede (R$ 7.858.587,00), aquisição de imóvel para implantação da ETE e indenização da faixa de servidão (R$ 650.000,00).
- 2510: Em 25/04/2019: conforme planilha controle gerencial Renova o município protocolou o projeto no banco no dia 27/02/2019.
- 2511: Em 25/04/2019: município recolheu o projeto do banco no dia 18/03 para revisão conforme planilha controle gerencial Renova
- 2512: Em 25/04/2019: município não terminou de revisar o projeto, considerado prazo até 03/05/2019 / Em 29/04/2019: atualizado como agendado / 21/05/2019: município protocolou projeto atualizado no banco dia 07/05/2019, porém banco solicitou pendências dia 17/05/2019. conferir qual o prazo para resolução dessas pendências com o município na reunião. / 28/05/2019: atualizar informações solicitadas pelo Dewid até dia 07/06/2019. / 01/07/2019: e-mail Carlos conforme contato via WhatSapp ainda estão aguardando a empresa projetista enviar o novo projeto da ETE para o banco e agendou a entrega para dia 03/07.
- 2515: Em 29/04/2019: atualizado como agendado / 21/05/2019: conferir andamento do licencimento com município em reunião / 28/05/2019: Licenciamento não foi iniciado de acordo com o município. O licenciamento vai começar após a vistoria e terminará em 6 meses conforme pactuado com o município
- 2528: Em 29/04/2019: atualizado como agendado

| ID | WBS | Task | Type | Duration | Start | Finish | Predecessors | Complete | Remaining | Baseline start | Baseline finish | Baseline duration | Baseline 1 start | Baseline 1 finish | Total slack | Free slack | Constraint | Text1 | Text2 | Text3 | Text4 | Text5 | Text6 | Text7 | Text8 | Text12 | Text14 | Text15 | Text16 | Text17 | Text9 | Text18 |
| --- | --- | --- | --- | --- | --- | --- | --- | --- | --- | --- | --- | --- | --- | --- | --- | --- | --- | --- | --- | --- | --- | --- | --- | --- | --- | --- | --- | --- | --- | --- | --- | --- |
| 2536 | 3.1.3.34.3 | **Pleito SDPRSPM01 - Elaboração do Plano Municipal de Gestão Integrada de Resíduos Sólidos (PGIRS)** |  | 192d | 2018-10-22 A | 2019-07-26 |  | 99% | 0d | 2018-10-22 | 2019-07-08 | 178d | 2018-10-22 | 2019-07-17 | 1059d |  |  | Verde | Verde | 85% | 66 | 85 | 75% | 75 | Compensatória | Vermelho | 97% | 97 | 73% | 73 |  |  |
| 2537 | 3.1.3.34.3.1 | **Licitação de Empresa para Elaboração de PGIRS** |  | 54d | 2018-10-22 A | 2019-01-04 A |  | 100% |  | 2018-10-22 | 2019-01-04 | 54d | 2018-10-22 | 2019-01-04 |  |  |  | Verde | Verde | 100% | 100 | 100 | 100% | 100 | Compensatória | Verde | 100% | 100 | 100% | 100 |  |  |
| 2538 | 3.1.3.34.3.1.1 | Documentação de licitação de São Domingos do Prata do Pleito SDPRSPM01 - Elaboração do Plano Municipal de Gestão Integrada de Resíduos Sólidos (PGIRS) apresentada ao banco | milestone | 0d | 2018-10-22 A | 2018-10-22 A |  | 100% |  | 2018-10-22 | 2018-10-22 | 0d | 2018-10-22 | 2018-10-22 |  |  | must start on 2018-10-22 | Verde | Verde | 100% | 100 | 100 | 100% | 100 | Compensatória | Verde | 100% | 100 | 100% | 100 | Município |  |
| 2539 | 3.1.3.34.3.1.2 | Licitação da empresa para elaboração de PGIRS de São Domingos do Prata do Pleito SDPRSPM01 - Elaboração do Plano Municipal de Gestão Integrada de Resíduos Sólidos (PGIRS) aprovada | milestone | 0d | 2019-01-04 A | 2019-01-04 A | 2538FS+54d | 100% |  | 2019-01-04 | 2019-01-04 | 0d | 2019-01-04 | 2019-01-04 |  |  |  | Verde | Verde | 100% | 100 | 100 | 100% | 100 | Compensatória | Verde | 100% | 100 | 100% | 100 | Município |  |
| 2540 | 3.1.3.34.3.2 | **Elaboração do PGIRS** |  | 118d | 2019-01-07 A | 2019-06-28 A |  | 100% |  | 2019-01-07 | 2019-06-07 | 104d | 2019-01-07 | 2019-07-10 |  |  |  | Verde | Verde | 95% | 66 | 95 | 75% | 75 | Compensatória | Vermelho | 97% | 97 | 73% | 73 |  |  |
| 2541 | 3.1.3.34.3.2.1 | Elaborar PGIRS |  | 60d | 2019-01-07 A | 2019-04-03 A | 2539 | 100% |  | 2019-01-07 | 2019-04-03 | 60d | 2019-01-07 | 2019-04-03 |  |  |  | Verde | Verde | 100% | 100 | 100 | 100% | 100 | Compensatória | Verde | 100% | 100 | 100% | 100 | Município |  |
| 2542 | 3.1.3.34.3.2.2 | PGIRS de São Domingos do Prata do Pleito SDPRSPM01 - Elaboração do Plano Municipal de Gestão Integrada de Resíduos Sólidos (PGIRS) apresentado ao banco | milestone | 0d | 2019-04-03 A | 2019-04-03 A | 2541 | 100% |  | 2019-04-03 | 2019-04-03 | 0d | 2019-04-03 | 2019-04-03 |  |  |  | Verde | Verde | 100% | 100 | 100 | 100% | 100 | Compensatória | Verde | 100% | 100 | 100% | 100 | Município |  |
| 2543 | 3.1.3.34.3.2.3 | Analisar PGIRS |  | 58d | 2019-04-04 A | 2019-06-28 A | 2542 | 100% |  | 2019-04-04 | 2019-06-07 | 44d | 2019-04-04 | 2019-05-08 |  |  |  | Verde | Verde | 88% | 19 | 88 | 0% |  | Compensatória | Vermelho | 88% | 88 | 0% |  | Banco | Conforme agendado |
| 2544 | 3.1.3.34.3.2.4 | PGIRS do pleito SDPRSPM01 de São Domingos do Prata de Elaboração do Plano Municipal de Gestão Integrada de Resíduos (PGIRS) aprovado pelo banco | milestone | 0d | 2019-06-28 A | 2019-06-28 A | 2543 | 100% |  | 2019-06-07 | 2019-06-07 | 0d | 2019-07-10 | 2019-07-10 |  |  |  | Verde | Verde | 0% |  |  | 0% |  | Compensatória | Verde | 0% |  | 0% |  | Município |  |
| 2545 | 3.1.3.34.3.3 | Recurso do serviço de São Domingos do Prata do Pleito SDPRSPM01 - Elaboração do Plano Municipal de Gestão Integrada de Resíduos Sólidos (PGIRS) repassado | milestone | 0d | 2019-07-26 | 2019-07-26 | 2544FS+20d |  |  | 2019-07-08 | 2019-07-08 | 0d | 2019-07-17 | 2019-07-17 | 1059d | 0d |  | Verde | Verde | 0% |  |  | 0% |  | Compensatória | Verde | 0% |  | 0% |  | Banco |  |
| 2546 | 3.1.3.34.3.4 | Pleito SDPRSPM01 - Elaboração do Plano Municipal de Gestão Integrada de Resíduos Sólidos (PGIRS) de São Domingos do Prata concluído | milestone | 0d | 2019-07-26 | 2019-07-26 | 2545 |  |  | 2019-07-08 | 2019-07-08 | 0d | 2019-07-17 | 2019-07-17 | 1059d | 626d |  | Verde | Verde | 0% |  |  | 0% |  | Compensatória | Verde | 0% |  | 0% |  | Município |  |
| 2547 | 3.1.3.34.4 | **Pleito SDPRSOB02 - Implantação do Centro de Tratamento e Reciclagem de Resíduos Orgânicos e Recicláveis, cujo projeto encontra-se elaborado** |  | 413d | 2019-01-16 A | 2020-09-14 |  | 25% | 308.16d | 2019-01-16 | 2020-09-14 | 413d | 2019-01-16 | 2021-01-13 | 777d |  |  | Verde | Verde | 22% | 24 | 22 | 90% | 90 | Compensatória | Vermelho | 10% | 10 | 9% |  |  |  |
| 2548 | 3.1.3.34.4.1 | **Aprovação do Projeto Executivo** |  | 88d | 2019-01-16 A | 2019-05-27 A |  | 100% |  | 2019-01-16 | 2019-05-27 | 88d | 2019-01-16 | 2019-08-08 |  |  |  | Verde | Verde | 100% | 100 | 100 | 100% | 100 | Compensatória | Verde | 100% | 100 | 100% | 100 |  |  |
| 2549 | 3.1.3.34.4.1.1 | Projeto apresentado de São Domingos do Prata do Pleito SDPRSOB02 - Implantação do Centro de Tratamento e Reciclagem de Resíduos Orgânicos e Recicláveis, cujo projeto encontra-se elaborado ao banco | milestone | 0d | 2019-01-16 A | 2019-01-16 A |  | 100% |  | 2019-01-16 | 2019-01-16 | 0d | 2019-01-16 | 2019-01-16 |  |  | must start on 2019-01-16 | Verde | Verde | 100% | 100 | 100 | 100% | 100 | Compensatória | Verde | 100% | 100 | 100% | 100 | Município |  |
| 2550 | 3.1.3.34.4.1.2 | Analisar projeto |  | 88d | 2019-01-16 A | 2019-05-27 A | 2549 | 100% |  | 2019-01-16 | 2019-05-27 | 88d | 2019-01-16 | 2019-06-06 |  |  |  | Verde | Verde | 100% | 100 | 100 | 100% | 100 | Compensatória | Verde | 100% | 100 | 100% | 100 | Banco |  |
| 2551 | 3.1.3.34.4.1.3 | Projeto de São Domingos do Prata do Pleito SDPRSOB02 - Implantação do Centro de Tratamento e Reciclagem de Resíduos Orgânicos e Recicláveis, cujo projeto encontra-se elaborado concluído | milestone | 0d | 2019-05-27 A | 2019-05-27 A | 2550 | 100% |  | 2019-05-27 | 2019-05-27 | 0d | 2019-08-08 | 2019-08-08 |  |  |  | Verde | Verde | 100% | 100 | 100 | 100% | 100 | Compensatória | Verde | 100% | 100 | 100% | 100 | Município |  |
| 2552 | 3.1.3.34.4.2 | **Licitação da obra** |  | 58d | 2019-05-27 A | 2019-08-19 |  | 19% | 47d | 2019-05-27 | 2019-08-19 | 58d | 2019-08-08 | 2019-12-02 | 777d |  |  | Verde | Verde | 6% |  |  | 0% |  | Compensatória | Vermelho | 6% |  | 0% |  |  |  |
| 2553 | 3.1.3.34.4.2.1 | Licitação da obra de São Domingos do Prata do Pleito SDPRSOB02 - Implantação do Centro de Tratamento e Reciclagem de Resíduos Orgânicos e Recicláveis, cujo projeto encontra-se elaborado autorizada pelo banco | milestone | 0d | 2019-05-27 A | 2019-05-27 A | 2551 | 100% |  | 2019-05-27 | 2019-05-27 | 0d | 2019-08-08 | 2019-08-08 |  |  |  | Verde | Verde | 100% | 100 | 100 | 100% | 100 | Compensatória | Verde | 100% | 100 | 100% | 100 | Banco |  |
| 2554 | 3.1.3.34.4.2.2 | Licitar obra |  | 44d | 2019-05-28 A | 2019-07-29 | 2553 | 25% | 33d | 2019-05-28 | 2019-07-29 | 44d | 2019-08-09 | 2019-11-11 | 777d | 0d |  | Verde | Verde | 9% |  |  | 0% |  | Compensatória | Vermelho | 9% |  | 0% |  | Município | Conforme agendado |
| 2555 | 3.1.3.34.4.2.3 | Analisar e emitir resultado da licitação da obra |  | 14d | 2019-07-30 | 2019-08-19 | 2554 |  |  | 2019-07-30 | 2019-08-19 | 14d | 2019-11-12 | 2019-12-02 | 777d | 0d |  | Verde | Verde | 0% |  |  | 0% |  | Compensatória | Verde | 0% |  | 0% |  | Banco | Critério FR |
| 2556 | 3.1.3.34.4.2.4 | Licitação da obra de São Domingos do Prata do Pleito SDPRSOB02 - Implantação do Centro de Tratamento e Reciclagem de Resíduos Orgânicos e Recicláveis, cujo projeto encontra-se elaborado concluída | milestone | 0d | 2019-08-19 | 2019-08-19 | 2555 |  |  | 2019-08-19 | 2019-08-19 | 0d | 2019-12-02 | 2019-12-02 | 777d | 0d |  | Verde | Verde | 0% |  |  | 0% |  | Compensatória | Verde | 0% |  | 0% |  | Município |  |
| 2557 | 3.1.3.34.4.3 | Executar obra |  | 124d | 2019-09-13 | 2020-03-16 | 2556FS+18d |  |  | 2019-09-13 | 2020-03-16 | 124d | 2020-01-02 | 2020-07-02 | 777d | 0d |  | Verde | Verde | 0% |  |  | 0% |  | Compensatória | Verde | 0% |  | 0% |  | Município |  |
| 2558 | 3.1.3.34.4.4 | Realizar processo de pré-operação |  | 120d | 2020-03-17 | 2020-09-04 | 2557 |  |  | 2020-03-17 | 2020-09-04 | 120d | 2020-07-03 | 2021-01-06 | 777d | 0d |  | Verde | Verde | 0% |  |  | 0% |  | Compensatória | Verde | 0% |  | 0% |  | Município |  |
| 2559 | 3.1.3.34.4.5 | Recurso da obra de São Domingos do Prata do Pleito SDPRSOB02 - Implantação do Centro de Tratamento e Reciclagem de Resíduos Orgânicos e Recicláveis, cujo projeto encontra-se elaborado repassado | milestone | 0d | 2020-09-14 | 2020-09-14 | 2558FS+5d |  |  | 2020-09-14 | 2020-09-14 | 0d | 2021-01-13 | 2021-01-13 | 777d | 0d |  | Verde | Verde | 0% |  |  | 0% |  | Compensatória | Verde | 0% |  | 0% |  | Banco |  |
| 2560 | 3.1.3.34.4.6 | Pleito SDPRSOB02 - Implantação do Centro de Tratamento e Reciclagem de Resíduos Orgânicos e Recicláveis, cujo projeto encontra-se elaborado de São Domingos do Prata concluído | milestone | 0d | 2020-09-14 | 2020-09-14 | 2559 |  |  | 2020-09-14 | 2020-09-14 | 0d | 2021-01-13 | 2021-01-13 | 777d | 344d |  | Verde | Verde | 0% |  |  | 0% |  | Compensatória | Verde | 0% |  | 0% |  | Município |  |

Notes:
- 2538: Em 24/04/2019: conforme planilha Controle Gerencial Renova o município protocolou licitação no dia 22/10/2018
- 2543: 21/05/2019: no dia 24/04/2019 o banco repassou os documentos para análise do Eng. Cláudio (planilha controle gerencial Renova - aba contatos & anotações) / 23/05/2019: data de término atualizada para 24/05/2019. Retorno também previsto para dentro do prazo 24/05 (fonte: e-mail Gislaine) / 28/05/2019: o Eng. Cláudio terminou a análise e vai encaminhar aprovação dia 7/06/2019 / 18/06/2019: Francisco solicitou o recurso a Renova. Banco considerou o plano aprovado e respondeu as observações da Cynthia (fonte: e-mail Francisco). / 02/07/2019: e-mail Cynthia - PGIRS aprovado dia 28/06/2019
- 2544: 02/07/2019: e-mail Cynthia - PGIRS aprovado dia 28/06/2019
- 2545: 29/05/2019: alterada a latência do marco, pois Cynthia vai analisar o plano antes de aprovar e repassar recurso
- 2550: Em 24/09/2019: foi utilizada a premissa de que o início do processo de análise do projeto da UTC a partir do último contato do banco com o município (orientado por Cynthia) / Em 29/04/2019: atualizado como agendado / 21/05/2019: dia 07/05/2019 o município encaminhou quadro de dívidas atualizado para análise de capacidade de pagamento do município. E custo de operação da UTC (conforme planilha Controle Gerencial Renova - aba contatos e anotações) / 28/05/2019: o projeto foi aprovado dia 27/05/2019
- 2551: 28/05/2019: o projeto foi aprovado dia 27/05/2019
- 2553: 28/05/2019: o projeto foi aprovado dia 27/05/2019
- 2554: 02/07/2019: município está terminando o TR da UTC.
- 2557: Em 24/04/2019: valor da obra R$ 299 mil

| ID | WBS | Task | Type | Duration | Start | Finish | Predecessors | Complete | Remaining | Baseline start | Baseline finish | Baseline duration | Baseline 1 start | Baseline 1 finish | Total slack | Free slack | Constraint | Text1 | Text2 | Text3 | Text5 | Text6 | Text8 | Text12 | Text14 | Text16 | Text4 | Text7 | Text9 | Text15 | Text17 | Text18 |
| --- | --- | --- | --- | --- | --- | --- | --- | --- | --- | --- | --- | --- | --- | --- | --- | --- | --- | --- | --- | --- | --- | --- | --- | --- | --- | --- | --- | --- | --- | --- | --- | --- |
| 2561 | 3.1.3.34.5 | **Pleito SDPRSPM04 - Elaboração do Plano de Recuperação de Área Degradada (PRAD) por lixão/aterro controlado apenas para o município de São Domingos do Prata** |  | 259d | 2019-03-28 A | 2020-04-13 |  | 8% | 238.58d | 2019-03-28 | 2020-04-13 | 259d | 2019-03-28 | 2020-02-14 | 883d |  |  | Verde | Verde | 16% | 16 | 0% | Compensatória | Vermelho | 5% | 0% |  |  |  |  |  |  |
| 2562 | 3.1.3.34.5.1 | Pleito SDPRSPM04 - Elaboração do Plano de Recuperação de Área Degradada (PRAD) por lixão/aterro controlado apenas para o município de São Domingos do Prata aprovado | milestone | 0d | 2019-03-28 A | 2019-03-28 A |  | 100% |  | 2019-03-28 | 2019-03-28 | 0d | 2019-03-28 | 2019-03-28 |  |  | must start on 2019-03-28 | Verde | Verde | 100% | 100 | 100% | Compensatória | Verde | 100% | 100% | 100 | 100 | CT/CIF | 100 | 100 |  |
| 2563 | 3.1.3.34.5.2 | **Licitação do Plano de Recuperação de Área Degradada** |  | 95d | 2019-04-08 A | 2019-08-26 |  | 21% | 74.94d | 2019-04-08 | 2019-08-26 | 95d | 2019-04-08 | 2019-07-03 | 883d |  |  | Verde | Verde | 37% | 37 | 0% | Compensatória | Vermelho | 24% | 0% | 16 |  |  | 24 |  |  |
| 2564 | 3.1.3.34.5.2.1 | Licitação do PRAD do Pleito SDPRSPM04 - Elaboração do Plano de Recuperação de Área Degradada (PRAD) por lixão/aterro controlado apenas para o município de São Domingos do Prata autorizada pelo banco | milestone | 0d | 2019-04-08 A | 2019-04-08 A | 2562FS+8d | 100% |  | 2019-04-08 | 2019-04-08 | 0d | 2019-04-08 | 2019-04-08 |  |  |  | Verde | Verde | 100% | 100 | 100% | Compensatória | Verde | 100% | 100% | 100 | 100 | Banco | 100 | 100 |  |
| 2565 | 3.1.3.34.5.2.2 | Licitar PRAD |  | 76d | 2019-04-09 A | 2019-07-29 | 2564 | 25% | 57d | 2019-04-09 | 2019-07-29 | 76d | 2019-04-09 | 2019-06-12 | 883d | 0d |  | Verde | Verde | 47% | 47 | 0% | Compensatória | Vermelho | 47% | 0% | 18 |  | Município | 47 |  | Conforme agendado |
| 2566 | 3.1.3.34.5.2.3 | Documentação de licitação do Pleito SDPRSPM04 - Elaboração do Plano de Recuperação de Área Degradada (PRAD) por lixão/aterro controlado apenas para o município de São Domingos do Prata apresentada ao banco | milestone | 0d | 2019-08-05 | 2019-08-05 | 2565FS+5d |  |  | 2019-08-05 | 2019-08-05 | 0d | 2019-06-12 | 2019-06-12 | 883d | 0d |  | Verde | Verde | 0% |  | 0% | Compensatória | Verde | 0% | 0% |  |  | Município |  |  |  |
| 2567 | 3.1.3.34.5.2.4 | Analisar e emitir resultado da licitação do PRAD |  | 14d | 2019-08-06 | 2019-08-26 | 2566 |  |  | 2019-08-06 | 2019-08-26 | 14d | 2019-06-13 | 2019-07-03 | 883d | 0d |  | Verde | Verde | 0% |  | 0% | Compensatória | Verde | 0% | 0% |  |  | Banco |  |  | Critério FR |
| 2568 | 3.1.3.34.5.2.5 | Licitação do PRAD do Pleito SDPRSPM04 - Elaboração do Plano de Recuperação de Área Degradada (PRAD) por lixão/aterro controlado apenas para o município de São Domingos do Prata concluída | milestone | 0d | 2019-08-26 | 2019-08-26 | 2567 |  |  | 2019-08-26 | 2019-08-26 | 0d | 2019-07-03 | 2019-07-03 | 883d | 0d |  | Verde | Verde | 0% |  | 0% | Compensatória | Verde | 0% | 0% |  |  | Município |  |  |  |
| 2569 | 3.1.3.34.5.3 | **Elaboração do Plano de Recuperação de Área Degradada** |  | 156d | 2019-08-27 | 2020-04-13 |  |  |  | 2019-08-27 | 2020-04-13 | 156d | 2019-07-04 | 2020-02-14 | 883d |  |  | Verde | Verde | 0% |  | 0% | Compensatória | Verde | 0% | 0% |  |  |  |  |  |  |
| 2570 | 3.1.3.34.5.3.1 | Elaborar PRAD |  | 87d | 2019-08-27 | 2019-12-31 | 2568 |  |  | 2019-08-27 | 2019-12-31 | 87d | 2019-07-04 | 2019-11-04 | 883d | 0d |  | Verde | Verde | 0% |  | 0% | Compensatória | Verde | 0% | 0% |  |  | Município |  |  | Critério FR |
| 2571 | 3.1.3.34.5.3.2 | PRAD do Pleito SDPRSPM04 - Elaboração do Plano de Recuperação de Área Degradada (PRAD) por lixão/aterro controlado apenas para o município de São Domingos do Prata apresentado ao banco | milestone | 0d | 2019-12-31 | 2019-12-31 | 2570 |  |  | 2019-12-31 | 2019-12-31 | 0d | 2019-11-04 | 2019-11-04 | 883d | 0d |  | Verde | Verde | 0% |  | 0% | Compensatória | Verde | 0% | 0% |  |  | Município |  |  |  |
| 2572 | 3.1.3.34.5.3.3 | Analisar PRAD |  | 64d | 2020-01-02 | 2020-04-03 | 2571 |  |  | 2020-01-02 | 2020-04-03 | 64d | 2019-11-05 | 2019-12-05 | 883d | 0d |  | Verde | Verde | 0% |  | 0% | Compensatória | Verde | 0% | 0% |  |  | Banco |  |  |  |
| 2573 | 3.1.3.34.5.3.4 | PRAD do Pleito SDPRSPM04 - Elaboração do Plano de Recuperação de Área Degradada (PRAD) por lixão/aterro controlado apenas para o município de São Domingos do Prata concluído | milestone | 0d | 2020-04-03 | 2020-04-03 | 2572 |  |  | 2020-04-03 | 2020-04-03 | 0d | 2020-02-07 | 2020-02-07 | 883d | 0d |  | Verde | Verde | 0% |  | 0% | Compensatória | Verde | 0% | 0% |  |  | Município |  |  |  |
| 2574 | 3.1.3.34.5.3.5 | Recurso do PRAD do Pleito SDPRSPM04 - Elaboração do Plano de Recuperação de Área Degradada (PRAD) por lixão/aterro controlado apenas para o município de São Domingos do Prata repassado | milestone | 0d | 2020-04-13 | 2020-04-13 | 2573FS+5d |  |  | 2020-04-13 | 2020-04-13 | 0d | 2020-02-14 | 2020-02-14 | 883d | 0d |  | Verde | Verde | 0% |  | 0% | Compensatória | Verde | 0% | 0% |  |  | Banco |  |  |  |
| 2575 | 3.1.3.34.5.4 | Pleito SDPRSPM04 - Elaboração do Plano de Recuperação de Área Degradada (PRAD) por lixão/aterro controlado apenas para o município de São Domingos do Prata concluído | milestone | 0d | 2020-04-13 | 2020-04-13 | 2574 |  |  | 2020-04-13 | 2020-04-13 | 0d | 2020-02-14 | 2020-02-14 | 883d | 450d |  | Verde | Verde | 0% |  | 0% | Compensatória | Verde | 0% | 0% |  |  | Município |  |  |  |
| 2576 | 3.1.3.34.6 | Recursos de São Domingos do Prata repassados | milestone | 0d | 2022-01-31 | 2022-01-31 | 2524, 2535, 2546, 2560, 2575 |  |  | 2022-01-06 | 2022-01-06 | 0d | 2021-11-16 | 2021-11-16 | 433d |  |  | Verde | Verde | 0% |  | 0% | Compensatória | Verde | 0% | 0% |  |  | Banco |  |  |  |
| 2577 | 3.1.3.35 | **São José do Goiabal** |  | 1325d | 2018-07-10 A | 2023-10-30 |  | 34% | 880.63d | 2018-07-10 | 2023-10-30 | 1325d | 2018-07-10 | 2024-01-30 | 0d |  |  | Verde | Verde | 17% | 17 | 93% | Compensatória | Vermelho | 14% | 13% | 22 | 93 |  | 14 | 13 |  |
| 2578 | 3.1.3.35.1 | **Pleito SJGESPJ02 - Adequação do projeto de SES da sede do municipio. Ajuste necessário à liberação dos recursos do TC/PAC 534/14 firmado com a Funasa** |  | 119d | 2018-07-10 A | 2018-12-21 A |  | 100% |  | 2018-07-10 | 2018-12-21 | 119d | 2018-07-10 | 2018-12-21 |  |  |  | Verde | Verde | 100% | 100 | 100% | Compensatória | Verde | 100% | 100% | 100 | 100 |  | 100 | 100 |  |
| 2579 | 3.1.3.35.1.1 | Licitação do projeto de São José do Goiabal do Pleito SJGESPJ02 - Adequação do projeto de SES da sede do municipio. Ajuste necessário à liberação dos recursos do TC/PAC 534/14 firmado com a Funasa autorizada pelo banco | milestone | 0d | 2018-07-10 A | 2018-07-10 A |  | 100% |  | 2018-07-10 | 2018-07-10 | 0d | 2018-07-10 | 2018-07-10 |  |  | must start on 2018-07-10 | Verde | Verde | 100% | 100 | 100% | Compensatória | Verde | 100% | 100% | 100 | 100 | Banco | 100 | 100 |  |
| 2580 | 3.1.3.35.1.2 | Documentação de licitação de São José do Goiabal do Pleito SJGESPJ02 - Adequação do projeto de SES da sede do municipio. Ajuste necessário à liberação dos recursos do TC/PAC 534/14 firmado com a Funasa apresentada ao banco | milestone | 0d | 2018-12-18 A | 2018-12-18 A | 2579FS+116d | 100% |  | 2018-12-18 | 2018-12-18 | 0d | 2018-12-18 | 2018-12-18 |  |  |  | Verde | Verde | 100% | 100 | 100% | Compensatória | Verde | 100% | 100% | 100 | 100 | Município | 100 | 100 |  |
| 2581 | 3.1.3.35.1.3 | Licitação do projeto de São José do Goiabal do Pleito SJGESPJ02 - Adequação do projeto de SES da sede do municipio. Ajuste necessário à liberação dos recursos do TC/PAC 534/14 firmado com a Funasa aprovada pelo banco | milestone | 0d | 2018-12-20 A | 2018-12-20 A | 2580FS+2d | 100% |  | 2018-12-20 | 2018-12-20 | 0d | 2018-12-20 | 2018-12-20 |  |  |  | Verde | Verde | 100% | 100 | 100% | Compensatória | Verde | 100% | 100% | 100 | 100 | Município | 100 | 100 |  |
| 2582 | 3.1.3.35.1.4 | Adequar projeto de SES |  | 1d | 2018-12-21 A | 2018-12-21 A | 2581 | 100% |  | 2018-12-21 | 2018-12-21 | 1d | 2018-12-21 | 2018-12-21 |  |  |  | Verde | Verde | 100% | 100 | 100% | Compensatória | Verde | 100% | 100% | 100 | 100 | Município | 100 | 100 |  |
| 2583 | 3.1.3.35.1.5 | Recurso do projeto de São José do Goiabal do Pleito SJGESPJ02 - Adequação do projeto de SES da sede do municipio. Ajuste necessário à liberação dos recursos do TC/PAC 534/14 firmado com a Funasa repassado | milestone | 0d | 2018-12-21 A | 2018-12-21 A | 2582 | 100% |  | 2018-12-21 | 2018-12-21 | 0d | 2018-12-21 | 2018-12-21 |  |  |  | Verde | Verde | 100% | 100 | 100% | Compensatória | Verde | 100% | 100% | 100 | 100 | Banco | 100 | 100 |  |
| 2584 | 3.1.3.35.1.6 | Pleito SJGESPJ02 - Adequação do projeto de SES da sede do municipio. Ajuste necessário à liberação dos recursos do TC/PAC 534/14 firmado com a Funasa de São José do Goiabal concluído | milestone | 0d | 2018-12-21 A | 2018-12-21 A | 2583 | 100% |  | 2018-12-21 | 2018-12-21 | 0d | 2018-12-21 | 2018-12-21 |  |  |  | Verde | Verde | 100% | 100 | 100% | Compensatória | Verde | 100% | 100% | 100 | 100 | Município | 100 | 100 |  |

Notes:
- 2562: Em 24/04/2019: pleito aprovado dia 28/03 pelo CIF na deliberação 269 conforme planilha de Gestão de Pleitos
- 2565: 21/05/2019: conferir com município o andamento da tarefa na reunião / 28/05/2019: município solicitou mais 2 meses para terminar a licitação / 02/07/2019: o município está elaborando o TR.
- 2576: Valor de recurso destinado ao munícipio: R$9.453.986,14
- 2577: São José do Goiabal teve 100% dos pleitos de Esgotamento Sanitário aprovado (R$4.254.000,00), conforme Deliberação 75. / O município teve o pleito de resíduos sólidos negado (R$472.699,31, equivalente a 10% do total do recurso) / São José do Goiabal solicitou mudança de pleito, e foi autorizado pelo CIF. / · Reembolso do projeto, já executado, para a sede/ ·100% dos recursos de SES para a Sede/ ·Retirada de São João do pleito de destinação de R$189.100,00 para projetos, pois o mesmo já foi contemplado no projeto da sede. / O pleito de projeto não está vinculado a nenhuma obra (o recurso para execução não será da Renova).
- 2579: Em 25/04/2019: conforme planilha controle gerencial Renova

| ID | WBS | Task | Type | Duration | Start | Finish | Predecessors | Complete | Remaining | Baseline start | Baseline finish | Baseline duration | Baseline 1 start | Baseline 1 finish | Total slack | Free slack | Text1 | Text2 | Text3 | Text4 | Text5 | Text6 | Text7 | Text8 | Text12 | Text14 | Text15 | Text16 | Text17 | Text9 | Text18 |
| --- | --- | --- | --- | --- | --- | --- | --- | --- | --- | --- | --- | --- | --- | --- | --- | --- | --- | --- | --- | --- | --- | --- | --- | --- | --- | --- | --- | --- | --- | --- | --- |
| 2585 | 3.1.3.35.2 | **Pleito SJGESPJ03 - Elaboração de projetos de engenharia de sistemas de esgotamento sanitário para as localidades de Biboca, Patrimônio, Lagoa das Palmeiras, Messias Gomes e Isidório** |  | 271d | 2018-08-28 A | 2019-09-24 |  | 77% | 63.32d | 2018-08-28 | 2019-12-31 | 337d | 2018-08-28 | 2019-08-30 | 1018d |  | Verde | Verde | 56% | 38 | 56 | 69% | 69 | Compensatória | Vermelho | 36% | 36 | 25% | 25 |  |  |
| 2586 | 3.1.3.35.2.1 | Licitar Projetos |  | 64d | 2018-08-28 A | 2018-12-03 A | 3046FS+12d | 100% |  | 2018-08-28 | 2018-12-03 | 64d | 2018-08-28 | 2018-12-03 |  |  | Verde | Verde | 100% | 100 | 100 | 100% | 100 | Compensatória | Verde | 100% | 100 | 100% | 100 | Município |  |
| 2587 | 3.1.3.35.2.2 | **Elaboração do Projeto** |  | 140d | 2019-02-28 A | 2019-09-24 |  | 66% | 48.22d | 2019-02-28 | 2019-12-31 | 206d | 2019-02-28 | 2019-08-30 | 1018d |  | Verde | Verde | 29% | 19 | 29 | 59% | 59 | Compensatória | Vermelho | 29% | 29 | 17% | 17 |  |  |
| 2588 | 3.1.3.35.2.2.1 | Elaborar Projeto |  | 73d | 2019-02-28 A | 2019-06-19 A | 2586FS+62d | 100% |  | 2019-02-28 | 2019-09-23 | 139d | 2019-02-28 | 2019-05-27 |  |  | Verde | Verde | 43% | 27 | 43 | 58% | 58 | Compensatória | Vermelho | 43% | 43 | 25% | 25 | Município | Conforme agendado |
| 2589 | 3.1.3.35.2.2.2 | Projeto de São José do Goiabal do Pleito SJGESPJ03 - Elaboração de projetos de engenharia de sistemas de esgotamento sanitário para as localidades de Biboca, Patrimônio, Lagoa das Palmeiras, Messias Gomes e Isidório apresentado ao banco | milestone | 0d | 2019-06-19 A | 2019-06-19 A | 2588 | 100% |  | 2019-09-23 | 2019-09-23 | 0d | 2019-05-27 | 2019-05-27 |  |  | Verde | Verde | 0% |  |  | 0% |  | Compensatória | Verde | 0% |  | 0% |  | Município |  |
| 2590 | 3.1.3.35.2.2.3 | Analisar projeto |  | 62d | 2019-06-21 A | 2019-09-17 | 2589 | 25% | 46.5d | 2019-09-24 | 2019-12-20 | 62d | 2019-05-28 | 2019-06-26 | 1018d | 0d | Verde | Verde | 0% |  |  | 0% |  | Compensatória | Verde | 0% |  | 0% |  | Banco | Critério FR |
| 2591 | 3.1.3.35.2.2.4 | Projeto de São José do Goiabal do Pleito SJGESPJ03 - Elaboração de projetos de engenharia de sistemas de esgotamento sanitário para as localidades de Biboca, Patrimônio, Lagoa das Palmeiras, Messias Gomes e Isidório concluído | milestone | 0d | 2019-09-17 | 2019-09-17 | 2590 |  |  | 2019-12-20 | 2019-12-20 | 0d | 2019-08-23 | 2019-08-23 | 1018d | 0d | Verde | Verde | 0% |  |  | 0% |  | Compensatória | Verde | 0% |  | 0% |  | Município |  |
| 2592 | 3.1.3.35.2.2.5 | Recurso do projeto de São José do Goiabal do Pleito SJGESPJ03 - Elaboração de projetos de engenharia de sistemas de esgotamento sanitário para as localidades de Biboca, Patrimônio, Lagoa das Palmeiras, Messias Gomes e Isidório repassado | milestone | 0d | 2019-09-24 | 2019-09-24 | 2591FS+5d |  |  | 2019-12-31 | 2019-12-31 | 0d | 2019-08-30 | 2019-08-30 | 1018d | 0d | Verde | Verde | 0% |  |  | 0% |  | Compensatória | Verde | 0% |  | 0% |  | Banco |  |
| 2593 | 3.1.3.35.2.3 | Pleito SJGESPJ03 - Elaboração de projetos de engenharia de sistemas de esgotamento sanitário para as localidades de Biboca, Patrimônio, Lagoa das Palmeiras, Messias Gomes e Isidório de São José do Goiabal concluído | milestone | 0d | 2019-09-24 | 2019-09-24 | 2592 |  |  | 2019-12-31 | 2019-12-31 | 0d | 2019-08-30 | 2019-08-30 | 1018d |  | Verde | Verde | 0% |  |  | 0% |  | Compensatória | Verde | 0% |  | 0% |  | Município |  |
| 2594 | 3.1.3.35.3 | **Pleito SJGESOB02 - Ampliação e adequação do sistema de esgotamento sanitário da sede do município** |  | 375d | 2019-04-05 A | 2020-10-06 |  | 10% | 336.49d | 2019-04-05 | 2020-10-06 | 375d | 2019-04-02 | 2020-10-14 | 761d |  | Verde | Verde | 10% | 10 | 10 | 100% | 100 | Compensatória | Verde | 13% | 13 | 13% | 13 |  |  |
| 2595 | 3.1.3.35.3.1 | Executar obra |  | 250d | 2019-04-05 A | 2020-04-07 | 3052FS+77d | 15% | 212d | 2019-04-05 | 2020-04-07 | 250d | 2019-04-02 | 2020-04-02 | 761d | 0d | Verde | Verde | 15% | 15 | 15 | 100% | 100 | Compensatória | Verde | 15% | 15 | 15% | 15 | Município |  |
| 2596 | 3.1.3.35.3.2 | Realizar processo de pré-operação |  | 120d | 2020-04-08 | 2020-09-29 | 2595 |  |  | 2020-04-08 | 2020-09-29 | 120d | 2020-04-03 | 2020-10-06 | 761d | 0d | Verde | Verde | 0% |  |  | 0% |  | Compensatória | Verde | 0% |  | 0% |  | Município |  |
| 2597 | 3.1.3.35.3.3 | Recurso da obra de São José do Goiabal do Pleito SJGESOB02 - Ampliação e adequação do sistema de esgotamento sanitário da sede do município repassado | milestone | 0d | 2020-10-06 | 2020-10-06 | 2596FS+5d |  |  | 2020-10-06 | 2020-10-06 | 0d | 2020-10-14 | 2020-10-14 | 761d | 0d | Verde | Verde | 0% |  |  | 0% |  | Compensatória | Verde | 0% |  | 0% |  | Banco |  |
| 2598 | 3.1.3.35.3.4 | Pleito SJGESOB02 - Ampliação e adequação do sistema de esgotamento sanitário da sede do município de São José do Goiabal concluído | milestone | 0d | 2020-10-06 | 2020-10-06 | 2597 |  |  | 2020-10-06 | 2020-10-06 | 0d | 2020-10-14 | 2020-10-14 | 761d |  | Verde | Verde | 0% |  |  | 0% |  | Compensatória | Verde | 0% |  | 0% |  | Município |  |
| 2599 | 3.1.3.35.4 | **Pleito SJGRSPM01 - Elaboração do Plano Intermunicipal de Gestão Integrada de Resíduos Sólidos para os Municípios associados ao Consórcio Intermunicipal Multissetorial do Vale do Piranga (PIGIRS/CIMVALPI),** |  | 1082d | 2019-06-25 A | 2023-10-30 |  |  | 1082d | 2019-08-30 | 2023-10-30 | 1035d | 2019-08-30 | 2024-01-30 | 0d |  | Verde | Verde | 0% |  |  | 0% |  | Compensatória | Verde | 0% |  | 0% |  |  |  |
| 2600 | 3.1.3.35.4.1 | Pleito SJGRSPM01 - Elaboração do Plano Intermunicipal de Gestão Integrada de Resíduos Sólidos para os Municípios associados ao Consórcio Intermunicipal Multissetorial do Vale do Piranga (PIGIRS/CIMVALPI), aprovado pelo CIF | milestone | 0d | 2019-06-25 A | 2019-06-25 A | 3046FS+219d | 100% |  | 2019-08-30 | 2019-08-30 | 0d | 2019-08-30 | 2019-08-30 |  |  | Verde | Verde | 0% |  |  | 0% |  | Compensatória | Verde | 0% |  | 0% |  | CT/CIF |  |
| 2601 | 3.1.3.35.4.2 | Iniciar serviço/projeto/obra do pleito de São José do Goiabal de Resíduos Sólidos a definir |  | 1d | 2019-09-02 | 2019-09-02 | 2600FS+47d |  |  | 2019-09-02 | 2019-09-02 | 1d | 2019-09-02 | 2019-09-02 | 0d |  | Verde | Verde | 0% |  |  | 0% |  | Compensatória | Verde | 0% |  | 0% |  | Município | Critério FR |
| 2602 | 3.1.3.35.4.3 | Pleito SJGRSPM01 - Elaboração do Plano Intermunicipal de Gestão Integrada de Resíduos Sólidos para os Municípios associados ao Consórcio Intermunicipal Multissetorial do Vale do Piranga (PIGIRS/CIMVALPI) concluído | milestone | 0d | 2023-10-30 | 2023-10-30 | 2601FS+1034d |  |  | 2023-10-30 | 2023-10-30 | 0d | 2024-01-30 | 2024-01-30 | 0d |  | Verde | Verde | 0% |  |  | 0% |  | Compensatória | Verde | 0% |  | 0% |  | Município |  |
| 2603 | 3.1.3.35.5 | Recursos de São José do Goiabal repassados | milestone | 0d | 2023-10-30 | 2023-10-30 | 2593, 2584, 2598, 2602 |  |  | 2023-10-30 | 2023-10-30 | 0d | 2018-12-19 | 2018-12-19 | 0d |  | Verde | Verde | 0% |  |  | 0% |  | Compensatória | Verde | 0% |  | 0% |  | Banco |  |
| 2604 | 3.1.3.36 | **São Pedro dos Ferros** |  | 1243d | 2018-11-01 A | 2023-10-30 |  | 11% | 1106.66d | 2018-11-01 | 2023-10-30 | 1243d | 2018-11-01 | 2024-01-30 | 0d |  | Verde | Verde | 11% |  | 11 | 0% |  | Compensatória | Vermelho | 0% |  | 0% |  |  |  |
| 2605 | 3.1.3.36.1 | **Pleito SPFESPJ01 - Elaboração de projeto de engenharia para a sede do município e distrito de Águas Férreas** |  | 570d | 2018-11-01 A | 2021-02-12 |  | 22% | 444.78d | 2018-11-01 | 2020-08-28 | 456d | 2018-11-01 | 2020-07-28 | 297d |  | Verde | Verde | 31% | 19 | 31 | 0% |  | Compensatória | Vermelho | 4% |  | 0% |  |  |  |
| 2606 | 3.1.3.36.1.1 | Avaliar escopo do pleito |  | 20d | 2019-09-02 | 2019-09-27 | 3052FS+178d |  |  | 2019-09-02 | 2019-09-27 | 20d |  |  | 297d | 0d |  |  |  |  |  |  |  |  |  |  |  |  |  |  |  |
| 2607 | 3.1.3.36.1.2 | **Licitação do Projeto** |  | 287d | 2018-11-01 A | 2019-12-23 |  | 74% | 74.51d | 2018-11-01 | 2019-07-11 | 173d | 2018-11-01 | 2019-06-07 | 297d |  | Verde | Verde | 83% | 73 | 83 | 0% |  | Compensatória | Vermelho | 47% | 47 | 0% |  |  |  |
| 2608 | 3.1.3.36.1.2.1 | Licitar projeto - processo cancelado |  | 154d | 2018-11-01 A | 2019-06-13 A | 3052FS-30d | 100% |  | 2018-11-01 | 2019-06-13 | 154d | 2018-11-01 | 2019-05-13 |  |  | Verde | Verde | 94% | 80 | 94 | 0% |  | Compensatória | Vermelho | 94% | 94 | 0% |  | Município | Conforme agendado |
| 2609 | 3.1.3.36.1.2.2 | Licitar projeto de engenharia para a sede do município e distrito de Águas Férreas de São Pedro dos Ferros |  | 40d | 2019-09-30 | 2019-11-25 | 2606, 2608 |  |  | 2019-09-30 | 2019-11-25 | 40d |  |  | 297d | 0d |  |  |  |  |  |  |  |  |  |  |  |  |  |  |  |
| 2610 | 3.1.3.36.1.2.3 | Documentação de licitação de São Pedro dos Ferros do Pleito SPFESPJ01 - Elaboração de projeto de engenharia para a sede do município e distrito de Águas Férreas apresentada ao banco | milestone | 0d | 2019-12-02 | 2019-12-02 | 2609FS+5d |  |  | 2019-06-21 | 2019-06-21 | 0d | 2019-05-20 | 2019-05-20 | 297d | 0d | Verde | Verde | 0% |  |  | 0% |  | Compensatória | Verde | 0% |  | 0% |  | Município |  |
| 2611 | 3.1.3.36.1.2.4 | Analisar e emitir resultado da licitação do projeto |  | 14d | 2019-12-03 | 2019-12-23 | 2610 |  |  | 2019-06-24 | 2019-07-11 | 14d | 2019-05-21 | 2019-06-07 | 297d | 0d | Verde | Verde | 0% |  |  | 0% |  | Compensatória | Verde | 0% |  | 0% |  | Banco | Critério FR |
| 2612 | 3.1.3.36.1.2.5 | Licitação do projeto de São Pedro dos Ferros do Pleito SPFESPJ01 - Elaboração de projeto de engenharia para a sede do município e distrito de Águas Férreas concluída | milestone | 0d | 2019-12-23 | 2019-12-23 | 2611 |  |  | 2019-07-11 | 2019-07-11 | 0d | 2019-06-07 | 2019-06-07 | 297d | 0d | Verde | Verde | 0% |  |  | 0% |  | Compensatória | Verde | 0% |  | 0% |  | Município |  |

Notes:
- 2586: 25/01/19 - A licitação foi concluída e está aguardando aprovação do banco
- 2588: Em 29/04/2019: atualizado como agendado / 21/05/2019: verificar com municío na reunião o andamento do projeto / 27/05/2019: a empresa contratada entregará o projeto dia 21/06/2019; pactuado mais 90 dias para analisar projeto e possível revisão do projeto. O município vai falar com empresa para apresentar o projeto em partes para o banco começar a análise e pagamento. / 02/07/2019: O prefeito Beto protolou projetos em mão ao BDMG no dia 19/06/2019 e pendências foram encaminhadas por email (Falta o volume de relatório de sondagem) no dia 24/06/2019.
- 2589: 02/07/2019: O prefeito Beto protolou projetos em mão ao BDMG no dia 19/06/2019 e pendências foram encaminhadas por email (Falta o volume de relatório de sondagem) no dia 24/06/2019.
- 2590: 02/07/2019: O prefeito Beto protolou projetos em mão ao BDMG no dia 19/06/2019 e pendências foram encaminhadas por email (Falta o volume de relatório de sondagem) no dia 24/06/2019.
- 2595: 25/04/2019: o início da obra (uso de recurso da Renova) foi autorizado pelo banco 02/04/2019. / 21/05/2019: verificar com o município o envio da OS ao banco e o andamento da obra / 22/05/2019: OS emitida dia 05/04/2019 / 27/05/2019: primeira medição apresentada ao banco hoje / 02/07/2019: Danielle vai conseguir amanhã os documentos das obras com o avanço físico.
- 2600: 22/05/2019: pleito de CIMVALPI
- 2603: Valor de recurso destinado ao munícipio: R$4.726.993,07
- 2604: São Pedro dos Ferros teve 88,9% (R$4.200.000,00) dos recursos destinado para Esgotamento Sanitário aprovado, conforme Deliberação 75. / O município teve o pleito de resíduos sólidos negado (R$472.699,31, equivalente a 10% do total do recurso,).
- 2606: 03/07/2019: Danielle informou que a diretoria da Copasa aprovou o processo de concessão 14/06/2019. Agora precisa da aprovação do conselho dia 25/07. Em agosto assina o contrato. A partir de setembro eles vão definir o que será licitado.
- 2608: 22/01/19 - Ainda não licitou pois está aguardando formalização da CT quato a necessidade de 3 orçamentos / Em 29/04/2019: atualizado como agendado / 21/05/2019: 17/05/2019 (Gislaine) - E-mail enviado cobrando processo licitatório do município conforme check list encaminhado (planilha controle gerencial Renova). conferir na reunião com o município a data de término prevista. / 27/05/2019: aguardando resposta da Copasa dia 13/06/2019 para incluir o esgoto na conta deles. em março começou a negociação com a Copasa / 03/07/2019: Danielle informou que a diretoria da Copasa aprovou o processo de concessão 14/06/2019. Agora precisa da aprovação do conselho dia 25/07. Em agosto assina o contrato. A partir de setembro eles vão definir o que será licitado.

| ID | WBS | Task | Type | Duration | Start | Finish | Predecessors | Baseline start | Baseline finish | Baseline duration | Baseline 1 start | Baseline 1 finish | Total slack | Free slack | Text1 | Text2 | Text3 | Text6 | Text8 | Text12 | Text14 | Text16 | Text9 | Text18 |
| --- | --- | --- | --- | --- | --- | --- | --- | --- | --- | --- | --- | --- | --- | --- | --- | --- | --- | --- | --- | --- | --- | --- | --- | --- |
| 2613 | 3.1.3.36.1.3 | **Elaboração do Projeto Básico** |  | 152d | 2019-12-26 | 2020-08-05 |  | 2019-07-12 | 2020-02-18 | 152d | 2019-06-10 | 2020-01-16 | 297d |  | Verde | Verde | 0% | 0% | Compensatória | Verde | 0% | 0% |  |  |
| 2614 | 3.1.3.36.1.3.1 | Elaborar Projeto Básico |  | 83d | 2019-12-26 | 2020-04-28 | 2612 | 2019-07-12 | 2019-11-06 | 83d | 2019-06-10 | 2019-10-04 | 297d | 0d | Verde | Verde | 0% | 0% | Compensatória | Verde | 0% | 0% | Município | Critério FR |
| 2615 | 3.1.3.36.1.3.2 | Projeto básico de São Pedro dos Ferros do Pleito SPFESPJ01 - Elaboração de projeto de engenharia para a sede do município e distrito de Águas Férreas apresentado ao banco | milestone | 0d | 2020-04-28 | 2020-04-28 | 2614 | 2019-11-06 | 2019-11-06 | 0d | 2019-10-04 | 2019-10-04 | 297d | 0d | Verde | Verde | 0% | 0% | Compensatória | Verde | 0% | 0% | Município |  |
| 2616 | 3.1.3.36.1.3.3 | Analisar projeto básico |  | 64d | 2020-04-29 | 2020-07-29 | 2615 | 2019-11-07 | 2020-02-11 | 64d | 2019-10-07 | 2019-11-05 | 297d | 0d | Verde | Verde | 0% | 0% | Compensatória | Verde | 0% | 0% | Banco | Critério FR |
| 2617 | 3.1.3.36.1.3.4 | Projeto básico de São Pedro dos Ferros do Pleito SPFESPJ01 - Elaboração de projeto de engenharia para a sede do município e distrito de Águas Férreas concluído | milestone | 0d | 2020-07-29 | 2020-07-29 | 2616 | 2020-02-11 | 2020-02-11 | 0d | 2020-01-09 | 2020-01-09 | 297d | 0d | Verde | Verde | 0% | 0% | Compensatória | Verde | 0% | 0% | Município |  |
| 2618 | 3.1.3.36.1.3.5 | Recurso do projeto básico de São Pedro dos Ferros do Pleito SPFESPJ01 - Elaboração de projeto de engenharia para a sede do município e distrito de Águas Férreas repassado | milestone | 0d | 2020-08-05 | 2020-08-05 | 2617FS+5d | 2020-02-18 | 2020-02-18 | 0d | 2020-01-16 | 2020-01-16 | 423d | 126d | Verde | Verde | 0% | 0% | Compensatória | Verde | 0% | 0% | Banco |  |
| 2619 | 3.1.3.36.1.4 | Realizar Licenciamento Ambiental |  | 195d | 2020-04-29 | 2021-02-05 | 2615 | 2019-11-07 | 2020-08-21 | 195d | 2019-10-07 | 2020-07-21 | 297d | 0d | Verde | Verde | 0% | 0% | Compensatória | Verde | 0% | 0% | Município |  |
| 2620 | 3.1.3.36.1.5 | **Elaboração do Projeto Executivo** |  | 136d | 2020-07-30 | 2021-02-12 |  | 2020-02-12 | 2020-08-28 | 136d | 2020-01-10 | 2020-07-28 | 297d |  | Verde | Verde | 0% | 0% | Compensatória | Verde | 0% | 0% |  |  |
| 2621 | 3.1.3.36.1.5.1 | Elaborar Projeto Executivo |  | 65d | 2020-07-30 | 2020-10-30 | 2617 | 2020-02-12 | 2020-05-20 | 65d | 2020-01-10 | 2020-04-15 | 297d | 0d | Verde | Verde | 0% | 0% | Compensatória | Verde | 0% | 0% | Município |  |
| 2622 | 3.1.3.36.1.5.2 | Projeto executivo de São Pedro dos Ferros do Pleito SPFESPJ01 - Elaboração de projeto de engenharia para a sede do município e distrito de Águas Férreas apresentado ao banco | milestone | 0d | 2020-10-30 | 2020-10-30 | 2621 | 2020-05-20 | 2020-05-20 | 0d | 2020-04-15 | 2020-04-15 | 297d | 0d | Verde | Verde | 0% | 0% | Compensatória | Verde | 0% | 0% | Município |  |
| 2623 | 3.1.3.36.1.5.3 | Analisar projeto executivo |  | 66d | 2020-11-03 | 2021-02-05 | 2622 | 2020-05-21 | 2020-08-21 | 66d | 2020-04-16 | 2020-05-20 | 297d | 0d | Verde | Verde | 0% | 0% | Compensatória | Verde | 0% | 0% | Banco |  |
| 2624 | 3.1.3.36.1.5.4 | Projeto Executivo de São Pedro dos Ferros do Pleito SPFESPJ01 - Elaboração de projeto de engenharia para a sede do município e distrito de Águas Férreas concluído | milestone | 0d | 2021-02-05 | 2021-02-05 | 2618, 2619, 2623 | 2020-08-21 | 2020-08-21 | 0d | 2020-07-21 | 2020-07-21 | 297d | 0d | Verde | Verde | 0% | 0% | Compensatória | Verde | 0% | 0% | Município |  |
| 2625 | 3.1.3.36.1.5.5 | Recurso do projeto executivo de São Pedro dos Ferros do Pleito SPFESPJ01 - Elaboração de projeto de engenharia para a sede do município e distrito de Águas Férreas repassado | milestone | 0d | 2021-02-12 | 2021-02-12 | 2624FS+5d | 2020-08-28 | 2020-08-28 | 0d | 2020-07-28 | 2020-07-28 | 297d | 0d | Verde | Verde | 0% | 0% | Compensatória | Verde | 0% | 0% | Banco |  |
| 2626 | 3.1.3.36.1.6 | Pleito SPFESPJ01 - Elaboração de projeto de engenharia para a sede do município e distrito de Águas Férreas de São Pedro dos Ferros concluído | milestone | 0d | 2021-02-12 | 2021-02-12 | 2625 | 2020-08-28 | 2020-08-28 | 0d | 2020-07-28 | 2020-07-28 | 297d | 0d | Verde | Verde | 0% | 0% | Compensatória | Verde | 0% | 0% | Município |  |
| 2627 | 3.1.3.36.2 | **Pleito SPFESOB01 - Execução de obras para coleta e tratamento de esgoto para a sede do município** |  | 376d | 2021-02-12 | 2022-08-18 |  | 2020-08-28 | 2022-03-07 | 376d | 2020-07-28 | 2022-02-09 | 297d |  | Verde | Verde | 0% | 0% | Compensatória | Verde | 0% | 0% |  |  |
| 2628 | 3.1.3.36.2.1 | **Licitação da Obra** |  | 59d | 2021-02-12 | 2021-05-13 |  | 2020-08-28 | 2020-11-24 | 59d | 2020-07-28 | 2020-10-21 | 297d |  | Verde | Verde | 0% | 0% | Compensatória | Verde | 0% | 0% |  |  |
| 2629 | 3.1.3.36.2.1.1 | Licitação da obra de São Pedro dos Ferros do Pleito SPFESOB01 - Execução de obras para coleta e tratamento de esgoto para a sede do município autorizada pelo banco | milestone | 0d | 2021-02-12 | 2021-02-12 | 2626 | 2020-08-28 | 2020-08-28 | 0d | 2020-07-28 | 2020-07-28 | 297d | 0d | Verde | Verde | 0% | 0% | Compensatória | Verde | 0% | 0% | Banco |  |
| 2630 | 3.1.3.36.2.1.2 | Licitar Obra |  | 44d | 2021-02-18 | 2021-04-22 | 2629 | 2020-08-31 | 2020-11-03 | 44d | 2020-07-29 | 2020-09-29 | 297d | 0d | Verde | Verde | 0% | 0% | Compensatória | Verde | 0% | 0% | Município |  |
| 2631 | 3.1.3.36.2.1.3 | Analisar e emitir resultado da licitação da obra |  | 15d | 2021-04-23 | 2021-05-13 | 2630 | 2020-11-04 | 2020-11-24 | 15d | 2020-09-30 | 2020-10-21 | 297d | 0d | Verde | Verde | 0% | 0% | Compensatória | Verde | 0% | 0% | Banco |  |
| 2632 | 3.1.3.36.2.1.4 | Licitação da obra de São Pedro dos Ferros do Pleito SPFESOB01 - Execução de obras para coleta e tratamento de esgoto para a sede do município concluída | milestone | 0d | 2021-05-13 | 2021-05-13 | 2631 | 2020-11-24 | 2020-11-24 | 0d | 2020-10-21 | 2020-10-21 | 297d | 0d | Verde | Verde | 0% | 0% | Compensatória | Verde | 0% | 0% | Município |  |
| 2633 | 3.1.3.36.2.2 | Executar obra |  | 172d | 2021-06-14 | 2022-02-15 | 2632FS+20d | 2020-12-23 | 2021-09-01 | 172d | 2020-11-20 | 2021-07-30 | 297d | 0d | Verde | Verde | 0% | 0% | Compensatória | Verde | 0% | 0% | Município |  |
| 2634 | 3.1.3.36.2.3 | Realizar processo de pré-operação |  | 120d | 2022-02-16 | 2022-08-10 | 2633 | 2021-09-02 | 2022-02-23 | 120d | 2021-08-02 | 2022-02-02 | 297d | 0d | Verde | Verde | 0% | 0% | Compensatória | Verde | 0% | 0% | Município |  |
| 2635 | 3.1.3.36.2.4 | Recurso da obra de São Pedro dos Ferros do Pleito SPFESOB01 - Execução de obras para coleta e tratamento de esgoto para a sede do município repassado | milestone | 0d | 2022-08-18 | 2022-08-18 | 2634FS+5d | 2022-03-07 | 2022-03-07 | 0d | 2022-02-09 | 2022-02-09 | 297d | 0d | Verde | Verde | 0% | 0% | Compensatória | Verde | 0% | 0% | Banco |  |
| 2636 | 3.1.3.36.2.5 | Pleito SPFESOB01 - Execução de obras para coleta e tratamento de esgoto para a sede do município de São Pedro dos Ferros concluído | milestone | 0d | 2022-08-18 | 2022-08-18 | 2635 | 2022-03-07 | 2022-03-07 | 0d | 2022-02-09 | 2022-02-09 | 297d |  | Verde | Verde | 0% | 0% | Compensatória | Verde | 0% | 0% | Município |  |

Notes:
- 2621: 24/05/2019: município pactuou com a Renova 3 meses para elaborar projeto executivo

| ID | WBS | Task | Type | Duration | Start | Finish | Predecessors | Complete | Remaining | Baseline start | Baseline finish | Baseline duration | Baseline 1 start | Baseline 1 finish | Total slack | Free slack | Text1 | Text2 | Text3 | Text6 | Text8 | Text12 | Text14 | Text16 | Text9 | Text18 | Text4 | Text5 | Text15 |
| --- | --- | --- | --- | --- | --- | --- | --- | --- | --- | --- | --- | --- | --- | --- | --- | --- | --- | --- | --- | --- | --- | --- | --- | --- | --- | --- | --- | --- | --- |
| 2637 | 3.1.3.36.3 | **Pleito SPFESOB02 - Execução de obras para coleta e tratamento de esgoto para distrito de Águas Férreas** |  | 376d | 2021-02-12 | 2022-08-18 |  |  |  | 2020-08-28 | 2022-03-07 | 376d | 2020-07-28 | 2022-02-09 | 297d |  | Verde | Verde | 0% | 0% | Compensatória | Verde | 0% | 0% |  |  |  |  |  |
| 2638 | 3.1.3.36.3.1 | **Licitação da Obra** |  | 59d | 2021-02-12 | 2021-05-13 |  |  |  | 2020-08-28 | 2020-11-24 | 59d | 2020-07-28 | 2020-10-21 | 297d |  | Verde | Verde | 0% | 0% | Compensatória | Verde | 0% | 0% |  |  |  |  |  |
| 2639 | 3.1.3.36.3.1.1 | Licitação da obra de São Pedro dos Ferros do Pleito SPFESOB02 - Execução de obras para coleta e tratamento de esgoto para distrito de Águas Férreas autorizada pelo banco | milestone | 0d | 2021-02-12 | 2021-02-12 | 2626 |  |  | 2020-08-28 | 2020-08-28 | 0d | 2020-07-28 | 2020-07-28 | 297d | 0d | Verde | Verde | 0% | 0% | Compensatória | Verde | 0% | 0% | Banco |  |  |  |  |
| 2640 | 3.1.3.36.3.1.2 | Licitar Obra |  | 44d | 2021-02-18 | 2021-04-22 | 2639 |  |  | 2020-08-31 | 2020-11-03 | 44d | 2020-07-29 | 2020-09-29 | 297d | 0d | Verde | Verde | 0% | 0% | Compensatória | Verde | 0% | 0% | Município |  |  |  |  |
| 2641 | 3.1.3.36.3.1.3 | Analisar e emitir resultado da licitação da obra |  | 15d | 2021-04-23 | 2021-05-13 | 2640 |  |  | 2020-11-04 | 2020-11-24 | 15d | 2020-09-30 | 2020-10-21 | 297d | 0d | Verde | Verde | 0% | 0% | Compensatória | Verde | 0% | 0% | Banco |  |  |  |  |
| 2642 | 3.1.3.36.3.1.4 | Licitação da obra de São Pedro dos Ferros do Pleito SPFESOB02 - Execução de obras para coleta e tratamento de esgoto para distrito de Águas Férreas concluída | milestone | 0d | 2021-05-13 | 2021-05-13 | 2641 |  |  | 2020-11-24 | 2020-11-24 | 0d | 2020-10-21 | 2020-10-21 | 297d | 0d | Verde | Verde | 0% | 0% | Compensatória | Verde | 0% | 0% | Município |  |  |  |  |
| 2643 | 3.1.3.36.3.2 | Executar obra |  | 172d | 2021-06-14 | 2022-02-15 | 2642FS+20d |  |  | 2020-12-23 | 2021-09-01 | 172d | 2020-11-20 | 2021-07-30 | 297d | 0d | Verde | Verde | 0% | 0% | Compensatória | Verde | 0% | 0% | Município |  |  |  |  |
| 2644 | 3.1.3.36.3.3 | Realizar processo de pré-operação |  | 120d | 2022-02-16 | 2022-08-10 | 2643 |  |  | 2021-09-02 | 2022-02-23 | 120d | 2021-08-02 | 2022-02-02 | 297d | 0d | Verde | Verde | 0% | 0% | Compensatória | Verde | 0% | 0% | Município |  |  |  |  |
| 2645 | 3.1.3.36.3.4 | Recurso da obra de São Pedro dos Ferros do Pleito SPFESOB02 - Execução de obras para coleta e tratamento de esgoto para distrito de Águas Férreas repassado | milestone | 0d | 2022-08-18 | 2022-08-18 | 2644FS+5d |  |  | 2022-03-07 | 2022-03-07 | 0d | 2022-02-09 | 2022-02-09 | 297d | 0d | Verde | Verde | 0% | 0% | Compensatória | Verde | 0% | 0% | Banco |  |  |  |  |
| 2646 | 3.1.3.36.3.5 | Pleito SPFESOB02 - Execução de obras para coleta e tratamento de esgoto para distrito de Águas Férreas de São Pedro dos Ferros concluído | milestone | 0d | 2022-08-18 | 2022-08-18 | 2645 |  |  | 2022-03-07 | 2022-03-07 | 0d | 2022-02-09 | 2022-02-09 | 297d |  | Verde | Verde | 0% | 0% | Compensatória | Verde | 0% | 0% | Município |  |  |  |  |
| 2647 | 3.1.3.36.4 | **Pleito SPFRSPM01 - Elaboração do Plano Intermunicipal de Gestão Integrada de Resíduos Sólidos para os Municípios associados ao Consórcio Intermunicipal Multissetorial do Vale do Piranga (PIGIRS/CIMVALPI),** |  | 1082d | 2019-06-25 A | 2023-10-30 |  |  | 1082d | 2019-08-30 | 2023-10-30 | 1035d | 2019-08-30 | 2024-01-30 | 0d |  | Verde | Verde | 0% | 0% | Compensatória | Verde | 0% | 0% |  |  |  |  |  |
| 2648 | 3.1.3.36.4.1 | Pleito SPFRSPM01 - Elaboração do Plano Intermunicipal de Gestão Integrada de Resíduos Sólidos para os Municípios associados ao Consórcio Intermunicipal Multissetorial do Vale do Piranga (PIGIRS/CIMVALPI) de São Pedro dos Ferros aprovado pelo CIF | milestone | 0d | 2019-06-25 A | 2019-06-25 A | 3047FS+219d | 100% |  | 2019-08-30 | 2019-08-30 | 0d | 2019-08-30 | 2019-08-30 |  |  | Verde | Verde | 0% | 0% | Compensatória | Verde | 0% | 0% | CT/CIF |  |  |  |  |
| 2649 | 3.1.3.36.4.2 | Iniciar serviço/projeto/obra do pleito de São Pedro dos Ferros de Resíduos Sólidos a definir |  | 1d | 2019-09-02 | 2019-09-02 | 2648FS+47d |  |  | 2019-09-02 | 2019-09-02 | 1d | 2019-09-02 | 2019-09-02 | 0d |  | Verde | Verde | 0% | 0% | Compensatória | Verde | 0% | 0% | Município | Critério FR |  |  |  |
| 2650 | 3.1.3.36.4.3 | Pleito SPFRSPM01 - Elaboração do Plano Intermunicipal de Gestão Integrada de Resíduos Sólidos para os Municípios associados ao Consórcio Intermunicipal Multissetorial do Vale do Piranga (PIGIRS/CIMVALPI) de São Pedro dos Ferros concluído | milestone | 0d | 2023-10-30 | 2023-10-30 | 2649FS+1034d |  |  | 2023-10-30 | 2023-10-30 | 0d | 2024-01-30 | 2024-01-30 | 0d |  | Verde | Verde | 0% | 0% | Compensatória | Verde | 0% | 0% | Município |  |  |  |  |
| 2651 | 3.1.3.36.5 | Recursos de São Pedro dos Ferros repassados | milestone | 0d | 2023-10-30 | 2023-10-30 | 2626, 2636, 2646, 2650 |  |  | 2023-10-30 | 2023-10-30 | 0d | 2024-01-30 | 2024-01-30 | 0d |  | Verde | Verde | 0% | 0% | Compensatória | Verde | 0% | 0% | Banco |  |  |  |  |
| 2652 | 3.1.3.37 | **Sem-Peixe** |  | 1177d | 2019-02-04 A | 2023-10-30 |  | 12% | 1031.94d | 2019-02-04 | 2023-10-30 | 1177d | 2019-02-04 | 2024-01-30 | 0d |  | Verde | Verde | 6% | 0% | Compensatória | Vermelho | 1% | 0% |  |  |  |  |  |
| 2653 | 3.1.3.37.1 | **Pleito SEPESPJ01 - Elaboração de projeto de engenharia do distrito de São Bartolomeu** |  | 226d | 2019-02-04 A | 2020-01-02 |  | 28% | 163.31d | 2019-02-04 | 2019-12-19 | 219d | 2019-02-04 | 2020-06-22 | 951d |  | Verde | Verde | 36% | 0% | Compensatória | Vermelho | 13% | 0% |  |  | 18 | 36 | 13 |
| 2654 | 3.1.3.37.1.1 | **Licitação do Projeto** |  | 47d | 2019-04-26 A | 2019-07-03 |  | 78% | 10.5d | 2019-04-26 | 2019-06-24 | 40d | 2019-05-02 | 2019-10-29 | 602d |  | Verde | Verde | 62% | 0% | Compensatória | Vermelho | 48% | 0% |  |  | 16 | 62 | 48 |
| 2655 | 3.1.3.37.1.1.1 | Licitar projeto |  | 33d | 2019-04-26 A | 2019-06-12 A | 3052FS+90d | 100% |  | 2019-04-26 | 2019-06-03 | 26d | 2019-05-02 | 2019-10-02 |  |  | Verde | Verde | 96% | 0% | Compensatória | Vermelho | 96% | 0% | Município | Conforme agendado | 25 | 96 | 96 |
| 2656 | 3.1.3.37.1.1.2 | Documentação de licitação de Sem-Peixe do Pleito SEPESPJ01 - Elaboração de projeto de engenharia do distrito de São Bartolomeu apresentada ao banco | milestone | 0d | 2019-06-12 A | 2019-06-12 A | 2655 | 100% |  | 2019-06-03 | 2019-06-03 | 0d | 2019-10-09 | 2019-10-09 |  |  | Verde | Verde | 0% | 0% | Compensatória | Verde | 0% | 0% | Município |  |  |  |  |
| 2657 | 3.1.3.37.1.1.3 | Analisar e emitir resultado da licitação do projeto |  | 14d | 2019-06-13 A | 2019-07-03 | 2656 | 25% | 10.5d | 2019-06-04 | 2019-06-24 | 14d | 2019-10-10 | 2019-10-29 | 602d | 0d | Verde | Verde | 0% | 0% | Compensatória | Verde | 0% | 0% | Banco | Critério FR |  |  |  |
| 2658 | 3.1.3.37.1.1.4 | Licitação do projeto de Sem-Peixe do Pleito SEPESPJ01 - Elaboração de projeto de engenharia do distrito de São Bartolomeu concluída | milestone | 0d | 2019-07-03 | 2019-07-03 | 2657 |  |  | 2019-06-24 | 2019-06-24 | 0d | 2019-10-29 | 2019-10-29 | 602d | 0d | Verde | Verde | 0% | 0% | Compensatória | Verde | 0% | 0% | Município |  |  |  |  |
| 2659 | 3.1.3.37.1.2 | **Elaboração do Estudo de Concepção** |  | 85d | 2019-07-04 | 2019-10-31 |  |  |  | 2019-06-25 | 2019-10-22 | 85d |  |  | 602d |  | Verde | Verde | 0% | 0% | Compensatória | Verde | 0% | 0% |  |  |  |  |  |
| 2660 | 3.1.3.37.1.2.1 | Elaborar estudo |  | 20d | 2019-07-04 | 2019-07-31 | 2658 |  |  | 2019-06-25 | 2019-07-22 | 20d |  |  | 602d | 0d | Verde | Verde | 0% | 0% | Compensatória | Verde | 0% | 0% |  | Critério FR |  |  |  |
| 2661 | 3.1.3.37.1.2.2 | Estudo de concepção de Sem-Peixe do Pleito SEPESPJ01 - Elaboração de projeto de engenharia do distrito de São Bartolomeu apresentado ao banco | milestone | 0d | 2019-07-31 | 2019-07-31 | 2660 |  |  | 2019-07-22 | 2019-07-22 | 0d |  |  | 632d | 0d | Verde | Verde | 0% | 0% | Compensatória | Verde | 0% | 0% |  |  |  |  |  |
| 2662 | 3.1.3.37.1.2.3 | Analisar estudo |  | 60d | 2019-08-01 | 2019-10-24 | 2661 |  |  | 2019-07-23 | 2019-10-15 | 60d |  |  | 632d | 0d | Verde | Verde | 0% | 0% | Compensatória | Verde | 0% | 0% |  | Critério FR |  |  |  |
| 2663 | 3.1.3.37.1.2.4 | Estudo de concepção de Sem-Peixe do Pleito SEPESPJ01 - Elaboração de projeto de engenharia do distrito de São Bartolomeu concluído | milestone | 0d | 2019-10-24 | 2019-10-24 | 2662 |  |  | 2019-10-15 | 2019-10-15 | 0d |  |  | 632d | 0d | Verde | Verde | 0% | 0% | Compensatória | Verde | 0% | 0% |  |  |  |  |  |
| 2664 | 3.1.3.37.1.2.5 | Recurso do estudo de concepção de Sem-Peixe do Pleito SEPESPJ01 - Elaboração de projeto de engenharia do distrito de São Bartolomeu repassado | milestone | 0d | 2019-10-31 | 2019-10-31 | 2663FS+5d |  |  | 2019-10-22 | 2019-10-22 | 0d |  |  | 632d | 15d | Verde | Verde | 0% | 0% | Compensatória | Verde | 0% | 0% |  |  |  |  |  |

Notes:
- 2648: 22/05/2019: início do pleito igual os pleitos do CIMVALPI
- 2651: Valor de recurso destinado ao munícipio: R$4.726.993,07
- 2652: Sem Peixe teve 100% dos pleitos de Esgotamento Sanitário Aprovado (R$4.254.293,76), conforme Deliberação 75. / O município teve o pleito de resíduos sólidos negado (R$472.699,31, equivalente a 10% do total do recurso). / Aderiu à ata de registro de preço.
- 2655: 25/04/2019: o município está verificando a possibilidade fazer uma licitação própria e cancelar a adesão a ATA de registro de preço (report de apoio técnico de abril 2019). Foi premissado que o município irá licitar o projeto em 5 meses visto necessidade de iniciar pela elaboração do TR. Início previsto para 02/05. / 27/05/2019: semana que vem o município entregará o processo licitatório ao banco (03/06/2019). 26/04/2019 edital e abertura 14/05/2019. / 13/06/2019: processo licitatório protocolado no banco dia 12/06 conforme planilha Controle Gerencial Renova. Porém banco solicitou alguns esclarecimentos em relação ao nome dos distritos no projeto e aguarda uma resposta.
- 2656: 17/06/2019: processo licitatório foi protocolado no banco dia 12/06 conforme planilha Controle Gerencial Renova
- 2657: 27/06/2019: processo licitatório encaminhado ao jurídico no dia 13/06/2019 conforme planilha Controle Gerencial Renova

| ID | WBS | Task | Type | Duration | Start | Finish | Predecessors | Complete | Remaining | Baseline start | Baseline finish | Baseline duration | Baseline 1 start | Baseline 1 finish | Total slack | Free slack | Text1 | Text2 | Text3 | Text6 | Text8 | Text12 | Text14 | Text16 | Text18 | Text9 | Text4 | Text5 | Text15 |
| --- | --- | --- | --- | --- | --- | --- | --- | --- | --- | --- | --- | --- | --- | --- | --- | --- | --- | --- | --- | --- | --- | --- | --- | --- | --- | --- | --- | --- | --- |
| 2665 | 3.1.3.37.1.3 | **Elaboração do Projeto Básico** |  | 85d | 2019-08-01 | 2019-11-29 |  |  |  | 2019-07-23 | 2019-11-20 | 85d |  |  | 602d |  | Verde | Verde | 0% | 0% | Compensatória | Verde | 0% | 0% |  |  |  |  |  |
| 2666 | 3.1.3.37.1.3.1 | Elaborar Projeto Básico |  | 20d | 2019-08-01 | 2019-08-29 | 2660 |  |  | 2019-07-23 | 2019-08-20 | 20d |  |  | 602d | 0d | Verde | Verde | 0% | 0% | Compensatória | Verde | 0% | 0% | Critério FR |  |  |  |  |
| 2667 | 3.1.3.37.1.3.2 | Projeto básico de Sem-Peixe do Pleito SEPESPJ01 - Elaboração de projeto de engenharia do distrito de São Bartolomeu apresentado ao banco | milestone | 0d | 2019-08-29 | 2019-08-29 | 2666 |  |  | 2019-08-20 | 2019-08-20 | 0d |  |  | 617d | 0d | Verde | Verde | 0% | 0% | Compensatória | Verde | 0% | 0% |  |  |  |  |  |
| 2668 | 3.1.3.37.1.3.3 | Analisar projeto básico |  | 60d | 2019-08-30 | 2019-11-22 | 2667 |  |  | 2019-08-21 | 2019-11-12 | 60d |  |  | 617d | 0d | Verde | Verde | 0% | 0% | Compensatória | Verde | 0% | 0% | Critério FR |  |  |  |  |
| 2669 | 3.1.3.37.1.3.4 | Projeto básico de Sem-Peixe do Pleito SEPESPJ01 - Elaboração de projeto de engenharia do distrito de São Bartolomeu concluído | milestone | 0d | 2019-11-22 | 2019-11-22 | 2664, 2668 |  |  | 2019-11-12 | 2019-11-12 | 0d |  |  | 617d | 0d | Verde | Verde | 0% | 0% | Compensatória | Verde | 0% | 0% |  |  |  |  |  |
| 2670 | 3.1.3.37.1.3.5 | Recurso do projeto básico de Sem-Peixe do Pleito SEPESPJ01 - Elaboração de projeto de engenharia do distrito de São Bartolomeu repassado | milestone | 0d | 2019-11-29 | 2019-11-29 | 2669FS+5d |  |  | 2019-11-20 | 2019-11-20 | 0d |  |  | 617d | 15d | Verde | Verde | 0% | 0% | Compensatória | Verde | 0% | 0% |  |  |  |  |  |
| 2671 | 3.1.3.37.1.4 | **Elaboração do Projeto Executivo** |  | 85d | 2019-08-30 | 2020-01-02 |  |  |  | 2019-08-21 | 2019-12-19 | 85d | 2019-10-30 | 2020-06-22 | 602d |  | Verde | Verde | 0% | 0% | Compensatória | Verde | 0% | 0% |  |  |  |  |  |
| 2672 | 3.1.3.37.1.4.1 | Elaborar Projeto Executivo |  | 20d | 2019-08-30 | 2019-09-26 | 2666 |  |  | 2019-08-21 | 2019-09-17 | 20d | 2019-10-30 | 2020-03-11 | 602d | 0d | Verde | Verde | 0% | 0% | Compensatória | Verde | 0% | 0% | Critério FR | Município |  |  |  |
| 2673 | 3.1.3.37.1.4.2 | Projeto de Sem-Peixe do Pleito SEPESPJ01 - Elaboração de projeto de engenharia do distrito de São Bartolomeu apresentado ao banco | milestone | 0d | 2019-09-26 | 2019-09-26 | 2672 |  |  | 2019-09-17 | 2019-09-17 | 0d | 2020-03-11 | 2020-03-11 | 602d | 0d | Verde | Verde | 0% | 0% | Compensatória | Verde | 0% | 0% |  | Município |  |  |  |
| 2674 | 3.1.3.37.1.4.3 | Analisar projeto |  | 60d | 2019-09-27 | 2019-12-23 | 2673 |  |  | 2019-09-18 | 2019-12-11 | 60d | 2020-03-12 | 2020-04-14 | 602d | 0d | Verde | Verde | 0% | 0% | Compensatória | Verde | 0% | 0% | Critério FR | Banco |  |  |  |
| 2675 | 3.1.3.37.1.4.4 | Projeto de Sem-Peixe do Pleito SEPESPJ01 - Elaboração de projeto de engenharia do distrito de São Bartolomeu concluído | milestone | 0d | 2019-12-23 | 2019-12-23 | 2677, 2670, 2674 |  |  | 2019-12-11 | 2019-12-11 | 0d | 2020-06-15 | 2020-06-15 | 602d | 0d | Verde | Verde | 0% | 0% | Compensatória | Verde | 0% | 0% |  | Município |  |  |  |
| 2676 | 3.1.3.37.1.4.5 | Recurso do projeto executivo de Sem-Peixe do Pleito SEPESPJ01 - Elaboração de projeto de engenharia do distrito de São Bartolomeu repassado | milestone | 0d | 2020-01-02 | 2020-01-02 | 2675FS+5d |  |  | 2019-12-19 | 2019-12-19 | 0d | 2020-06-22 | 2020-06-22 | 951d | 0d | Verde | Verde | 0% | 0% | Compensatória | Verde | 0% | 0% |  | Banco |  |  |  |
| 2677 | 3.1.3.37.1.5 | Realizar Licenciamento Ambiental |  | 102d | 2019-02-04 A | 2019-07-04 | 3048FS+120d | 70% | 30.6d | 2019-02-04 | 2019-06-05 | 82d | 2019-02-04 | 2019-06-05 | 721d | 119d | Verde | Verde | 96% | 0% | Compensatória | Vermelho | 96% | 0% | Conforme agendado | Município | 70 | 96 | 96 |
| 2678 | 3.1.3.37.1.6 | Pleito SEPESPJ01 de Sem-Peixe de Elaboração do projeto de engenharia do distrito de São Bartolomeu de Sem-Peixe concluído | milestone | 0d | 2020-01-02 | 2020-01-02 | 2676 |  |  | 2019-12-19 | 2019-12-19 | 0d | 2020-06-22 | 2020-06-22 | 951d |  | Verde | Verde | 0% | 0% | Compensatória | Verde | 0% | 0% |  | Município |  |  |  |
| 2679 | 3.1.3.37.2 | **Pleito SEPESPJ02 - Elaboração de projeto de engenharia do vilarejo de São Paulino e toda a zona rural** |  | 226d | 2019-02-04 A | 2020-01-02 |  | 28% | 163.31d | 2019-02-04 | 2019-12-19 | 219d | 2019-02-04 | 2020-06-22 | 951d |  | Verde | Verde | 36% | 0% | Compensatória | Vermelho | 11% | 0% |  |  | 18 | 36 | 11 |
| 2680 | 3.1.3.37.2.1 | **Licitação do Projeto** |  | 47d | 2019-04-26 A | 2019-07-03 |  | 78% | 10.5d | 2019-04-26 | 2019-06-24 | 40d | 2019-05-02 | 2019-10-29 | 567d |  | Verde | Verde | 62% | 0% | Compensatória | Vermelho | 48% | 0% |  |  | 16 | 62 | 48 |
| 2681 | 3.1.3.37.2.1.1 | Licitar projeto |  | 33d | 2019-04-26 A | 2019-06-12 A | 2655SS | 100% |  | 2019-04-26 | 2019-06-03 | 26d | 2019-05-02 | 2019-10-02 |  |  | Verde | Verde | 96% | 0% | Compensatória | Vermelho | 96% | 0% | Conforme agendado | Município | 25 | 96 | 96 |
| 2682 | 3.1.3.37.2.1.2 | Documentação de licitação de Sem-Peixe do Pleito SEPESPJ02 - Elaboração de projeto de engenharia do vilarejo de São Paulino e toda a zona rural apresentada ao banco | milestone | 0d | 2019-06-12 A | 2019-06-12 A | 2681 | 100% |  | 2019-06-03 | 2019-06-03 | 0d | 2019-10-09 | 2019-10-09 |  |  | Verde | Verde | 0% | 0% | Compensatória | Verde | 0% | 0% |  | Município |  |  |  |
| 2683 | 3.1.3.37.2.1.3 | Analisar e emitir resultado da licitação do projeto |  | 14d | 2019-06-13 A | 2019-07-03 | 2682 | 25% | 10.5d | 2019-06-04 | 2019-06-24 | 14d | 2019-10-10 | 2019-10-29 | 567d | 0d | Verde | Verde | 0% | 0% | Compensatória | Verde | 0% | 0% | Critério FR | Banco |  |  |  |
| 2684 | 3.1.3.37.2.1.4 | Licitação do projeto de Sem-Peixe do Pleito SEPESPJ02 - Elaboração de projeto de engenharia do vilarejo de São Paulino e toda a zona rural concluída | milestone | 0d | 2019-07-03 | 2019-07-03 | 2683 |  |  | 2019-06-24 | 2019-06-24 | 0d | 2019-10-29 | 2019-10-29 | 567d | 0d | Verde | Verde | 0% | 0% | Compensatória | Verde | 0% | 0% |  | Município |  |  |  |
| 2685 | 3.1.3.37.2.2 | **Elaboração do Estudo de Concepção** |  | 85d | 2019-07-04 | 2019-10-31 |  |  |  | 2019-06-25 | 2019-10-22 | 85d |  |  | 567d |  | Verde | Verde | 0% | 0% | Compensatória | Verde | 0% | 0% |  |  |  |  |  |
| 2686 | 3.1.3.37.2.2.1 | Elaborar estudo |  | 20d | 2019-07-04 | 2019-07-31 | 2684 |  |  | 2019-06-25 | 2019-07-22 | 20d |  |  | 567d | 0d | Verde | Verde | 0% | 0% | Compensatória | Verde | 0% | 0% | Critério FR |  |  |  |  |
| 2687 | 3.1.3.37.2.2.2 | Estudo de concepção de Sem-Peixe do Pleito SEPESPJ02 - Elaboração de projeto de engenharia do vilarejo de São Paulino e toda a zona rural apresentado ao banco | milestone | 0d | 2019-07-31 | 2019-07-31 | 2686 |  |  | 2019-07-22 | 2019-07-22 | 0d |  |  | 597d | 0d | Verde | Verde | 0% | 0% | Compensatória | Verde | 0% | 0% |  |  |  |  |  |
| 2688 | 3.1.3.37.2.2.3 | Analisar estudo |  | 60d | 2019-08-01 | 2019-10-24 | 2687 |  |  | 2019-07-23 | 2019-10-15 | 60d |  |  | 597d | 0d | Verde | Verde | 0% | 0% | Compensatória | Verde | 0% | 0% | Critério FR |  |  |  |  |
| 2689 | 3.1.3.37.2.2.4 | Estudo de concepção de Sem-Peixe do Pleito SEPESPJ02 - Elaboração de projeto de engenharia do vilarejo de São Paulino e toda a zona rural concluído | milestone | 0d | 2019-10-24 | 2019-10-24 | 2688 |  |  | 2019-10-15 | 2019-10-15 | 0d |  |  | 597d | 0d | Verde | Verde | 0% | 0% | Compensatória | Verde | 0% | 0% |  |  |  |  |  |
| 2690 | 3.1.3.37.2.2.5 | Recurso do estudo de concepção de Sem-Peixe do Pleito SEPESPJ02 - Elaboração de projeto de engenharia do vilarejo de São Paulino e toda a zona rural repassado | milestone | 0d | 2019-10-31 | 2019-10-31 | 2689FS+5d |  |  | 2019-10-22 | 2019-10-22 | 0d |  |  | 597d | 15d | Verde | Verde | 0% | 0% | Compensatória | Verde | 0% | 0% |  |  |  |  |  |

Notes:
- 2677: Em 29/04/2019: atualizado como agendado / 21/05/2019: verificar com município o andamento do licenciamento / 02/07/2019: Danielle informou que o município não conseguiu a licença ambiental ainda da SUPRAM. Atividade reprogramada para próximo ciclo.
- 2681: 25/04/2019: o município está verificando a possibilidade fazer uma licitação própria e cancelar a adesão a ATA de registro de preço (report de apoio técnico de abril 2019). Foi premissado que o município irá licitar o projeto em 5 meses visto necessidade de iniciar pela elaboração do TR. Início previsto para 02/05. / 27/05/2019: semana que vem o município entregará o processo licitatório ao banco (03/06/2019). 26/04/2019 edital e abertura 14/05/2019. / 13/06/2019: processo licitatório protocolado no banco dia 12/06 conforme planilha Controle Gerencial Renova. Porém banco solicitou alguns esclarecimentos em relação ao nome dos distritos no projeto e aguarda uma resposta.
- 2682: 17/06/2019: processo licitatório foi protocolado no banco dia 12/06 conforme planilha Controle Gerencial Renova
- 2683: 27/06/2019: processo licitatório encaminhado ao jurídico no dia 13/06/2019 conforme planilha Controle Gerencial Renova

| ID | WBS | Task | Type | Duration | Start | Finish | Predecessors | Complete | Remaining | Baseline start | Baseline finish | Baseline duration | Baseline 1 start | Baseline 1 finish | Total slack | Free slack | Text1 | Text2 | Text3 | Text6 | Text8 | Text12 | Text14 | Text16 | Text18 | Text9 | Text4 | Text5 | Text15 |
| --- | --- | --- | --- | --- | --- | --- | --- | --- | --- | --- | --- | --- | --- | --- | --- | --- | --- | --- | --- | --- | --- | --- | --- | --- | --- | --- | --- | --- | --- |
| 2691 | 3.1.3.37.2.3 | **Elaboração do Projeto Básico** |  | 85d | 2019-08-01 | 2019-11-29 |  |  |  | 2019-07-23 | 2019-11-20 | 85d |  |  | 567d |  | Verde | Verde | 0% | 0% | Compensatória | Verde | 0% | 0% |  |  |  |  |  |
| 2692 | 3.1.3.37.2.3.1 | Elaborar Projeto Básico |  | 20d | 2019-08-01 | 2019-08-29 | 2686 |  |  | 2019-07-23 | 2019-08-20 | 20d |  |  | 567d | 0d | Verde | Verde | 0% | 0% | Compensatória | Verde | 0% | 0% | Critério FR |  |  |  |  |
| 2693 | 3.1.3.37.2.3.2 | Projeto básico de Sem-Peixe do Pleito SEPESPJ02 - Elaboração de projeto de engenharia do vilarejo de São Paulino e toda a zona rural apresentado ao banco | milestone | 0d | 2019-08-29 | 2019-08-29 | 2692 |  |  | 2019-08-20 | 2019-08-20 | 0d |  |  | 582d | 0d | Verde | Verde | 0% | 0% | Compensatória | Verde | 0% | 0% |  |  |  |  |  |
| 2694 | 3.1.3.37.2.3.3 | Analisar projeto básico |  | 60d | 2019-08-30 | 2019-11-22 | 2693 |  |  | 2019-08-21 | 2019-11-12 | 60d |  |  | 582d | 0d | Verde | Verde | 0% | 0% | Compensatória | Verde | 0% | 0% | Critério FR |  |  |  |  |
| 2695 | 3.1.3.37.2.3.4 | Projeto básico de Sem-Peixe do Pleito SEPESPJ02 - Elaboração de projeto de engenharia do vilarejo de São Paulino e toda a zona rural concluído | milestone | 0d | 2019-11-22 | 2019-11-22 | 2690, 2694 |  |  | 2019-11-12 | 2019-11-12 | 0d |  |  | 582d | 0d | Verde | Verde | 0% | 0% | Compensatória | Verde | 0% | 0% |  |  |  |  |  |
| 2696 | 3.1.3.37.2.3.5 | Recurso do projeto básico de Sem-Peixe do Pleito SEPESPJ02 - Elaboração de projeto de engenharia do vilarejo de São Paulino e toda a zona rural repassado | milestone | 0d | 2019-11-29 | 2019-11-29 | 2695FS+5d, 2690 |  |  | 2019-11-20 | 2019-11-20 | 0d |  |  | 582d | 15d | Verde | Verde | 0% | 0% | Compensatória | Verde | 0% | 0% |  |  |  |  |  |
| 2697 | 3.1.3.37.2.4 | **Elaboração do Projeto Executivo** |  | 85d | 2019-08-30 | 2020-01-02 |  |  |  | 2019-08-21 | 2019-12-19 | 85d | 2019-10-30 | 2020-06-22 | 567d |  | Verde | Verde | 0% | 0% | Compensatória | Verde | 0% | 0% |  |  |  |  |  |
| 2698 | 3.1.3.37.2.4.1 | Elaborar Projeto Executivo |  | 20d | 2019-08-30 | 2019-09-26 | 2692 |  |  | 2019-08-21 | 2019-09-17 | 20d | 2019-10-30 | 2020-03-11 | 567d | 0d | Verde | Verde | 0% | 0% | Compensatória | Verde | 0% | 0% | Critério FR | Município |  |  |  |
| 2699 | 3.1.3.37.2.4.2 | Projeto executivo de Sem-Peixe do Pleito SEPESPJ02 - Elaboração de projeto de engenharia do vilarejo de São Paulino e toda a zona rural apresentado ao banco | milestone | 0d | 2019-09-26 | 2019-09-26 | 2698 |  |  | 2019-09-17 | 2019-09-17 | 0d | 2020-03-11 | 2020-03-11 | 567d | 0d | Verde | Verde | 0% | 0% | Compensatória | Verde | 0% | 0% |  | Município |  |  |  |
| 2700 | 3.1.3.37.2.4.3 | Analisar projeto |  | 60d | 2019-09-27 | 2019-12-23 | 2699 |  |  | 2019-09-18 | 2019-12-11 | 60d | 2020-03-12 | 2020-04-14 | 567d | 0d | Verde | Verde | 0% | 0% | Compensatória | Verde | 0% | 0% | Critério FR | Banco |  |  |  |
| 2701 | 3.1.3.37.2.4.4 | Projeto executivo de Sem-Peixe do Pleito SEPESPJ02 - Elaboração de projeto de engenharia do vilarejo de São Paulino e toda a zona rural concluído | milestone | 0d | 2019-12-23 | 2019-12-23 | 2703, 2696, 2700 |  |  | 2019-12-11 | 2019-12-11 | 0d | 2020-06-15 | 2020-06-15 | 567d | 0d | Verde | Verde | 0% | 0% | Compensatória | Verde | 0% | 0% |  | Município |  |  |  |
| 2702 | 3.1.3.37.2.4.5 | Recurso do projeto executivo de Sem-Peixe do Pleito SEPESPJ02 - Elaboração de projeto de engenharia do vilarejo de São Paulino e toda a zona rural repassado | milestone | 0d | 2020-01-02 | 2020-01-02 | 2701FS+5d |  |  | 2019-12-19 | 2019-12-19 | 0d | 2020-06-22 | 2020-06-22 | 951d | 0d | Verde | Verde | 0% | 0% | Compensatória | Verde | 0% | 0% |  | Banco |  |  |  |
| 2703 | 3.1.3.37.2.5 | Realizar Licenciamento Ambiental |  | 102d | 2019-02-04 A | 2019-07-04 | 2681SS-57d | 70% | 30.6d | 2019-02-04 | 2019-06-05 | 82d | 2019-02-04 | 2019-06-05 | 686d | 119d | Verde | Verde | 96% | 0% | Compensatória | Vermelho | 96% | 0% | Conforme agendado | Município | 70 | 96 | 96 |
| 2704 | 3.1.3.37.2.6 | Pleito SEPESPJ02 - Elaboração de projeto de engenharia do vilarejo de São Paulino e toda a zona rural de Sem-Peixe concluído | milestone | 0d | 2020-01-02 | 2020-01-02 | 2702 |  |  | 2019-12-19 | 2019-12-19 | 0d | 2020-06-22 | 2020-06-22 | 951d |  | Verde | Verde | 0% | 0% | Compensatória | Verde | 0% | 0% |  | Município |  |  |  |
| 2705 | 3.1.3.37.3 | **Pleito SEPESOB01 - Complementação de recursos de contrapartida para o TC/PAC 0366/14** |  | 285d | 2019-08-01 | 2020-09-22 |  |  |  | 2019-08-01 | 2020-09-22 | 285d | 2019-06-03 | 2020-08-17 | 771d |  | Verde | Verde | 0% | 0% | Compensatória | Verde | 0% | 0% |  |  |  |  |  |
| 2706 | 3.1.3.37.3.1 | Executar obra |  | 160d | 2019-08-01 | 2020-03-24 | 3052FS+157d |  |  | 2019-08-01 | 2020-03-24 | 160d | 2019-06-03 | 2020-02-03 | 771d | 0d | Verde | Verde | 0% | 0% | Compensatória | Verde | 0% | 0% |  | Município |  |  |  |
| 2707 | 3.1.3.37.3.2 | Realizar processo de pré-operação |  | 120d | 2020-03-25 | 2020-09-15 | 2706 |  |  | 2020-03-25 | 2020-09-15 | 120d | 2020-02-04 | 2020-08-10 | 771d | 0d | Verde | Verde | 0% | 0% | Compensatória | Verde | 0% | 0% |  | Município |  |  |  |
| 2708 | 3.1.3.37.3.3 | Recurso da obra de Sem-Peixe do Pleito SEPESOB01 - Complementação de recursos de contrapartida para o TC/PAC 0366/14 repassado | milestone | 0d | 2020-09-22 | 2020-09-22 | 2707FS+5d |  |  | 2020-09-22 | 2020-09-22 | 0d | 2020-08-17 | 2020-08-17 | 771d | 0d | Verde | Verde | 0% | 0% | Compensatória | Verde | 0% | 0% |  | Banco |  |  |  |
| 2709 | 3.1.3.37.3.4 | Pleito SEPESOB01 - Complementação de recursos de contrapartida para o TC/PAC 0366/14 de Sem-Peixe concluído | milestone | 0d | 2020-09-22 | 2020-09-22 | 2708 |  |  | 2020-09-22 | 2020-09-22 | 0d | 2020-08-17 | 2020-08-17 | 771d |  | Verde | Verde | 0% | 0% | Compensatória | Verde | 0% | 0% |  | Município |  |  |  |
| 2710 | 3.1.3.37.4 | **Pleito SEPESOB02 - Implantação tratamento de esgotos do Distrito de São Bartolomeu** |  | 354d | 2019-12-23 | 2021-05-31 |  |  |  | 2019-12-11 | 2021-05-20 | 354d | 2020-06-15 | 2021-11-25 | 602d |  | Verde | Verde | 0% | 0% | Compensatória | Verde | 0% | 0% |  |  |  |  |  |
| 2711 | 3.1.3.37.4.1 | **Licitação da Obra** |  | 80d | 2019-12-23 | 2020-04-23 |  |  |  | 2019-12-11 | 2020-04-13 | 80d | 2020-06-15 | 2020-10-06 | 602d |  | Verde | Verde | 0% | 0% | Compensatória | Verde | 0% | 0% |  |  |  |  |  |
| 2712 | 3.1.3.37.4.1.1 | Licitação da obra de Sem-Peixe do Pleito SEPESOB02 - Implantação tratamento de esgotos do Distrito de São Bartolomeu autorizada pelo banco | milestone | 0d | 2019-12-23 | 2019-12-23 | 2675 |  |  | 2019-12-11 | 2019-12-11 | 0d | 2020-06-15 | 2020-06-15 | 602d | 0d | Verde | Verde | 0% | 0% | Compensatória | Verde | 0% | 0% |  | Banco |  |  |  |
| 2713 | 3.1.3.37.4.1.2 | Licitar Obra |  | 66d | 2019-12-26 | 2020-04-01 | 2712 |  |  | 2019-12-13 | 2020-03-23 | 66d | 2020-06-16 | 2020-09-16 | 602d | 0d | Verde | Verde | 0% | 0% | Compensatória | Verde | 0% | 0% |  | Município |  |  |  |
| 2714 | 3.1.3.37.4.1.3 | Analisar e emitir resultado da licitação da obra |  | 14d | 2020-04-02 | 2020-04-23 | 2713 |  |  | 2020-03-24 | 2020-04-13 | 14d | 2020-09-17 | 2020-10-06 | 602d | 0d | Verde | Verde | 0% | 0% | Compensatória | Verde | 0% | 0% |  | Banco |  |  |  |
| 2715 | 3.1.3.37.4.1.4 | Licitação da obra de Sem-Peixe do Pleito SEPESOB02 - Implantação tratamento de esgotos do Distrito de São Bartolomeu concluída | milestone | 0d | 2020-04-23 | 2020-04-23 | 2714 |  |  | 2020-04-13 | 2020-04-13 | 0d | 2020-10-06 | 2020-10-06 | 602d | 0d | Verde | Verde | 0% | 0% | Compensatória | Verde | 0% | 0% |  | Município |  |  |  |
| 2716 | 3.1.3.37.4.2 | Executar obra |  | 128d | 2020-05-26 | 2020-11-25 | 2715FS+21d |  |  | 2020-05-15 | 2020-11-16 | 128d | 2020-11-09 | 2021-05-17 | 602d | 0d | Verde | Verde | 0% | 0% | Compensatória | Verde | 0% | 0% |  | Município |  |  |  |
| 2717 | 3.1.3.37.4.3 | Realizar processo de pré-operação |  | 120d | 2020-11-26 | 2021-05-24 | 2716 |  |  | 2020-11-17 | 2021-05-13 | 120d | 2021-05-18 | 2021-11-18 | 602d | 0d | Verde | Verde | 0% | 0% | Compensatória | Verde | 0% | 0% |  | Município |  |  |  |
| 2718 | 3.1.3.37.4.4 | Recurso da obra de Sem-Peixe do Pleito SEPESOB02 - Implantação tratamento de esgotos do Distrito de São Bartolomeu repassado | milestone | 0d | 2021-05-31 | 2021-05-31 | 2717FS+5d |  |  | 2021-05-20 | 2021-05-20 | 0d | 2021-11-25 | 2021-11-25 | 602d | 0d | Verde | Verde | 0% | 0% | Compensatória | Verde | 0% | 0% |  | Banco |  |  |  |
| 2719 | 3.1.3.37.4.5 | Pleito SEPESOB02 - Implantação tratamento de esgotos do Distrito de São Bartolomeu de Sem-Peixe concluído | milestone | 0d | 2021-05-31 | 2021-05-31 | 2718 |  |  | 2021-05-20 | 2021-05-20 | 0d | 2021-11-25 | 2021-11-25 | 602d |  | Verde | Verde | 0% | 0% | Compensatória | Verde | 0% | 0% |  | Município |  |  |  |

Notes:
- 2703: 02/07/2019: Danielle informou que o município não conseguiu a licença ambiental ainda da SUPRAM. Atividade reprogramada para próximo ciclo.
- 2706: Em 25/04/2019: obra está em andamento e sendo paga com o recurso da Funasa. Foi considerado que a Renova iniciará o pagamento da obra em 01/06/2019, com base no cálculo da duração da obra da Funasa. Em fevereiro de 2019 a obra estava com avanço de 85% (planilha cronograma). Considerando que o recurso da Funasa é de 3,4 milhões, o que representa 12 meses de acordo com as premissas utilizadas nesse cronograma, 15% seriam mais 5 meses de obra. Portanto, a parte da obra com recurso Funasa será concluída em julho de 2019. / 27/05/2019: 8 meses de obra conforme cronograma do município
- 2716: Em 25/04/2019: o valor da obra é R$ 1 milhão

| ID | WBS | Task | Type | Duration | Start | Finish | Predecessors | Complete | Remaining | Baseline start | Baseline finish | Baseline duration | Baseline 1 start | Baseline 1 finish | Total slack | Free slack | Text1 | Text2 | Text3 | Text6 | Text8 | Text12 | Text14 | Text16 | Text9 | Text18 | Text4 | Text5 | Text15 |
| --- | --- | --- | --- | --- | --- | --- | --- | --- | --- | --- | --- | --- | --- | --- | --- | --- | --- | --- | --- | --- | --- | --- | --- | --- | --- | --- | --- | --- | --- |
| 2720 | 3.1.3.37.5 | **Pleito SEPESOB03 - Construção de fossas e sumiduros em todo o vilarejo de São Paulino e toda a zona rural** |  | 389d | 2019-12-23 | 2021-07-20 |  |  |  | 2019-12-11 | 2021-07-09 | 389d | 2020-06-15 | 2021-11-24 | 567d |  | Verde | Verde | 0% | 0% | Compensatória | Verde | 0% | 0% |  |  |  |  |  |
| 2721 | 3.1.3.37.5.1 | **Licitação da Obra** |  | 80d | 2019-12-23 | 2020-04-23 |  |  |  | 2019-12-11 | 2020-04-13 | 80d | 2020-06-15 | 2020-10-06 | 567d |  | Verde | Verde | 0% | 0% | Compensatória | Verde | 0% | 0% |  |  |  |  |  |
| 2722 | 3.1.3.37.5.1.1 | Licitação da obra de Sem-Peixe do Pleito SEPESOB03 - Construção de fossas e sumiduros em todo o vilarejo de São Paulino e toda a zona rural autorizada pelo banco | milestone | 0d | 2019-12-23 | 2019-12-23 | 2701 |  |  | 2019-12-11 | 2019-12-11 | 0d | 2020-06-15 | 2020-06-15 | 567d | 0d | Verde | Verde | 0% | 0% | Compensatória | Verde | 0% | 0% | Banco |  |  |  |  |
| 2723 | 3.1.3.37.5.1.2 | Licitar Obra |  | 66d | 2019-12-26 | 2020-04-01 | 2722 |  |  | 2019-12-13 | 2020-03-23 | 66d | 2020-06-16 | 2020-09-16 | 567d | 0d | Verde | Verde | 0% | 0% | Compensatória | Verde | 0% | 0% | Município |  |  |  |  |
| 2724 | 3.1.3.37.5.1.3 | Analisar e emitir resultado da licitação da obra |  | 14d | 2020-04-02 | 2020-04-23 | 2723 |  |  | 2020-03-24 | 2020-04-13 | 14d | 2020-09-17 | 2020-10-06 | 567d | 0d | Verde | Verde | 0% | 0% | Compensatória | Verde | 0% | 0% | Banco |  |  |  |  |
| 2725 | 3.1.3.37.5.1.4 | Licitação da obra de Sem-Peixe do Pleito SEPESOB03 - Construção de fossas e sumiduros em todo o vilarejo de São Paulino e toda a zona rural concluída | milestone | 0d | 2020-04-23 | 2020-04-23 | 2724 |  |  | 2020-04-13 | 2020-04-13 | 0d | 2020-10-06 | 2020-10-06 | 567d | 0d | Verde | Verde | 0% | 0% | Compensatória | Verde | 0% | 0% | Município |  |  |  |  |
| 2726 | 3.1.3.37.5.2 | Executar obra |  | 164d | 2020-05-25 | 2021-01-18 | 2725FS+20d |  |  | 2020-05-14 | 2021-01-07 | 164d | 2020-11-06 | 2021-05-14 | 567d | 0d | Verde | Verde | 0% | 0% | Compensatória | Verde | 0% | 0% | Município |  |  |  |  |
| 2727 | 3.1.3.37.5.3 | Realizar processo de pré-operação |  | 120d | 2021-01-19 | 2021-07-13 | 2726 |  |  | 2021-01-08 | 2021-07-02 | 120d | 2021-05-17 | 2021-11-17 | 567d | 0d | Verde | Verde | 0% | 0% | Compensatória | Verde | 0% | 0% | Município |  |  |  |  |
| 2728 | 3.1.3.37.5.4 | Recurso da obra de Sem-Peixe do Pleito SEPESOB03 - Construção de fossas e sumiduros em todo o vilarejo de São Paulino e toda a zona rural repassado | milestone | 0d | 2021-07-20 | 2021-07-20 | 2727FS+5d |  |  | 2021-07-09 | 2021-07-09 | 0d | 2021-11-24 | 2021-11-24 | 567d | 0d | Verde | Verde | 0% | 0% | Compensatória | Verde | 0% | 0% | Banco |  |  |  |  |
| 2729 | 3.1.3.37.5.5 | Pleito SEPESOB03 - Construção de fossas e sumiduros em todo o vilarejo de São Paulino e toda a zona rural de Sem-Peixe concluído | milestone | 0d | 2021-07-20 | 2021-07-20 | 2728 |  |  | 2021-07-09 | 2021-07-09 | 0d | 2021-11-24 | 2021-11-24 | 567d |  | Verde | Verde | 0% | 0% | Compensatória | Verde | 0% | 0% | Município |  |  |  |  |
| 2730 | 3.1.3.37.6 | **Pleito SEPRSPM01 - Elaboração do Plano Intermunicipal de Gestão Integrada de Resíduos Sólidos para os Municípios associados ao Consórcio Intermunicipal Multissetorial do Vale do Piranga (PIGIRS/CIMVALPI),** |  | 1082d | 2019-06-25 A | 2023-10-30 |  |  | 1082d | 2019-08-30 | 2023-10-30 | 1035d | 2019-08-30 | 2024-01-30 | 0d |  | Verde | Verde | 0% | 0% | Compensatória | Verde | 0% | 0% |  |  |  |  |  |
| 2731 | 3.1.3.37.6.1 | Pleito SEPRSPM01 - Elaboração do Plano Intermunicipal de Gestão Integrada de Resíduos Sólidos para os Municípios associados ao Consórcio Intermunicipal Multissetorial do Vale do Piranga (PIGIRS/CIMVALPI) aprovado pelo CIF | milestone | 0d | 2019-06-25 A | 2019-06-25 A | 3048FS+215d | 100% |  | 2019-08-30 | 2019-08-30 | 0d | 2019-08-30 | 2019-08-30 |  |  | Verde | Verde | 0% | 0% | Compensatória | Verde | 0% | 0% | CT/CIF |  |  |  |  |
| 2732 | 3.1.3.37.6.2 | Iniciar serviço/projeto/obra do pleito de Sem Peixe de Resíduos Sólidos a definir |  | 1d | 2019-09-02 | 2019-09-02 | 2731FS+47d |  |  | 2019-09-02 | 2019-09-02 | 1d | 2019-09-02 | 2019-09-02 | 0d |  | Verde | Verde | 0% | 0% | Compensatória | Verde | 0% | 0% | Município | Critério FR |  |  |  |
| 2733 | 3.1.3.37.6.3 | Pleito SEPRSPM01 - Elaboração do Plano Intermunicipal de Gestão Integrada de Resíduos Sólidos para os Municípios associados ao Consórcio Intermunicipal Multissetorial do Vale do Piranga (PIGIRS/CIMVALPI) de Sem-Peixe concluído | milestone | 0d | 2023-10-30 | 2023-10-30 | 2732FS+1034d |  |  | 2023-10-30 | 2023-10-30 | 0d | 2024-01-30 | 2024-01-30 | 0d |  | Verde | Verde | 0% | 0% | Compensatória | Verde | 0% | 0% | Município |  |  |  |  |
| 2734 | 3.1.3.37.7 | Recursos de Sem Peixe repassados | milestone | 0d | 2023-10-30 | 2023-10-30 | 2678, 2704, 2709, 2719, 2729, 2733 |  |  | 2023-10-30 | 2023-10-30 | 0d | 2024-01-30 | 2024-01-30 | 0d |  | Verde | Verde | 0% | 0% | Compensatória | Verde | 0% | 0% | Banco |  |  |  |  |
| 2735 | 3.1.3.38 | **Sobrália** |  | 992d | 2018-06-15 A | 2022-06-02 |  | 13% | 861.23d | 2018-06-15 | 2022-06-02 | 992d | 2018-06-15 | 2022-03-18 | 350d |  | Verde | Verde | 24% | 0% | Compensatória | Vermelho | 1% | 0% |  |  | 13 | 24 |  |
| 2736 | 3.1.3.38.1 | **Pleito SOBESPJ01 - Elaboração de projetos de sistema de esgotamento sanitário da sede do município e distrito de Plautino Soares** |  | 327d | 2019-03-15 A | 2020-07-08 |  | 5% | 309.12d | 2019-03-15 | 2020-07-08 | 327d | 2019-03-15 | 2020-04-07 | 824d |  | Verde | Verde | 16% | 0% | Compensatória | Vermelho | 3% | 0% |  |  |  | 16 |  |
| 2737 | 3.1.3.38.1.1 | **Licitação do Projeto** |  | 135d | 2019-03-15 A | 2019-09-26 |  | 24% | 102.81d | 2019-03-15 | 2019-09-26 | 135d | 2019-03-15 | 2019-06-18 | 350d |  | Verde | Verde | 39% | 0% | Compensatória | Vermelho | 22% | 0% |  |  | 24 | 39 | 22 |
| 2738 | 3.1.3.38.1.1.1 | Licitar projeto |  | 116d | 2019-03-15 A | 2019-08-30 | 3052FS+62d | 27% | 85d | 2019-03-15 | 2019-08-30 | 116d | 2019-03-15 | 2019-05-22 | 350d | 0d | Verde | Verde | 45% | 0% | Compensatória | Vermelho | 45% | 0% | Município | Conforme agendado | 27 | 45 | 45 |
| 2739 | 3.1.3.38.1.1.2 | Documentação de licitação de Sobrália do Pleito SOBESPJ01 - Elaboração de projetos de sistema de esgotamento sanitário da sede do município e distrito de Plautino Soares apresentada ao banco | milestone | 0d | 2019-09-06 | 2019-09-06 | 2738FS+5d |  |  | 2019-09-06 | 2019-09-06 | 0d | 2019-05-29 | 2019-05-29 | 350d | 0d | Verde | Verde | 0% | 0% | Compensatória | Verde | 0% | 0% | Município |  |  |  |  |
| 2740 | 3.1.3.38.1.1.3 | Analisar e emitir resultado da licitação do projeto |  | 14d | 2019-09-09 | 2019-09-26 | 2739 |  |  | 2019-09-09 | 2019-09-26 | 14d | 2019-05-30 | 2019-06-18 | 350d | 0d | Verde | Verde | 0% | 0% | Compensatória | Verde | 0% | 0% | Banco | Critério FR |  |  |  |
| 2741 | 3.1.3.38.1.1.4 | Licitação do projeto de Sobrália do Pleito SOBESPJ01 - Elaboração de projetos de sistema de esgotamento sanitário da sede do município e distrito de Plautino Soares concluída | milestone | 0d | 2019-09-26 | 2019-09-26 | 2740 |  |  | 2019-09-26 | 2019-09-26 | 0d | 2019-06-18 | 2019-06-18 | 350d | 0d | Verde | Verde | 0% | 0% | Compensatória | Verde | 0% | 0% | Município |  |  |  |  |
| 2742 | 3.1.3.38.1.2 | **Elaboração do Estudo de Concepção** |  | 105d | 2019-09-27 | 2020-03-03 |  |  |  | 2019-09-27 | 2020-03-03 | 105d |  |  | 350d |  | Verde | Verde | 0% | 0% | Compensatória | Verde | 0% | 0% |  |  |  |  |  |
| 2743 | 3.1.3.38.1.2.1 | Elaborar estudo |  | 40d | 2019-09-27 | 2019-11-22 | 2741 |  |  | 2019-09-27 | 2019-11-22 | 40d |  |  | 350d | 0d | Verde | Verde | 0% | 0% | Compensatória | Verde | 0% | 0% |  | Critério FR |  |  |  |
| 2744 | 3.1.3.38.1.2.2 | Estudo de concepção de Sobrália do Pleito SOBESPJ01 - Elaboração de projetos de sistema de esgotamento sanitário da sede do município e distrito de Plautino Soares apresentado ao banco | milestone | 0d | 2019-11-22 | 2019-11-22 | 2743 |  |  | 2019-11-22 | 2019-11-22 | 0d |  |  | 350d | 0d | Verde | Verde | 0% | 0% | Compensatória | Verde | 0% | 0% |  |  |  |  |  |
| 2745 | 3.1.3.38.1.2.3 | Analisar estudo |  | 60d | 2019-11-25 | 2020-02-20 | 2744 |  |  | 2019-11-25 | 2020-02-20 | 60d |  |  | 350d | 0d | Verde | Verde | 0% | 0% | Compensatória | Verde | 0% | 0% |  | Critério FR |  |  |  |
| 2746 | 3.1.3.38.1.2.4 | Estudo de concepção de Sobrália do Pleito SOBESPJ01 - Elaboração de projetos de sistema de esgotamento sanitário da sede do município e distrito de Plautino Soares concluído | milestone | 0d | 2020-02-20 | 2020-02-20 | 2745 |  |  | 2020-02-20 | 2020-02-20 | 0d |  |  | 432d | 0d | Verde | Verde | 0% | 0% | Compensatória | Verde | 0% | 0% |  |  |  |  |  |
| 2747 | 3.1.3.38.1.2.5 | Recurso do estudo de concepção de Sobrália do Pleito SOBESPJ01 - Elaboração de projetos de sistema de esgotamento sanitário da sede do município e distrito de Plautino Soares repassado | milestone | 0d | 2020-03-03 | 2020-03-03 | 2746FS+5d |  |  | 2020-03-03 | 2020-03-03 | 0d |  |  | 432d | 43d | Verde | Verde | 0% | 0% | Compensatória | Verde | 0% | 0% |  |  |  |  |  |

Notes:
- 2726: 22/05/2019: valor da obra 1.278.447,95 - 8 meses
- 2731: 22/05/2019: será definido junto com os outros pleitos do CIMVALPI
- 2734: Valor de recurso destinado ao munícipio: R$4.726.993,07
- 2735: Sobrália teve 100% dos pleitos de Esgotamento Sanitário Aprovado (R$4.254.193,76), conforme Deliberação 75. / O município teve 0,8%, dos 10% do valor teto destinado a Resíduos Sólidos aprovado (R$37.131,34). / Aderiu à ata de registro de preço.
- 2738: Em 25/04/2019: dia 15/03/2019 o município informou ao banco que foi cancelado o processo licitatório anterior. Considerado o início do novo processo em seguida. / Em 29/04/2019: atualizado como agendado / 21/05/2019: verificar com município em reunião qual o status da licitação / 30/05/2019: novo engenheiro vai avaliar a planilha orçamentária. TR está pronto. Município pediu mais 3 meses para finalizar a licitação. / 02/07/2019: Telefonema Livia - mesmo status.

| ID | WBS | Task | Type | Duration | Start | Finish | Predecessors | Baseline start | Baseline finish | Baseline duration | Baseline 1 start | Baseline 1 finish | Total slack | Free slack | Text1 | Text2 | Text3 | Text6 | Text8 | Text12 | Text14 | Text16 | Text9 |
| --- | --- | --- | --- | --- | --- | --- | --- | --- | --- | --- | --- | --- | --- | --- | --- | --- | --- | --- | --- | --- | --- | --- | --- |
| 2748 | 3.1.3.38.1.3 | **Elaboração do Projeto Básico** |  | 108d | 2019-11-25 | 2020-05-06 |  | 2019-11-25 | 2020-05-06 | 108d | 2019-06-19 | 2019-12-27 | 350d |  | Verde | Verde | 0% | 0% | Compensatória | Verde | 0% | 0% |  |
| 2749 | 3.1.3.38.1.3.1 | Elaborar Projeto Básico |  | 40d | 2019-11-25 | 2020-01-23 | 2743 | 2019-11-25 | 2020-01-23 | 40d | 2019-06-19 | 2019-09-18 | 350d | 0d | Verde | Verde | 0% | 0% | Compensatória | Verde | 0% | 0% | Município |
| 2750 | 3.1.3.38.1.3.2 | Projeto básico de Sobrália do Pleito SOBESPJ01 - Elaboração de projetos de sistema de esgotamento sanitário da sede do município e distrito de Plautino Soares apresentado ao banco | milestone | 0d | 2020-01-23 | 2020-01-23 | 2749 | 2020-01-23 | 2020-01-23 | 0d | 2019-09-18 | 2019-09-18 | 389d | 0d | Verde | Verde | 0% | 0% | Compensatória | Verde | 0% | 0% | Município |
| 2751 | 3.1.3.38.1.3.3 | Analisar projeto básico |  | 63d | 2020-01-24 | 2020-04-28 | 2750 | 2020-01-24 | 2020-04-28 | 63d | 2019-09-19 | 2019-10-16 | 389d | 0d | Verde | Verde | 0% | 0% | Compensatória | Verde | 0% | 0% | Banco |
| 2752 | 3.1.3.38.1.3.4 | Projeto básico de Sobrália do Pleito SOBESPJ01 - Elaboração de projetos de sistema de esgotamento sanitário da sede do município e distrito de Plautino Soares concluído | milestone | 0d | 2020-04-28 | 2020-04-28 | 2751 | 2020-04-28 | 2020-04-28 | 0d | 2019-12-18 | 2019-12-18 | 389d | 0d | Verde | Verde | 0% | 0% | Compensatória | Verde | 0% | 0% | Município |
| 2753 | 3.1.3.38.1.3.5 | Recurso do projeto básico de Sobrália do Pleito SOBESPJ01 - Elaboração de projetos de sistema de esgotamento sanitário da sede do município e distrito de Plautino Soares repassado | milestone | 0d | 2020-05-06 | 2020-05-06 | 2752FS+5d, 2747 | 2020-05-06 | 2020-05-06 | 0d | 2019-12-27 | 2019-12-27 | 389d | 39d | Verde | Verde | 0% | 0% | Compensatória | Verde | 0% | 0% | Banco |
| 2754 | 3.1.3.38.1.4 | Realizar Licenciamento Ambiental |  | 127d | 2019-12-26 | 2020-07-01 | 2745FS-40d | 2019-12-26 | 2020-07-01 | 127d | 2019-03-18 | 2020-02-13 | 350d | 0d | Verde | Verde | 0% | 0% | Compensatória | Verde | 0% | 0% | Município |
| 2755 | 3.1.3.38.1.5 | **Elaboração do Projeto Executivo** |  | 112d | 2020-01-24 | 2020-07-08 |  | 2020-01-24 | 2020-07-08 | 112d | 2019-09-19 | 2020-04-07 | 350d |  | Verde | Verde | 0% | 0% | Compensatória | Verde | 0% | 0% |  |
| 2756 | 3.1.3.38.1.5.1 | Elaborar Projeto Executivo |  | 40d | 2020-01-24 | 2020-03-24 | 2749 | 2020-01-24 | 2020-03-24 | 40d | 2019-09-19 | 2019-12-19 | 350d | 0d | Verde | Verde | 0% | 0% | Compensatória | Verde | 0% | 0% | Município |
| 2757 | 3.1.3.38.1.5.2 | Analisar projeto executivo |  | 67d | 2020-03-25 | 2020-07-01 | 2756 | 2020-03-25 | 2020-07-01 | 67d | 2019-12-20 | 2020-01-22 | 350d | 0d | Verde | Verde | 0% | 0% | Compensatória | Verde | 0% | 0% | Banco |
| 2758 | 3.1.3.38.1.5.3 | Projeto executivo de Sobrália do Pleito SOBESPJ01 - Elaboração de projetos de sistema de esgotamento sanitário da sede do município e distrito de Plautino Soares concluído | milestone | 0d | 2020-07-01 | 2020-07-01 | 2753, 2754, 2757 | 2020-07-01 | 2020-07-01 | 0d | 2020-03-31 | 2020-03-31 | 350d | 0d | Verde | Verde | 0% | 0% | Compensatória | Verde | 0% | 0% | Município |
| 2759 | 3.1.3.38.1.5.4 | Recurso do projeto executivo de Sobrália do Pleito SOBESPJ01 - Elaboração de projetos de sistema de esgotamento sanitário da sede do município e distrito de Plautino Soares repassado | milestone | 0d | 2020-07-08 | 2020-07-08 | 2758FS+5d | 2020-07-08 | 2020-07-08 | 0d | 2020-04-07 | 2020-04-07 | 824d | 0d | Verde | Verde | 0% | 0% | Compensatória | Verde | 0% | 0% | Banco |
| 2760 | 3.1.3.38.1.6 | Pleito SOBESPJ01 - Elaboração de projetos de sistema de esgotamento sanitário da sede do município e distrito de Plautino Soares de Sobrália concluído | milestone | 0d | 2020-07-08 | 2020-07-08 | 2759 | 2020-07-08 | 2020-07-08 | 0d | 2020-04-07 | 2020-04-07 | 824d | 474d | Verde | Verde | 0% | 0% | Compensatória | Verde | 0% | 0% | Município |
| 2761 | 3.1.3.38.2 | **Pleito de Sobrália a definir - Aquisição de Imóvel** |  | 157d | 2019-11-29 | 2020-07-22 |  | 2019-11-29 | 2020-07-22 | 157d | 2018-11-29 | 2019-07-17 | 814d |  | Verde | Verde | 0% | 0% | Compensatória | Verde | 0% | 0% |  |
| 2762 | 3.1.3.38.2.1 | Pleito de Sobrália a definir - Aquisição de Imóvel aprovado | milestone | 0d | 2019-11-29 | 2019-11-29 | 3052FS+242d | 2019-11-29 | 2019-11-29 | 0d | 2018-11-29 | 2018-11-29 | 814d | 0d | Verde | Verde | 0% | 0% | Compensatória | Verde | 0% | 0% | CT/CIF |
| 2763 | 3.1.3.38.2.2 | **Aquisição de Imóvel** |  | 147d | 2019-12-17 | 2020-07-22 |  | 2019-12-17 | 2020-07-22 | 147d | 2018-12-13 | 2019-07-17 | 814d |  | Verde | Verde | 0% | 0% | Compensatória | Verde | 0% | 0% |  |
| 2764 | 3.1.3.38.2.2.1 | Regularizar terreno e apresentar escritura ao banco |  | 88d | 2019-12-17 | 2020-04-28 | 2762FS+10d | 2019-12-17 | 2020-04-28 | 88d | 2018-12-13 | 2019-04-23 | 814d | 0d | Verde | Verde | 0% | 0% | Compensatória | Verde | 0% | 0% | Município |
| 2765 | 3.1.3.38.2.2.2 | Analisar documentação do terreno |  | 10d | 2020-04-29 | 2020-05-13 | 2764 | 2020-04-29 | 2020-05-13 | 10d | 2019-04-24 | 2019-05-08 | 858d | 0d | Verde | Verde | 0% | 0% | Compensatória | Verde | 0% | 0% | Banco |
| 2766 | 3.1.3.38.2.2.3 | 50% do valor do imóvel do pleito de Sobrália a definir - Aquisição de Imóvel repassado | milestone | 0d | 2020-05-20 | 2020-05-20 | 2765FS+5d | 2020-05-20 | 2020-05-20 | 0d | 2019-05-15 | 2019-05-15 | 858d | 44d | Verde | Verde | 0% | 0% | Compensatória | Verde | 0% | 0% | Banco |
| 2767 | 3.1.3.38.2.2.4 | Registrar imóvel e apresentar documentação ao banco |  | 44d | 2020-04-29 | 2020-07-01 | 2764 | 2020-04-29 | 2020-07-01 | 44d | 2019-04-24 | 2019-06-26 | 814d | 0d | Verde | Verde | 0% | 0% | Compensatória | Verde | 0% | 0% | Município |
| 2768 | 3.1.3.38.2.2.5 | Analisar documentação do terreno |  | 10d | 2020-07-02 | 2020-07-15 | 2767 | 2020-07-02 | 2020-07-15 | 10d | 2019-06-27 | 2019-07-10 | 814d | 0d | Verde | Verde | 0% | 0% | Compensatória | Verde | 0% | 0% | Banco |
| 2769 | 3.1.3.38.2.2.6 | 50% do valor do imóvel do pleito de Sobrália a definir - Aquisição de Imóvel repassado | milestone | 0d | 2020-07-22 | 2020-07-22 | 2768FS+5d | 2020-07-22 | 2020-07-22 | 0d | 2019-07-17 | 2019-07-17 | 814d | 0d | Verde | Verde | 0% | 0% | Compensatória | Verde | 0% | 0% | Banco |
| 2770 | 3.1.3.38.2.2.7 | Aquisição do imóvel do Pleito de Sobrália a definir concluída | milestone | 0d | 2020-07-22 | 2020-07-22 | 2766, 2769 | 2020-07-22 | 2020-07-22 | 0d | 2019-07-17 | 2019-07-17 | 814d | 0d | Verde | Verde | 0% | 0% | Compensatória | Verde | 0% | 0% | Município |
| 2771 | 3.1.3.38.2.3 | Pleito de Sobrália a definir - Aquisição de Imóvel concluído | milestone | 0d | 2020-07-22 | 2020-07-22 | 2770 | 2020-07-22 | 2020-07-22 | 0d | 2019-07-17 | 2019-07-17 | 814d | 464d | Verde | Verde | 0% | 0% | Compensatória | Verde | 0% | 0% | Município |

Notes:
- 2754: 25/01/19 - Não foram iniciados / Em 29/04/2019: atualizado como agendado / 21/05/2019: verificar com município o andamento do licenciamento
- 2756: 24/05/2019: município pactuou com a Renova 3 meses para elaborar projeto executivo
- 2762: Em 25/04/2019: o pleito será apresentado dia 20/09/2019 e será aprovado na CT/CIF final de novembro (NT33)

| ID | WBS | Task | Type | Duration | Start | Finish | Predecessors | Complete | Remaining | Baseline start | Baseline finish | Baseline duration | Baseline 1 start | Baseline 1 finish | Total slack | Free slack | Text1 | Text2 | Text3 | Text6 | Text8 | Text12 | Text14 | Text16 | Text9 | Text4 | Text5 | Text7 | Text15 | Text17 | Text18 |
| --- | --- | --- | --- | --- | --- | --- | --- | --- | --- | --- | --- | --- | --- | --- | --- | --- | --- | --- | --- | --- | --- | --- | --- | --- | --- | --- | --- | --- | --- | --- | --- |
| 2772 | 3.1.3.38.3 | **Pleito SOBESOB01 - Implantação de sistema de esgotamento sanitário da sede do município e distrito de Plautino Soares** |  | 479d | 2020-07-01 | 2022-06-02 |  |  |  | 2020-07-01 | 2022-06-02 | 479d | 2020-03-31 | 2022-03-18 | 350d |  | Verde | Verde | 0% | 0% | Compensatória | Verde | 0% | 0% |  |  |  |  |  |  |  |
| 2773 | 3.1.3.38.3.1 | **Licitação da Obra** |  | 77d | 2020-07-01 | 2020-10-20 |  |  |  | 2020-07-01 | 2020-10-20 | 77d | 2020-03-31 | 2020-07-22 | 350d |  | Verde | Verde | 0% | 0% | Compensatória | Verde | 0% | 0% |  |  |  |  |  |  |  |
| 2774 | 3.1.3.38.3.1.1 | Licitação da obra de Sobrália do Pleito SOBESOB01 - Implantação de sistema de esgotamento sanitário da sede do município e distrito de Plautino Soares autorizada pelo banco | milestone | 0d | 2020-07-01 | 2020-07-01 | 2758 |  |  | 2020-07-01 | 2020-07-01 | 0d | 2020-03-31 | 2020-03-31 | 350d | 0d | Verde | Verde | 0% | 0% | Compensatória | Verde | 0% | 0% | Banco |  |  |  |  |  |  |
| 2775 | 3.1.3.38.3.1.2 | Licitar Obra |  | 62d | 2020-07-02 | 2020-09-28 | 2774 |  |  | 2020-07-02 | 2020-09-28 | 62d | 2020-04-01 | 2020-07-01 | 350d | 0d | Verde | Verde | 0% | 0% | Compensatória | Verde | 0% | 0% | Município |  |  |  |  |  |  |
| 2776 | 3.1.3.38.3.1.3 | Analisar e emitir resultado da licitação da obra |  | 15d | 2020-09-29 | 2020-10-20 | 2775 |  |  | 2020-09-29 | 2020-10-20 | 15d | 2020-07-02 | 2020-07-22 | 350d | 0d | Verde | Verde | 0% | 0% | Compensatória | Verde | 0% | 0% | Banco |  |  |  |  |  |  |
| 2777 | 3.1.3.38.3.1.4 | Licitação da obra de Sobrália do Pleito SOBESOB01 - Implantação de sistema de esgotamento sanitário da sede do município e distrito de Plautino Soares concluída | milestone | 0d | 2020-10-20 | 2020-10-20 | 2776 |  |  | 2020-10-20 | 2020-10-20 | 0d | 2020-07-22 | 2020-07-22 | 350d | 0d | Verde | Verde | 0% | 0% | Compensatória | Verde | 0% | 0% | Município |  |  |  |  |  |  |
| 2778 | 3.1.3.38.3.2 | Executar obra |  | 257d | 2020-11-19 | 2021-12-01 | 2777FS+20d |  |  | 2020-11-19 | 2021-12-01 | 257d | 2020-08-20 | 2021-08-31 | 350d | 0d | Verde | Verde | 0% | 0% | Compensatória | Verde | 0% | 0% | Município |  |  |  |  |  |  |
| 2779 | 3.1.3.38.3.3 | Realizar processo de pré-operação |  | 120d | 2021-12-02 | 2022-05-26 | 2778 |  |  | 2021-12-02 | 2022-05-26 | 120d | 2021-09-01 | 2022-03-11 | 350d | 0d | Verde | Verde | 0% | 0% | Compensatória | Verde | 0% | 0% | Município |  |  |  |  |  |  |
| 2780 | 3.1.3.38.3.4 | Recurso da obra de Sobrália do Pleito SOBESOB01 - Implantação de sistema de esgotamento sanitário da sede do município e distrito de Plautino Soares repassado | milestone | 0d | 2022-06-02 | 2022-06-02 | 2779FS+5d |  |  | 2022-06-02 | 2022-06-02 | 0d | 2022-03-18 | 2022-03-18 | 350d | 0d | Verde | Verde | 0% | 0% | Compensatória | Verde | 0% | 0% | Banco |  |  |  |  |  |  |
| 2781 | 3.1.3.38.3.5 | Pleito SOBESOB01 - Implantação de sistema de esgotamento sanitário da sede do município e distrito de Plautino Soares de Sobrália concluído | milestone | 0d | 2022-06-02 | 2022-06-02 | 2780 |  |  | 2022-06-02 | 2022-06-02 | 0d | 2022-03-18 | 2022-03-18 | 350d | 0d | Verde | Verde | 0% | 0% | Compensatória | Verde | 0% | 0% | Município |  |  |  |  |  |  |
| 2782 | 3.1.3.38.4 | **Pleito SOBRSPM01 - Elaboração de estudos de viabilidade para concepção dos serviços de infraestrutura de sistemas integrados de destinação final de resíduos sólidos urbanos** |  | 486d | 2018-06-15 A | 2020-05-22 |  | 43% | 278.87d | 2018-06-15 | 2020-05-22 | 486d | 2018-06-15 | 2020-03-11 | 856d |  | Verde | Verde | 50% | 67% | Compensatória | Vermelho | 6% | 4% |  | 43 | 50 | 67 |  |  |  |
| 2783 | 3.1.3.38.4.1 | **Licitação de Empresa para Estudo de Viabilidade** |  | 332d | 2018-06-15 A | 2019-10-04 |  | 66% | 112.71d | 2018-06-15 | 2019-10-04 | 332d | 2018-06-15 | 2019-07-26 | 856d |  | Verde | Verde | 73% | 69% | Compensatória | Vermelho | 58% | 40% |  | 66 | 73 | 69 | 58 | 40 |  |
| 2784 | 3.1.3.38.4.1.1 | Licitação da empresa para Estudo de Viabilidade de Sobrália do Pleito SOBRSPM01 - Elaboração de estudos de viabilidade para concepção dos serviços de infraestrutura de sistemas integrados de destinação final de resíduos sólidos autorizada pelo banco | milestone | 0d | 2018-06-15 A | 2018-06-15 A | 272 | 100% |  | 2018-06-15 | 2018-06-15 | 0d | 2018-06-15 | 2018-06-15 |  |  | Verde | Verde | 100% | 100% | Compensatória | Verde | 100% | 100% | Banco | 100 | 100 | 100 | 100 | 100 |  |
| 2785 | 3.1.3.38.4.1.2 | Licitar empresa para Estudo de Viabilidade |  | 257d | 2018-09-03 A | 2019-09-09 | 2784FS+56d | 70% | 78d | 2018-09-03 | 2019-09-09 | 257d | 2018-09-03 | 2019-07-01 | 856d | 0d | Verde | Verde | 73% | 68% | Compensatória | Vermelho | 73% | 50% | Município | 70 | 73 | 68 | 73 | 50 | Conforme agendado |
| 2786 | 3.1.3.38.4.1.3 | Documentação de licitação de Sobrália do Pleito SOBRSPM01 - Elaboração de estudos de viabilidade para concepção dos serviços de infraestrutura de sistemas integrados de destinação final de resíduos sólidos apresentada ao banco | milestone | 0d | 2019-09-16 | 2019-09-16 | 2785FS+5d |  |  | 2019-09-16 | 2019-09-16 | 0d | 2019-07-08 | 2019-07-08 | 856d | 0d | Verde | Verde | 0% | 0% | Compensatória | Verde | 0% | 0% | Município |  |  |  |  |  |  |
| 2787 | 3.1.3.38.4.1.4 | Analisar e emitir resultado da licitação da empresa para Estudo de Viabilidade |  | 14d | 2019-09-17 | 2019-10-04 | 2786 |  |  | 2019-09-17 | 2019-10-04 | 14d | 2019-07-09 | 2019-07-26 | 856d | 0d | Verde | Verde | 0% | 0% | Compensatória | Verde | 0% | 0% | Banco |  |  |  |  |  | Critério FR |
| 2788 | 3.1.3.38.4.1.5 | Licitação da empresa para Estudo de Viabilidade de Sobrália do Pleito SOBRSPM01 - Elaboração de estudos de viabilidade para concepção dos serviços de infraestrutura de sistemas integrados de destinação final de resíduos sólidos concluída | milestone | 0d | 2019-10-04 | 2019-10-04 | 2787 |  |  | 2019-10-04 | 2019-10-04 | 0d | 2019-07-26 | 2019-07-26 | 856d | 0d | Verde | Verde | 0% | 0% | Compensatória | Verde | 0% | 0% | Município |  |  |  |  |  |  |
| 2789 | 3.1.3.38.4.2 | **Elaboração do estudo de viabilidade** |  | 149d | 2019-10-07 | 2020-05-15 |  |  |  | 2019-10-07 | 2020-05-15 | 149d | 2019-07-29 | 2020-03-04 | 856d |  | Verde | Verde | 0% | 0% | Compensatória | Verde | 0% | 0% |  |  |  |  |  |  |  |
| 2790 | 3.1.3.38.4.2.1 | Elaborar estudo de viabilidade |  | 88d | 2019-10-07 | 2020-02-12 | 2788 |  |  | 2019-10-07 | 2020-02-12 | 88d | 2019-07-29 | 2019-11-29 | 856d | 0d | Verde | Verde | 0% | 0% | Compensatória | Verde | 0% | 0% | Município |  |  |  |  |  |  |
| 2791 | 3.1.3.38.4.2.2 | Analisar estudo |  | 61d | 2020-02-13 | 2020-05-15 | 2790 |  |  | 2020-02-13 | 2020-05-15 | 61d | 2019-12-02 | 2020-01-02 | 856d | 0d | Verde | Verde | 0% | 0% | Compensatória | Verde | 0% | 0% | Banco |  |  |  |  |  |  |
| 2792 | 3.1.3.38.4.2.3 | Estudo de viabilidade de Sobrália do Pleito SOBRSPM01 - Elaboração de estudos de viabilidade para concepção dos serviços de infraestrutura de sistemas integrados de destinação final de resíduos sólidos concluído | milestone | 0d | 2020-05-15 | 2020-05-15 | 2791 |  |  | 2020-05-15 | 2020-05-15 | 0d | 2020-03-04 | 2020-03-04 | 856d | 0d | Verde | Verde | 0% | 0% | Compensatória | Verde | 0% | 0% | Município |  |  |  |  |  |  |
| 2793 | 3.1.3.38.4.3 | Recurso do serviço de Sobrália do Pleito SOBRSPM01 - Elaboração de estudos de viabilidade para concepção dos serviços de infraestrutura de sistemas integrados de destinação final de resíduos sólidos repassado | milestone | 0d | 2020-05-22 | 2020-05-22 | 2792FS+5d |  |  | 2020-05-22 | 2020-05-22 | 0d | 2020-03-11 | 2020-03-11 | 856d | 0d | Verde | Verde | 0% | 0% | Compensatória | Verde | 0% | 0% | Banco |  |  |  |  |  |  |
| 2794 | 3.1.3.38.4.4 | Pleito SOBRSPM01 - Elaboração de estudos de viabilidade para concepção dos serviços de infraestrutura de sistemas integrados de destinação final de resíduos sólidos urbanos de Sobrália concluído | milestone | 0d | 2020-05-22 | 2020-05-22 | 2793 |  |  | 2020-05-22 | 2020-05-22 | 0d | 2020-03-11 | 2020-03-11 | 856d | 506d | Verde | Verde | 0% | 0% | Compensatória | Verde | 0% | 0% | Município |  |  |  |  |  |  |
| 2795 | 3.1.3.38.5 | Recursos de Sobrália repassados | milestone | 0d | 2022-06-02 | 2022-06-02 | 2760, 2771, 2781, 2794 |  |  | 2022-06-02 | 2022-06-02 | 0d | 2022-03-18 | 2022-03-18 | 350d |  | Verde | Verde | 0% | 0% | Compensatória | Verde | 0% | 0% | Banco |  |  |  |  |  |  |

Notes:
- 2784: 22/05/2019: mesma data de início dos pleitos de CIMDOCE
- 2785: 21/05/2019: atualizado conforme cronograma dos consórcios definido dia 08/05/2019 - 09/05/2019
- 2795: Valor de recurso destinado ao munícipio: R$4.726.993,07

| ID | WBS | Task | Type | Duration | Start | Finish | Predecessors | Complete | Remaining | Baseline start | Baseline finish | Baseline duration | Baseline 1 start | Baseline 1 finish | Total slack | Free slack | Text1 | Text2 | Text3 | Text6 | Text8 | Text12 | Text14 | Text16 | Text9 | Text18 |
| --- | --- | --- | --- | --- | --- | --- | --- | --- | --- | --- | --- | --- | --- | --- | --- | --- | --- | --- | --- | --- | --- | --- | --- | --- | --- | --- |
| 2796 | 3.1.3.39 | **Timóteo** |  | 737d | 2019-05-29 A | 2022-05-16 |  |  | 737d | 2019-06-07 | 2022-05-16 | 730d | 2019-05-03 | 2022-05-30 | 363d |  | Verde | Verde | 0% | 0% | Compensatória | Verde | 0% | 0% |  |  |
| 2797 | 3.1.3.39.1 | **Pleito TIMRSPM01 - Estudos de viabilidade para a implantação de aterro sanitário regional** |  | 227d | 2019-08-01 | 2020-07-02 |  |  |  | 2019-08-01 | 2020-07-02 | 227d | 2019-05-03 | 2020-03-17 | 828d |  | Verde | Verde | 0% | 0% | Compensatória | Verde | 0% | 0% |  |  |
| 2798 | 3.1.3.39.1.1 | Alteração do Pleito TIMRSPM01 - Estudos de viabilidade para a implantação de aterro sanitário regional de Timóteo aprovado | milestone | 0d | 2019-08-01 | 2019-08-01 | 3052FS+158d |  |  | 2019-08-01 | 2019-08-01 | 0d |  |  | 828d | 0d | Verde | Verde | 0% | 0% | Compensatória | Verde | 0% | 0% |  |  |
| 2799 | 3.1.3.39.1.2 | **Licitação de Empresa para Estudo de Viabilidade** |  | 63d | 2019-08-16 | 2019-11-13 |  |  |  | 2019-08-16 | 2019-11-13 | 63d | 2019-05-03 | 2019-08-01 | 828d |  | Verde | Verde | 0% | 0% | Compensatória | Verde | 0% | 0% |  |  |
| 2800 | 3.1.3.39.1.2.1 | Licitação da empresa para Estudo de Viabilidade de Timóteo do Pleito TIMRSPM01 - Estudos de viabilidade para a implantação de aterro sanitário regional autorizada pelo banco | milestone | 0d | 2019-08-16 | 2019-08-16 | 2798FS+10d |  |  | 2019-08-16 | 2019-08-16 | 0d | 2019-05-03 | 2019-05-03 | 828d | 0d | Verde | Verde | 0% | 0% | Compensatória | Verde | 0% | 0% | Banco |  |
| 2801 | 3.1.3.39.1.2.2 | Licitar empresa para Estudo de Viabilidade |  | 44d | 2019-08-19 | 2019-10-17 | 2800 |  |  | 2019-08-19 | 2019-10-17 | 44d | 2019-05-06 | 2019-07-05 | 828d | 0d | Verde | Verde | 0% | 0% | Compensatória | Verde | 0% | 0% | Município | Critério FR |
| 2802 | 3.1.3.39.1.2.3 | Documentação de licitação de Timóteo do Pleito TIMRSPM01 - Estudos de viabilidade para a implantação de aterro sanitário regional apresentada ao banco | milestone | 0d | 2019-10-24 | 2019-10-24 | 2801FS+5d |  |  | 2019-10-24 | 2019-10-24 | 0d | 2019-07-12 | 2019-07-12 | 828d | 0d | Verde | Verde | 0% | 0% | Compensatória | Verde | 0% | 0% | Município |  |
| 2803 | 3.1.3.39.1.2.4 | Analisar e emitir resultado da licitação da empresa para Estudo de Viabilidade |  | 14d | 2019-10-25 | 2019-11-13 | 2802 |  |  | 2019-10-25 | 2019-11-13 | 14d | 2019-07-15 | 2019-08-01 | 828d | 0d | Verde | Verde | 0% | 0% | Compensatória | Verde | 0% | 0% | Banco | Critério FR |
| 2804 | 3.1.3.39.1.2.5 | Licitação da empresa para Estudo de Viabilidade de Timóteo do Pleito TIMRSPM01 - Estudos de viabilidade para a implantação de aterro sanitário regional concluída | milestone | 0d | 2019-11-13 | 2019-11-13 | 2803 |  |  | 2019-11-13 | 2019-11-13 | 0d | 2019-08-01 | 2019-08-01 | 828d | 0d | Verde | Verde | 0% | 0% | Compensatória | Verde | 0% | 0% | Município |  |
| 2805 | 3.1.3.39.1.3 | **Elaboração do estudo de viabilidade** |  | 149d | 2019-11-14 | 2020-06-25 |  |  |  | 2019-11-14 | 2020-06-25 | 149d | 2019-08-02 | 2020-03-10 | 828d |  | Verde | Verde | 0% | 0% | Compensatória | Verde | 0% | 0% |  |  |
| 2806 | 3.1.3.39.1.3.1 | Elaborar estudo de viabilidade |  | 88d | 2019-11-14 | 2020-03-26 | 2804 |  |  | 2019-11-14 | 2020-03-26 | 88d | 2019-08-02 | 2019-12-05 | 828d | 0d | Verde | Verde | 0% | 0% | Compensatória | Verde | 0% | 0% | Município |  |
| 2807 | 3.1.3.39.1.3.2 | Analisar estudo |  | 61d | 2020-03-27 | 2020-06-25 | 2806 |  |  | 2020-03-27 | 2020-06-25 | 61d | 2019-12-06 | 2020-01-08 | 828d | 0d | Verde | Verde | 0% | 0% | Compensatória | Verde | 0% | 0% | Banco |  |
| 2808 | 3.1.3.39.1.3.3 | Estudo de viabilidade de Timóteo do Pleito TIMRSPM01 - Estudos de viabilidade para a implantação de aterro sanitário regional concluído | milestone | 0d | 2020-06-25 | 2020-06-25 | 2807 |  |  | 2020-06-25 | 2020-06-25 | 0d | 2020-03-10 | 2020-03-10 | 828d | 0d | Verde | Verde | 0% | 0% | Compensatória | Verde | 0% | 0% | Município |  |
| 2809 | 3.1.3.39.1.4 | Recurso do serviço de Timóteo do Pleito TIMRSPM01 - Estudos de viabilidade para a implantação de aterro sanitário regional repassado | milestone | 0d | 2020-07-02 | 2020-07-02 | 2808FS+5d |  |  | 2020-07-02 | 2020-07-02 | 0d | 2020-03-17 | 2020-03-17 | 828d | 0d | Verde | Verde | 0% | 0% | Compensatória | Verde | 0% | 0% | Banco |  |
| 2810 | 3.1.3.39.1.5 | Pleito TIMRSPM01 - Estudos de viabilidade para a implantação de aterro sanitário regional de Timóteo concluído | milestone | 0d | 2020-07-02 | 2020-07-02 | 2809 |  |  | 2020-07-02 | 2020-07-02 | 0d | 2020-03-17 | 2020-03-17 | 828d | 465d | Verde | Verde | 0% | 0% | Compensatória | Verde | 0% | 0% | Município |  |
| 2811 | 3.1.3.39.2 | **Pleito TIMRSPJ01 - Erradicação do lixão** |  | 580d | 2019-05-29 A | 2021-09-24 |  |  | 580d | 2019-06-07 | 2021-09-10 | 563d | 2019-06-28 | 2022-03-10 | 520d |  | Verde | Verde | 0% | 0% | Compensatória | Verde | 0% | 0% |  |  |
| 2812 | 3.1.3.39.2.1 | Alteração do Pleito TIMRSPJ01 - Erradicação do lixão de Timóteo aprovada | milestone | 0d | 2019-08-01 | 2019-08-01 | 3052FS+158d |  |  | 2019-08-01 | 2019-08-01 | 0d |  |  | 557d | 37d | Verde | Verde | 0% | 0% | Compensatória | Verde | 0% | 0% |  |  |
| 2813 | 3.1.3.39.2.2 | **Aprovação do PRAD** |  | 82d | 2019-05-29 A | 2019-09-24 |  |  | 82d | 2019-06-07 | 2019-09-10 | 65d |  |  | 520d |  | Verde | Verde | 0% | 0% | Compensatória | Verde | 0% | 0% |  |  |
| 2814 | 3.1.3.39.2.2.1 | Apresentação do PRAD de Timóteo do Pleito TIMRSPJ01 - Erradicação do lixão solicitado pelo banco | milestone | 0d | 2019-05-29 A | 2019-05-29 A | 3052FS+113d | 100% |  | 2019-06-07 | 2019-06-07 | 0d |  |  |  |  | Verde | Verde | 0% | 0% | Compensatória | Verde | 0% | 0% |  |  |
| 2815 | 3.1.3.39.2.2.2 | PRAD de Timóteo do Pleito TIMRSPJ01 - Erradicação do lixão apresentado ao banco | milestone | 0d | 2019-07-01 | 2019-07-01 | 2814FS+22d |  |  | 2019-06-14 | 2019-06-14 | 0d |  |  | 520d | 0d | Verde | Verde | 0% | 0% | Compensatória | Verde | 0% | 0% |  |  |
| 2816 | 3.1.3.39.2.2.3 | Analisar PRAD |  | 60d | 2019-07-02 | 2019-09-24 | 2815 |  |  | 2019-06-17 | 2019-09-10 | 60d |  |  | 520d | 0d | Verde | Verde | 0% | 0% | Compensatória | Verde | 0% | 0% |  | Critério FR |
| 2817 | 3.1.3.39.2.2.4 | PRAD de Timóteo do Pleito TIMRSPJ01 - Erradicação do lixão aprovado | milestone | 0d | 2019-09-24 | 2019-09-24 | 2812, 2816 |  |  | 2019-09-10 | 2019-09-10 | 0d |  |  | 520d | 0d | Verde | Verde | 0% | 0% | Compensatória | Verde | 0% | 0% |  |  |
| 2818 | 3.1.3.39.2.3 | Iniciar erradicação do lixão de Timóteo |  | 1d | 2019-09-25 | 2019-09-25 | 2817 |  |  | 2019-09-11 | 2019-09-11 | 1d | 2019-06-28 | 2019-06-28 | 520d | 0d | Verde | Verde | 0% | 0% | Compensatória | Verde | 0% | 0% | Município | Critério FR |
| 2819 | 3.1.3.39.2.4 | Recurso do serviço de Timóteo do Pleito TIMRSPJ01 - Erradicação do lixão repassado | milestone | 0d | 2021-09-24 | 2021-09-24 | 2818FS+497d |  |  | 2021-09-10 | 2021-09-10 | 0d | 2022-03-10 | 2022-03-10 | 520d | 0d | Verde | Verde | 0% | 0% | Compensatória | Verde | 0% | 0% | Banco |  |
| 2820 | 3.1.3.39.2.5 | Pleito TIMRSPJ01 - Erradicação do lixão de Timóteo concluído | milestone | 0d | 2021-09-24 | 2021-09-24 | 2819 |  |  | 2021-09-10 | 2021-09-10 | 0d | 2022-03-10 | 2022-03-10 | 520d | 157d | Verde | Verde | 0% | 0% | Compensatória | Verde | 0% | 0% | Município |  |

Notes:
- 2796: Timóteo solicitou mudança de pleito e foi autorizado pelo CIF na NT21. / ·Alteração de pleito e da proporção 90% para Esgotamento Sanitário e 10% para Resíduos Sólidos./ ·Com o novo pleito aprovado Timóteo terá 18% (R$3.970.674,18) para Esgotamento Sanitário e 82% para Resíduos Sólidos. / Já foi autorizado 18% (R$3.970.674,18) para Esgotamento Sanitário e 21,7%(R$4.783.065,71) para Resíduos Sólidos.
- 2800: 22/05/2019: início é o mesmo dos outros pleitos de estudo de viabilidade do COMDIN
- 2814: 17/06/2019: no dia 29/05/2019 foi enviado e-mail solicitando PRAD para análise conforme planilha Controle Gerencial Renova
- 2815: 02/07/2019: município não entregou o PRAD ao banco no dia 05/06/2019 conforme planilha Controle Gerencial Renova. Atividade reprogramada para o próximo ciclo.
- 2818: Em 24/04/2019: foi considerado o início do pleito 30/06/2019 em virtude da dependência da contrapartida financeira de Coronel Fabriciano, ainda pendente de negociação.
- 2819: 02/06/2019: valor da obra R$ 4.335.046,10. Conforme premissas seriam 12 meses para a obra. Mais 3 meses de licitação e 6 meses de pré-operação. Considerados 2 anos para todo o processo.
- 2820: Em 24/09/2019: Foram considerados os prazos de aprovação de projeto, licenciamento e obra (conforme valor do pleito)

| ID | WBS | Task | Type | Duration | Start | Finish | Predecessors | Baseline start | Baseline finish | Baseline duration | Baseline 1 start | Baseline 1 finish | Total slack | Free slack | Text1 | Text2 | Text3 | Text6 | Text8 | Text12 | Text14 | Text16 | Text9 | Text18 |
| --- | --- | --- | --- | --- | --- | --- | --- | --- | --- | --- | --- | --- | --- | --- | --- | --- | --- | --- | --- | --- | --- | --- | --- | --- |
| 2821 | 3.1.3.39.3 | **Pleito de Timóteo a definir - Projeto** |  | 224d | 2019-08-01 | 2020-06-29 |  | 2019-08-01 | 2020-06-29 | 224d | 2019-08-30 | 2020-07-01 | 363d |  | Verde | Verde | 0% | 0% | Compensatória | Verde | 0% | 0% |  |  |
| 2822 | 3.1.3.39.3.1 | Pleito de Timóteo a definir - Projeto aprovado | milestone | 0d | 2019-08-01 | 2019-08-01 | 3052FS+158d | 2019-08-01 | 2019-08-01 | 0d | 2019-08-30 | 2019-08-30 | 363d | 0d | Verde | Verde | 0% | 0% | Compensatória | Verde | 0% | 0% | CT/CIF |  |
| 2823 | 3.1.3.39.3.2 | **Licitação do Projeto** |  | 64d | 2019-08-16 | 2019-11-14 |  | 2019-08-16 | 2019-11-14 | 64d | 2019-09-13 | 2019-12-09 | 363d |  | Verde | Verde | 0% | 0% | Compensatória | Verde | 0% | 0% |  |  |
| 2824 | 3.1.3.39.3.2.1 | Licitação do projeto do Pleito de Timóteo a definir - Projeto autorizada pelo banco | milestone | 0d | 2019-08-16 | 2019-08-16 | 2822FS+10d | 2019-08-16 | 2019-08-16 | 0d | 2019-09-13 | 2019-09-13 | 363d | 0d | Verde | Verde | 0% | 0% | Compensatória | Verde | 0% | 0% | Banco |  |
| 2825 | 3.1.3.39.3.2.2 | Licitar projeto |  | 45d | 2019-08-19 | 2019-10-18 | 2824 | 2019-08-19 | 2019-10-18 | 45d | 2019-09-16 | 2019-11-11 | 363d | 0d | Verde | Verde | 0% | 0% | Compensatória | Verde | 0% | 0% | Município | Critério FR |
| 2826 | 3.1.3.39.3.2.3 | Documentação de licitação do Pleito de Timóteo a definir - Projeto apresentada ao banco | milestone | 0d | 2019-10-25 | 2019-10-25 | 2825FS+5d | 2019-10-25 | 2019-10-25 | 0d | 2019-11-19 | 2019-11-19 | 363d | 0d | Verde | Verde | 0% | 0% | Compensatória | Verde | 0% | 0% | Município |  |
| 2827 | 3.1.3.39.3.2.4 | Analisar e emitir resultado da licitação do projeto |  | 14d | 2019-10-28 | 2019-11-14 | 2826 | 2019-10-28 | 2019-11-14 | 14d | 2019-11-20 | 2019-12-09 | 363d | 0d | Verde | Verde | 0% | 0% | Compensatória | Verde | 0% | 0% | Banco | Critério FR |
| 2828 | 3.1.3.39.3.2.5 | Licitação do projeto do Pleito de Timóteo a definir - Projeto concluída | milestone | 0d | 2019-11-14 | 2019-11-14 | 2827 | 2019-11-14 | 2019-11-14 | 0d | 2019-12-09 | 2019-12-09 | 363d | 0d | Verde | Verde | 0% | 0% | Compensatória | Verde | 0% | 0% | Município |  |
| 2829 | 3.1.3.39.3.3 | Realizar licenciamento ambiental |  | 48d | 2019-08-02 | 2019-10-09 | 2822SS | 2019-08-02 | 2019-10-09 | 48d | 2019-09-02 | 2019-11-06 | 534d | 171d | Verde | Verde | 0% | 0% | Compensatória | Verde | 0% | 0% | Município | Critério FR |
| 2830 | 3.1.3.39.3.4 | **Elaboração de Projeto Executivo** |  | 150d | 2019-11-18 | 2020-06-29 |  | 2019-11-18 | 2020-06-29 | 150d | 2019-12-10 | 2020-07-01 | 363d |  | Verde | Verde | 0% | 0% | Compensatória | Verde | 0% | 0% |  |  |
| 2831 | 3.1.3.39.3.4.1 | Elaborar Projeto Executivo |  | 80d | 2019-11-18 | 2020-03-17 | 2828 | 2019-11-18 | 2020-03-17 | 80d | 2019-12-10 | 2020-03-19 | 363d | 0d | Verde | Verde | 0% | 0% | Compensatória | Verde | 0% | 0% | Município |  |
| 2832 | 3.1.3.39.3.4.2 | Projeto executivo do Pleito de Timóteo a definir - Projeto apresentado ao banco | milestone | 0d | 2020-03-17 | 2020-03-17 | 2831 | 2020-03-17 | 2020-03-17 | 0d | 2020-03-19 | 2020-03-19 | 363d | 0d | Verde | Verde | 0% | 0% | Compensatória | Verde | 0% | 0% | Município |  |
| 2833 | 3.1.3.39.3.4.3 | Analisar projeto executivo |  | 65d | 2020-03-18 | 2020-06-22 | 2832 | 2020-03-18 | 2020-06-22 | 65d | 2020-03-20 | 2020-04-17 | 363d | 0d | Verde | Verde | 0% | 0% | Compensatória | Verde | 0% | 0% | Banco |  |
| 2834 | 3.1.3.39.3.4.4 | Projeto executivo do Pleito de Timóteo a definir - Projeto concluído | milestone | 0d | 2020-06-22 | 2020-06-22 | 2829, 2833 | 2020-06-22 | 2020-06-22 | 0d | 2020-06-24 | 2020-06-24 | 363d | 0d | Verde | Verde | 0% | 0% | Compensatória | Verde | 0% | 0% | Município |  |
| 2835 | 3.1.3.39.3.4.5 | Recurso do projeto do Pleito de Timóteo a definir - Projeto repassado | milestone | 0d | 2020-06-29 | 2020-06-29 | 2834FS+5d | 2020-06-29 | 2020-06-29 | 0d | 2020-07-01 | 2020-07-01 | 831d | 0d | Verde | Verde | 0% | 0% | Compensatória | Verde | 0% | 0% | Banco |  |
| 2836 | 3.1.3.39.3.5 | Pleito de Timóteo a definir - Projeto concluído | milestone | 0d | 2020-06-29 | 2020-06-29 | 2835 | 2020-06-29 | 2020-06-29 | 0d | 2020-07-01 | 2020-07-01 | 831d | 468d | Verde | Verde | 0% | 0% | Compensatória | Verde | 0% | 0% | Município |  |
| 2837 | 3.1.3.39.4 | **Pleito TIMESOB02 - Implantação de interceptores em Caichoeira do Vale (ME) e Piracicaba (MD) além de EEB-2 e respectiva LR-2** |  | 473d | 2020-06-22 | 2022-05-16 |  | 2020-06-22 | 2022-05-16 | 473d | 2020-06-24 | 2022-05-30 | 363d |  | Verde | Verde | 0% | 0% | Compensatória | Verde | 0% | 0% |  |  |
| 2838 | 3.1.3.39.4.1 | **Licitação da Obra** |  | 78d | 2020-06-22 | 2020-10-09 |  | 2020-06-22 | 2020-10-09 | 78d | 2020-06-24 | 2020-10-14 | 363d |  | Verde | Verde | 0% | 0% | Compensatória | Verde | 0% | 0% |  |  |
| 2839 | 3.1.3.39.4.1.1 | Licitação da obra de Timóteo do Pleito TIMESOB02 - Implantação de interceptores em Caichoeira do Vale (ME) e Piracicaba (MD) além de EEB-2 e respectiva LR-2 autorizada pelo banco | milestone | 0d | 2020-06-22 | 2020-06-22 | 2834 | 2020-06-22 | 2020-06-22 | 0d | 2020-06-24 | 2020-06-24 | 363d | 0d | Verde | Verde | 0% | 0% | Compensatória | Verde | 0% | 0% | Banco |  |
| 2840 | 3.1.3.39.4.1.2 | Licitar Obra |  | 63d | 2020-06-23 | 2020-09-18 | 2839 | 2020-06-23 | 2020-09-18 | 63d | 2020-06-25 | 2020-09-22 | 363d | 0d | Verde | Verde | 0% | 0% | Compensatória | Verde | 0% | 0% | Município |  |
| 2841 | 3.1.3.39.4.1.3 | Analisar e emitir resultado da licitação da obra |  | 15d | 2020-09-21 | 2020-10-09 | 2840 | 2020-09-21 | 2020-10-09 | 15d | 2020-09-23 | 2020-10-14 | 363d | 0d | Verde | Verde | 0% | 0% | Compensatória | Verde | 0% | 0% | Banco |  |
| 2842 | 3.1.3.39.4.1.4 | Licitação da obra de Timóteo do Pleito TIMESOB02 - Implantação de interceptores em Caichoeira do Vale (ME) e Piracicaba (MD) além de EEB-2 e respectiva LR-2 concluída | milestone | 0d | 2020-10-09 | 2020-10-09 | 2841 | 2020-10-09 | 2020-10-09 | 0d | 2020-10-14 | 2020-10-14 | 363d | 0d | Verde | Verde | 0% | 0% | Compensatória | Verde | 0% | 0% | Município |  |
| 2843 | 3.1.3.39.4.2 | Executar obra |  | 250d | 2020-11-11 | 2021-11-11 | 2842FS+20d | 2020-11-11 | 2021-11-11 | 250d | 2020-11-13 | 2021-11-16 | 363d | 0d | Verde | Verde | 0% | 0% | Compensatória | Verde | 0% | 0% | Município |  |
| 2844 | 3.1.3.39.4.3 | Realizar processo de pré-operação |  | 120d | 2021-11-12 | 2022-05-09 | 2843 | 2021-11-12 | 2022-05-09 | 120d | 2021-11-17 | 2022-05-23 | 363d | 0d | Verde | Verde | 0% | 0% | Compensatória | Verde | 0% | 0% | Município |  |
| 2845 | 3.1.3.39.4.4 | Recurso da obra de Timóteo do Pleito TIMESOB02 - Implantação de interceptores em Caichoeira do Vale (ME) e Piracicaba (MD) além de EEB-2 e respectiva LR-2 repassado | milestone | 0d | 2022-05-16 | 2022-05-16 | 2844FS+5d | 2022-05-16 | 2022-05-16 | 0d | 2022-05-30 | 2022-05-30 | 363d | 0d | Verde | Verde | 0% | 0% | Compensatória | Verde | 0% | 0% | Banco |  |
| 2846 | 3.1.3.39.4.5 | Pleito TIMESOB02 - Implantação de interceptores em Caichoeira do Vale (ME) e Piracicaba (MD) além de EEB-2 e respectiva LR-2 de Timóteo concluído | milestone | 0d | 2022-05-16 | 2022-05-16 | 2845 | 2022-05-16 | 2022-05-16 | 0d | 2022-05-30 | 2022-05-30 | 363d | 0d | Verde | Verde | 0% | 0% | Compensatória | Verde | 0% | 0% | Município |  |

Notes:
- 2822: Em 25/04/2019: considerado que o pleito será aprovado na próxima CIF no dia 30/08/2019 conforme NT33
- 2831: 24/05/2019: município pactuou com a Renova 3 meses para elaborar projeto executivo / 29/05/2019: município repactuou com a Renova 4 meses para elaborar projeto executivo
- 2839: 22/01/19 - Ainda não licitando. Fase de elaboração de TR para: / - Licitação de obra SES (Copasa) / - PRAD / - Contratação de estudo de viabilidade de implantação de aterro sanitário (CONDIM)

| ID | WBS | Task | Type | Duration | Start | Finish | Predecessors | Complete | Remaining | Baseline start | Baseline finish | Baseline duration | Baseline 1 start | Baseline 1 finish | Total slack | Free slack | Text1 | Text2 | Text3 | Text6 | Text8 | Text12 | Text14 | Text16 | Text9 | Text18 |
| --- | --- | --- | --- | --- | --- | --- | --- | --- | --- | --- | --- | --- | --- | --- | --- | --- | --- | --- | --- | --- | --- | --- | --- | --- | --- | --- |
| 2847 | 3.1.3.39.5 | **Pleito de Timóteo a definir - Gerenciadora de obra** |  | 572d | 2019-08-01 | 2021-11-19 |  |  |  | 2019-08-01 | 2021-11-19 | 572d | 2019-08-30 | 2021-11-23 | 483d |  | Verde | Verde | 0% | 0% | Compensatória | Verde | 0% | 0% |  |  |
| 2848 | 3.1.3.39.5.1 | Pleito de Timóteo a definir - Gerenciadora de obra aprovado | milestone | 0d | 2019-08-01 | 2019-08-01 | 3052FS+158d |  |  | 2019-08-01 | 2019-08-01 | 0d | 2019-08-30 | 2019-08-30 | 745d | 219d | Verde | Verde | 0% | 0% | Compensatória | Verde | 0% | 0% | CT/CIF |  |
| 2849 | 3.1.3.39.5.2 | **Licitação da Empresa Gerenciadora** |  | 55d | 2020-06-22 | 2020-09-08 |  |  |  | 2020-06-22 | 2020-09-08 | 55d | 2020-06-24 | 2020-09-10 | 526d |  | Verde | Verde | 0% | 0% | Compensatória | Verde | 0% | 0% |  |  |
| 2850 | 3.1.3.39.5.2.1 | Licitação da gerenciadora do Pleito de Timóteo a definir - Gerenciadora de obra autorizada pelo banco | milestone | 0d | 2020-06-22 | 2020-06-22 | 2839, 2848 |  |  | 2020-06-22 | 2020-06-22 | 0d | 2020-06-24 | 2020-06-24 | 526d | 0d | Verde | Verde | 0% | 0% | Compensatória | Verde | 0% | 0% | Banco |  |
| 2851 | 3.1.3.39.5.2.2 | Licitar gerenciadora |  | 41d | 2020-06-23 | 2020-08-18 | 2850 |  |  | 2020-06-23 | 2020-08-18 | 41d | 2020-06-25 | 2020-08-20 | 526d | 0d | Verde | Verde | 0% | 0% | Compensatória | Verde | 0% | 0% | Município |  |
| 2852 | 3.1.3.39.5.2.3 | Analisar e emitir resultado da licitação da gerenciadora |  | 14d | 2020-08-19 | 2020-09-08 | 2851 |  |  | 2020-08-19 | 2020-09-08 | 14d | 2020-08-21 | 2020-09-10 | 526d | 0d | Verde | Verde | 0% | 0% | Compensatória | Verde | 0% | 0% | Banco |  |
| 2853 | 3.1.3.39.5.2.4 | Licitação da gerenciadora do Pleito de Timóteo a definir - Gerenciadora de obra concluída | milestone | 0d | 2020-09-08 | 2020-09-08 | 2852 |  |  | 2020-09-08 | 2020-09-08 | 0d | 2020-09-10 | 2020-09-10 | 526d | 43d | Verde | Verde | 0% | 0% | Compensatória | Verde | 0% | 0% | Município |  |
| 2854 | 3.1.3.39.5.3 | Executar serviço |  | 250d | 2020-11-11 | 2021-11-11 | 2853, 2843SS |  |  | 2020-11-11 | 2021-11-11 | 250d | 2020-11-13 | 2021-11-16 | 483d | 0d | Verde | Verde | 0% | 0% | Compensatória | Verde | 0% | 0% | Município |  |
| 2855 | 3.1.3.39.5.4 | Recurso da gerenciadora do Pleito de Timóteo a definir - Gerenciadora de obra repassado | milestone | 0d | 2021-11-19 | 2021-11-19 | 2854FS+5d |  |  | 2021-11-19 | 2021-11-19 | 0d | 2021-11-23 | 2021-11-23 | 483d | 0d | Verde | Verde | 0% | 0% | Compensatória | Verde | 0% | 0% | Banco |  |
| 2856 | 3.1.3.39.5.5 | Pleito de Timóteo a definir - Gerenciadora de obra concluído | milestone | 0d | 2021-11-19 | 2021-11-19 | 2855 |  |  | 2021-11-19 | 2021-11-19 | 0d | 2021-11-23 | 2021-11-23 | 483d | 120d | Verde | Verde | 0% | 0% | Compensatória | Verde | 0% | 0% | Município |  |
| 2857 | 3.1.3.39.6 | Recursos de Timóteo repassados | milestone | 0d | 2022-05-16 | 2022-05-16 | 2810, 2820, 2836, 2846, 2856 |  |  | 2022-05-16 | 2022-05-16 | 0d | 2022-05-30 | 2022-05-30 | 363d |  | Verde | Verde | 0% | 0% | Compensatória | Verde | 0% | 0% | Banco |  |
| 2858 | 3.1.3.40 | **Tumiritinga** |  | 726d | 2019-05-31 A | 2022-05-02 |  | 1% | 716.57d | 2019-05-31 | 2022-05-02 | 726d | 2019-05-03 | 2023-01-13 | 373d |  | Verde | Verde | 0% | 0% | Compensatória | Verde | 0% | 0% |  |  |
| 2859 | 3.1.3.40.1 | **Pleito TUMESPJ01 - Elaboração de projetos de sistema de esgotamento sanitário da sede do município e distrito de São Geraldo do Tumiritinga** |  | 273d | 2019-05-31 A | 2020-07-06 |  | 3% | 264.42d | 2019-05-31 | 2020-07-06 | 273d | 2019-05-03 | 2020-05-20 | 441d |  | Verde | Verde | 0% | 0% | Compensatória | Verde | 0% | 0% |  |  |
| 2860 | 3.1.3.40.1.1 | **Licitação do Projeto** |  | 82d | 2019-05-31 A | 2019-09-25 |  | 21% | 65.18d | 2019-05-31 | 2019-09-25 | 82d | 2019-05-03 | 2019-07-29 | 441d |  | Verde | Verde | 1% | 0% | Compensatória | Vermelho | 1% | 0% |  |  |
| 2861 | 3.1.3.40.1.1.1 | Licitar projeto |  | 64d | 2019-05-31 A | 2019-08-30 | 3052FS+114d | 25% | 48d | 2019-05-31 | 2019-08-30 | 64d | 2019-05-03 | 2019-07-03 | 441d | 0d | Verde | Verde | 1% | 0% | Compensatória | Vermelho | 1% | 0% | Município | Conforme agendado |
| 2862 | 3.1.3.40.1.1.2 | Documentação de licitação do projeto de Tumiritinga do Pleito TUMESPJ01 - Elaboração de projetos de sistema de esgotamento sanitário da sede do município e distrito de São Geraldo do Tumiritinga apresentada ao banco | milestone | 0d | 2019-09-05 | 2019-09-05 | 2861FS+4d |  |  | 2019-09-05 | 2019-09-05 | 0d | 2019-07-09 | 2019-07-09 | 441d | 0d | Verde | Verde | 0% | 0% | Compensatória | Verde | 0% | 0% | Município |  |
| 2863 | 3.1.3.40.1.1.3 | Analisar e emitir resultado da licitação do projeto |  | 14d | 2019-09-06 | 2019-09-25 | 2862 |  |  | 2019-09-06 | 2019-09-25 | 14d | 2019-07-10 | 2019-07-29 | 441d | 0d | Verde | Verde | 0% | 0% | Compensatória | Verde | 0% | 0% | Banco | Critério FR |
| 2864 | 3.1.3.40.1.1.4 | Licitação do projeto de Tumiritinga do Pleito TUMESPJ01 - Elaboração de projetos de sistema de esgotamento sanitário da sede do município e distrito de São Geraldo do Tumiritinga concluída | milestone | 0d | 2019-09-25 | 2019-09-25 | 2863 |  |  | 2019-09-25 | 2019-09-25 | 0d | 2019-07-29 | 2019-07-29 | 441d | 0d | Verde | Verde | 0% | 0% | Compensatória | Verde | 0% | 0% | Município |  |
| 2865 | 3.1.3.40.1.2 | **Elaboração do Estudo de Concepção** |  | 105d | 2019-09-26 | 2020-03-02 |  |  |  | 2019-09-26 | 2020-03-02 | 105d |  |  | 441d |  | Verde | Verde | 0% | 0% | Compensatória | Verde | 0% | 0% |  |  |
| 2866 | 3.1.3.40.1.2.1 | Elaborar estudo |  | 40d | 2019-09-26 | 2019-11-21 | 2864 |  |  | 2019-09-26 | 2019-11-21 | 40d |  |  | 441d | 0d | Verde | Verde | 0% | 0% | Compensatória | Verde | 0% | 0% |  | Critério FR |
| 2867 | 3.1.3.40.1.2.2 | Estudo de concepção de Tumiritinga do Pleito TUMESPJ01 - Elaboração de projetos de sistema de esgotamento sanitário da sede do município e distrito de São Geraldo do Tumiritinga apresentado ao banco | milestone | 0d | 2019-11-21 | 2019-11-21 | 2866 |  |  | 2019-11-21 | 2019-11-21 | 0d |  |  | 447d | 0d | Verde | Verde | 0% | 0% | Compensatória | Verde | 0% | 0% |  |  |
| 2868 | 3.1.3.40.1.2.3 | Analisar estudo |  | 60d | 2019-11-22 | 2020-02-19 | 2867 |  |  | 2019-11-22 | 2020-02-19 | 60d |  |  | 447d | 0d | Verde | Verde | 0% | 0% | Compensatória | Verde | 0% | 0% |  | Critério FR |
| 2869 | 3.1.3.40.1.2.4 | Estudo de concepção de Tumiritinga do Pleito TUMESPJ01 - Elaboração de projetos de sistema de esgotamento sanitário da sede do município e distrito de São Geraldo do Tumiritinga concluído | milestone | 0d | 2020-02-19 | 2020-02-19 | 2868 |  |  | 2020-02-19 | 2020-02-19 | 0d |  |  | 517d | 0d | Verde | Verde | 0% | 0% | Compensatória | Verde | 0% | 0% |  |  |
| 2870 | 3.1.3.40.1.2.5 | Recurso do estudo de Tumiritinga do Pleito TUMESPJ01 - Elaboração de projetos de sistema de esgotamento sanitário da sede do município e distrito de São Geraldo do Tumiritinga repassado | milestone | 0d | 2020-03-02 | 2020-03-02 | 2869FS+5d |  |  | 2020-03-02 | 2020-03-02 | 0d |  |  | 517d | 40d | Verde | Verde | 0% | 0% | Compensatória | Verde | 0% | 0% |  |  |

Notes:
- 2848: Em 25/04/2019: considerado que o pleito será aprovado na próxima CIF no dia 30/08/2019 conforme NT33
- 2857: Valor de recurso destinado ao munícipio: R$22.059.301,00
- 2858: Tumiritinga solicitou 60,3% (R$2.850.000,00) dos 90% de recursos destinado para Esgotamento Sanitário e teve todo o pleito aprovado, conforme Deliberação 75. / O município teve o pleito de resíduos sólidos negado (R$472.699,31), equivalente a 10% do total do recurso). / Tumiritinga aderiu a ata de registro de preços
- 2861: 21/05/2019: confirmar com município o andamento da licitação na reunião / 31/05/2019: município cancelou processo anterior e reiniciou o processo. Município já possui TR e planilha orçamentária. Considerado o dia da reunião como início da licitação. / 02/07/2019: Fernanda informou que em reunião realizada em 10/06/19, foi confirmada a data de término prevista.
- 2866: 31/05/2019: município solicitou 2 meses para cada etapa do projeto

| ID | WBS | Task | Type | Duration | Start | Finish | Predecessors | Baseline start | Baseline finish | Baseline duration | Baseline 1 start | Baseline 1 finish | Total slack | Free slack | Text1 | Text2 | Text3 | Text6 | Text8 | Text12 | Text14 | Text16 | Text9 |
| --- | --- | --- | --- | --- | --- | --- | --- | --- | --- | --- | --- | --- | --- | --- | --- | --- | --- | --- | --- | --- | --- | --- | --- |
| 2871 | 3.1.3.40.1.3 | **Elaboração do Projeto Básico** |  | 110d | 2019-11-22 | 2020-05-07 |  | 2019-11-22 | 2020-05-07 | 110d | 2019-07-30 | 2020-02-10 | 441d |  | Verde | Verde | 0% | 0% | Compensatória | Verde | 0% | 0% |  |
| 2872 | 3.1.3.40.1.3.1 | Elaborar Projeto Básico |  | 40d | 2019-11-22 | 2020-01-22 | 2866 | 2019-11-22 | 2020-01-22 | 40d | 2019-07-30 | 2019-10-28 | 441d | 0d | Verde | Verde | 0% | 0% | Compensatória | Verde | 0% | 0% | Município |
| 2873 | 3.1.3.40.1.3.2 | Projeto básico de Tumiritinga do Pleito TUMESPJ01 - Elaboração de projetos de sistema de esgotamento sanitário da sede do município e distrito de São Geraldo do Tumiritinga apresentado ao banco | milestone | 0d | 2020-01-22 | 2020-01-22 | 2872 | 2020-01-22 | 2020-01-22 | 0d | 2019-10-28 | 2019-10-28 | 477d | 0d | Verde | Verde | 0% | 0% | Compensatória | Verde | 0% | 0% | Município |
| 2874 | 3.1.3.40.1.3.3 | Analisar projeto básico |  | 65d | 2020-01-23 | 2020-04-29 | 2873 | 2020-01-23 | 2020-04-29 | 65d | 2019-10-29 | 2019-11-27 | 477d | 0d | Verde | Verde | 0% | 0% | Compensatória | Verde | 0% | 0% | Banco |
| 2875 | 3.1.3.40.1.3.4 | Projeto básico de Tumiritinga do Pleito TUMESPJ01 - Elaboração de projetos de sistema de esgotamento sanitário da sede do município e distrito de São Geraldo do Tumiritinga concluído | milestone | 0d | 2020-04-29 | 2020-04-29 | 2870, 2874 | 2020-04-29 | 2020-04-29 | 0d | 2020-02-03 | 2020-02-03 | 477d | 0d | Verde | Verde | 0% | 0% | Compensatória | Verde | 0% | 0% | Município |
| 2876 | 3.1.3.40.1.3.5 | Recurso do projeto básico de Tumiritinga do Pleito TUMESPJ01 - Elaboração de projetos de sistema de esgotamento sanitário da sede do município e distrito de São Geraldo do Tumiritinga repassado | milestone | 0d | 2020-05-07 | 2020-05-07 | 2875FS+5d | 2020-05-07 | 2020-05-07 | 0d | 2020-02-10 | 2020-02-10 | 477d | 36d | Verde | Verde | 0% | 0% | Compensatória | Verde | 0% | 0% | Banco |
| 2877 | 3.1.3.40.1.4 | Realizar Licenciamento Ambiental |  | 120d | 2019-12-23 | 2020-06-19 | 2868FS-40d | 2019-12-23 | 2020-06-19 | 120d | 2019-10-29 | 2020-05-13 | 447d | 6d | Verde | Verde | 0% | 0% | Compensatória | Verde | 0% | 0% | Município |
| 2878 | 3.1.3.40.1.5 | **Elaboração do Projeto Executivo** |  | 111d | 2020-01-23 | 2020-07-06 |  | 2020-01-23 | 2020-07-06 | 111d | 2019-10-29 | 2020-05-20 | 441d |  | Verde | Verde | 0% | 0% | Compensatória | Verde | 0% | 0% |  |
| 2879 | 3.1.3.40.1.5.1 | Elaborar Projeto Executivo |  | 40d | 2020-01-23 | 2020-03-23 | 2872 | 2020-01-23 | 2020-03-23 | 40d | 2019-10-29 | 2020-02-03 | 441d | 0d | Verde | Verde | 0% | 0% | Compensatória | Verde | 0% | 0% | Município |
| 2880 | 3.1.3.40.1.5.2 | Projeto executivo de Tumiritinga do Pleito TUMESPJ01 - Elaboração de projetos de sistema de esgotamento sanitário da sede do município e distrito de São Geraldo do Tumiritinga apresentado ao banco | milestone | 0d | 2020-03-23 | 2020-03-23 | 2879 | 2020-03-23 | 2020-03-23 | 0d | 2020-02-03 | 2020-02-03 | 441d | 0d | Verde | Verde | 0% | 0% | Compensatória | Verde | 0% | 0% | Município |
| 2881 | 3.1.3.40.1.5.3 | Analisar projeto executivo |  | 66d | 2020-03-24 | 2020-06-29 | 2880 | 2020-03-24 | 2020-06-29 | 66d | 2020-02-04 | 2020-03-06 | 441d | 0d | Verde | Verde | 0% | 0% | Compensatória | Verde | 0% | 0% | Banco |
| 2882 | 3.1.3.40.1.5.4 | Projeto executivo de Tumiritinga do Pleito TUMESPJ01 - Elaboração de projetos de sistema de esgotamento sanitário da sede do município e distrito de São Geraldo do Tumiritinga concluído | milestone | 0d | 2020-06-29 | 2020-06-29 | 2876, 2877, 2881 | 2020-06-29 | 2020-06-29 | 0d | 2020-05-13 | 2020-05-13 | 441d | 0d | Verde | Verde | 0% | 0% | Compensatória | Verde | 0% | 0% | Município |
| 2883 | 3.1.3.40.1.5.5 | Recurso do projeto executivo de Tumiritinga do Pleito TUMESPJ01 - Elaboração de projetos de sistema de esgotamento sanitário da sede do município e distrito de São Geraldo do Tumiritinga repassado | milestone | 0d | 2020-07-06 | 2020-07-06 | 2882FS+5d | 2020-07-06 | 2020-07-06 | 0d | 2020-05-20 | 2020-05-20 | 441d | 0d | Verde | Verde | 0% | 0% | Compensatória | Verde | 0% | 0% | Banco |
| 2884 | 3.1.3.40.1.6 | Pleito TUMESPJ01 - Elaboração de projetos de sistema de esgotamento sanitário da sede do município e distrito de São Geraldo do Tumiritinga concluído | milestone | 0d | 2020-07-06 | 2020-07-06 | 2883 | 2020-07-06 | 2020-07-06 | 0d | 2020-05-20 | 2020-05-20 | 441d | 0d | Verde | Verde | 0% | 0% | Compensatória | Verde | 0% | 0% | Município |
| 2885 | 3.1.3.40.2 | **Pleito TUMESOB01 - Execução de obras de rede de esgotamento sanitário e ampliação de estação de ETE da Sede** |  | 385d | 2020-07-06 | 2022-01-19 |  | 2020-07-06 | 2022-01-19 | 385d | 2020-05-20 | 2021-11-29 | 441d |  | Verde | Verde | 0% | 0% | Compensatória | Verde | 0% | 0% |  |
| 2886 | 3.1.3.40.2.1 | **Licitação da Obra** |  | 76d | 2020-07-06 | 2020-10-22 |  | 2020-07-06 | 2020-10-22 | 76d | 2020-05-20 | 2020-09-04 | 441d |  | Verde | Verde | 0% | 0% | Compensatória | Verde | 0% | 0% |  |
| 2887 | 3.1.3.40.2.1.1 | Licitação da obra de Tumiritinga do Pleito TUMESOB01 - Execução de obras de rede de esgotamento sanitário e ampliação de estação de ETE da Sede autorizada pelo banco | milestone | 0d | 2020-07-06 | 2020-07-06 | 2884 | 2020-07-06 | 2020-07-06 | 0d | 2020-05-20 | 2020-05-20 | 441d | 0d | Verde | Verde | 0% | 0% | Compensatória | Verde | 0% | 0% | Banco |
| 2888 | 3.1.3.40.2.1.2 | Licitar Obra |  | 63d | 2020-07-07 | 2020-10-02 | 2887 | 2020-07-07 | 2020-10-02 | 63d | 2020-05-21 | 2020-08-18 | 441d | 0d | Verde | Verde | 0% | 0% | Compensatória | Verde | 0% | 0% | Município |
| 2889 | 3.1.3.40.2.1.3 | Analisar e emitir resultado da licitação da obra |  | 13d | 2020-10-05 | 2020-10-22 | 2888 | 2020-10-05 | 2020-10-22 | 13d | 2020-08-19 | 2020-09-04 | 441d | 0d | Verde | Verde | 0% | 0% | Compensatória | Verde | 0% | 0% | Banco |
| 2890 | 3.1.3.40.2.1.4 | Licitação da obra de Tumiritinga do Pleito TUMESOB01 - Execução de obras de rede de esgotamento sanitário e ampliação de estação de ETE da Sede concluída | milestone | 0d | 2020-10-22 | 2020-10-22 | 2889 | 2020-10-22 | 2020-10-22 | 0d | 2020-09-04 | 2020-09-04 | 441d | 0d | Verde | Verde | 0% | 0% | Compensatória | Verde | 0% | 0% | Município |
| 2891 | 3.1.3.40.2.2 | Executar obra |  | 165d | 2020-11-20 | 2021-07-21 | 2890FS+19d | 2020-11-20 | 2021-07-21 | 165d | 2020-09-08 | 2021-05-19 | 441d | 0d | Verde | Verde | 0% | 0% | Compensatória | Verde | 0% | 0% | Município |
| 2892 | 3.1.3.40.2.3 | Realizar processo de pré-operação |  | 120d | 2021-07-22 | 2022-01-12 | 2891 | 2021-07-22 | 2022-01-12 | 120d | 2021-05-20 | 2021-11-22 | 441d | 0d | Verde | Verde | 0% | 0% | Compensatória | Verde | 0% | 0% | Município |
| 2893 | 3.1.3.40.2.4 | Recurso da obra de Tumiritinga do Pleito TUMESOB01 - Execução de obras de rede de esgotamento sanitário e ampliação de estação de ETE da Sede repassado | milestone | 0d | 2022-01-19 | 2022-01-19 | 2892FS+5d | 2022-01-19 | 2022-01-19 | 0d | 2021-11-29 | 2021-11-29 | 441d | 0d | Verde | Verde | 0% | 0% | Compensatória | Verde | 0% | 0% | Banco |
| 2894 | 3.1.3.40.2.5 | Pleito TUMESOB01 - Execução de obras de rede de esgotamento sanitário e ampliação de estação de ETE da Sede de Tumiritinga concluído | milestone | 0d | 2022-01-19 | 2022-01-19 | 2893 | 2022-01-19 | 2022-01-19 | 0d | 2021-11-29 | 2021-11-29 | 441d | 68d | Verde | Verde | 0% | 0% | Compensatória | Verde | 0% | 0% | Município |

Notes:
- 2872: 31/05/2019: município solicitou 2 meses para cada etapa do projeto
- 2879: 24/05/2019: município pactuou com a Renova 3 meses para elaborar projeto executivo / 31/05/2019: município solicitou 2 meses para cada etapa do projeto
- 2891: Em 24/04/2019: valor da obra R$ 1,7 milhões

| ID | WBS | Task | Type | Duration | Start | Finish | Predecessors | Baseline start | Baseline finish | Baseline duration | Baseline 1 start | Baseline 1 finish | Total slack | Free slack | Text1 | Text2 | Text3 | Text6 | Text8 | Text12 | Text14 | Text16 | Text9 | Text18 |
| --- | --- | --- | --- | --- | --- | --- | --- | --- | --- | --- | --- | --- | --- | --- | --- | --- | --- | --- | --- | --- | --- | --- | --- | --- |
| 2895 | 3.1.3.40.3 | **Pleito TUMESOB02 - Execução de obras de rede de esgotamento sanitário e implantação de estação de ETE de São Geraldo do Tumiritinga** |  | 385d | 2020-07-06 | 2022-01-19 |  | 2020-07-06 | 2022-01-19 | 385d | 2020-05-20 | 2021-11-29 | 441d |  | Verde | Verde | 0% | 0% | Compensatória | Verde | 0% | 0% |  |  |
| 2896 | 3.1.3.40.3.1 | **Licitação da Obra** |  | 76d | 2020-07-06 | 2020-10-22 |  | 2020-07-06 | 2020-10-22 | 76d | 2020-05-20 | 2020-09-04 | 441d |  | Verde | Verde | 0% | 0% | Compensatória | Verde | 0% | 0% |  |  |
| 2897 | 3.1.3.40.3.1.1 | Licitação da obra de Tumiritinga do Pleito TUMESOB02 - Execução de obras de rede de esgotamento sanitário e implantação de estação de ETE de São Geraldo do Tumiritinga autorizada pelo banco | milestone | 0d | 2020-07-06 | 2020-07-06 | 2884 | 2020-07-06 | 2020-07-06 | 0d | 2020-05-20 | 2020-05-20 | 441d | 0d | Verde | Verde | 0% | 0% | Compensatória | Verde | 0% | 0% | Banco |  |
| 2898 | 3.1.3.40.3.1.2 | Licitar Obra |  | 63d | 2020-07-07 | 2020-10-02 | 2897 | 2020-07-07 | 2020-10-02 | 63d | 2020-05-21 | 2020-08-18 | 441d | 0d | Verde | Verde | 0% | 0% | Compensatória | Verde | 0% | 0% | Município |  |
| 2899 | 3.1.3.40.3.1.3 | Analisar e emitir resultado da licitação da obra |  | 13d | 2020-10-05 | 2020-10-22 | 2898 | 2020-10-05 | 2020-10-22 | 13d | 2020-08-19 | 2020-09-04 | 441d | 0d | Verde | Verde | 0% | 0% | Compensatória | Verde | 0% | 0% | Banco |  |
| 2900 | 3.1.3.40.3.1.4 | Licitação da obra de Tumiritinga do Pleito TUMESOB02 - Execução de obras de rede de esgotamento sanitário e implantação de estação de ETE de São Geraldo do Tumiritinga concluída | milestone | 0d | 2020-10-22 | 2020-10-22 | 2899 | 2020-10-22 | 2020-10-22 | 0d | 2020-09-04 | 2020-09-04 | 441d | 0d | Verde | Verde | 0% | 0% | Compensatória | Verde | 0% | 0% | Município |  |
| 2901 | 3.1.3.40.3.2 | Executar obra |  | 165d | 2020-11-20 | 2021-07-21 | 2900FS+19d | 2020-11-20 | 2021-07-21 | 165d | 2020-09-08 | 2021-05-19 | 441d | 0d | Verde | Verde | 0% | 0% | Compensatória | Verde | 0% | 0% | Município |  |
| 2902 | 3.1.3.40.3.3 | Realizar processo de pré-operação |  | 120d | 2021-07-22 | 2022-01-12 | 2901 | 2021-07-22 | 2022-01-12 | 120d | 2021-05-20 | 2021-11-22 | 441d | 0d | Verde | Verde | 0% | 0% | Compensatória | Verde | 0% | 0% | Município |  |
| 2903 | 3.1.3.40.3.4 | Recurso da obra de Tumiritinga do Pleito TUMESOB02 - Execução de obras de rede de esgotamento sanitário e implantação de estação de ETE de São Geraldo do Tumiritinga repassado | milestone | 0d | 2022-01-19 | 2022-01-19 | 2902FS+5d | 2022-01-19 | 2022-01-19 | 0d | 2021-11-29 | 2021-11-29 | 441d | 0d | Verde | Verde | 0% | 0% | Compensatória | Verde | 0% | 0% | Banco |  |
| 2904 | 3.1.3.40.3.5 | Pleito TUMESOB02 - Execução de obras de rede de esgotamento sanitário e implantação de estação de ETE de São Geraldo do Tumiritinga concluído | milestone | 0d | 2022-01-19 | 2022-01-19 | 2903 | 2022-01-19 | 2022-01-19 | 0d | 2021-11-29 | 2021-11-29 | 441d | 68d | Verde | Verde | 0% | 0% | Compensatória | Verde | 0% | 0% | Município |  |
| 2905 | 3.1.3.40.4 | **Pleito de Tumiritinga de Resíduos Sólidos a definir** |  | 662d | 2019-08-30 | 2022-05-02 |  | 2019-08-30 | 2022-05-02 | 662d | 2019-08-30 | 2023-01-13 | 373d |  | Verde | Verde | 0% | 0% | Compensatória | Verde | 0% | 0% |  |  |
| 2906 | 3.1.3.40.4.1 | Pleito de Tumiritinga de Resíduos Sólidos a definir aprovado | milestone | 0d | 2019-08-30 | 2019-08-30 | 3052FS+178d | 2019-08-30 | 2019-08-30 | 0d | 2019-08-30 | 2019-08-30 | 373d | 0d | Verde | Verde | 0% | 0% | Compensatória | Verde | 0% | 0% | CT/CIF |  |
| 2907 | 3.1.3.40.4.2 | Iniciar serviço/projeto/obra do pleito de Tumiritinga de Resíduos Sólidos a definir |  | 1d | 2019-09-02 | 2019-09-02 | 2906 | 2019-09-02 | 2019-09-02 | 1d | 2019-09-02 | 2019-09-02 | 373d | 0d | Verde | Verde | 0% | 0% | Compensatória | Verde | 0% | 0% | Município | Critério FR |
| 2908 | 3.1.3.40.4.3 | Pleito de Tumiritinga de Resíduos Sólidos a definir concluído | milestone | 0d | 2022-05-02 | 2022-05-02 | 2907FS+661d | 2022-05-02 | 2022-05-02 | 0d | 2023-01-13 | 2023-01-13 | 373d | 0d | Verde | Verde | 0% | 0% | Compensatória | Verde | 0% | 0% | Município |  |
| 2909 | 3.1.3.40.5 | Recursos de Tumiritinga repassados | milestone | 0d | 2022-05-02 | 2022-05-02 | 2884, 2894, 2904, 2908 | 2022-05-02 | 2022-05-02 | 0d | 2023-01-13 | 2023-01-13 | 373d |  | Verde | Verde | 0% | 0% | Compensatória | Verde | 0% | 0% | Banco |  |
| 2910 | 3.1.3.41 | **CONDOESTE** |  | 857d | 2019-09-06 | 2023-02-14 |  | 2019-09-06 | 2023-02-14 | 857d | 2019-08-30 | 2024-04-09 | 197d |  | Verde | Verde | 0% | 0% | Compensatória | Verde | 0% | 0% |  |  |
| 2911 | 3.1.3.41.1 | **Pleito CDTRSOB01 - Construção das 05 Estações de Transbordo, projetadas para serem construídas nos municípios de Alto Rio Novo, Itarana, Laranja da Terra, São Domingos do Norte e Colatina** |  | 857d | 2019-09-06 | 2023-02-14 |  | 2019-09-06 | 2023-02-14 | 857d | 2019-08-30 | 2024-04-09 | 197d |  | Verde | Verde | 0% | 0% | Compensatória | Verde | 0% | 0% |  |  |
| 2912 | 3.1.3.41.1.1 | Realizar Licenciamento Ambiental |  | 80d | 2019-09-06 | 2020-01-02 | 2914SS | 2019-09-06 | 2020-01-02 | 80d | 2020-02-19 | 2020-05-20 | 249d | 52d | Verde | Verde | 0% | 0% | Compensatória | Verde | 0% | 0% | Município |  |
| 2913 | 3.1.3.41.1.2 | **Aprovação do Projeto** |  | 132d | 2019-09-06 | 2020-03-19 |  | 2019-09-06 | 2020-03-19 | 132d | 2020-02-19 | 2020-09-08 | 197d |  | Verde | Verde | 0% | 0% | Compensatória | Verde | 0% | 0% |  |  |
| 2914 | 3.1.3.41.1.2.1 | Adequar projeto |  | 66d | 2019-09-06 | 2019-12-09 | 3052FS+182d | 2019-09-06 | 2019-12-09 | 66d | 2020-02-19 | 2020-05-28 | 197d | 0d | Verde | Verde | 0% | 0% | Compensatória | Verde | 0% | 0% | Município |  |
| 2915 | 3.1.3.41.1.2.2 | Projeto do CONDOESTE do Pleito CDTRSOB01 - Construção das 05 Estações de Transbordo, projetadas para serem construídas nos municípios de Alto Rio Novo, Itarana, Laranja da Terra, São Domingos do Norte e Colatina apresentado ao banco | milestone | 0d | 2019-12-09 | 2019-12-09 | 2914 | 2019-12-09 | 2019-12-09 | 0d | 2020-05-28 | 2020-05-28 | 197d | 0d | Verde | Verde | 0% | 0% | Compensatória | Verde | 0% | 0% | Município |  |
| 2916 | 3.1.3.41.1.2.3 | Analisar projeto |  | 66d | 2019-12-10 | 2020-03-19 | 2915 | 2019-12-10 | 2020-03-19 | 66d | 2020-05-29 | 2020-06-30 | 197d | 0d | Verde | Verde | 0% | 0% | Compensatória | Verde | 0% | 0% | Banco |  |
| 2917 | 3.1.3.41.1.2.4 | Projeto do CONDOESTE do Pleito CDTRSOB01 - Construção das 05 Estações de Transbordo, projetadas para serem construídas nos municípios de Alto Rio Novo, Itarana, Laranja da Terra, São Domingos do Norte e Colatina aprovado | milestone | 0d | 2020-03-19 | 2020-03-19 | 2912, 2916 | 2020-03-19 | 2020-03-19 | 0d | 2020-08-31 | 2020-08-31 | 197d | 0d | Verde | Verde | 0% | 0% | Compensatória | Verde | 0% | 0% | Município |  |
| 2918 | 3.1.3.41.1.3 | **Licitação da obra** |  | 80d | 2020-03-19 | 2020-07-15 |  | 2020-03-19 | 2020-07-15 | 80d | 2020-08-31 | 2020-12-28 | 197d |  | Verde | Verde | 0% | 0% | Compensatória | Verde | 0% | 0% |  |  |
| 2919 | 3.1.3.41.1.3.1 | Licitação da obra do CONDOESTE do Pleito CDTRSOB01 - Construção das 05 Estações de Transbordo, projetadas para serem construídas nos municípios de Alto Rio Novo, Itarana, Laranja da Terra, São Domingos do Norte e Colatina autorizada pelo banco | milestone | 0d | 2020-03-19 | 2020-03-19 | 2917 | 2020-03-19 | 2020-03-19 | 0d | 2020-08-31 | 2020-08-31 | 197d | 0d | Verde | Verde | 0% | 0% | Compensatória | Verde | 0% | 0% | Banco |  |
| 2920 | 3.1.3.41.1.3.2 | Licitar obra |  | 66d | 2020-03-20 | 2020-06-25 | 2919 | 2020-03-20 | 2020-06-25 | 66d | 2020-09-01 | 2020-12-04 | 197d | 0d | Verde | Verde | 0% | 0% | Compensatória | Verde | 0% | 0% | Município |  |
| 2921 | 3.1.3.41.1.3.3 | Analisar e emitir resultado da licitação da obra |  | 14d | 2020-06-26 | 2020-07-15 | 2920 | 2020-06-26 | 2020-07-15 | 14d | 2020-12-07 | 2020-12-28 | 197d | 0d | Verde | Verde | 0% | 0% | Compensatória | Verde | 0% | 0% | Banco |  |
| 2922 | 3.1.3.41.1.3.4 | Licitação da obra do CONDOESTE do Pleito CDTRSOB01 - Construção das 05 Estações de Transbordo, projetadas para serem construídas nos municípios de Alto Rio Novo, Itarana, Laranja da Terra, São Domingos do Norte e Colatina concluída | milestone | 0d | 2020-07-15 | 2020-07-15 | 2921 | 2020-07-15 | 2020-07-15 | 0d | 2020-12-28 | 2020-12-28 | 197d | 0d | Verde | Verde | 0% | 0% | Compensatória | Verde | 0% | 0% | Município |  |
| 2923 | 3.1.3.41.1.4 | Executar obra |  | 500d | 2020-08-13 | 2022-08-16 | 2922FS+20d | 2020-08-13 | 2022-08-16 | 500d | 2021-01-27 | 2023-09-21 | 197d | 0d | Verde | Verde | 0% | 0% | Compensatória | Verde | 0% | 0% | Município |  |
| 2924 | 3.1.3.41.1.5 | Realizar processo de pré-operação |  | 120d | 2022-08-17 | 2023-02-07 | 2923 | 2022-08-17 | 2023-02-07 | 120d | 2023-09-22 | 2024-04-02 | 197d | 0d | Verde | Verde | 0% | 0% | Compensatória | Verde | 0% | 0% | Município |  |
| 2925 | 3.1.3.41.1.6 | Recurso da obra do CONDOESTE do Pleito CDTRSOB01 - Construção das 05 Estações de Transbordo, projetadas para serem construídas nos municípios de Alto Rio Novo, Itarana, Laranja da Terra, São Domingos do Norte e Colatina repassado | milestone | 0d | 2023-02-14 | 2023-02-14 | 2924FS+5d | 2023-02-14 | 2023-02-14 | 0d | 2024-04-09 | 2024-04-09 | 197d | 0d | Verde | Verde | 0% | 0% | Compensatória | Verde | 0% | 0% | Banco |  |
| 2926 | 3.1.3.41.1.7 | Pleito CDTRSOB01 - Construção das 05 Estações de Transbordo, projetadas para serem construídas nos municípios de Alto Rio Novo, Itarana, Laranja da Terra, São Domingos do Norte e Colatina do CONDOESTE concluído | milestone | 0d | 2023-02-14 | 2023-02-14 | 2925 | 2023-02-14 | 2023-02-14 | 0d | 2024-04-09 | 2024-04-09 | 197d | 0d | Verde | Verde | 0% | 0% | Compensatória | Verde | 0% | 0% | Município |  |
| 2927 | 3.1.3.41.2 | Recursos de CONDOESTE repassados | milestone | 0d | 2023-02-14 | 2023-02-14 | 2926 | 2023-02-14 | 2023-02-14 | 0d | 2024-04-09 | 2024-04-09 | 197d |  | Verde | Verde | 0% | 0% | Compensatória | Verde | 0% | 0% | Banco |  |
| 2928 | 3.1.3.42 | Processo de Repasse de Recursos aos Municípios concluído | milestone | 0d | 2023-10-30 | 2023-10-30 | 220, 283, 323, 364, 421, 485, 546, 591, 1017, 1059, 1079, 1127, 1236, 1300, 1384, 1437, 1493, 1568, 1652, 1778, 1912, 1963, 2009, 2060, 2113, 2167, 2212, 2283, 2354, 2402, 2440, 2506, 2576, 2603, 2651, 2734, 2795, 2857, 2909 | 2023-10-30 | 2023-10-30 | 0d | 2025-02-25 | 2025-02-25 | 0d |  | Verde | Verde | 0% | 0% | Compensatória | Verde | 0% | 0% |  |  |
| 2929 | 3.1.4 | Processo de Repasse de Recurso Concluído | milestone | 0d | 2023-10-30 | 2023-10-30 | 76, 2928, 78 | 2023-10-30 | 2023-10-30 | 0d | 2025-02-25 | 2025-02-25 | 0d |  | Verde | Verde | 0% | 0% | Compensatória | Verde | 0% | 0% |  |  |

Notes:
- 2906: Em 24/04/2019: considerado que o pleito será elaborado até julho de 2019 e aprovado no CT/CIF de agosto
- 2909: Valor de recurso destinado ao munícipio: R$4.726.993,07
- 2914: 24/05/2019: consórcio pactuou com a Renova 3 meses para elaborar projeto executivo
- 2923: 21/05/2019: premissa de duração da obra alterada para 24 meses

| ID | WBS | Task | Type | Duration | Start | Finish | Predecessors | Complete | Remaining | Baseline start | Baseline finish | Baseline duration | Baseline 1 start | Baseline 1 finish | Total slack | Text1 | Text2 | Text3 | Text4 | Text5 | Text6 | Text7 | Text8 | Text12 | Text14 | Text15 | Text16 | Text17 |
| --- | --- | --- | --- | --- | --- | --- | --- | --- | --- | --- | --- | --- | --- | --- | --- | --- | --- | --- | --- | --- | --- | --- | --- | --- | --- | --- | --- | --- |
| 2930 | 3.2 | **Atividade Interna Renova** |  | 527d | 2017-09-08 A | 2019-09-27 |  | 86% | 71.79d | 2017-09-08 | 2019-10-24 | 546d | 2017-09-08 | 2025-02-25 | 1038d | Verde | Verde | 81% | 90 | 81 | 100% | 100 | Compensatória | Verde | 95% | 95 | 95% | 95 |
| 2931 | 3.2.1 | **Atividade Interna Renova** |  | 74d | 2017-09-08 A | 2017-12-20 A |  | 100% |  | 2017-09-08 | 2017-12-20 | 74d | 2017-09-08 | 2017-12-20 |  | Verde | Verde | 100% | 100 | 100 | 100% | 100 | Compensatória | Verde | 100% | 100 | 100% | 100 |
| 2932 | 3.2.1.1 | Atividade Interna Renova |  | 65d | 2017-09-08 A | 2017-12-07 A | 45SS+7ed | 100% |  | 2017-09-08 | 2017-12-07 | 65d | 2017-09-08 | 2017-12-07 |  | Verde | Verde | 100% | 100 | 100 | 100% | 100 | Compensatória | Verde | 100% | 100 | 100% | 100 |
| 2933 | 3.2.1.2 | Atividade Interna Renova | milestone | 0d | 2017-12-15 A | 2017-12-15 A | 2932FS+8ed | 100% |  | 2017-12-15 | 2017-12-15 | 0d | 2017-12-15 | 2017-12-15 |  | Verde | Verde | 100% | 100 | 100 | 100% | 100 | Compensatória | Verde | 100% | 100 | 100% | 100 |
| 2934 | 3.2.1.3 | **Atividade Interna Renova** |  | 61d | 2017-09-27 A | 2017-12-20 A |  | 100% |  | 2017-09-27 | 2017-12-20 | 61d | 2017-09-27 | 2017-12-20 |  | Verde | Verde | 100% | 100 | 100 | 100% | 100 | Compensatória | Verde | 100% | 100 | 100% | 100 |
| 2935 | 3.2.1.3.1 | **Atividade Interna Renova** |  | 61d | 2017-09-27 A | 2017-12-20 A |  | 100% |  | 2017-09-27 | 2017-12-20 | 61d | 2017-09-27 | 2017-12-20 |  | Verde | Verde | 100% | 100 | 100 | 100% | 100 | Compensatória | Verde | 100% | 100 | 100% | 100 |
| 2936 | 3.2.1.3.1.1 | Atividade Interna Renova |  | 1d | 2017-09-27 A | 2017-09-27 A | 2932SS+19ed | 100% |  | 2017-09-27 | 2017-09-27 | 1d | 2017-09-27 | 2017-09-27 |  | Verde | Verde | 100% | 100 | 100 | 100% | 100 | Compensatória | Verde | 100% | 100 | 100% | 100 |
| 2937 | 3.2.1.3.1.2 | Atividade Interna Renova |  | 1d | 2017-10-02 A | 2017-10-02 A | 2932SS+23ed | 100% |  | 2017-10-02 | 2017-10-02 | 1d | 2017-10-02 | 2017-10-02 |  | Verde | Verde | 100% | 100 | 100 | 100% | 100 | Compensatória | Verde | 100% | 100 | 100% | 100 |
| 2938 | 3.2.1.3.1.3 | Atividade Interna Renova |  | 1d | 2017-10-03 A | 2017-10-03 A | 2932SS+25ed | 100% |  | 2017-10-03 | 2017-10-03 | 1d | 2017-10-03 | 2017-10-03 |  | Verde | Verde | 100% | 100 | 100 | 100% | 100 | Compensatória | Verde | 100% | 100 | 100% | 100 |
| 2939 | 3.2.1.3.1.4 | Atividade Interna Renova |  | 1d | 2017-10-03 A | 2017-10-03 A | 2932SS+25ed | 100% |  | 2017-10-03 | 2017-10-03 | 1d | 2017-10-03 | 2017-10-03 |  | Verde | Verde | 100% | 100 | 100 | 100% | 100 | Compensatória | Verde | 100% | 100 | 100% | 100 |
| 2940 | 3.2.1.3.1.5 | Atividade Interna Renova |  | 1d | 2017-10-04 A | 2017-10-04 A | 2932SS+26ed | 100% |  | 2017-10-04 | 2017-10-04 | 1d | 2017-10-04 | 2017-10-04 |  | Verde | Verde | 100% | 100 | 100 | 100% | 100 | Compensatória | Verde | 100% | 100 | 100% | 100 |
| 2941 | 3.2.1.3.1.6 | Atividade Interna Renova |  | 1d | 2017-10-04 A | 2017-10-04 A | 2932SS+26ed | 100% |  | 2017-10-04 | 2017-10-04 | 1d | 2017-10-04 | 2017-10-04 |  | Verde | Verde | 100% | 100 | 100 | 100% | 100 | Compensatória | Verde | 100% | 100 | 100% | 100 |
| 2942 | 3.2.1.3.1.7 | Atividade Interna Renova |  | 1d | 2017-10-05 A | 2017-10-05 A | 2932SS+27ed | 100% |  | 2017-10-05 | 2017-10-05 | 1d | 2017-10-05 | 2017-10-05 |  | Verde | Verde | 100% | 100 | 100 | 100% | 100 | Compensatória | Verde | 100% | 100 | 100% | 100 |
| 2943 | 3.2.1.3.1.8 | Atividade Interna Renova |  | 1d | 2017-10-05 A | 2017-10-05 A | 2932SS+27ed | 100% |  | 2017-10-05 | 2017-10-05 | 1d | 2017-10-05 | 2017-10-05 |  | Verde | Verde | 100% | 100 | 100 | 100% | 100 | Compensatória | Verde | 100% | 100 | 100% | 100 |
| 2944 | 3.2.1.3.1.9 | Atividade Interna Renova |  | 1d | 2017-10-09 A | 2017-10-09 A | 2932SS+31ed | 100% |  | 2017-10-09 | 2017-10-09 | 1d | 2017-10-09 | 2017-10-09 |  | Verde | Verde | 100% | 100 | 100 | 100% | 100 | Compensatória | Verde | 100% | 100 | 100% | 100 |
| 2945 | 3.2.1.3.1.10 | Atividade Interna Renova |  | 1d | 2017-10-10 A | 2017-10-10 A | 2932SS+32ed | 100% |  | 2017-10-10 | 2017-10-10 | 1d | 2017-10-10 | 2017-10-10 |  | Verde | Verde | 100% | 100 | 100 | 100% | 100 | Compensatória | Verde | 100% | 100 | 100% | 100 |
| 2946 | 3.2.1.3.1.11 | Atividade Interna Renova |  | 1d | 2017-10-11 A | 2017-10-11 A | 2932SS+33ed | 100% |  | 2017-10-11 | 2017-10-11 | 1d | 2017-10-11 | 2017-10-11 |  | Verde | Verde | 100% | 100 | 100 | 100% | 100 | Compensatória | Verde | 100% | 100 | 100% | 100 |
| 2947 | 3.2.1.3.1.12 | Atividade Interna Renova |  | 1d | 2017-10-16 A | 2017-10-16 A | 2932SS+38ed | 100% |  | 2017-10-16 | 2017-10-16 | 1d | 2017-10-16 | 2017-10-16 |  | Verde | Verde | 100% | 100 | 100 | 100% | 100 | Compensatória | Verde | 100% | 100 | 100% | 100 |
| 2948 | 3.2.1.3.1.13 | Atividade Interna Renova |  | 1d | 2017-10-17 A | 2017-10-17 A | 2932SS+39ed | 100% |  | 2017-10-17 | 2017-10-17 | 1d | 2017-10-17 | 2017-10-17 |  | Verde | Verde | 100% | 100 | 100 | 100% | 100 | Compensatória | Verde | 100% | 100 | 100% | 100 |
| 2949 | 3.2.1.3.1.14 | Atividade Interna Renova |  | 1d | 2017-10-17 A | 2017-10-17 A | 2932SS+39ed | 100% |  | 2017-10-17 | 2017-10-17 | 1d | 2017-10-17 | 2017-10-17 |  | Verde | Verde | 100% | 100 | 100 | 100% | 100 | Compensatória | Verde | 100% | 100 | 100% | 100 |
| 2950 | 3.2.1.3.1.15 | Atividade Interna Renova |  | 1d | 2017-10-18 A | 2017-10-18 A | 2932SS+40ed | 100% |  | 2017-10-18 | 2017-10-18 | 1d | 2017-10-18 | 2017-10-18 |  | Verde | Verde | 100% | 100 | 100 | 100% | 100 | Compensatória | Verde | 100% | 100 | 100% | 100 |
| 2951 | 3.2.1.3.1.16 | Atividade Interna Renova |  | 1d | 2017-10-18 A | 2017-10-18 A | 2932SS+40ed | 100% |  | 2017-10-18 | 2017-10-18 | 1d | 2017-10-18 | 2017-10-18 |  | Verde | Verde | 100% | 100 | 100 | 100% | 100 | Compensatória | Verde | 100% | 100 | 100% | 100 |
| 2952 | 3.2.1.3.1.17 | Atividade Interna Renova |  | 1d | 2017-10-19 A | 2017-10-19 A | 2932SS+41ed | 100% |  | 2017-10-19 | 2017-10-19 | 1d | 2017-10-19 | 2017-10-19 |  | Verde | Verde | 100% | 100 | 100 | 100% | 100 | Compensatória | Verde | 100% | 100 | 100% | 100 |
| 2953 | 3.2.1.3.1.18 | Atividade Interna Renova |  | 1d | 2017-10-20 A | 2017-10-20 A | 2932SS+42ed | 100% |  | 2017-10-20 | 2017-10-20 | 1d | 2017-10-20 | 2017-10-20 |  | Verde | Verde | 100% | 100 | 100 | 100% | 100 | Compensatória | Verde | 100% | 100 | 100% | 100 |
| 2954 | 3.2.1.3.1.19 | Atividade Interna Renova |  | 1d | 2017-10-20 A | 2017-10-20 A | 2932SS+42ed | 100% |  | 2017-10-20 | 2017-10-20 | 1d | 2017-10-20 | 2017-10-20 |  | Verde | Verde | 100% | 100 | 100 | 100% | 100 | Compensatória | Verde | 100% | 100 | 100% | 100 |
| 2955 | 3.2.1.3.1.20 | Atividade Interna Renova |  | 1d | 2017-10-20 A | 2017-10-20 A | 2932SS+42ed | 100% |  | 2017-10-20 | 2017-10-20 | 1d | 2017-10-20 | 2017-10-20 |  | Verde | Verde | 100% | 100 | 100 | 100% | 100 | Compensatória | Verde | 100% | 100 | 100% | 100 |
| 2956 | 3.2.1.3.1.21 | Atividade Interna Renova |  | 1d | 2017-10-20 A | 2017-10-20 A | 2932SS+42ed | 100% |  | 2017-10-20 | 2017-10-20 | 1d | 2017-10-20 | 2017-10-20 |  | Verde | Verde | 100% | 100 | 100 | 100% | 100 | Compensatória | Verde | 100% | 100 | 100% | 100 |
| 2957 | 3.2.1.3.1.22 | Atividade Interna Renova |  | 1d | 2017-10-24 A | 2017-10-24 A | 2932SS+46ed | 100% |  | 2017-10-24 | 2017-10-24 | 1d | 2017-10-24 | 2017-10-24 |  | Verde | Verde | 100% | 100 | 100 | 100% | 100 | Compensatória | Verde | 100% | 100 | 100% | 100 |
| 2958 | 3.2.1.3.1.23 | Atividade Interna Renova |  | 1d | 2017-10-24 A | 2017-10-24 A | 2932SS+46ed | 100% |  | 2017-10-24 | 2017-10-24 | 1d | 2017-10-24 | 2017-10-24 |  | Verde | Verde | 100% | 100 | 100 | 100% | 100 | Compensatória | Verde | 100% | 100 | 100% | 100 |
| 2959 | 3.2.1.3.1.24 | Atividade Interna Renova |  | 1d | 2017-10-25 A | 2017-10-25 A | 2932SS+47ed | 100% |  | 2017-10-25 | 2017-10-25 | 1d | 2017-10-25 | 2017-10-25 |  | Verde | Verde | 100% | 100 | 100 | 100% | 100 | Compensatória | Verde | 100% | 100 | 100% | 100 |
| 2960 | 3.2.1.3.1.25 | Atividade Interna Renova |  | 1d | 2017-10-25 A | 2017-10-25 A | 2932SS+47ed | 100% |  | 2017-10-25 | 2017-10-25 | 1d | 2017-10-25 | 2017-10-25 |  | Verde | Verde | 100% | 100 | 100 | 100% | 100 | Compensatória | Verde | 100% | 100 | 100% | 100 |
| 2961 | 3.2.1.3.1.26 | Atividade Interna Renova |  | 1d | 2017-10-27 A | 2017-10-27 A | 2932SS+49ed | 100% |  | 2017-10-27 | 2017-10-27 | 1d | 2017-10-27 | 2017-10-27 |  | Verde | Verde | 100% | 100 | 100 | 100% | 100 | Compensatória | Verde | 100% | 100 | 100% | 100 |
| 2962 | 3.2.1.3.1.27 | Atividade Interna Renova |  | 1d | 2017-11-14 A | 2017-11-14 A | 2932SS+67ed | 100% |  | 2017-11-14 | 2017-11-14 | 1d | 2017-11-14 | 2017-11-14 |  | Verde | Verde | 100% | 100 | 100 | 100% | 100 | Compensatória | Verde | 100% | 100 | 100% | 100 |
| 2963 | 3.2.1.3.1.28 | Atividade Interna Renova |  | 1d | 2017-11-14 A | 2017-11-14 A | 2932SS+67ed | 100% |  | 2017-11-14 | 2017-11-14 | 1d | 2017-11-14 | 2017-11-14 |  | Verde | Verde | 100% | 100 | 100 | 100% | 100 | Compensatória | Verde | 100% | 100 | 100% | 100 |
| 2964 | 3.2.1.3.1.29 | Atividade Interna Renova |  | 1d | 2017-11-23 A | 2017-11-23 A | 2932SS+76ed | 100% |  | 2017-11-23 | 2017-11-23 | 1d | 2017-11-23 | 2017-11-23 |  | Verde | Verde | 100% | 100 | 100 | 100% | 100 | Compensatória | Verde | 100% | 100 | 100% | 100 |
| 2965 | 3.2.1.3.1.30 | Atividade Interna Renova |  | 1d | 2017-11-28 A | 2017-11-28 A | 2932SS+81ed | 100% |  | 2017-11-28 | 2017-11-28 | 1d | 2017-11-28 | 2017-11-28 |  | Verde | Verde | 100% | 100 | 100 | 100% | 100 | Compensatória | Verde | 100% | 100 | 100% | 100 |
| 2966 | 3.2.1.3.1.31 | Atividade Interna Renova |  | 1d | 2017-11-28 A | 2017-11-28 A | 2932SS+81ed | 100% |  | 2017-11-28 | 2017-11-28 | 1d | 2017-11-28 | 2017-11-28 |  | Verde | Verde | 100% | 100 | 100 | 100% | 100 | Compensatória | Verde | 100% | 100 | 100% | 100 |
| 2967 | 3.2.1.3.1.32 | Atividade Interna Renova |  | 1d | 2017-11-28 A | 2017-11-28 A | 2932SS+81ed | 100% |  | 2017-11-28 | 2017-11-28 | 1d | 2017-11-28 | 2017-11-28 |  | Verde | Verde | 100% | 100 | 100 | 100% | 100 | Compensatória | Verde | 100% | 100 | 100% | 100 |
| 2968 | 3.2.1.3.1.33 | Atividade Interna Renova |  | 1d | 2017-11-29 A | 2017-11-29 A | 2932SS+82ed | 100% |  | 2017-11-29 | 2017-11-29 | 1d | 2017-11-29 | 2017-11-29 |  | Verde | Verde | 100% | 100 | 100 | 100% | 100 | Compensatória | Verde | 100% | 100 | 100% | 100 |
| 2969 | 3.2.1.3.1.34 | Atividade Interna Renova |  | 1d | 2017-11-29 A | 2017-11-29 A | 2932SS+82ed | 100% |  | 2017-11-29 | 2017-11-29 | 1d | 2017-11-29 | 2017-11-29 |  | Verde | Verde | 100% | 100 | 100 | 100% | 100 | Compensatória | Verde | 100% | 100 | 100% | 100 |
| 2970 | 3.2.1.3.1.35 | Atividade Interna Renova |  | 1d | 2017-11-30 A | 2017-11-30 A | 2932SS+83ed | 100% |  | 2017-11-30 | 2017-11-30 | 1d | 2017-11-30 | 2017-11-30 |  | Verde | Verde | 100% | 100 | 100 | 100% | 100 | Compensatória | Verde | 100% | 100 | 100% | 100 |
| 2971 | 3.2.1.3.1.36 | Atividade Interna Renova |  | 1d | 2017-12-18 A | 2017-12-18 A | 2932SS+101ed | 100% |  | 2017-12-18 | 2017-12-18 | 1d | 2017-12-18 | 2017-12-18 |  | Verde | Verde | 100% | 100 | 100 | 100% | 100 | Compensatória | Verde | 100% | 100 | 100% | 100 |
| 2972 | 3.2.1.3.1.37 | Atividade Interna Renova |  | 1d | 2017-12-15 A | 2017-12-15 A | 2932SS+98ed | 100% |  | 2017-12-15 | 2017-12-15 | 1d | 2017-12-15 | 2017-12-15 |  | Verde | Verde | 100% | 100 | 100 | 100% | 100 | Compensatória | Verde | 100% | 100 | 100% | 100 |
| 2973 | 3.2.1.3.1.38 | Atividade Interna Renova |  | 1d | 2017-12-19 A | 2017-12-19 A | 2932SS+102ed | 100% |  | 2017-12-19 | 2017-12-19 | 1d | 2017-12-19 | 2017-12-19 |  | Verde | Verde | 100% | 100 | 100 | 100% | 100 | Compensatória | Verde | 100% | 100 | 100% | 100 |
| 2974 | 3.2.1.3.1.39 | Atividade Interna Renova |  | 1d | 2017-12-20 A | 2017-12-20 A | 2932SS+103ed | 100% |  | 2017-12-20 | 2017-12-20 | 1d | 2017-12-20 | 2017-12-20 |  | Verde | Verde | 100% | 100 | 100 | 100% | 100 | Compensatória | Verde | 100% | 100 | 100% | 100 |
| 2975 | 3.2.1.3.1.40 | Atividade Interna Renova | milestone | 0d | 2017-12-20 A | 2017-12-20 A | 2974, 2936, 2937, 2938, 2939, 2940, 2941, 2942, 2943, 2944, 2945, 2946, 2947, 2948, 2949, 2950, 2951, 2952, 2953, 2954, 2955, 2956, 2957, 2958, 2959, 2960, 2961, 2962, 2963, 2964, 2965, 2966, 2967, 2968, 2969, 2970, 2971, 2972, 2973 | 100% |  | 2017-12-20 | 2017-12-20 | 0d | 2017-12-20 | 2017-12-20 |  | Verde | Verde | 100% | 100 | 100 | 100% | 100 | Compensatória | Verde | 100% | 100 | 100% | 100 |

Notes:
- 2936: Reunião de partida para apresentação e alinhamento do programa. / Nesta visita foi solicitado ao município o preenchimento de uma ficha técnica com identificação dos pontos focais, detalhamento de pleitos e requerimento das atividades de apoio técnico e capacitação que o município gostaria de receber
- 2937: Reunião de partida para apresentação e alinhamento do programa. / Nesta visita foi solicitado ao município o preenchimento de uma ficha técnica com identificação dos pontos focais, detalhamento de pleitos e requerimento das atividades de apoio técnico e capacitação que o município gostaria de receber
- 2938: Reunião de partida para apresentação e alinhamento do programa. / Nesta visita foi solicitado ao município o preenchimento de uma ficha técnica com identificação dos pontos focais, detalhamento de pleitos e requerimento das atividades de apoio técnico e capacitação que o município gostaria de receber
- 2939: Reunião de partida para apresentação e alinhamento do programa. / Nesta visita foi solicitado ao município o preenchimento de uma ficha técnica com identificação dos pontos focais, detalhamento de pleitos e requerimento das atividades de apoio técnico e capacitação que o município gostaria de receber
- 2940: Reunião de partida para apresentação e alinhamento do programa. / Nesta visita foi solicitado ao município o preenchimento de uma ficha técnica com identificação dos pontos focais, detalhamento de pleitos e requerimento das atividades de apoio técnico e capacitação que o município gostaria de receber
- 2941: Reunião de partida para apresentação e alinhamento do programa. / Nesta visita foi solicitado ao município o preenchimento de uma ficha técnica com identificação dos pontos focais, detalhamento de pleitos e requerimento das atividades de apoio técnico e capacitação que o município gostaria de receber
- 2942: Reunião de partida para apresentação e alinhamento do programa. / Nesta visita foi solicitado ao município o preenchimento de uma ficha técnica com identificação dos pontos focais, detalhamento de pleitos e requerimento das atividades de apoio técnico e capacitação que o município gostaria de receber
- 2943: Reunião de partida para apresentação e alinhamento do programa. / Nesta visita foi solicitado ao município o preenchimento de uma ficha técnica com identificação dos pontos focais, detalhamento de pleitos e requerimento das atividades de apoio técnico e capacitação que o município gostaria de receber
- 2944: Reunião de partida para apresentação e alinhamento do programa. / Nesta visita foi solicitado ao município o preenchimento de uma ficha técnica com identificação dos pontos focais, detalhamento de pleitos e requerimento das atividades de apoio técnico e capacitação que o município gostaria de receber
- 2945: Reunião de partida para apresentação e alinhamento do programa. / Nesta visita foi solicitado ao município o preenchimento de uma ficha técnica com identificação dos pontos focais, detalhamento de pleitos e requerimento das atividades de apoio técnico e capacitação que o município gostaria de receber
- 2946: Reunião de partida para apresentação e alinhamento do programa. / Nesta visita foi solicitado ao município o preenchimento de uma ficha técnica com identificação dos pontos focais, detalhamento de pleitos e requerimento das atividades de apoio técnico e capacitação que o município gostaria de receber
- 2947: Reunião de partida para apresentação e alinhamento do programa. / Nesta visita foi solicitado ao município o preenchimento de uma ficha técnica com identificação dos pontos focais, detalhamento de pleitos e requerimento das atividades de apoio técnico e capacitação que o município gostaria de receber
- 2948: Reunião de partida para apresentação e alinhamento do programa. / Nesta visita foi solicitado ao município o preenchimento de uma ficha técnica com identificação dos pontos focais, detalhamento de pleitos e requerimento das atividades de apoio técnico e capacitação que o município gostaria de receber
- 2949: Reunião de partida para apresentação e alinhamento do programa. / Nesta visita foi solicitado ao município o preenchimento de uma ficha técnica com identificação dos pontos focais, detalhamento de pleitos e requerimento das atividades de apoio técnico e capacitação que o município gostaria de receber
- 2950: Reunião de partida para apresentação e alinhamento do programa. / Nesta visita foi solicitado ao município o preenchimento de uma ficha técnica com identificação dos pontos focais, detalhamento de pleitos e requerimento das atividades de apoio técnico e capacitação que o município gostaria de receber
- 2951: Reunião de partida para apresentação e alinhamento do programa. / Nesta visita foi solicitado ao município o preenchimento de uma ficha técnica com identificação dos pontos focais, detalhamento de pleitos e requerimento das atividades de apoio técnico e capacitação que o município gostaria de receber
- 2952: Reunião de partida para apresentação e alinhamento do programa. / Nesta visita foi solicitado ao município o preenchimento de uma ficha técnica com identificação dos pontos focais, detalhamento de pleitos e requerimento das atividades de apoio técnico e capacitação que o município gostaria de receber
- 2953: Reunião de partida para apresentação e alinhamento do programa. / Nesta visita foi solicitado ao município o preenchimento de uma ficha técnica com identificação dos pontos focais, detalhamento de pleitos e requerimento das atividades de apoio técnico e capacitação que o município gostaria de receber
- 2954: Reunião de partida para apresentação e alinhamento do programa. / Nesta visita foi solicitado ao município o preenchimento de uma ficha técnica com identificação dos pontos focais, detalhamento de pleitos e requerimento das atividades de apoio técnico e capacitação que o município gostaria de receber.
- 2955: Reunião de partida para apresentação e alinhamento do programa. / Nesta visita foi solicitado ao município o preenchimento de uma ficha técnica com identificação dos pontos focais, detalhamento de pleitos e requerimento das atividades de apoio técnico e capacitação que o município gostaria de receber
- 2956: Reunião de partida para apresentação e alinhamento do programa. / Nesta visita foi solicitado ao município o preenchimento de uma ficha técnica com identificação dos pontos focais, detalhamento de pleitos e requerimento das atividades de apoio técnico e capacitação que o município gostaria de receber
- 2957: Reunião de partida para apresentação e alinhamento do programa. / Nesta visita foi solicitado ao município o preenchimento de uma ficha técnica com identificação dos pontos focais, detalhamento de pleitos e requerimento das atividades de apoio técnico e capacitação que o município gostaria de receber
- 2958: Reunião de partida para apresentação e alinhamento do programa. / Nesta visita foi solicitado ao município o preenchimento de uma ficha técnica com identificação dos pontos focais, detalhamento de pleitos e requerimento das atividades de apoio técnico e capacitação que o município gostaria de receber
- 2959: Reunião de partida para apresentação e alinhamento do programa. / Nesta visita foi solicitado ao município o preenchimento de uma ficha técnica com identificação dos pontos focais, detalhamento de pleitos e requerimento das atividades de apoio técnico e capacitação que o município gostaria de receber
- 2960: Reunião de partida para apresentação e alinhamento do programa. / Nesta visita foi solicitado ao município o preenchimento de uma ficha técnica com identificação dos pontos focais, detalhamento de pleitos e requerimento das atividades de apoio técnico e capacitação que o município gostaria de receber
- 2961: Reunião de partida para apresentação e alinhamento do programa. / Nesta visita foi solicitado ao município o preenchimento de uma ficha técnica com identificação dos pontos focais, detalhamento de pleitos e requerimento das atividades de apoio técnico e capacitação que o município gostaria de receber
- 2962: Reunião de partida para apresentação e alinhamento do programa. / Nesta visita foi solicitado ao município o preenchimento de uma ficha técnica com identificação dos pontos focais, detalhamento de pleitos e requerimento das atividades de apoio técnico e capacitação que o município gostaria de receber
- 2963: Reunião de partida para apresentação e alinhamento do programa. / Nesta visita foi solicitado ao município o preenchimento de uma ficha técnica com identificação dos pontos focais, detalhamento de pleitos e requerimento das atividades de apoio técnico e capacitação que o município gostaria de receber
- 2964: Reunião de partida para apresentação e alinhamento do programa. / Nesta visita foi solicitado ao município o preenchimento de uma ficha técnica com identificação dos pontos focais, detalhamento de pleitos e requerimento das atividades de apoio técnico e capacitação que o município gostaria de receber
- 2965: Reunião de partida para apresentação e alinhamento do programa. / Nesta visita foi solicitado ao município o preenchimento de uma ficha técnica com identificação dos pontos focais, detalhamento de pleitos e requerimento das atividades de apoio técnico e capacitação que o município gostaria de receber
- 2966: Reunião de partida para apresentação e alinhamento do programa. / Nesta visita foi solicitado ao município o preenchimento de uma ficha técnica com identificação dos pontos focais, detalhamento de pleitos e requerimento das atividades de apoio técnico e capacitação que o município gostaria de receber
- 2967: Reunião de partida para apresentação e alinhamento do programa. / Nesta visita foi solicitado ao município o preenchimento de uma ficha técnica com identificação dos pontos focais, detalhamento de pleitos e requerimento das atividades de apoio técnico e capacitação que o município gostaria de receber
- 2968: Reunião de partida para apresentação e alinhamento do programa. / Nesta visita foi solicitado ao município o preenchimento de uma ficha técnica com identificação dos pontos focais, detalhamento de pleitos e requerimento das atividades de apoio técnico e capacitação que o município gostaria de receber
- 2969: Reunião de partida para apresentação e alinhamento do programa. / Nesta visita foi solicitado ao município o preenchimento de uma ficha técnica com identificação dos pontos focais, detalhamento de pleitos e requerimento das atividades de apoio técnico e capacitação que o município gostaria de receber
- 2970: Reunião de partida para apresentação e alinhamento do programa. / Nesta visita foi solicitado ao município o preenchimento de uma ficha técnica com identificação dos pontos focais, detalhamento de pleitos e requerimento das atividades de apoio técnico e capacitação que o município gostaria de receber
- 2971: Reunião de partida para apresentação e alinhamento do programa. / Nesta visita foi solicitado ao município o preenchimento de uma ficha técnica com identificação dos pontos focais, detalhamento de pleitos e requerimento das atividades de apoio técnico e capacitação que o município gostaria de receber
- 2972: Reunião de partida para apresentação e alinhamento do programa. / Nesta visita foi solicitado ao município o preenchimento de uma ficha técnica com identificação dos pontos focais, detalhamento de pleitos e requerimento das atividades de apoio técnico e capacitação que o município gostaria de receber
- 2973: Reunião de partida para apresentação e alinhamento do programa. / Nesta visita foi solicitado ao município o preenchimento de uma ficha técnica com identificação dos pontos focais, detalhamento de pleitos e requerimento das atividades de apoio técnico e capacitação que o município gostaria de receber
- 2974: Reunião de partida para apresentação e alinhamento do programa. / Nesta visita foi solicitado ao município o preenchimento de uma ficha técnica com identificação dos pontos focais, detalhamento de pleitos e requerimento das atividades de apoio técnico e capacitação que o município gostaria de receber

| ID | WBS | Task | Type | Duration | Start | Finish | Predecessors | Complete | Remaining | Baseline start | Baseline finish | Baseline duration | Baseline 1 start | Baseline 1 finish | Total slack | Free slack | Constraint | Text1 | Text2 | Text3 | Text4 | Text5 | Text6 | Text7 | Text8 | Text12 | Text14 | Text16 | Text13 | Text15 | Text17 | Text18 |
| --- | --- | --- | --- | --- | --- | --- | --- | --- | --- | --- | --- | --- | --- | --- | --- | --- | --- | --- | --- | --- | --- | --- | --- | --- | --- | --- | --- | --- | --- | --- | --- | --- |
| 2976 | 3.2.2 | **Atividade Interna Renova** |  | 124d | 2019-04-02 A | 2019-09-27 |  | 16% | 104.03d | 2019-04-02 | 2019-10-24 | 143d | 2019-04-02 | 2019-10-24 | 1015d |  |  | Verde | Verde | 28% | 16 | 28 | 43% | 43 | Compensatória | Vermelho | 7% | 3% |  |  |  |  |
| 2977 | 3.2.2.1 | Atividade Interna Renova | milestone | 0d | 2019-04-02 A | 2019-04-02 A |  | 100% |  | 2019-04-02 | 2019-04-02 | 0d | 2019-04-02 | 2019-04-02 |  |  | start no earlier than 2019-04-02 | Verde | Verde | 100% | 100 | 100 | 100% | 100 | Compensatória | Verde | 100% | 100% | Suprimentos | 100 | 100 |  |
| 2978 | 3.2.2.2 | Atividade Interna Renova |  | 62d | 2019-04-02 A | 2019-07-02 | 2977 | 31% | 43d | 2019-04-02 | 2019-07-02 | 62d | 2019-04-02 | 2019-07-02 | 1015d | 0d |  | Verde | Verde | 66% | 31 | 66 | 47% | 47 | Compensatória | Vermelho | 66% | 31% | Suprimentos | 66 | 31 | Critério FR |
| 2979 | 3.2.2.3 | Atividade Interna Renova |  | 2d | 2019-07-03 | 2019-07-04 | 2978 |  |  | 2019-07-03 | 2019-07-04 | 2d | 2019-07-03 | 2019-07-04 | 1015d | 0d |  | Verde | Verde | 0% |  |  | 0% |  | Compensatória | Verde | 0% | 0% | Suprimentos |  |  | Critério FR |
| 2980 | 3.2.2.4 | Atividade Interna Renova |  | 5d | 2019-07-05 | 2019-07-11 | 2979 |  |  | 2019-07-05 | 2019-07-11 | 5d | 2019-07-05 | 2019-07-11 | 1015d | 0d |  | Verde | Verde | 0% |  |  | 0% |  | Compensatória | Verde | 0% | 0% | Suprimentos |  |  | Critério FR |
| 2981 | 3.2.2.5 | Atividade Interna Renova |  | 2d | 2019-07-12 | 2019-07-15 | 2980 |  |  | 2019-07-12 | 2019-07-15 | 2d | 2019-07-12 | 2019-07-15 | 1015d | 0d |  | Verde | Verde | 0% |  |  | 0% |  | Compensatória | Verde | 0% | 0% | Suprimentos |  |  | Critério FR |
| 2982 | 3.2.2.6 | Atividade Interna Renova |  | 1d | 2019-07-16 | 2019-07-16 | 2981 |  |  | 2019-07-16 | 2019-07-16 | 1d | 2019-07-16 | 2019-07-16 | 1015d | 0d |  | Verde | Verde | 0% |  |  | 0% |  | Compensatória | Verde | 0% | 0% | Suprimentos |  |  | Critério FR |
| 2983 | 3.2.2.7 | Atividade Interna Renova |  | 1d | 2019-07-25 | 2019-07-25 | 2982FS+6d |  |  | 2019-08-22 | 2019-08-22 | 1d | 2019-08-22 | 2019-08-22 | 1015d | 0d |  | Verde | Verde | 0% |  |  | 0% |  | Compensatória | Verde | 0% | 0% | Suprimentos |  |  | Critério FR |
| 2984 | 3.2.2.8 | Atividade Interna Renova |  | 22d | 2019-07-26 | 2019-08-27 | 2983 |  |  | 2019-08-23 | 2019-09-23 | 22d | 2019-08-23 | 2019-09-23 | 1015d | 0d |  | Verde | Verde | 0% |  |  | 0% |  | Compensatória | Verde | 0% | 0% | Suprimentos |  |  | Critério FR |
| 2985 | 3.2.2.9 | Atividade Interna Renova |  | 23d | 2019-08-28 | 2019-09-27 | 2984 |  |  | 2019-09-24 | 2019-10-24 | 23d | 2019-09-24 | 2019-10-24 | 1015d | 0d |  | Verde | Verde | 0% |  |  | 0% |  | Compensatória | Verde | 0% | 0% | Suprimentos |  |  | Critério FR |
| 2986 | 3.2.2.10 | Atividade Interna Renova | milestone | 0d | 2019-09-27 | 2019-09-27 | 2985 |  |  | 2019-10-24 | 2019-10-24 | 0d | 2019-10-24 | 2019-10-24 | 1015d | 0d |  | Verde | Verde | 0% |  |  | 0% |  | Compensatória | Verde | 0% | 0% | Suprimentos |  |  |  |
| 2987 | 3.2.3 | **Atividade Interna Renova** |  | 347d | 2017-11-20 A | 2019-03-25 A |  | 100% |  | 2017-11-20 | 2019-03-25 | 347d | 2017-11-20 | 2019-03-25 |  |  |  | Verde | Verde | 100% | 100 | 100 | 100% | 100 | Compensatória | Verde | 100% | 100% |  | 100 | 100 |  |
| 2988 | 3.2.3.1 | Atividade Interna Renova |  | 83d | 2017-11-20 A | 2018-03-14 A | 57FS+24ed | 100% |  | 2017-11-20 | 2018-03-14 | 83d | 2017-11-20 | 2018-03-14 |  |  |  | Verde | Verde | 100% | 100 | 100 | 100% | 100 | Compensatória | Verde | 100% | 100% |  | 100 | 100 |  |
| 2989 | 3.2.3.2 | Atividade Interna Renova | milestone | 0d | 2018-03-13 A | 2018-03-13 A | 2988 | 100% |  | 2018-03-13 | 2018-03-13 | 0d | 2018-03-13 | 2018-03-13 |  |  |  | Verde | Verde | 100% | 100 | 100 | 100% | 100 | Compensatória | Verde | 100% | 100% |  | 100 | 100 |  |
| 2990 | 3.2.3.3 | **Atividade Interna Renova** |  | 266d | 2018-03-13 A | 2019-03-25 A |  | 100% |  | 2018-03-13 | 2019-03-25 | 266d | 2018-03-13 | 2019-03-25 |  |  |  | Verde | Verde | 100% | 100 | 100 | 100% | 100 | Compensatória | Verde | 100% | 100% | Suprimentos | 100 | 100 |  |
| 2991 | 3.2.3.3.1 | Atividade Interna Renova |  | 37d | 2018-03-13 A | 2018-05-02 A | 2989 | 100% |  | 2018-03-13 | 2018-05-02 | 37d | 2018-03-13 | 2018-05-02 |  |  |  | Verde | Verde | 100% | 100 | 100 | 100% | 100 | Compensatória | Verde | 100% | 100% | Suprimentos | 100 | 100 |  |
| 2992 | 3.2.3.3.2 | Atividade Interna Renova |  | 6d | 2018-05-02 A | 2018-05-09 A | 2991 | 100% |  | 2018-05-02 | 2018-05-09 | 6d | 2018-05-02 | 2018-05-09 |  |  |  | Verde | Verde | 100% | 100 | 100 | 100% | 100 | Compensatória | Verde | 100% | 100% | Suprimentos | 100 | 100 |  |
| 2993 | 3.2.3.3.3 | Atividade Interna Renova |  | 56d | 2018-05-09 A | 2018-07-26 A | 2992, 3073 | 100% |  | 2018-05-09 | 2018-07-26 | 56d | 2018-05-09 | 2018-07-26 |  |  |  | Verde | Verde | 100% | 100 | 100 | 100% | 100 | Compensatória | Verde | 100% | 100% | Suprimentos | 100 | 100 |  |
| 2994 | 3.2.3.3.4 | Atividade Interna Renova |  | 80d | 2018-07-23 A | 2018-11-14 A | 2993 | 100% |  | 2018-07-23 | 2018-11-14 | 80d | 2018-07-23 | 2018-11-14 |  |  |  | Verde | Verde | 100% | 100 | 100 | 100% | 100 | Compensatória | Verde | 100% | 100% | Suprimentos | 100 | 100 |  |
| 2995 | 3.2.3.3.5 | Atividade Interna Renova |  | 2d | 2018-11-12 A | 2018-11-13 A | 2994 | 100% |  | 2018-11-12 | 2018-11-13 | 2d | 2018-11-12 | 2018-11-13 |  |  |  | Verde | Verde | 100% | 100 | 100 | 100% | 100 | Compensatória | Verde | 100% | 100% | Suprimentos | 100 | 100 |  |
| 2996 | 3.2.3.3.6 | Atividade Interna Renova |  | 10d | 2018-11-14 A | 2018-11-29 A | 2995 | 100% |  | 2018-11-14 | 2018-11-29 | 10d | 2018-11-14 | 2018-11-29 |  |  |  | Verde | Verde | 100% | 100 | 100 | 100% | 100 | Compensatória | Verde | 100% | 100% | Suprimentos | 100 | 100 |  |
| 2997 | 3.2.3.3.7 | Atividade Interna Renova |  | 14d | 2018-11-28 A | 2018-12-17 A | 2996 | 100% |  | 2018-11-28 | 2018-12-17 | 14d | 2018-11-28 | 2018-12-17 |  |  |  | Verde | Verde | 100% | 100 | 100 | 100% | 100 | Compensatória | Verde | 100% | 100% | Suprimentos | 100 | 100 |  |
| 2998 | 3.2.3.3.8 | Atividade Interna Renova |  | 12d | 2019-01-24 A | 2019-02-08 A | 2997FS+37ed | 100% |  | 2019-01-24 | 2019-02-08 | 12d | 2019-01-24 | 2019-02-08 |  |  |  | Verde | Verde | 100% | 100 | 100 | 100% | 100 | Compensatória | Verde | 100% | 100% | Suprimentos | 100 | 100 |  |
| 2999 | 3.2.3.3.9 | Atividade Interna Renova |  | 22d | 2019-02-08 A | 2019-03-15 A | 2998 | 100% |  | 2019-02-08 | 2019-03-15 | 22d | 2019-02-08 | 2019-03-15 |  |  |  | Verde | Verde | 100% | 100 | 100 | 100% | 100 | Compensatória | Verde | 100% | 100% | Suprimentos | 100 | 100 |  |
| 3000 | 3.2.3.3.10 | Atividade Interna Renova |  | 4d | 2019-03-18 A | 2019-03-21 A | 2999 | 100% |  | 2019-03-18 | 2019-03-21 | 4d | 2019-03-18 | 2019-03-21 |  |  |  | Verde | Verde | 100% | 100 | 100 | 100% | 100 | Compensatória | Verde | 100% | 100% | Suprimentos | 100 | 100 |  |
| 3001 | 3.2.3.3.11 | Atividade Interna Renova |  | 2d | 2019-03-22 A | 2019-03-25 A | 3000 | 100% |  | 2019-03-22 | 2019-03-25 | 2d | 2019-03-22 | 2019-03-25 |  |  |  | Verde | Verde | 100% | 100 | 100 | 100% | 100 | Compensatória | Verde | 100% | 100% | Suprimentos | 100 | 100 |  |
| 3002 | 3.2.3.3.12 | Atividade Interna Renova | milestone | 0d | 2019-03-25 A | 2019-03-25 A | 3001 | 100% |  | 2019-03-25 | 2019-03-25 | 0d | 2019-03-25 | 2019-03-25 |  |  |  | Verde | Verde | 100% | 100 | 100 | 100% | 100 | Compensatória | Verde | 100% | 100% | Suprimentos | 100 | 100 |  |

Notes:
- 2998: - Foi solicitado esclarecimento pelo Comitê Interno de Programas socioambientais. O email com esclarecimento foi enviado dia 08/01/2019. / O Programa está aguardando a resposta do Comitê após o dia 24/01/2019.

| ID | WBS | Task | Type | Duration | Start | Finish | Predecessors | Complete | Baseline start | Baseline finish | Baseline duration | Baseline 1 start | Baseline 1 finish | Text1 | Text2 | Text3 | Text4 | Text5 | Text6 | Text7 | Text8 | Text12 | Text13 | Text14 | Text15 | Text16 | Text17 |
| --- | --- | --- | --- | --- | --- | --- | --- | --- | --- | --- | --- | --- | --- | --- | --- | --- | --- | --- | --- | --- | --- | --- | --- | --- | --- | --- | --- |
| 3003 | 3.2.4 | **Atividade Interna Renova** |  | 213d | 2018-06-28 A | 2019-04-30 A |  | 100% | 2018-06-28 | 2019-04-30 | 213d | 2018-06-28 | 2019-04-30 | Verde | Verde | 100% | 100 | 100 | 100% | 100 | Compensatória | Verde | Suprimentos | 100% | 100 | 100% | 100 |
| 3004 | 3.2.4.1 | Atividade Interna Renova |  | 144d | 2018-07-01 A | 2019-02-08 A | 2991FS+60ed | 100% | 2018-07-01 | 2019-02-08 | 144d | 2018-07-01 | 2019-02-08 | Verde | Verde | 100% | 100 | 100 | 100% | 100 | Compensatória | Verde | Suprimentos | 100% | 100 | 100% | 100 |
| 3005 | 3.2.4.2 | Atividade Interna Renova | milestone | 0d | 2018-06-28 A | 2018-06-28 A | 3006SS | 100% | 2018-06-28 | 2018-06-28 | 0d |  |  | Verde | Verde | 100% | 100 | 100 | 100% | 100 | Compensatória | Verde |  | 100% | 100 | 100% | 100 |
| 3006 | 3.2.4.3 | Atividade Interna Renova |  | 198d | 2018-06-28 A | 2019-04-30 A | 3004SS+3ed | 100% | 2018-06-28 | 2019-04-30 | 198d | 2018-06-28 | 2019-04-30 | Verde | Verde | 100% | 100 | 100 | 100% | 100 | Compensatória | Verde | Suprimentos | 100% | 100 | 100% | 100 |
| 3007 | 3.2.4.4 | Atividade Interna Renova | milestone | 0d | 2019-04-30 A | 2019-04-30 A | 3006, 3005 | 100% | 2019-04-30 | 2019-04-30 | 0d | 2019-04-30 | 2019-04-30 | Verde | Verde | 100% | 100 | 100 | 100% | 100 | Compensatória | Verde | Suprimentos | 100% | 100 | 100% | 100 |
| 3008 | 3.2.5 | **Atividade Interna Renova** |  | 203d | 2018-03-05 A | 2018-12-12 A |  | 100% | 2018-03-05 | 2018-12-12 | 203d | 2018-03-05 | 2025-02-25 | Verde | Verde | 100% | 100 | 100 | 100% | 100 | Compensatória | Verde |  | 100% | 100 | 100% | 100 |
| 3009 | 3.2.5.1 | Atividade Interna Renova |  | 23d | 2018-03-05 A | 2018-04-04 A | 2933FS+80ed, 2975 | 100% | 2018-03-05 | 2018-04-04 | 23d | 2018-03-05 | 2018-04-04 | Verde | Verde | 100% | 100 | 100 | 100% | 100 | Compensatória | Verde | Suprimentos | 100% | 100 | 100% | 100 |
| 3010 | 3.2.5.2 | Atividade Interna Renova |  | 15d | 2018-04-04 A | 2018-04-24 A | 3009 | 100% | 2018-04-04 | 2018-04-24 | 15d | 2018-04-04 | 2018-04-24 | Verde | Verde | 100% | 100 | 100 | 100% | 100 | Compensatória | Verde | Suprimentos | 100% | 100 | 100% | 100 |
| 3011 | 3.2.5.3 | Atividade Interna Renova |  | 1d | 2018-05-15 A | 2018-05-16 A | 3010FS+16d | 100% | 2018-05-15 | 2018-05-16 | 1d | 2018-05-15 | 2018-05-16 | Verde | Verde | 100% | 100 | 100 | 100% | 100 | Compensatória | Verde | Suprimentos | 100% | 100 | 100% | 100 |
| 3012 | 3.2.5.4 | **Atividade Interna Renova** |  | 124d | 2018-06-22 A | 2018-12-12 A |  | 100% | 2018-06-22 | 2018-12-12 | 124d | 2018-06-22 | 2018-12-12 | Verde | Verde | 100% | 100 | 100 | 100% | 100 | Compensatória | Verde |  | 100% | 100 | 100% | 100 |
| 3013 | 3.2.5.4.1 | Atividade Interna Renova |  | 1d | 2018-08-15 A | 2018-08-15 A | 3011FS+90ed | 100% | 2018-08-15 | 2018-08-15 | 1d | 2018-08-15 | 2018-08-15 | Verde | Verde | 100% | 100 | 100 | 100% | 100 | Compensatória | Verde |  | 100% | 100 | 100% | 100 |
| 3014 | 3.2.5.4.2 | Atividade Interna Renova |  | 1d | 2018-07-09 A | 2018-07-10 A | 3011FS+52ed | 100% | 2018-07-09 | 2018-07-10 | 1d | 2018-07-09 | 2018-07-10 | Verde | Verde | 100% | 100 | 100 | 100% | 100 | Compensatória | Verde |  | 100% | 100 | 100% | 100 |
| 3015 | 3.2.5.4.3 | Atividade Interna Renova |  | 1d | 2018-08-10 A | 2018-08-10 A | 3011FS+85ed | 100% | 2018-08-10 | 2018-08-10 | 1d | 2018-08-10 | 2018-08-10 | Verde | Verde | 100% | 100 | 100 | 100% | 100 | Compensatória | Verde |  | 100% | 100 | 100% | 100 |
| 3016 | 3.2.5.4.4 | Atividade Interna Renova |  | 1d | 2018-08-09 A | 2018-08-09 A | 3011FS+84ed | 100% | 2018-08-09 | 2018-08-09 | 1d | 2018-08-09 | 2018-08-09 | Verde | Verde | 100% | 100 | 100 | 100% | 100 | Compensatória | Verde |  | 100% | 100 | 100% | 100 |
| 3017 | 3.2.5.4.5 | Atividade Interna Renova |  | 1d | 2018-08-10 A | 2018-08-10 A | 3011FS+85ed | 100% | 2018-08-10 | 2018-08-10 | 1d | 2018-08-10 | 2018-08-10 | Verde | Verde | 100% | 100 | 100 | 100% | 100 | Compensatória | Verde |  | 100% | 100 | 100% | 100 |
| 3018 | 3.2.5.4.6 | Atividade Interna Renova |  | 1d | 2018-07-18 A | 2018-07-18 A | 3011FS+62ed | 100% | 2018-07-18 | 2018-07-18 | 1d | 2018-07-18 | 2018-07-18 | Verde | Verde | 100% | 100 | 100 | 100% | 100 | Compensatória | Verde |  | 100% | 100 | 100% | 100 |
| 3019 | 3.2.5.4.7 | Atividade Interna Renova |  | 1d | 2018-08-13 A | 2018-08-13 A | 3011FS+88ed | 100% | 2018-08-13 | 2018-08-13 | 1d | 2018-08-13 | 2018-08-13 | Verde | Verde | 100% | 100 | 100 | 100% | 100 | Compensatória | Verde |  | 100% | 100 | 100% | 100 |
| 3020 | 3.2.5.4.8 | Atividade Interna Renova |  | 1d | 2018-07-18 A | 2018-07-18 A | 3011FS+62ed | 100% | 2018-07-18 | 2018-07-18 | 1d | 2018-07-18 | 2018-07-18 | Verde | Verde | 100% | 100 | 100 | 100% | 100 | Compensatória | Verde |  | 100% | 100 | 100% | 100 |
| 3021 | 3.2.5.4.9 | Atividade Interna Renova |  | 1d | 2018-12-12 A | 2018-12-12 A | 3011FS+209ed | 100% | 2018-12-12 | 2018-12-12 | 1d | 2018-12-12 | 2018-12-12 | Verde | Verde | 100% | 100 | 100 | 100% | 100 | Compensatória | Verde |  | 100% | 100 | 100% | 100 |
| 3022 | 3.2.5.4.10 | Atividade Interna Renova |  | 1d | 2018-08-16 A | 2018-08-16 A | 3011FS+91ed | 100% | 2018-08-16 | 2018-08-16 | 1d | 2018-08-16 | 2018-08-16 | Verde | Verde | 100% | 100 | 100 | 100% | 100 | Compensatória | Verde |  | 100% | 100 | 100% | 100 |
| 3023 | 3.2.5.4.11 | Atividade Interna Renova |  | 1d | 2018-07-19 A | 2018-07-19 A | 3011FS+63ed | 100% | 2018-07-19 | 2018-07-19 | 1d | 2018-07-19 | 2018-07-19 | Verde | Verde | 100% | 100 | 100 | 100% | 100 | Compensatória | Verde |  | 100% | 100 | 100% | 100 |
| 3024 | 3.2.5.4.12 | Atividade Interna Renova |  | 1d | 2018-09-13 A | 2018-09-13 A | 3011FS+119ed | 100% | 2018-09-13 | 2018-09-13 | 1d | 2018-09-13 | 2018-09-13 | Verde | Verde | 100% | 100 | 100 | 100% | 100 | Compensatória | Verde |  | 100% | 100 | 100% | 100 |
| 3025 | 3.2.5.4.13 | Atividade Interna Renova |  | 1d | 2018-07-18 A | 2018-07-18 A | 3011FS+62ed | 100% | 2018-07-18 | 2018-07-18 | 1d | 2018-07-18 | 2018-07-18 | Verde | Verde | 100% | 100 | 100 | 100% | 100 | Compensatória | Verde |  | 100% | 100 | 100% | 100 |
| 3026 | 3.2.5.4.14 | Atividade Interna Renova |  | 1d | 2018-06-27 A | 2018-06-27 A | 3011FS+41ed | 100% | 2018-06-27 | 2018-06-27 | 1d | 2018-06-27 | 2018-06-27 | Verde | Verde | 100% | 100 | 100 | 100% | 100 | Compensatória | Verde |  | 100% | 100 | 100% | 100 |
| 3027 | 3.2.5.4.15 | Atividade Interna Renova |  | 1d | 2018-08-31 A | 2018-08-31 A | 3011FS+106ed | 100% | 2018-08-31 | 2018-08-31 | 1d | 2018-08-31 | 2018-08-31 | Verde | Verde | 100% | 100 | 100 | 100% | 100 | Compensatória | Verde |  | 100% | 100 | 100% | 100 |
| 3028 | 3.2.5.4.16 | Atividade Interna Renova |  | 1d | 2018-07-12 A | 2018-07-12 A | 3011FS+56ed | 100% | 2018-07-12 | 2018-07-12 | 1d | 2018-07-12 | 2018-07-12 | Verde | Verde | 100% | 100 | 100 | 100% | 100 | Compensatória | Verde |  | 100% | 100 | 100% | 100 |
| 3029 | 3.2.5.4.17 | Atividade Interna Renova |  | 1d | 2018-07-19 A | 2018-07-19 A | 3011FS+63ed | 100% | 2018-07-19 | 2018-07-19 | 1d | 2018-07-19 | 2018-07-19 | Verde | Verde | 100% | 100 | 100 | 100% | 100 | Compensatória | Verde |  | 100% | 100 | 100% | 100 |
| 3030 | 3.2.5.4.18 | Atividade Interna Renova |  | 1d | 2018-07-19 A | 2018-07-19 A | 3011FS+63ed | 100% | 2018-07-19 | 2018-07-19 | 1d | 2018-07-19 | 2018-07-19 | Verde | Verde | 100% | 100 | 100 | 100% | 100 | Compensatória | Verde |  | 100% | 100 | 100% | 100 |
| 3031 | 3.2.5.4.19 | Atividade Interna Renova |  | 1d | 2018-10-03 A | 2018-10-03 A | 3011FS+139ed | 100% | 2018-10-03 | 2018-10-03 | 1d | 2018-10-03 | 2018-10-03 | Verde | Verde | 100% | 100 | 100 | 100% | 100 | Compensatória | Verde |  | 100% | 100 | 100% | 100 |
| 3032 | 3.2.5.4.20 | Atividade Interna Renova |  | 1d | 2018-10-10 A | 2018-10-10 A | 3011FS+146ed | 100% | 2018-10-10 | 2018-10-10 | 1d | 2018-10-10 | 2018-10-10 | Verde | Verde | 100% | 100 | 100 | 100% | 100 | Compensatória | Verde |  | 100% | 100 | 100% | 100 |
| 3033 | 3.2.5.4.21 | Atividade Interna Renova |  | 1d | 2018-08-31 A | 2018-08-31 A | 3011FS+106ed | 100% | 2018-08-31 | 2018-08-31 | 1d | 2018-08-31 | 2018-08-31 | Verde | Verde | 100% | 100 | 100 | 100% | 100 | Compensatória | Verde |  | 100% | 100 | 100% | 100 |
| 3034 | 3.2.5.4.22 | Atividade Interna Renova |  | 1d | 2018-07-12 A | 2018-07-12 A | 3011FS+56ed | 100% | 2018-07-12 | 2018-07-12 | 1d | 2018-07-12 | 2018-07-12 | Verde | Verde | 100% | 100 | 100 | 100% | 100 | Compensatória | Verde |  | 100% | 100 | 100% | 100 |
| 3035 | 3.2.5.4.23 | Atividade Interna Renova |  | 1d | 2018-06-22 A | 2018-06-22 A | 3011FS+36ed | 100% | 2018-06-22 | 2018-06-22 | 1d | 2018-06-22 | 2018-06-22 | Verde | Verde | 100% | 100 | 100 | 100% | 100 | Compensatória | Verde |  | 100% | 100 | 100% | 100 |
| 3036 | 3.2.5.4.24 | Atividade Interna Renova |  | 1d | 2018-06-25 A | 2018-06-25 A | 3011FS+39ed | 100% | 2018-06-25 | 2018-06-25 | 1d | 2018-06-25 | 2018-06-25 | Verde | Verde | 100% | 100 | 100 | 100% | 100 | Compensatória | Verde |  | 100% | 100 | 100% | 100 |
| 3037 | 3.2.5.4.25 | Atividade Interna Renova |  | 1d | 2018-07-18 A | 2018-07-18 A | 3011FS+62ed | 100% | 2018-07-18 | 2018-07-18 | 1d | 2018-07-18 | 2018-07-18 | Verde | Verde | 100% | 100 | 100 | 100% | 100 | Compensatória | Verde |  | 100% | 100 | 100% | 100 |
| 3038 | 3.2.5.4.26 | Atividade Interna Renova |  | 1d | 2018-07-19 A | 2018-07-19 A | 3011FS+63ed | 100% | 2018-07-19 | 2018-07-19 | 1d | 2018-07-19 | 2018-07-19 | Verde | Verde | 100% | 100 | 100 | 100% | 100 | Compensatória | Verde |  | 100% | 100 | 100% | 100 |
| 3039 | 3.2.5.4.27 | Atividade Interna Renova |  | 1d | 2018-07-18 A | 2018-07-18 A | 3011FS+62ed | 100% | 2018-07-18 | 2018-07-18 | 1d | 2018-07-18 | 2018-07-18 | Verde | Verde | 100% | 100 | 100 | 100% | 100 | Compensatória | Verde |  | 100% | 100 | 100% | 100 |
| 3040 | 3.2.5.4.28 | Atividade Interna Renova |  | 1d | 2018-06-25 A | 2018-06-25 A | 3011FS+39ed | 100% | 2018-06-25 | 2018-06-25 | 1d | 2018-06-25 | 2018-06-25 | Verde | Verde | 100% | 100 | 100 | 100% | 100 | Compensatória | Verde |  | 100% | 100 | 100% | 100 |
| 3041 | 3.2.5.4.29 | Atividade Interna Renova |  | 1d | 2018-07-12 A | 2018-07-12 A | 3011FS+56ed | 100% | 2018-07-12 | 2018-07-12 | 1d | 2018-07-12 | 2018-07-12 | Verde | Verde | 100% | 100 | 100 | 100% | 100 | Compensatória | Verde |  | 100% | 100 | 100% | 100 |
| 3042 | 3.2.5.4.30 | Atividade Interna Renova |  | 1d | 2018-07-18 A | 2018-07-18 A | 3011FS+62ed | 100% | 2018-07-18 | 2018-07-18 | 1d | 2018-07-18 | 2018-07-18 | Verde | Verde | 100% | 100 | 100 | 100% | 100 | Compensatória | Verde |  | 100% | 100 | 100% | 100 |
| 3043 | 3.2.5.4.31 | Atividade Interna Renova |  | 1d | 2018-08-31 A | 2018-08-31 A | 3011FS+106ed | 100% | 2018-08-31 | 2018-08-31 | 1d | 2018-08-31 | 2018-08-31 | Verde | Verde | 100% | 100 | 100 | 100% | 100 | Compensatória | Verde |  | 100% | 100 | 100% | 100 |
| 3044 | 3.2.5.4.32 | Atividade Interna Renova |  | 1d | 2018-07-03 A | 2018-07-03 A | 3011FS+47ed | 100% | 2018-07-03 | 2018-07-03 | 1d | 2018-07-03 | 2018-07-03 | Verde | Verde | 100% | 100 | 100 | 100% | 100 | Compensatória | Verde |  | 100% | 100 | 100% | 100 |
| 3045 | 3.2.5.4.33 | Atividade Interna Renova |  | 1d | 2018-07-17 A | 2018-07-17 A | 3011FS+61ed | 100% | 2018-07-17 | 2018-07-17 | 1d | 2018-07-17 | 2018-07-17 | Verde | Verde | 100% | 100 | 100 | 100% | 100 | Compensatória | Verde |  | 100% | 100 | 100% | 100 |
| 3046 | 3.2.5.4.34 | Atividade Interna Renova |  | 1d | 2018-08-10 A | 2018-08-10 A | 3011FS+85ed | 100% | 2018-08-10 | 2018-08-10 | 1d | 2018-08-10 | 2018-08-10 | Verde | Verde | 100% | 100 | 100 | 100% | 100 | Compensatória | Verde |  | 100% | 100 | 100% | 100 |
| 3047 | 3.2.5.4.35 | Atividade Interna Renova |  | 1d | 2018-08-10 A | 2018-08-10 A | 3011FS+85ed | 100% | 2018-08-10 | 2018-08-10 | 1d | 2018-08-10 | 2018-08-10 | Verde | Verde | 100% | 100 | 100 | 100% | 100 | Compensatória | Verde |  | 100% | 100 | 100% | 100 |
| 3048 | 3.2.5.4.36 | Atividade Interna Renova |  | 1d | 2018-08-16 A | 2018-08-16 A | 3011FS+91ed | 100% | 2018-08-16 | 2018-08-16 | 1d | 2018-08-16 | 2018-08-16 | Verde | Verde | 100% | 100 | 100 | 100% | 100 | Compensatória | Verde |  | 100% | 100 | 100% | 100 |
| 3049 | 3.2.5.4.37 | Atividade Interna Renova |  | 1d | 2018-07-18 A | 2018-07-18 A | 3011FS+62ed | 100% | 2018-07-18 | 2018-07-18 | 1d | 2018-07-18 | 2018-07-18 | Verde | Verde | 100% | 100 | 100 | 100% | 100 | Compensatória | Verde |  | 100% | 100 | 100% | 100 |
| 3050 | 3.2.5.4.38 | Atividade Interna Renova |  | 1d | 2018-08-16 A | 2018-08-16 A | 3011FS+91ed | 100% | 2018-08-16 | 2018-08-16 | 1d | 2018-08-16 | 2018-08-16 | Verde | Verde | 100% | 100 | 100 | 100% | 100 | Compensatória | Verde |  | 100% | 100 | 100% | 100 |
| 3051 | 3.2.5.4.39 | Atividade Interna Renova |  | 1d | 2018-07-18 A | 2018-07-18 A | 3011FS+62ed | 100% | 2018-07-18 | 2018-07-18 | 1d | 2018-07-18 | 2018-07-18 | Verde | Verde | 100% | 100 | 100 | 100% | 100 | Compensatória | Verde |  | 100% | 100 | 100% | 100 |
| 3052 | 3.2.5.4.40 | Atividade Interna Renova | milestone | 0d | 2018-12-12 A | 2018-12-12 A | 3021, 3036, 3051, 3022, 3039, 3023, 3035, 3037, 3041, 3047, 3048, 3017, 3029, 3028, 3020, 3015, 3050, 3044, 3031, 3040, 3013, 3025, 3049, 3019, 3030, 3032, 3046, 3045, 3014, 3033, 3043, 3042, 3026, 3027, 3038, 3024, 3018, 3016, 3034 | 100% | 2018-12-12 | 2018-12-12 | 0d | 2018-12-12 | 2018-12-12 | Verde | Verde | 100% | 100 | 100 | 100% | 100 | Compensatória | Verde |  | 100% | 100 | 100% | 100 |

Notes:
- 3008: 16/05/2019: as ações de apoio técnico serão acompanhadas via indicadores mensalmente conforme base de premissas

| ID | WBS | Task | Type | Duration | Start | Finish | Predecessors | Complete | Remaining | Baseline start | Baseline finish | Baseline duration | Baseline 1 start | Baseline 1 finish | Total slack | Free slack | Constraint | Text1 | Text2 | Text3 | Text6 | Text8 | Text12 | Text14 | Text16 | Text4 | Text5 | Text7 | Text15 | Text17 | Text13 | Text18 |
| --- | --- | --- | --- | --- | --- | --- | --- | --- | --- | --- | --- | --- | --- | --- | --- | --- | --- | --- | --- | --- | --- | --- | --- | --- | --- | --- | --- | --- | --- | --- | --- | --- |
| 3053 | 3.2.6 | **Atividade Interna Renova** |  | 27d | 2019-06-25 A | 2019-07-31 |  | 25% | 20.25d | 2019-06-25 | 2019-07-31 | 27d |  |  | 1079d |  |  |  |  |  |  |  |  |  |  |  |  |  |  |  |  |  |
| 3054 | 3.2.6.1 | Atividade Interna Renova |  | 27d | 2019-06-25 A | 2019-07-31 | 3002FS+61d | 25% | 20.25d | 2019-06-25 | 2019-07-31 | 27d |  |  | 1079d | 0d |  |  |  |  |  |  |  |  |  |  |  |  |  |  |  |  |
| 3055 | 3.2.6.2 | Atividade Interna Renova | milestone | 0d | 2019-07-31 | 2019-07-31 | 3054 |  |  | 2019-07-31 | 2019-07-31 | 0d |  |  | 1079d | 0d |  |  |  |  |  |  |  |  |  |  |  |  |  |  |  |  |
| 3056 | 3.2.7 | **Atividade Interna Renova** |  | 27d | 2019-06-25 A | 2019-07-31 |  | 25% | 20.25d | 2019-06-25 | 2019-07-31 | 27d |  |  | 1079d |  |  |  |  |  |  |  |  |  |  |  |  |  |  |  |  |  |
| 3057 | 3.2.7.1 | Atividade Interna Renova |  | 27d | 2019-06-25 A | 2019-07-31 |  | 25% | 20.25d | 2019-06-25 | 2019-07-31 | 27d |  |  | 1079d | 0d | start no earlier than 2019-06-25 |  |  |  |  |  |  |  |  |  |  |  |  |  |  |  |
| 3058 | 3.2.7.2 | Atividade Interna Renova | milestone | 0d | 2019-07-31 | 2019-07-31 | 3057 |  |  | 2019-07-31 | 2019-07-31 | 0d |  |  | 1079d | 0d |  |  |  |  |  |  |  |  |  |  |  |  |  |  |  |  |
| 3059 | 3.2.8 | Atividade Interna Renova | milestone | 0d | 2019-09-27 | 2019-09-27 | 2986, 3002, 3007, 3052 |  |  | 2019-10-24 | 2019-10-24 | 0d | 2025-02-25 | 2025-02-25 | 1015d |  |  | Verde | Verde | 0% | 0% | Compensatória | Verde | 0% | 0% |  |  |  |  |  |  |  |
| 3060 | 3.3 | **Atividade Interna Renova** |  | 576d | 2017-11-10 A | 2020-02-13 |  | 88% | 69.94d | 2017-11-10 | 2020-01-30 | 566d | 2017-11-10 | 2020-02-10 | 921d |  |  | Verde | Verde | 70% | 100% | Compensatória | Verde | 49% | 49% | 89 | 70 | 100 | 49 | 49 |  |  |
| 3061 | 3.3.1 | **Atividade Interna Renova** |  | 424d | 2017-11-10 A | 2019-07-08 |  | 94% | 26.91d | 2017-11-10 | 2019-06-24 | 414d | 2017-11-10 | 2019-07-03 | 921d |  |  | Verde | Verde | 96% | 99% | Compensatória | Vermelho | 94% | 93% | 96 | 96 | 99 | 94 | 93 |  |  |
| 3062 | 3.3.1.1 | Atividade Interna Renova |  | 54d | 2017-11-10 A | 2018-01-24 A | 57FS+14ed | 100% |  | 2017-11-10 | 2018-01-24 | 54d | 2017-11-10 | 2018-01-24 |  |  |  | Verde | Verde | 100% | 100% | Compensatória | Verde | 100% | 100% | 100 | 100 | 100 | 100 | 100 |  |  |
| 3063 | 3.3.1.2 | **Atividade Interna Renova** |  | 371d | 2018-01-24 A | 2019-07-08 |  | 93% | 27.38d | 2018-01-24 | 2019-06-24 | 361d | 2018-01-24 | 2019-07-03 | 921d |  |  | Verde | Verde | 95% | 100% | Compensatória | Verde | 92% | 92% | 95 | 95 | 100 | 92 | 92 |  |  |
| 3064 | 3.3.1.2.1 | Atividade Interna Renova |  | 93d | 2018-01-24 A | 2018-06-01 A | 3062 | 100% |  | 2018-01-24 | 2018-06-01 | 93d | 2018-01-24 | 2018-06-01 |  |  |  | Verde | Verde | 100% | 1% | Compensatória | Vermelho | 10000% | 100% | 100 | 100 |  | 10000 | 100 | Suprimentos |  |
| 3065 | 3.3.1.2.2 | Atividade Interna Renova |  | 5d | 2018-06-03 A | 2018-06-08 A | 3064 | 100% |  | 2018-06-03 | 2018-06-08 | 5d | 2018-06-03 | 2018-06-08 |  |  |  | Verde | Verde | 100% | 1% | Compensatória | Vermelho | 10000% | 100% | 100 | 100 |  | 10000 | 100 | Suprimentos |  |
| 3066 | 3.3.1.2.3 | Atividade Interna Renova |  | 1d | 2018-06-07 A | 2018-06-07 A | 3065 | 100% |  | 2018-06-07 | 2018-06-07 | 1d | 2018-06-07 | 2018-06-07 |  |  |  | Verde | Verde | 100% | 1% | Compensatória | Vermelho | 10000% | 100% | 100 | 100 |  | 10000 | 100 | Suprimentos |  |
| 3067 | 3.3.1.2.4 | Atividade Interna Renova |  | 34d | 2018-06-11 A | 2018-07-30 A | 3065FS+2d | 100% |  | 2018-06-11 | 2018-07-30 | 34d | 2018-06-11 | 2018-07-30 |  |  |  | Verde | Verde | 100% | 1% | Compensatória | Vermelho | 10000% | 100% | 100 | 100 |  | 10000 | 100 | Suprimentos |  |
| 3068 | 3.3.1.2.5 | Atividade Interna Renova |  | 5d | 2018-06-18 A | 2018-06-22 A | 3066, 3067SS+5ed | 100% |  | 2018-06-18 | 2018-06-22 | 5d | 2018-06-18 | 2018-06-22 |  |  |  | Verde | Verde | 100% | 1% | Compensatória | Vermelho | 10000% | 100% | 100 | 100 |  | 10000 | 100 | Suprimentos |  |
| 3069 | 3.3.1.2.6 | Atividade Interna Renova |  | 5d | 2018-06-22 A | 2018-06-29 A | 3068 | 100% |  | 2018-06-22 | 2018-06-29 | 5d | 2018-06-22 | 2018-06-29 |  |  |  | Verde | Verde | 100% | 1% | Compensatória | Vermelho | 10000% | 100% | 100 | 100 |  | 10000 | 100 | Suprimentos |  |
| 3070 | 3.3.1.2.7 | Atividade Interna Renova |  | 5d | 2018-07-30 A | 2018-08-03 A | 3067 | 100% |  | 2018-07-30 | 2018-08-03 | 5d | 2018-07-30 | 2018-08-03 |  |  |  | Verde | Verde | 100% | 1% | Compensatória | Vermelho | 10000% | 100% | 100 | 100 |  | 10000 | 100 | Suprimentos |  |
| 3071 | 3.3.1.2.8 | Atividade Interna Renova |  | 11d | 2018-07-02 A | 2018-07-18 A | 3069FS+1d | 100% |  | 2018-07-02 | 2018-07-18 | 11d | 2018-07-02 | 2018-07-18 |  |  |  | Verde | Verde | 100% | 1% | Compensatória | Vermelho | 10000% | 100% | 100 | 100 |  | 10000 | 100 | Suprimentos |  |
| 3072 | 3.3.1.2.9 | Atividade Interna Renova |  | 19d | 2018-08-02 A | 2018-08-28 A | 3070, 3071 | 100% |  | 2018-08-02 | 2018-08-28 | 19d | 2018-08-02 | 2018-08-28 |  |  | finish no earlier than 2018-08-28 | Verde | Verde | 100% | 1% | Compensatória | Vermelho | 10000% | 100% | 100 | 100 |  | 10000 | 100 | Suprimentos |  |
| 3073 | 3.3.1.2.10 | Atividade Interna Renova |  | 1d | 2018-09-12 A | 2018-09-12 A | 3072FS+14ed | 100% |  | 2018-09-12 | 2018-09-12 | 1d | 2018-09-12 | 2018-09-12 |  |  |  | Verde | Verde | 100% | 1% | Compensatória | Vermelho | 10000% | 100% | 100 | 100 |  | 10000 | 100 | Suprimentos |  |
| 3074 | 3.3.1.2.11 | Atividade Interna Renova | milestone | 0d | 2018-10-01 A | 2018-10-01 A | 3073FS+13d | 100% |  | 2018-10-01 | 2018-10-01 | 0d | 2018-10-01 | 2018-10-01 |  |  |  | Verde | Verde | 100% | 100% | Compensatória | Verde | 100% | 100% | 100 | 100 | 100 | 100 | 100 | Suprimentos |  |
| 3075 | 3.3.1.2.12 | **Atividade Interna Renova** |  | 205d | 2018-09-12 A | 2019-07-08 |  | 84% | 32.83d | 2018-09-12 | 2019-06-24 | 195d | 2018-09-12 | 2019-07-03 | 921d |  |  | Verde | Verde | 92% | 100% | Compensatória | Verde | 92% | 92% | 89 | 92 | 100 | 92 | 92 | Suprimentos |  |
| 3076 | 3.3.1.2.12.1 | Atividade Interna Renova |  | 36d | 2018-09-12 A | 2018-11-02 A | 3073 | 100% |  | 2018-09-12 | 2018-11-02 | 36d | 2018-09-12 | 2018-11-02 |  |  |  | Verde | Verde | 100% | 100% | Compensatória | Verde | 100% | 100% | 100 | 100 | 100 | 100 | 100 | Suprimentos |  |
| 3077 | 3.3.1.2.12.2 | Atividade Interna Renova |  | 49d | 2018-11-05 A | 2019-01-29 A | 3076 | 100% |  | 2018-11-05 | 2019-01-29 | 49d | 2018-11-05 | 2019-01-29 |  |  |  | Verde | Verde | 100% | 100% | Compensatória | Verde | 100% | 100% | 100 | 100 | 100 | 100 | 100 | Suprimentos |  |
| 3078 | 3.3.1.2.12.3 | Atividade Interna Renova |  | 4d | 2019-01-29 A | 2019-02-04 A | 3077 | 100% |  | 2019-01-29 | 2019-02-04 | 4d | 2019-01-29 | 2019-02-04 |  |  |  | Verde | Verde | 100% | 100% | Compensatória | Verde | 100% | 100% | 100 | 100 | 100 | 100 | 100 | Suprimentos |  |
| 3079 | 3.3.1.2.12.4 | Atividade Interna Renova |  | 30d | 2019-03-28 A | 2019-05-13 A | 3078FS+34d | 100% |  | 2019-03-28 | 2019-05-13 | 30d | 2019-03-28 | 2019-05-17 |  |  |  | Verde | Verde | 100% | 100% | Compensatória | Verde | 100% | 100% | 100 | 100 | 100 | 100 | 100 | Suprimentos |  |
| 3080 | 3.3.1.2.12.5 | Atividade Interna Renova |  | 1d | 2019-05-13 A | 2019-05-13 A | 3079FF | 100% |  | 2019-05-13 | 2019-05-13 | 1d |  |  |  |  |  | Verde | Verde | 100% | 100% | Compensatória | Verde | 100% | 100% | 100 | 100 | 100 | 100 | 100 |  |  |
| 3081 | 3.3.1.2.12.6 | Atividade Interna Renova |  | 1d | 2019-05-13 A | 2019-05-13 A | 3080FF | 100% |  | 2019-05-13 | 2019-05-13 | 1d | 2019-05-27 | 2019-05-27 |  |  |  | Verde | Verde | 100% | 100% | Compensatória | Verde | 100% | 100% | 100 | 100 | 100 | 100 | 100 | Suprimentos |  |
| 3082 | 3.3.1.2.12.7 | Atividade Interna Renova |  | 1d | 2019-05-23 A | 2019-05-23 A | 3081FS+7d | 100% |  | 2019-05-23 | 2019-05-23 | 1d | 2019-06-18 | 2019-06-18 |  |  |  | Verde | Verde | 100% | 100% | Compensatória | Verde | 100% | 100% | 100 | 100 | 100 | 100 | 100 | Suprimentos |  |
| 3083 | 3.3.1.2.12.8 | Atividade Interna Renova |  | 26d | 2019-05-24 A | 2019-07-01 | 3082 | 25% | 19.5d | 2019-05-24 | 2019-06-24 | 21d | 2019-06-19 | 2019-07-03 | 921d | 0d |  | Verde | Verde | 28% | 86% | Compensatória | Vermelho | 28% | 24% | 25 | 28 | 86 | 28 | 24 | Suprimentos | Critério FR |
| 3084 | 3.3.1.2.12.9 | Atividade Interna Renova |  | 5d | 2019-07-02 | 2019-07-08 | 3083 |  |  | 2019-07-02 | 2019-07-08 | 5d |  |  | 921d | 0d |  |  |  |  |  |  |  |  |  |  |  |  |  |  |  |  |
| 3085 | 3.3.1.2.12.10 | Atividade Interna Renova | milestone | 0d | 2019-07-08 | 2019-07-08 | 3084 |  |  | 2019-06-24 | 2019-06-24 | 0d | 2019-07-03 | 2019-07-03 | 921d | 0d |  | Verde | Verde | 0% | 0% | Compensatória | Verde | 0% | 0% |  |  |  |  |  | Suprimentos |  |

Notes:
- 3072: A reunião do conselho para aprovação de APRO que estava agendada para o dia 17/07,foi adiada para o dia 01/08. / Com este adiamento as atividades subsequentes à esta aprovação ficaram todas atrasadas.
- 3079: Em 25/04/2019: houve atraso em suprimentos e foi considerado mais uma semana para a entrega da análise da APRO. Considerado 20% de conclusão por estar na primeira parte de analises. / 23/05/2019: considerado que a APRO foi analisada por todas as áreas dia 13/05/2019 (fonte: Bruna Buldrini)
- 3082: 23/05/2019: APRO foi aprovada dia 23/05/2019 (fonte: Bruna Buldrini)

| ID | WBS | Task | Type | Duration | Start | Finish | Predecessors | Complete | Baseline start | Baseline finish | Baseline duration | Baseline 1 start | Baseline 1 finish | Total slack | Free slack | Constraint | Text1 | Text2 | Text3 | Text6 | Text8 | Text12 | Text14 | Text16 | Text18 | Text4 | Text5 | Text7 | Text15 | Text17 | Text13 |
| --- | --- | --- | --- | --- | --- | --- | --- | --- | --- | --- | --- | --- | --- | --- | --- | --- | --- | --- | --- | --- | --- | --- | --- | --- | --- | --- | --- | --- | --- | --- | --- |
| 3086 | 3.3.2 | **Atividade Interna Renova** |  | 144d | 2019-07-19 | 2020-02-13 |  |  | 2019-07-05 | 2020-01-30 | 144d | 2019-07-16 | 2020-02-10 | 921d |  |  | Verde | Verde | 0% | 0% | Compensatória | Verde | 0% | 0% |  |  |  |  |  |  |  |
| 3087 | 3.3.2.1 | Atividade Interna Renova |  | 1d | 2019-07-19 | 2019-07-19 | 3085FS+8d |  | 2019-07-05 | 2019-07-05 | 1d | 2019-07-16 | 2019-07-16 | 921d | 0d |  | Verde | Verde | 0% | 0% | Compensatória | Verde | 0% | 0% | Critério FR |  |  |  |  |  |  |
| 3088 | 3.3.2.2 | Atividade Interna Renova |  | 35d | 2019-07-22 | 2019-09-09 | 3087 |  | 2019-07-08 | 2019-08-26 | 35d | 2019-07-17 | 2019-09-04 | 921d | 0d |  | Verde | Verde | 0% | 0% | Compensatória | Verde | 0% | 0% | Critério FR |  |  |  |  |  |  |
| 3089 | 3.3.2.3 | Atividade Interna Renova |  | 21d | 2019-08-01 | 2019-08-30 | 3088SS+10ed |  | 2019-07-18 | 2019-08-16 | 21d | 2019-07-29 | 2019-08-27 | 1034d | 6d |  | Verde | Verde | 0% | 0% | Compensatória | Verde | 0% | 0% | Critério FR |  |  |  |  |  |  |
| 3090 | 3.3.2.4 | Atividade Interna Renova |  | 11d | 2019-08-21 | 2019-09-04 | 3088SS+30ed |  | 2019-08-07 | 2019-08-22 | 11d | 2019-08-16 | 2019-08-30 | 1031d | 3d |  | Verde | Verde | 0% | 0% | Compensatória | Verde | 0% | 0% | Critério FR |  |  |  |  |  |  |
| 3091 | 3.3.2.5 | Atividade Interna Renova |  | 1d | 2019-09-10 | 2019-09-10 | 3090, 3089, 3088 |  | 2019-08-27 | 2019-08-27 | 1d | 2019-09-05 | 2019-09-05 | 1028d | 107d |  | Verde | Verde | 0% | 0% | Compensatória | Verde | 0% | 0% | Critério FR |  |  |  |  |  |  |
| 3092 | 3.3.2.6 | Atividade Interna Renova | milestone | 0ed | 2020-02-13 | 2020-02-13 | 3088FS+108d, 3089, 3090, 3091 |  | 2020-01-30 | 2020-01-30 | 0ed | 2020-02-10 | 2020-02-10 | 4066.88d | 0d |  | Verde | Verde | 0% | 0% | Compensatória | Verde | 0% | 0% |  |  |  |  |  |  |  |
| 3093 | 3.3.3 | **Atividade Interna Renova** |  | 125d | 2018-10-01 A | 2019-03-29 A |  | 100% | 2018-10-01 | 2019-03-29 | 125d | 2018-10-25 | 2019-03-29 |  |  |  | Verde | Verde | 100% | 100% | Compensatória | Verde | 100% | 100% |  | 100 | 100 | 100 | 100 | 100 |  |
| 3094 | 3.3.3.1 | Atividade Interna Renova | milestone | 0d | 2018-10-01 A | 2018-10-01 A | 3074 | 100% | 2018-10-01 | 2018-10-01 | 0d |  |  |  |  |  | Verde | Verde | 100% | 100% | Compensatória | Verde | 100% | 100% |  | 100 | 100 | 100 | 100 | 100 |  |
| 3095 | 3.3.3.2 | Atividade Interna Renova |  | 1d | 2018-10-25 A | 2018-10-25 A | 3074 | 100% | 2018-10-25 | 2018-10-25 | 1d | 2018-10-25 | 2018-10-25 |  |  | start no earlier than 2018-10-25 | Verde | Verde | 100% | 100% | Compensatória | Verde | 100% | 100% |  | 100 | 100 | 100 | 100 | 100 |  |
| 3096 | 3.3.3.3 | Atividade Interna Renova |  | 33d | 2018-10-29 A | 2018-12-18 A | 3095FS+4ed | 100% | 2018-10-29 | 2018-12-18 | 33d | 2018-10-29 | 2018-12-18 |  |  |  | Verde | Verde | 100% | 100% | Compensatória | Verde | 100% | 100% |  | 100 | 100 | 100 | 100 | 100 |  |
| 3097 | 3.3.3.4 | Atividade Interna Renova |  | 62d | 2018-12-12 A | 2019-03-27 A | 3095FS+48ed | 100% | 2018-12-12 | 2019-03-27 | 62d | 2018-12-12 | 2019-03-27 |  |  |  | Verde | Verde | 100% | 100% | Compensatória | Verde | 100% | 100% |  | 100 | 100 | 100 | 100 | 100 |  |
| 3098 | 3.3.3.5 | Atividade Interna Renova |  | 55d | 2019-01-08 A | 2019-03-29 A | 3095FS+75ed | 100% | 2019-01-08 | 2019-03-29 | 55d | 2019-01-08 | 2019-03-29 |  |  |  | Verde | Verde | 100% | 100% | Compensatória | Verde | 100% | 100% |  | 100 | 100 | 100 | 100 | 100 |  |
| 3099 | 3.3.3.6 | Atividade Interna Renova | milestone | 0d | 2019-03-29 A | 2019-03-29 A | 3096, 3097, 3098, 3094 | 100% | 2019-03-29 | 2019-03-29 | 0d | 2019-03-29 | 2019-03-29 |  |  |  | Verde | Verde | 100% | 100% | Compensatória | Verde | 100% | 100% |  | 100 | 100 | 100 | 100 | 100 |  |
| 3100 | 3.3.4 | **Atividade Interna Renova** |  | 173d | 2018-05-13 A | 2019-01-10 A |  | 100% | 2018-05-13 | 2019-01-10 | 173d | 2018-05-13 | 2019-01-10 |  |  |  | Verde | Verde | 100% | 100% | Compensatória | Verde | 100% | 100% |  | 100 | 100 | 100 | 100 | 100 | Suprimentos |
| 3101 | 3.3.4.1 | Atividade Interna Renova |  | 33d | 2018-05-13 A | 2018-06-27 A | 3064FS-21ed | 100% | 2018-05-13 | 2018-06-27 | 33d | 2018-05-13 | 2018-06-27 |  |  |  | Verde | Verde | 100% | 100% | Compensatória | Verde | 100% | 100% |  | 100 | 100 | 100 | 100 | 100 | Suprimentos |
| 3102 | 3.3.4.2 | Atividade Interna Renova |  | 1d | 2018-06-28 A | 2018-06-28 A | 3101FS+1d | 100% | 2018-06-28 | 2018-06-28 | 1d | 2018-06-28 | 2018-06-28 |  |  |  | Verde | Verde | 100% | 100% | Compensatória | Verde | 100% | 100% |  | 100 | 100 | 100 | 100 | 100 | Suprimentos |
| 3103 | 3.3.4.3 | Atividade Interna Renova |  | 17d | 2018-06-28 A | 2018-07-24 A | 3102 | 100% | 2018-06-28 | 2018-07-24 | 17d | 2018-06-28 | 2018-07-24 |  |  |  | Verde | Verde | 100% | 100% | Compensatória | Verde | 100% | 100% |  | 100 | 100 | 100 | 100 | 100 | Suprimentos |
| 3104 | 3.3.4.4 | Atividade Interna Renova |  | 70d | 2018-07-23 A | 2018-10-31 A | 3103 | 100% | 2018-07-23 | 2018-10-31 | 70d | 2018-07-23 | 2018-10-31 |  |  |  | Verde | Verde | 100% | 100% | Compensatória | Verde | 100% | 100% |  | 100 | 100 | 100 | 100 | 100 | Suprimentos |
| 3105 | 3.3.4.5 | Atividade Interna Renova |  | 10d | 2018-11-26 A | 2018-12-10 A | 3104FS+26ed | 100% | 2018-11-26 | 2018-12-10 | 10d | 2018-11-26 | 2018-12-10 |  |  |  | Verde | Verde | 100% | 100% | Compensatória | Verde | 100% | 100% |  | 100 | 100 | 100 | 100 | 100 | Suprimentos |
| 3106 | 3.3.4.6 | Atividade Interna Renova |  | 9d | 2018-12-11 A | 2018-12-21 A | 3105 | 100% | 2018-12-11 | 2018-12-21 | 9d | 2018-12-11 | 2018-12-21 |  |  |  | Verde | Verde | 100% | 100% | Compensatória | Verde | 100% | 100% |  | 100 | 100 | 100 | 100 | 100 | Suprimentos |
| 3107 | 3.3.4.7 | Atividade Interna Renova |  | 2d | 2018-10-26 A | 2018-11-01 A | 3104 | 100% | 2018-10-26 | 2018-11-01 | 2d | 2018-10-26 | 2018-11-01 |  |  |  | Verde | Verde | 100% | 100% | Compensatória | Verde | 100% | 100% |  | 100 | 100 | 100 | 100 | 100 | Suprimentos |
| 3108 | 3.3.4.8 | Atividade Interna Renova |  | 6d | 2018-11-02 A | 2018-11-12 A | 3107 | 100% | 2018-11-02 | 2018-11-12 | 6d | 2018-11-02 | 2018-11-12 |  |  |  | Verde | Verde | 100% | 100% | Compensatória | Verde | 100% | 100% |  | 100 | 100 | 100 | 100 | 100 | Suprimentos |
| 3109 | 3.3.4.9 | Atividade Interna Renova |  | 6d | 2018-11-13 A | 2018-11-22 A | 3108 | 100% | 2018-11-13 | 2018-11-22 | 6d | 2018-11-13 | 2018-11-22 |  |  |  | Verde | Verde | 100% | 100% | Compensatória | Verde | 100% | 100% |  | 100 | 100 | 100 | 100 | 100 | Suprimentos |
| 3110 | 3.3.4.10 | Atividade Interna Renova |  | 2d | 2018-11-22 A | 2018-11-26 A | 3109 | 100% | 2018-11-22 | 2018-11-26 | 2d | 2018-11-22 | 2018-11-26 |  |  |  | Verde | Verde | 100% | 100% | Compensatória | Verde | 100% | 100% |  | 100 | 100 | 100 | 100 | 100 | Suprimentos |
| 3111 | 3.3.4.11 | Atividade Interna Renova |  | 4d | 2018-11-27 A | 2018-11-30 A | 3110 | 100% | 2018-11-27 | 2018-11-30 | 4d | 2018-11-27 | 2018-11-30 |  |  |  | Verde | Verde | 100% | 100% | Compensatória | Verde | 100% | 100% |  | 100 | 100 | 100 | 100 | 100 | Suprimentos |
| 3112 | 3.3.4.12 | Atividade Interna Renova |  | 4d | 2018-12-21 A | 2019-01-10 A | 3106, 3111 | 100% | 2018-12-21 | 2019-01-10 | 4d | 2018-12-21 | 2019-01-10 |  |  |  | Verde | Verde | 100% | 100% | Compensatória | Verde | 100% | 100% |  | 100 | 100 | 100 | 100 | 100 | Suprimentos |
| 3113 | 3.3.4.13 | Atividade Interna Renova | milestone | 0d | 2019-01-10 A | 2019-01-10 A | 3112 | 100% | 2019-01-10 | 2019-01-10 | 0d | 2019-01-10 | 2019-01-10 |  |  |  | Verde | Verde | 100% | 100% | Compensatória | Verde | 100% | 100% |  | 100 | 100 | 100 | 100 | 100 | Suprimentos |
| 3114 | 3.3.5 | Atividade Interna Renova | milestone | 0d | 2020-02-13 | 2020-02-13 | 3085, 3099, 3113, 3092 |  | 2020-01-30 | 2020-01-30 | 0d | 2020-02-10 | 2020-02-10 | 921d |  |  | Verde | Verde | 0% | 0% | Compensatória | Verde | 0% | 0% |  |  |  |  |  |  |  |
| 3115 | 3.4 | Atividade Interna Renova | milestone | 0d | 2023-10-30 | 2023-10-30 | 2929, 3059, 3114 |  | 2023-10-30 | 2023-10-30 | 0d | 2025-02-25 | 2025-02-25 | 0d |  |  | Verde | Verde | 0% | 0% | Compensatória | Verde | 0% | 0% |  |  |  |  |  |  |  |

Notes:
- 3086: Esta implementação deverá ser detalhada após a contratação concorrencial da empresa para dar a capacitação.
- 3093: Esta capacitação teve como data de início o Workshop de Licenciamento e Outorga em Colatina - ES.
- 3096: 22/05/2019: foram realizadas 11 oficinas de Licenciamento Ambiental e Outorga de outubro até dezembro de 2018.
- 3097: 22/05/2019: foram realizadas 12 oficinas de Elaboração de projetos referentes a esgotamento sanitário: conceitual, básico, executivo e ambiental de dez/2018 até mar/2019.
- 3098: 22/05/2019: foram realizadas 9 oficinas de Estruturação de soluções consorciadas para destinação de resíduos sólidos entre janeiro e março de 2019 (planilha Capacitação_V3)

| ID | WBS | Task | Type | Duration | Start | Finish | Predecessors | Baseline start | Baseline finish | Baseline duration | Baseline 1 start | Baseline 1 finish | Total slack | Text1 | Text2 | Text3 | Text6 | Text8 | Text12 | Text14 | Text16 |
| --- | --- | --- | --- | --- | --- | --- | --- | --- | --- | --- | --- | --- | --- | --- | --- | --- | --- | --- | --- | --- | --- |
| 3116 | 4 | **Atividade Interna Renova** |  | 23d | 2023-10-31 | 2023-12-04 |  | 2023-10-31 | 2023-12-04 | 23d | 2025-02-26 | 2026-02-12 | 0d | Verde | Verde | 0% | 0% | Compensatória | Verde | 0% | 0% |
| 3117 | 4.1 | Atividade Interna Renova |  | 22d | 2023-10-31 | 2023-12-01 | 14, 4, 11, 12, 63 | 2023-10-31 | 2023-12-01 | 22d | 2025-02-26 | 2026-02-12 | 0d | Verde | Verde | 0% | 0% | Compensatória | Verde | 0% | 0% |
| 3118 | 4.2 | Atividade Interna Renova |  | 1d | 2023-12-04 | 2023-12-04 | 3117 | 2023-12-04 | 2023-12-04 | 1d |  |  | 0d | Verde | Verde | 0% | 0% | Compensatória | Verde | 0% | 0% |
| 3119 | 4.3 | Atividade Interna Renova | milestone | 0d | 2023-12-04 | 2023-12-04 | 3118 | 2023-12-04 | 2023-12-04 | 0d | 2026-02-12 | 2026-02-12 | 0d | Verde | Verde | 0% | 0% | Compensatória | Verde | 0% | 0% |
| 3120 | 5 | Programa finalizado | milestone | 0d | 2023-12-04 | 2023-12-04 | 3119 | 2023-12-04 | 2023-12-04 | 0d | 2026-02-12 | 2026-02-12 | 0d | Verde | Verde | 0% | 0% | Compensatória | Verde | 0% | 0% |

Notes:
- 3119: Em 19/03/19: por solicitação da A&M foi modificada a duração e as predecessoras da atividade Encerramento Interno de 6 meses para 8 meses e de 6TT; 5TT; 4TT; 61 para 6TI; 4TI; 5TI para atendimento à demanda do MP e igualar as datas de término tendência às da definição do programa.
